# IMPACT Master Schedule

Schedule from MS Project, 2003-02-26 to 2005-11-21, status date 2004-04-30, A marks actual dates.
IMPACT Instrument Suites
NASA GSFC - STEREO
This is the IMPACT Consolidated Schedule. Creation began in October 2003 and was then put on hold and subsequently completed in January 2004. Completed tasks, redundant milestones, contingency blocks and obsolete tasks were deleted from this schedule. / Schedule was baselined on 2/18/04 with status through January 31, 2004. / Maintenance of this Schedule was transferred from Jim Rodgers to Tabitha Merchant on 03/22/04

## Calendars

- Standard: Mon-Fri 08:00-12:00, 13:00-17:00; Sat-Sun off. Exceptions (off unless hours are given): 2003-05-26, 2003-07-04, 2003-09-01, 2003-10-13, 2003-11-11, 2003-11-27, 2003-12-25, 2004-01-01, 2004-01-19, 2004-02-16, 2004-05-31, 2004-07-05, 2004-09-06, 2004-10-11, 2004-11-11, 2004-11-25.
- Boom Test Calendar: Mon-Fri 08:00-12:00, 13:00-17:00; Sat-Sun off. Exceptions (off unless hours are given): 2003-05-26, 2003-07-04, 2003-09-01, 2003-10-13, 2003-11-11, 2003-11-27, 2003-12-25, 2004-01-01, 2004-01-19, 2004-02-16, 2004-02-28 to 2004-02-29 08:00-12:00, 13:00-17:00, 2004-03-06 to 2004-03-07 08:00-12:00, 13:00-17:00, 2004-05-31, 2004-09-06, 2004-10-11, 2004-11-11, 2004-11-25.
- Weekend: Mon-Fri 08:00-12:00, 13:00-17:00; Sat-Sun off. Exceptions (off unless hours are given): 2004-07-10 to 2004-07-11 08:00-12:00, 13:00-17:00.
- Internation Work Schedule: Mon-Fri 08:00-12:00, 13:00-17:00; Sat-Sun off. Exceptions (off unless hours are given): 2003-05-26, 2003-07-04, 2003-09-01, 2003-10-13, 2003-11-11, 2003-11-27, 2003-12-25, 2004-01-01, 2004-01-19, 2004-02-16, 2004-05-31, 2004-07-05, 2004-09-06, 2004-10-11 08:00-12:00, 13:00-17:00, 2004-11-11, 2004-11-25.

## Schedule

| ID | WBS | Task | Type | Duration | Start | Finish | Predecessors | Complete | Remaining | Baseline start | Baseline finish | Baseline duration | Total slack | Free slack | Constraint | Text1 |
| --- | --- | --- | --- | --- | --- | --- | --- | --- | --- | --- | --- | --- | --- | --- | --- | --- |
| 1 | 1 | **IMPACT - Dave Curtis (UCB) & Lil Reichenthal (GSFC)** |  | 698d | 2003-02-26 A | 2005-11-21 |  | 77% | 160.47d | 2003-02-26 | 2005-11-18 | 698d | 0d |  |  |  |
| 2 | 1.1 | **Suite Deliveries to APL** |  | 44d | 2004-10-07 | 2004-12-10 |  |  |  | 2004-08-13 | 2004-10-28 | 51d | -30d | 0d |  |  |
| 3 | 1.1.1 | FM 1 Target Delivery Date | milestone | 0d | 2004-10-07 | 2004-10-07 | 5, 7 |  |  | 2004-10-07 | 2004-10-07 | 0d | -35d | 0d | must start on 2004-10-07 | MS-BOOM |
| 4 | 1.1.2 | FM 2 Target Delivery Date | milestone | 0d | 2004-10-28 | 2004-10-28 | 8, 6 |  |  | 2004-10-28 | 2004-10-28 | 0d | -30d | 0d | must start on 2004-10-28 | MS-BOOM |
| 5 | 1.1.3 | Boom Suite FM 1 Ready for Delivery to APL | milestone | 0d | 2004-10-25 | 2004-10-25 | 350 |  |  | 2004-08-13 | 2004-08-13 | 0d | -12d | 0d |  | MS-BOOM |
| 6 | 1.1.4 | Boom Suite FM 2 Ready for Delivery to APL | milestone | 0d | 2004-11-23 | 2004-11-23 | 356 |  |  | 2004-09-28 | 2004-09-28 | 0d | -18d | 0d |  | MS-BOOM |
| 7 | 1.1.5 | SEP Suite FM 1 Ready for Delivery to APL | milestone | 0d | 2004-11-29 | 2004-11-29 | 825, 645, 539 |  |  | 2004-09-14 | 2004-09-14 | 0d | -35d | 0d |  | MS-SEP |
| 8 | 1.1.6 | SEP Suite FM 2 Ready for Delivery to APL | milestone | 0d | 2004-12-10 | 2004-12-10 | 832, 648, 542 |  |  | 2004-10-12 | 2004-10-12 | 0d | -30d | 0d |  | MS-SEP |
| 9 | 1.2 | **Environmental Testing - PER, Impact Suite EMC, Snapshots of Boom & SEP Suite Test Flows** |  | 226d | 2004-01-14 A | 2004-12-06 |  | 13% | 196.95d | 2004-01-14 | 2004-10-05 | 186d | 250d |  |  |  |
| 10 | 1.2.1 | **Reviews (PER and TRR's) - TRR Dates are Tentative** |  | 173d | 2004-01-14 A | 2004-09-17 |  | 50% | 86.5d | 2004-01-14 | 2004-07-08 | 124d | 303d |  |  |  |
| 11 | 1.2.1.1 | Instrument PER at UCB |  | 1d | 2004-01-14 A | 2004-01-14 A |  | 100% |  | 2004-01-14 | 2004-01-14 | 1d |  |  | start no earlier than 2004-01-14 |  |
| 12 | 1.2.1.2 | TRR 1 - Prior to FM 1 SEPT Thermal Vac |  | 1d | 2004-02-13 A | 2004-02-13 A | 39SS-6d | 100% |  | 2004-02-13 | 2004-02-13 | 1d |  |  |  |  |
| 13 | 1.2.1.3 | TRR 2 - Prior to FM 1 STE-U Thermal Vac/Thermal Balance |  | 1d | 2004-04-19 A | 2004-04-19 A | 21SS-6d | 100% |  | 2004-03-25 | 2004-03-25 | 1d |  |  | start no earlier than 2004-04-19 |  |
| 14 | 1.2.1.4 | TRR 3 - Prior to FM 1 Boom Structure Vibration |  | 1d | 2004-04-19 A | 2004-04-19 A | 22SS-19d | 100% |  | 2004-04-20 | 2004-04-20 | 1d |  |  |  |  |
| 15 | 1.2.1.5 | TRR 4 - Prior to FM 1 IDPU Vibration |  | 1d | 2004-09-14 | 2004-09-14 | 23SS-5d |  |  | 2004-04-26 | 2004-04-26 | 1d | 306d |  |  |  |
| 16 | 1.2.1.6 | TRR 5 - Prior to FM 1 SWEA Vibration |  | 1d | 2004-09-14 | 2004-09-14 | 26SS-5d |  |  | 2004-05-28 | 2004-05-28 | 1d | 306d |  |  |  |
| 17 | 1.2.1.7 | TRR 6 - Prior to FM 1 Impact Suite EMC (for Boom and SEP) |  | 1d | 2004-08-30 | 2004-08-30 | 19SS-5d |  |  | 2004-06-22 | 2004-06-22 | 1d | 316d |  |  |  |
| 18 | 1.2.1.8 | TRR 7 - Prior to FM 1 SIT Vibration |  | 1d | 2004-09-17 | 2004-09-17 | 43SS-5d |  |  | 2004-07-08 | 2004-07-08 | 1d | 303d |  |  |  |
| 19 | 1.2.2 | IMPACT Suite FM 1 EMC Testing at UCB |  | 10d | 2004-09-07 | 2004-09-20 | 802, 431 |  |  | 2004-06-29 | 2004-07-12 | 10d | -31d | 0d |  | MS-BOOM |
| 20 | 1.2.3 | **Boom Suite FM 1 Environmental Test Flow Snapshot - UCB** |  | 122d | 2004-04-26 A | 2004-10-18 |  | 7% | 112.9d | 2004-04-01 | 2004-07-30 | 86d | 283d |  |  |  |
| 21 | 1.2.3.1 | STE-U Thermal Vac/Thermal Balance/Bake Out |  | 14d | 2004-04-26 A | 2004-05-13 | 269SS | 36% | 9d | 2004-04-01 | 2004-04-20 | 14d | 391d | 0d |  |  |
| 22 | 1.2.3.2 | Boom Structure Vibration |  | 4d | 2004-06-23 | 2004-06-28 | 211SS |  |  | 2004-04-27 | 2004-04-30 | 4d | 360d | 0d |  |  |
| 23 | 1.2.3.3 | IDPU Vibration |  | 5d | 2004-09-21 | 2004-09-27 | 174SS |  |  | 2004-05-03 | 2004-05-07 | 5d | 297d | 0d |  |  |
| 24 | 1.2.3.4 | Boom Structure Thermal Vac & Bake Out |  | 15d | 2004-06-29 | 2004-07-20 | 212SS |  |  | 2004-05-03 | 2004-05-21 | 15d | 345d |  |  |  |
| 25 | 1.2.3.5 | IDPU Thermal Vac & Bake Out |  | 10d | 2004-09-28 | 2004-10-12 | 175SS |  |  | 2004-05-10 | 2004-05-21 | 10d | 287d |  |  |  |
| 26 | 1.2.3.6 | SWEA/STE Vibration |  | 5d | 2004-09-21 | 2004-09-27 | 335SS |  |  | 2004-06-07 | 2004-06-11 | 5d | 297d | 0d |  |  |
| 27 | 1.2.3.7 | SWEA/STE Thermal Vac/Thermal Balance/Bake Out |  | 14d | 2004-09-28 | 2004-10-18 | 336SS |  |  | 2004-07-13 | 2004-07-30 | 14d | 283d |  |  |  |

Notes:
- 1: This is the new IMPACT Consolidated Schedule. Creation began in October 2003 and was then put on hold and subsequently completed in January 2004. Completed tasks, redundant milestones, contingency blocks and obsolete tasks were deleted from this schedule. / Schedule was baselined on 2/18/04 with status through January 31, 2004.
- 7: The SEPT (FM 1) and SIT (FM 1 & 2) instruments are being delivered directly to APL after their environmental testing at GSFC and seperate from the other SEP Suite instruments (SEP Central, LET and HET).
- 8: The SEPT (FM 1) and SIT (FM 1 & 2) instruments are being delivered directly to APL after their environmental testing at GSFC and seperate from the other SEP Suite instruments (SEP Central, LET and HET).
- 11: This is the initial IMPACT PER. Additional TRR's (Test Readiness Reviews) will be scheduled and held as the suite instruments become ready for their environmental testing.
- 20: This section is a "snapshot" of the environmental test flow for the FM 1 Boom Suite. It reflects the details of the testing activities found within the body of the schedule. It was placed in the schedule to allow someone to get a quick look at the test flow and the associated dates. The tasks contained within this section are not tied to any other activities (and do not drive any other activities) and so therefore you will see large float values associated with them. It is simply a quick look at the test flow so that one does not have to filter through the schedule to locate the environmental test activities.

| ID | WBS | Task | Duration | Start | Finish | Predecessors | Complete | Remaining | Baseline start | Baseline finish | Baseline duration | Total slack | Free slack | Calendar |
| --- | --- | --- | --- | --- | --- | --- | --- | --- | --- | --- | --- | --- | --- | --- |
| 28 | 1.2.4 | **Boom Suite FM 2 Environmental Test Flow Snapshot - UCB** | 79d | 2004-07-26 | 2004-11-16 |  |  |  | 2004-04-27 | 2004-09-14 | 99d | 263d |  |  |
| 29 | 1.2.4.1 | STE-U Thermal Vac/Bake Out | 10d | 2004-07-26 | 2004-08-06 | 277SS |  |  | 2004-04-27 | 2004-05-10 | 10d | 332d |  |  |
| 30 | 1.2.4.2 | IDPU Vibration | 5d | 2004-10-13 | 2004-10-19 | 178SS |  |  | 2004-05-10 | 2004-05-14 | 5d | 282d |  |  |
| 31 | 1.2.4.3 | Boom Structure Vibration | 4d | 2004-08-13 | 2004-08-18 | 232SS |  |  | 2004-05-17 | 2004-05-20 | 4d | 324d |  |  |
| 32 | 1.2.4.4 | IDPU Thermal Vac & Bake Out | 10d | 2004-10-20 | 2004-11-02 | 179SS |  |  | 2004-05-17 | 2004-05-28 | 10d | 272d |  |  |
| 33 | 1.2.4.5 | Boom Structure Thermal Vac & Bake Out | 15d | 2004-08-19 | 2004-09-09 | 233SS |  |  | 2004-05-24 | 2004-06-14 | 15d | 309d |  |  |
| 34 | 1.2.4.6 | SWEA/STE Vibration | 5d | 2004-10-07 | 2004-10-14 | 343SS |  |  | 2004-08-09 | 2004-08-13 | 5d | 285d |  |  |
| 35 | 1.2.4.7 | SWEA/STE Thermal Vac & Bake Out | 10d | 2004-10-15 | 2004-10-28 | 344SS |  |  | 2004-08-16 | 2004-08-27 | 10d | 275d |  |  |
| 36 | 1.2.4.8 | Boom Suite FM 2 EMC | 5d | 2004-11-09 | 2004-11-16 | 355SS |  |  | 2004-09-08 | 2004-09-14 | 5d | 263d |  |  |
| 37 | 1.2.5 | **SEP Suite FM 1 Environmental Test Flow Snapshot** | 186d | 2004-02-19 A | 2004-11-10 |  | 19% | 151.25d | 2004-02-17 | 2004-09-14 | 149d | 266d |  |  |
| 38 | 1.2.5.1 | SEPT (NS & E) Vibration (in Europe) | 4d | 2004-02-19 A | 2004-02-24 A | 577SS | 100% |  | 2004-02-17 | 2004-02-24 | 8d |  |  |  |
| 39 | 1.2.5.2 | SEPT (NS & E) Thermal Vac (in Europe) | 11d | 2004-02-27 A | 2004-03-12 A | 578SS, 594SS | 100% |  | 2004-02-25 | 2004-03-08 | 9d |  |  |  |
| 40 | 1.2.5.3 | SEPT (NS & E) Bake Out (in Europe) | 2d | 2004-03-05 A | 2004-03-08 A | 579SS, 595SS | 100% |  | 2004-03-09 | 2004-03-10 | 2d |  |  |  |
| 41 | 1.2.5.4 | SEPT (NS & E) Thermal Balance (at GSFC) | 10d | 2004-10-26 | 2004-11-08 | 587SS, 603SS |  |  | 2004-07-13 | 2004-07-26 | 10d | 268d |  |  |
| 42 | 1.2.5.5 | LET/HET/SEP Cen Accelerator Test (at MSU) | 3d | 2004-07-10 | 2004-07-12 | 834SS |  |  | 2004-07-13 | 2004-07-27 | 11d | 355d |  | Weekend |
| 43 | 1.2.5.6 | SIT Vibe and Acoustics (at GSFC) | 10d | 2004-09-24 | 2004-10-07 | 755SS |  |  | 2004-07-15 | 2004-07-28 | 10d | 289d | 0d |  |
| 44 | 1.2.5.7 | LET/HET/SEP Cen Vibe and Acoustics (at JPL) | 10d | 2004-09-24 | 2004-10-07 | 820SS |  |  | 2004-07-23 | 2004-08-05 | 10d | 289d |  |  |
| 45 | 1.2.5.8 | SIT Thermal Balance (at GSFC) | 5d | 2004-10-12 | 2004-10-18 | 757SS |  |  | 2004-07-30 | 2004-08-05 | 5d | 283d |  |  |
| 46 | 1.2.5.9 | LET/HET/SEP Cen Thermal Balance (at JPL) | 5d | 2004-10-08 | 2004-10-15 | 821SS |  |  | 2004-08-06 | 2004-08-12 | 5d | 284d |  |  |
| 47 | 1.2.5.10 | SIT Thermal Vac (at GSFC) | 10d | 2004-10-19 | 2004-11-01 | 758SS |  |  | 2004-08-06 | 2004-08-19 | 10d | 273d |  |  |
| 48 | 1.2.5.11 | LET/HET/SEP Cen Thermal Vac (at JPL) | 15d | 2004-10-18 | 2004-11-05 | 822SS |  |  | 2004-08-19 | 2004-09-09 | 15d | 269d |  |  |
| 49 | 1.2.5.12 | SIT Bake Out (at GSFC) | 3d | 2004-11-04 | 2004-11-08 | 760SS |  |  | 2004-08-24 | 2004-08-26 | 3d | 268d |  |  |
| 50 | 1.2.5.13 | LET/HET/SEP Cen Bake Out (at JPL) | 3d | 2004-11-08 | 2004-11-10 | 825SS |  |  | 2004-09-10 | 2004-09-14 | 3d | 266d |  |  |
| 51 | 1.2.6 | **SEP Suite FM 2 Environmental Test Flow Snapshot** | 202d | 2004-02-19 A | 2004-12-06 |  | 19% | 163.65d | 2004-02-17 | 2004-10-05 | 164d | 250d |  |  |
| 52 | 1.2.6.1 | SEPT (NS & E) Vibe and Acoustics (in Europe) | 4d | 2004-02-19 A | 2004-02-24 A | 610SS | 100% |  | 2004-02-17 | 2004-02-24 | 8d |  |  |  |
| 53 | 1.2.6.2 | SEPT (NS & E) Thermal Vac (in Europe) | 9d | 2004-03-05 A | 2004-03-17 A | 611SS, 628SS | 100% |  | 2004-03-09 | 2004-03-17 | 9d |  |  |  |
| 54 | 1.2.6.3 | SEPT (NS & E) Bake Out (in Europe) | 2d | 2004-03-12 A | 2004-03-15 A | 612SS, 629SS | 100% |  | 2004-03-18 | 2004-03-19 | 2d |  |  |  |
| 55 | 1.2.6.4 | LET/HET/SEP Cen Accelerator Test (at MSU) | 3d | 2004-07-10 | 2004-07-12 | 835SS |  |  | 2004-07-13 | 2004-07-27 | 11d | 355d |  | Weekend |
| 56 | 1.2.6.5 | LET/HET/SEP Cen Vibe and Acoustics (at JPL) | 10d | 2004-10-18 | 2004-10-29 | 828SS |  |  | 2004-07-23 | 2004-08-05 | 10d | 274d |  |  |
| 57 | 1.2.6.6 | SEP Suite FM 2 EMC (at Caltech) | 5d | 2004-10-14 | 2004-10-20 | 827SS |  |  | 2004-08-12 | 2004-08-18 | 5d | 281d |  |  |
| 58 | 1.2.6.7 | LET/HET/SEP Cen Thermal Vac (at JPL) | 15d | 2004-11-01 | 2004-11-22 | 829SS |  |  | 2004-08-19 | 2004-09-09 | 15d | 259d |  |  |
| 59 | 1.2.6.8 | SIT Vibe and Acoustics (at GSFC) | 10d | 2004-10-21 | 2004-11-03 | 764SS |  |  | 2004-08-23 | 2004-09-03 | 10d | 271d |  |  |
| 60 | 1.2.6.9 | SIT Thermal Balance (at GSFC) | 5d | 2004-11-05 | 2004-11-12 | 766SS |  |  | 2004-09-08 | 2004-09-14 | 5d | 265d |  |  |
| 61 | 1.2.6.10 | LET/HET/SEP Cen Bake Out (at JPL) | 3d | 2004-11-23 | 2004-11-26 | 832SS |  |  | 2004-09-10 | 2004-09-14 | 3d | 256d |  |  |
| 62 | 1.2.6.11 | SIT Thermal Vac (at GSFC) | 10d | 2004-11-15 | 2004-11-29 | 767SS |  |  | 2004-09-15 | 2004-09-28 | 10d | 255d |  |  |
| 63 | 1.2.6.12 | SIT Bake Out (at GSFC) | 3d | 2004-12-02 | 2004-12-06 | 769SS |  |  | 2004-10-01 | 2004-10-05 | 3d | 250d |  |  |

Notes:
- 28: This section is a "snapshot" of the environmental test flow for the FM 2 Boom Suite. It reflects the details of the testing activities found within the body of the schedule. It was placed in the schedule to allow someone to get a quick look at the test flow and the associated dates. The tasks contained within this section are not tied to any other activities (and do not drive any other activities) and so therefore you will see large float values associated with them. It is simply a quick look at the test flow so that one does not have to filter through the schedule to locate the environmental test activities.
- 37: This section is a "snapshot" of the environmental test flow for the FM 1 SEP Suite. It reflects the details of the testing activities found within the body of the schedule. It was placed in the schedule to allow someone to get a quick look at the test flow and the associated dates. The tasks contained within this section are not tied to any other activities (and do not drive any other activities) and so therefore you will see large float values associated with them. It is simply a quick look at the test flow so that one does not have to filter through the schedule to locate the environmental test activities.
- 38: There was a failure on the SEPT door during Vibration Test. Vibration Test will be repeated once the fix to the door is implemented. Time and place is TBD.
- 51: This section is a "snapshot" of the environmental test flow for the FM 2 SEP Suite. It reflects the details of the testing activities found within the body of the schedule. It was placed in the schedule to allow someone to get a quick look at the test flow and the associated dates. The tasks contained within this section are not tied to any other activities (and do not drive any other activities) and so therefore you will see large float values associated with them. It is simply a quick look at the test flow so that one does not have to filter through the schedule to locate the environmental test activities.
- 52: There was a failure on the SEPT door during Vibration Test. Vibration Test will be repeated once the fix to the door is implemented. Time and place is TBD.

| ID | WBS | Task | Type | Duration | Start | Finish | Predecessors | Complete | Remaining | Baseline start | Baseline finish | Baseline duration | Total slack | Free slack | Constraint | Text1 |
| --- | --- | --- | --- | --- | --- | --- | --- | --- | --- | --- | --- | --- | --- | --- | --- | --- |
| 64 | 1.3 | **Power Converters - UCB** |  | 402d | 2003-02-26 A | 2004-09-28 |  | 78% | 89.03d | 2003-02-26 | 2004-06-23 | 335d | -35d | 0d |  |  |
| 65 | 1.3.1 | **Deliveries** |  | 204d | 2003-12-09 A | 2004-09-28 |  | 50% | 102d | 2003-12-09 | 2004-04-30 | 100d | -35d | 0d |  |  |
| 66 | 1.3.1.1 | **FM 1** |  | 174d | 2003-12-09 A | 2004-08-16 |  | 99% | 0d | 2003-12-09 | 2004-04-23 | 95d | -31d | 0d |  |  |
| 67 | 1.3.1.1.1 | Deliver IDPU FM 1 LVPS (stays at UCB) | milestone | 0d | 2004-08-16 | 2004-08-16 | 121 |  |  | 2004-04-23 | 2004-04-23 | 0d | -31d | 0d |  | MS-BOOM |
| 68 | 1.3.1.1.2 | Deliver SEP FM 1 LVPS (to Caltech) |  | 1d | 2004-06-01 A | 2004-06-01 A | 125 | 100% |  | 2004-04-06 | 2004-04-06 | 1d |  |  |  | MS-SEP |
| 69 | 1.3.1.1.3 | Deliver SWEA/STE FM 1 LVPS (stays at UCB) | milestone | 0d | 2004-07-06 | 2004-07-06 | 129 |  |  | 2004-04-15 | 2004-04-15 | 0d | -29d | 0d |  | MS-BOOM |
| 70 | 1.3.1.1.4 | Deliver PLASTIC FM 1 LVPS (to UNH) |  | 2d | 2004-05-24 A | 2004-05-25 A | 133 | 100% |  | 2004-03-24 | 2004-03-25 | 2d |  |  | finish no later than 2004-06-10 |  |
| 71 | 1.3.1.1.5 | Deliver SIT FM 1 HVPS (to UMD) |  | 2d | 2003-12-09 A | 2003-12-10 A | 135 | 100% |  | 2003-12-09 | 2003-12-10 | 2d |  |  |  |  |
| 72 | 1.3.1.2 | **FM 2** |  | 59d | 2004-07-07 | 2004-09-28 |  |  |  | 2004-04-12 | 2004-04-30 | 15d | -35d | 0d |  |  |
| 73 | 1.3.1.2.1 | Deliver IDPU FM 2 LVPS (stays at UCB) | milestone | 0d | 2004-09-28 | 2004-09-28 | 140 |  |  | 2004-04-30 | 2004-04-30 | 0d | -35d | 0d |  | MS-BOOM |
| 74 | 1.3.1.2.2 | Deliver SEP FM 2 LVPS (to Caltech) |  | 1d | 2004-07-26 | 2004-07-26 | 145 |  |  | 2004-04-19 | 2004-04-19 | 1d | 9d | 0d |  | MS-SEP |
| 75 | 1.3.1.2.3 | Deliver SWEA/STE FM 2 LVPS (stays at UCB) | milestone | 0d | 2004-08-17 | 2004-08-17 | 149 |  |  | 2004-04-26 | 2004-04-26 | 0d | -17d | 0d |  | MS-BOOM |
| 76 | 1.3.1.2.4 | Deliver PLASTIC FM 2 LVPS (to UNH) |  | 2d | 2004-07-13 | 2004-07-14 | 153 |  |  | 2004-04-12 | 2004-04-13 | 2d | 5d |  | finish no later than 2004-07-21 |  |
| 77 | 1.3.1.2.5 | Deliver SIT FM 2 HVPS (to UMD) |  | 2d | 2004-07-07 | 2004-07-08 | 157 |  |  | 2004-04-12 | 2004-04-13 | 2d | -25d | 0d |  | MS-SEP |
| 78 | 1.3.2 | **Remaining Flight Procurements** |  | 95d | 2003-10-24 A | 2004-03-12 A |  | 100% |  | 2003-10-24 | 2004-02-19 | 79d |  |  |  |  |
| 79 | 1.3.2.1 | Procure IDPU Flight Printed Wiring Board |  | 10d | 2004-03-01 A | 2004-03-12 A | 85 | 100% |  | 2004-02-05 | 2004-02-19 | 10d |  |  | start no earlier than 2004-03-01 |  |
| 80 | 1.3.2.2 | Procure SEP Flight Printed Wiring Board |  | 10d | 2003-11-24 A | 2003-12-08 A | 86 | 100% |  | 2003-11-24 | 2003-12-08 | 10d |  |  | start no earlier than 2003-11-24 |  |
| 81 | 1.3.2.3 | Procure SWEA Flight Printed Wiring Board |  | 10d | 2003-12-04 A | 2003-12-17 A | 87 | 100% |  | 2003-12-04 | 2003-12-17 | 10d |  |  |  |  |
| 82 | 1.3.2.4 | Procure PLASTIC Flight Printed Wiring Board |  | 10d | 2003-10-24 A | 2003-11-06 A |  | 100% |  | 2003-10-24 | 2003-11-06 | 10d |  |  | start no earlier than 2003-10-24 |  |
| 83 | 1.3.3 | **Fabrication** |  | 239d | 2003-02-26 A | 2004-02-06 A |  | 100% |  | 2003-02-26 | 2004-02-06 | 239d |  |  |  |  |
| 84 | 1.3.3.1 | **FM 1 & FM 2** |  | 195d | 2003-02-26 A | 2003-12-03 A |  | 100% |  | 2003-02-26 | 2003-12-03 | 195d |  |  |  |  |
| 85 | 1.3.3.1.1 | Re-layout IDPU LVPS Flight Printed Wiring Board |  | 186d | 2003-02-26 A | 2003-11-19 A |  | 100% |  | 2003-02-26 | 2003-11-19 | 186d |  |  | start no earlier than 2003-02-26 |  |
| 86 | 1.3.3.1.2 | Re-layout SEP LVPS Flight Printed Wiring Board |  | 32d | 2003-09-24 A | 2003-11-07 A |  | 100% |  | 2003-09-24 | 2003-11-07 | 32d |  |  | start no earlier than 2003-09-24 |  |
| 87 | 1.3.3.1.3 | Re-layout SWEA LVPS Flight Printed Wiring Board |  | 5d | 2003-11-26 A | 2003-12-03 A |  | 100% |  | 2003-11-26 | 2003-12-03 | 5d |  |  | start no earlier than 2003-11-26 |  |

| ID | WBS | Task | Duration | Start | Finish | Predecessors | Complete | Remaining | Baseline start | Baseline finish | Baseline duration | Total slack | Free slack | Constraint |
| --- | --- | --- | --- | --- | --- | --- | --- | --- | --- | --- | --- | --- | --- | --- |
| 88 | 1.3.3.2 | **FM 1** | 45d | 2003-09-29 A | 2003-12-03 A |  | 100% |  | 2003-09-29 | 2003-12-03 | 45d |  |  |  |
| 89 | 1.3.3.2.1 | Wind IDPU LVPS FM 1 Magnets | 10d | 2003-10-17 A | 2003-10-30 A |  | 100% |  | 2003-10-17 | 2003-10-30 | 10d |  |  | start no earlier than 2003-10-17 |
| 90 | 1.3.3.2.2 | Wind SEP LVPS FM 1 Magnets | 15d | 2003-09-29 A | 2003-10-20 A |  | 100% |  | 2003-09-29 | 2003-10-20 | 15d |  |  | start no earlier than 2003-09-29 |
| 91 | 1.3.3.2.3 | Wind SWEA LVPS FM 1 Magnets | 5d | 2003-11-26 A | 2003-12-03 A |  | 100% |  | 2003-11-26 | 2003-12-03 | 5d |  |  | start no earlier than 2003-11-26 |
| 92 | 1.3.3.2.4 | Wind PLASTIC LVPS FM 1 Magnets | 45d | 2003-09-29 A | 2003-12-03 A |  | 100% |  | 2003-09-29 | 2003-12-03 | 45d |  |  | start no earlier than 2003-09-29 |
| 93 | 1.3.3.3 | **FM 2** | 28d | 2003-12-29 A | 2004-02-06 A |  | 100% |  | 2003-12-29 | 2004-02-06 | 28d |  |  |  |
| 94 | 1.3.3.3.1 | Wind HVPS FM 2 Magnets | 28d | 2003-12-29 A | 2004-02-06 A |  | 100% |  | 2003-12-29 | 2004-02-06 | 28d |  |  | start no earlier than 2003-12-29 |
| 95 | 1.3.3.3.2 | Wind IDPU LVPS FM 2 Magnets | 28d | 2003-12-29 A | 2004-02-06 A | 94SS | 100% |  | 2003-12-29 | 2004-02-06 | 28d |  |  |  |
| 96 | 1.3.3.3.3 | Wind SEP LVPS FM 2 Magnets | 28d | 2003-12-29 A | 2004-02-06 A | 94SS | 100% |  | 2003-12-29 | 2004-02-06 | 28d |  |  |  |
| 97 | 1.3.3.3.4 | Wind SWEA LVPS FM 2 Magnets | 28d | 2003-12-29 A | 2004-02-06 A | 94SS | 100% |  | 2003-12-29 | 2004-02-06 | 28d |  |  |  |
| 98 | 1.3.3.3.5 | Wind PLASTIC LVPS FM 2 Magnets | 28d | 2003-12-29 A | 2004-02-06 A | 94SS | 100% |  | 2003-12-29 | 2004-02-06 | 28d |  |  |  |
| 99 | 1.3.4 | **Assembly** | 166d | 2003-12-29 A | 2004-08-23 |  | 78% | 36.2d | 2003-12-29 | 2004-03-19 | 57d | -29d | 0d |  |
| 100 | 1.3.4.1 | **FM 1** | 84d | 2003-12-29 A | 2004-04-27 A |  | 100% |  | 2003-12-29 | 2004-03-12 | 52d |  |  |  |
| 101 | 1.3.4.1.1 | Assemble IDPU FM 1 LVPS | 17d | 2004-04-05 A | 2004-04-27 A | 89, 113FS+2d | 100% |  | 2004-02-26 | 2004-03-12 | 12d |  |  |  |
| 102 | 1.3.4.1.2 | Assemble SEP FM 1 LVPS | 40d | 2004-01-12 A | 2004-03-09 A | 114, 90 | 100% |  | 2004-01-12 | 2004-02-23 | 29d |  |  | start no earlier than 2004-01-12 |
| 103 | 1.3.4.1.3 | Assemble SWEA FM 1 LVPS | 30d | 2004-02-13 A | 2004-03-26 A | 91, 115 | 100% |  | 2004-02-13 | 2004-03-04 | 14d |  |  | start no earlier than 2004-02-13 |
| 104 | 1.3.4.1.4 | Assemble PLASTIC FM 1 LVPS | 29d | 2003-12-29 A | 2004-02-09 A | 116, 92 | 100% |  | 2003-12-29 | 2004-02-09 | 29d |  |  | start no earlier than 2003-12-29 |
| 105 | 1.3.4.2 | **FM 2** | 104d | 2004-03-29 A | 2004-08-23 |  | 61% | 40.21d | 2004-02-09 | 2004-03-19 | 29d | -29d | 0d |  |
| 106 | 1.3.4.2.1 | Assemble IDPU FM 2 LVPS | 15d | 2004-08-03 | 2004-08-23 | 95, 119 |  |  | 2004-03-01 | 2004-03-19 | 15d | -35d | 0d | start no earlier than 2004-03-01 |
| 107 | 1.3.4.2.2 | Assemble SEP FM 2 LVPS | 25d | 2004-05-24 A | 2004-06-28 | 96, 123FS+5d | 56% | 11d | 2004-02-13 | 2004-03-05 | 15d | 9d | 0d | start no earlier than 2004-02-13 |
| 108 | 1.3.4.2.3 | Assemble SWEA FM 2 LVPS | 15d | 2004-06-22 | 2004-07-13 | 97, 127 |  |  | 2004-02-24 | 2004-03-15 | 15d | -17d | 0d | start no earlier than 2004-02-24 |
| 109 | 1.3.4.2.4 | Assemble PLASTIC FM 2 LVPS | 30d | 2004-05-10 A | 2004-06-21 | 98, 131 | 80% | 6d | 2004-02-09 | 2004-02-27 | 14d | 15d | 0d | start no earlier than 2004-02-09 |
| 110 | 1.3.4.2.5 | Assemble SIT FM 2 HVPS | 65d | 2004-03-29 A | 2004-06-28 | 94, 103 | 83% | 11d | 2004-02-09 | 2004-02-27 | 14d | 9d | 0d |  |
| 111 | 1.3.5 | **Testing** | 229d | 2003-10-31 A | 2004-09-28 |  | 54% | 106.23d | 2003-10-31 | 2004-06-23 | 162d | -35d | 0d |  |
| 112 | 1.3.5.1 | **FM 1 & FM 2** | 88d | 2003-11-24 A | 2004-03-31 A |  | 100% |  | 2003-11-24 | 2004-02-25 | 63d |  |  |  |
| 113 | 1.3.5.1.1 | Coupon Test IDPU Flight Printed Wiring Board | 4d | 2004-03-26 A | 2004-03-31 A | 79FS+9d | 100% |  | 2004-02-20 | 2004-02-25 | 4d |  |  |  |
| 114 | 1.3.5.1.2 | Coupon Test SEP Flight Printed Wiring Board | 5d | 2003-12-09 A | 2003-12-15 A | 80 | 100% |  | 2003-12-09 | 2003-12-15 | 5d |  |  |  |
| 115 | 1.3.5.1.3 | Coupon Test SWEA Flight Printed Wiring Board | 6d | 2004-01-09 A | 2004-01-16 A | 81 | 100% |  | 2004-01-09 | 2004-01-16 | 6d |  |  | start no earlier than 2004-01-09 |
| 116 | 1.3.5.1.4 | Coupon Test PLASTIC Flight Printed Wiring Board | 5d | 2003-11-24 A | 2003-12-01 A | 82 | 100% |  | 2003-11-24 | 2003-12-01 | 5d |  |  | start no earlier than 2003-11-24 |

Notes:
- 110: Stuck in the technician backlog

| ID | WBS | Task | Duration | Start | Finish | Predecessors | Complete | Remaining | Baseline start | Baseline finish | Baseline duration | Total slack | Free slack | Constraint |
| --- | --- | --- | --- | --- | --- | --- | --- | --- | --- | --- | --- | --- | --- | --- |
| 117 | 1.3.5.2 | **FM 1** | 199d | 2003-10-31 A | 2004-08-16 |  | 69% | 61.29d | 2003-10-31 | 2004-06-23 | 162d | -31d | 0d |  |
| 118 | 1.3.5.2.1 | **IDPU** | 40d | 2004-06-21 | 2004-08-16 |  |  |  | 2004-03-15 | 2004-04-23 | 30d | -35d | 0d |  |
| 119 | 1.3.5.2.1.1 | Test IDPU FM 1 LVPS | 30d | 2004-06-21 | 2004-08-02 | 101FS+37d |  |  | 2004-03-15 | 2004-04-02 | 15d | -35d | 0d |  |
| 120 | 1.3.5.2.1.2 | Coat & Stake IDPU LVPS FM 1 Boards | 5d | 2004-08-03 | 2004-08-09 | 119 |  |  | 2004-04-05 | 2004-04-09 | 5d | -31d | 0d |  |
| 121 | 1.3.5.2.1.3 | Retest IDPU LVPS FM 1 Boards | 5d | 2004-08-10 | 2004-08-16 | 120 |  |  | 2004-04-12 | 2004-04-23 | 10d | -31d | 0d |  |
| 122 | 1.3.5.2.2 | **SEP** | 58d | 2004-03-10 A | 2004-05-28 A |  | 100% |  | 2004-02-24 | 2004-04-05 | 30d |  |  |  |
| 123 | 1.3.5.2.2.1 | Test SEP FM 1 LVPS | 48d | 2004-03-10 A | 2004-05-14 A | 102 | 100% |  | 2004-02-24 | 2004-03-15 | 15d |  |  |  |
| 124 | 1.3.5.2.2.2 | Coat & Stake SEP LVPS FM 1 Boards | 5d | 2004-05-17 A | 2004-05-21 A | 123 | 100% |  | 2004-03-16 | 2004-03-22 | 5d |  |  |  |
| 125 | 1.3.5.2.2.3 | Retest SEP LVPS FM 1 Boards | 5d | 2004-05-24 A | 2004-05-28 A | 124, 368 | 100% |  | 2004-03-23 | 2004-04-05 | 10d |  |  |  |
| 126 | 1.3.5.2.3 | **SWEA** | 80d | 2004-03-15 A | 2004-07-06 |  | 44% | 45d | 2004-03-05 | 2004-04-15 | 30d | -10d | 0d |  |
| 127 | 1.3.5.2.3.1 | Test SWEA FM 1 LVPS | 70d | 2004-03-15 A | 2004-06-21 | 103 | 50% | 35d | 2004-03-05 | 2004-03-25 | 15d | -29d | 0d |  |
| 128 | 1.3.5.2.3.2 | Coat & Stake SWEA LVPS FM 1 Boards | 5d | 2004-06-22 | 2004-06-28 | 127 |  |  | 2004-03-26 | 2004-04-01 | 5d | -29d | 0d |  |
| 129 | 1.3.5.2.3.3 | Retest SWEA LVPS FM 1 Boards | 5d | 2004-06-29 | 2004-07-06 | 128 |  |  | 2004-04-02 | 2004-04-15 | 10d | -29d | 0d |  |
| 130 | 1.3.5.2.4 | **PLASTIC** | 73d | 2004-02-10 A | 2004-05-21 A |  | 100% |  | 2004-02-10 | 2004-03-23 | 30d |  |  |  |
| 131 | 1.3.5.2.4.1 | Test PLASTIC FM 1 LVPS | 63d | 2004-02-10 A | 2004-05-07 A | 104 | 100% |  | 2004-02-10 | 2004-03-02 | 15d |  |  |  |
| 132 | 1.3.5.2.4.2 | Coat & Stake PLASTIC LVPS FM 1 Boards | 5d | 2004-05-10 A | 2004-05-14 A | 131 | 100% |  | 2004-03-03 | 2004-03-09 | 5d |  |  |  |
| 133 | 1.3.5.2.4.3 | Retest PLASTIC LVPS FM 1 Boards | 5d | 2004-05-17 A | 2004-05-21 A | 132 | 100% |  | 2004-03-10 | 2004-03-23 | 10d |  |  |  |
| 134 | 1.3.5.2.5 | **SIT** | 25d | 2003-10-31 A | 2003-12-08 A |  | 100% |  | 2003-10-31 | 2004-06-23 | 162d |  |  |  |
| 135 | 1.3.5.2.5.1 | Test SIT FM 1 HVPS | 25d | 2003-10-31 A | 2003-12-08 A |  | 100% |  | 2003-10-31 | 2003-12-08 | 25d |  |  | start no earlier than 2003-10-31 |
| 136 | 1.3.5.3 | **FM 2** | 85d | 2004-05-28 A | 2004-09-28 |  | 14% | 72.86d | 2004-03-01 | 2004-04-30 | 45d | -35d | 0d |  |
| 137 | 1.3.5.3.1 | **IDPU** | 25d | 2004-08-24 | 2004-09-28 |  |  |  | 2004-03-22 | 2004-04-30 | 30d | -35d | 0d |  |
| 138 | 1.3.5.3.1.1 | Test IDPU FM 2 LVPS | 15d | 2004-08-24 | 2004-09-14 | 106 |  |  | 2004-03-22 | 2004-04-09 | 15d | -35d | 0d |  |
| 139 | 1.3.5.3.1.2 | Coat & Stake IDPU LVPS FM 2 Boards | 5d | 2004-09-15 | 2004-09-21 | 138 |  |  | 2004-04-12 | 2004-04-16 | 5d | -35d | 0d |  |
| 140 | 1.3.5.3.1.3 | Retest IDPU LVPS FM 2 Boards | 5d | 2004-09-22 | 2004-09-28 | 139 |  |  | 2004-04-19 | 2004-04-30 | 10d | -35d | 0d |  |

| ID | WBS | Task | Type | Duration | Start | Finish | Predecessors | Complete | Remaining | Baseline start | Baseline finish | Baseline duration | Total slack | Free slack | Constraint | Text1 |
| --- | --- | --- | --- | --- | --- | --- | --- | --- | --- | --- | --- | --- | --- | --- | --- | --- |
| 141 | 1.3.5.3.2 | **SEP** |  | 28d | 2004-06-15 | 2004-07-23 |  |  |  | 2004-03-08 | 2004-04-16 | 30d | 9d |  |  |  |
| 142 | 1.3.5.3.2.1 | Test SEP FM 2 LVPS |  | 15d | 2004-06-15 | 2004-07-06 | 107FS-10d |  |  | 2004-03-08 | 2004-03-26 | 15d | 9d | 0d |  |  |
| 143 | 1.3.5.3.2.2 | Coat & Stake SEP LVPS FM 2 Boards |  | 5d | 2004-07-07 | 2004-07-13 | 142 |  |  | 2004-03-29 | 2004-04-02 | 5d | 9d | 0d |  |  |
| 144 | 1.3.5.3.2.3 | Retest SEP LVPS FM 2 Boards |  | 5d | 2004-07-14 | 2004-07-20 | 143, 368 |  |  | 2004-04-05 | 2004-04-16 | 10d | 9d | 0d |  |  |
| 145 | 1.3.5.3.2.4 | Bakeout SEP LVPS FM 2 Boards |  | 3d | 2004-07-21 | 2004-07-23 | 144 |  |  | 2004-06-22 | 2004-06-24 | 3d | 9d | 0d |  |  |
| 146 | 1.3.5.3.3 | **SWEA** |  | 25d | 2004-07-14 | 2004-08-17 |  |  |  | 2004-03-16 | 2004-04-26 | 30d | -17d | 0d |  |  |
| 147 | 1.3.5.3.3.1 | Test SWEA FM 2 LVPS |  | 15d | 2004-07-14 | 2004-08-03 | 108 |  |  | 2004-03-16 | 2004-04-05 | 15d | -17d | 0d |  |  |
| 148 | 1.3.5.3.3.2 | Coat & Stake SWEA LVPS FM 2 Boards |  | 5d | 2004-08-04 | 2004-08-10 | 147 |  |  | 2004-04-06 | 2004-04-12 | 5d | -17d | 0d |  |  |
| 149 | 1.3.5.3.3.3 | Retest SWEA LVPS FM 2 Boards |  | 5d | 2004-08-11 | 2004-08-17 | 148 |  |  | 2004-04-13 | 2004-04-26 | 10d | -17d | 0d |  |  |
| 150 | 1.3.5.3.4 | **PLASTIC** |  | 30d | 2004-05-28 A | 2004-07-12 |  | 33% | 20d | 2004-03-01 | 2004-04-09 | 30d | 5d |  |  |  |
| 151 | 1.3.5.3.4.1 | Test PLASTIC FM 2 LVPS |  | 20d | 2004-05-28 A | 2004-06-25 | 109FS-16d | 50% | 10d | 2004-03-01 | 2004-03-19 | 15d | 5d | 0d |  |  |
| 152 | 1.3.5.3.4.2 | Coat & Stake PLASTIC LVPS FM 2 Boards |  | 5d | 2004-06-28 | 2004-07-02 | 151 |  |  | 2004-03-22 | 2004-03-26 | 5d | 5d | 0d |  |  |
| 153 | 1.3.5.3.4.3 | Retest PLASTIC LVPS FM 2 Boards |  | 5d | 2004-07-06 | 2004-07-12 | 152 |  |  | 2004-03-29 | 2004-04-09 | 10d | 5d | 0d |  |  |
| 154 | 1.3.5.3.5 | **SIT** |  | 25d | 2004-06-01 A | 2004-07-06 |  | 36% | 16d | 2004-03-01 | 2004-04-09 | 30d | -10d | 0d |  |  |
| 155 | 1.3.5.3.5.1 | Test SIT FM 2 HVPS |  | 15d | 2004-06-01 A | 2004-06-21 | 110FS-20d | 60% | 6d | 2004-03-01 | 2004-03-19 | 15d | -25d | 0d |  |  |
| 156 | 1.3.5.3.5.2 | Coat & Stake SIT FM 2 HVPS Boards |  | 5d | 2004-06-22 | 2004-06-28 | 155 |  |  | 2004-03-22 | 2004-03-26 | 5d | -25d | 0d |  |  |
| 157 | 1.3.5.3.5.3 | Retest SIT FM 2 HVPS Boards |  | 5d | 2004-06-29 | 2004-07-06 | 156 |  |  | 2004-03-29 | 2004-04-09 | 10d | -25d | 0d |  |  |
| 158 | 1.4 | **IDPU - UCB** |  | 378d | 2003-05-05 A | 2004-11-02 |  | 86% | 52.88d | 2003-05-05 | 2004-09-07 | 340d | -18d | 0d |  |  |
| 159 | 1.4.1 | **Deliveries** |  | 30d | 2004-08-23 | 2004-10-05 |  |  |  | 2004-04-13 | 2004-05-28 | 33d | -35d | 0d |  |  |
| 160 | 1.4.1.1 | IDPU FM 1 Complete (to UCB for Boom I&T, then to CIT for SEP I&T, Suite EMC, BO & Final Boom I&T) | milestone | 0d | 2004-08-23 | 2004-08-23 | 173 |  |  | 2004-05-21 | 2004-05-21 | 0d | -31d | 0d |  | MS-BOOM |
| 161 | 1.4.1.2 | IDPU FM 2 Complete (to CIT for SEP I&T, then to UCB for Boom I&T, Boom EMC, BO & Final Boom I&T) | milestone | 0d | 2004-10-05 | 2004-10-05 | 177 |  |  | 2004-05-28 | 2004-05-28 | 0d | -35d | 0d |  | MS-BOOM |
| 162 | 1.4.2 | **Flight Software** |  | 306d | 2003-05-05 A | 2004-07-21 |  | 93% | 22.64d | 2003-05-05 | 2004-04-13 | 237d | 44d |  |  |  |
| 163 | 1.4.2.1 | IDPU S/W Build #2.5 |  | 131d | 2003-05-05 A | 2003-11-07 A |  | 100% |  | 2003-05-05 | 2003-11-07 | 131d |  |  | start no earlier than 2003-05-05 |  |
| 164 | 1.4.2.2 | IDPU S/W Build #3 (also goes to UNH) |  | 234d | 2003-08-15 A | 2004-07-21 |  | 88% | 27d | 2003-08-15 | 2004-04-13 | 165d | 44d |  | start no earlier than 2003-08-15 | MS-BOOM |

| ID | WBS | Task | Type | Duration | Start | Finish | Predecessors | Complete | Remaining | Baseline start | Baseline finish | Baseline duration | Total slack | Free slack | Constraint | Text1 |
| --- | --- | --- | --- | --- | --- | --- | --- | --- | --- | --- | --- | --- | --- | --- | --- | --- |
| 165 | 1.4.3 | **GSE** |  | 301d | 2003-06-30 A | 2004-09-08 |  | 87% | 37.86d | 2003-06-30 | 2004-09-07 | 301d | 0d |  |  |  |
| 166 | 1.4.3.1 | STE Science Display |  | 27d | 2003-10-23 A | 2003-12-02 A |  | 100% |  | 2003-10-23 | 2003-12-02 | 27d |  |  | start no earlier than 2003-10-23 |  |
| 167 | 1.4.3.2 | SWEA Science Display |  | 167d | 2003-06-30 A | 2004-03-01 A |  | 100% |  | 2003-06-30 | 2004-02-23 | 162d |  |  | start no earlier than 2003-06-30 |  |
| 168 | 1.4.3.3 | GSE Continued Development (LOE) |  | 291d | 2003-07-15 A | 2004-09-08 |  | 79% | 61d | 2003-07-15 | 2004-09-07 | 291d | 0d |  | must start on 2003-07-15 |  |
| 169 | 1.4.4 | **Integration & Test** |  | 270d | 2003-10-07 A | 2004-11-02 |  | 38% | 166.15d | 2003-10-07 | 2004-05-28 | 162d | -18d | 0d |  |  |
| 170 | 1.4.4.1 | IDPU DCB FM 2 Board Level Testing |  | 15d | 2003-10-07 A | 2003-10-28 A |  | 100% |  | 2003-10-07 | 2003-10-28 | 15d |  |  | start no earlier than 2003-10-07 |  |
| 171 | 1.4.4.2 | IDPU DCB Clean/Stake/Coat (FM 1 & FM 2) |  | 10d | 2003-12-26 A | 2004-01-09 A | 170 | 100% |  | 2003-12-26 | 2004-01-09 | 10d |  |  | start no earlier than 2003-12-26 |  |
| 172 | 1.4.4.3 | **FM 1** |  | 39d | 2004-08-17 | 2004-10-12 |  |  |  | 2004-04-26 | 2004-05-21 | 20d | -31d | 0d |  |  |
| 173 | 1.4.4.3.1 | IDPU FM 1 I & T |  | 5d | 2004-08-17 | 2004-08-23 | 163, 67, 236, 280, 171 |  |  | 2004-04-26 | 2004-04-30 | 5d | -31d | 0d |  | MS-BOOM |
| 174 | 1.4.4.3.2 | IDPU FM 1 Vibration |  | 5d | 2004-09-21 | 2004-09-27 | 173, 19 |  |  | 2004-05-03 | 2004-05-07 | 5d | -8d | 0d |  |  |
| 175 | 1.4.4.3.3 | IDPU FM 1 Thermal Vacuum & Bake Out |  | 10d | 2004-09-28 | 2004-10-12 | 174 |  |  | 2004-05-10 | 2004-05-21 | 10d | -8d | 0d |  |  |
| 176 | 1.4.4.4 | **FM 2** |  | 24d | 2004-09-29 | 2004-11-02 |  |  |  | 2004-05-03 | 2004-05-28 | 20d | -35d | 0d |  |  |
| 177 | 1.4.4.4.1 | IDPU FM 2 I & T |  | 5d | 2004-09-29 | 2004-10-05 | 73, 237, 281, 170, 171 |  |  | 2004-05-03 | 2004-05-07 | 5d | -35d | 0d |  |  |
| 178 | 1.4.4.4.2 | IDPU FM 2 Vibration |  | 5d | 2004-10-13 | 2004-10-19 | 812FS+2d |  |  | 2004-05-10 | 2004-05-14 | 5d | -18d | 0d |  |  |
| 179 | 1.4.4.4.3 | IDPU FM 2 Thermal Vacuum & Bake Out |  | 10d | 2004-10-20 | 2004-11-02 | 178, 164 |  |  | 2004-05-17 | 2004-05-28 | 10d | -18d | 0d |  |  |
| 180 | 1.5 | **BOOM Suite - UCB** |  | 352d | 2003-07-01 A | 2004-11-23 |  | 87% | 44.2d | 2003-07-01 | 2004-09-28 | 315d | -18d | 0d |  |  |
| 181 | 1.5.1 | **BOOM Structure - UCB** |  | 252d | 2003-09-10 A | 2004-09-09 |  | 88% | 31.29d | 2003-09-10 | 2004-06-18 | 195d | 17d |  |  |  |
| 182 | 1.5.1.1 | **Deliveries** |  | 169d | 2004-01-09 A | 2004-09-09 |  |  | 169d | 2004-01-09 | 2004-06-18 | 112d | 17d |  |  |  |
| 183 | 1.5.1.1.1 | Protoflight Boom available for I&T (if needed) | milestone | 0d | 2004-01-09 A | 2004-01-09 A | 188 | 100% |  | 2004-01-09 | 2004-01-09 | 0d |  |  |  |  |
| 184 | 1.5.1.1.2 | Deliver Boom Structure FM 1 (stays at UCB for Boom Suite FM 1 I&T) | milestone | 0d | 2004-07-20 | 2004-07-20 | 212 |  |  | 2004-05-27 | 2004-05-27 | 0d | -9d | 0d |  | MS-BOOM |
| 185 | 1.5.1.1.3 | Deliver Boom Structure FM 2 (stays at UCB for Boom Suite FM 2 I&T) | milestone | 0d | 2004-09-09 | 2004-09-09 | 233 |  |  | 2004-06-18 | 2004-06-18 | 0d | 17d |  |  | MS-BOOM |
| 186 | 1.5.1.2 | **Protoflight** |  | 79d | 2003-09-16 A | 2004-01-09 A |  | 100% |  | 2003-09-16 | 2004-01-09 | 79d |  |  |  |  |
| 187 | 1.5.1.2.1 | Protoflight Boom Post Environmental Deployment Test |  | 35d | 2003-09-16 A | 2003-11-04 A |  | 100% |  | 2003-09-16 | 2003-11-04 | 35d |  |  | start no earlier than 2003-09-16 |  |
| 188 | 1.5.1.2.2 | Document Protoflight Boom Test Results |  | 44d | 2003-11-05 A | 2004-01-09 A | 187 | 100% |  | 2003-11-05 | 2004-01-09 | 44d |  |  |  |  |

| ID | WBS | Task | Duration | Start | Finish | Predecessors | Complete | Remaining | Baseline start | Baseline finish | Baseline duration | Total slack | Free slack | Constraint | Calendar | Text1 |
| --- | --- | --- | --- | --- | --- | --- | --- | --- | --- | --- | --- | --- | --- | --- | --- | --- |
| 189 | 1.5.1.3 | **Flight Procurements** | 40d | 2003-09-10 A | 2003-11-05 A |  | 100% |  | 2003-09-10 | 2003-11-05 | 40d |  |  |  |  |  |
| 190 | 1.5.1.3.1 | Receive and Inspect Flight Boom Structure Tubes (FM 1) | 32d | 2003-09-10 A | 2003-10-24 A |  | 100% |  | 2003-09-10 | 2003-10-24 | 32d |  |  | start no earlier than 2003-09-10 |  |  |
| 191 | 1.5.1.3.2 | Receive and Inspect Flight Boom Structure Tubes (FM 2) | 40d | 2003-09-10 A | 2003-11-05 A |  | 100% |  | 2003-09-10 | 2003-11-05 | 40d |  |  | start no earlier than 2003-09-10 |  |  |
| 192 | 1.5.1.4 | **FM 1** | 203d | 2003-09-29 A | 2004-07-20 |  | 93% | 13.73d | 2003-09-29 | 2004-05-27 | 167d | -9d | 0d |  |  |  |
| 193 | 1.5.1.4.1 | **Telescoping** | 84d | 2003-10-27 A | 2004-02-29 A |  | 100% |  | 2003-10-27 | 2004-02-29 | 84d |  |  |  |  |  |
| 194 | 1.5.1.4.1.1 | **Fabrication, Assembly & Test** | 84d | 2003-10-27 A | 2004-02-29 A |  | 100% |  | 2003-10-27 | 2004-02-29 | 84d |  |  |  |  |  |
| 195 | 1.5.1.4.1.1.1 | Machine FM 1 Boom Structure Tubes as necessary | 5d | 2003-10-27 A | 2003-10-31 A | 190 | 100% |  | 2003-10-27 | 2003-10-31 | 5d |  |  |  |  |  |
| 196 | 1.5.1.4.1.1.2 | Machine FM 1 Boom Structure Parts (Rings) | 38d | 2003-11-07 A | 2004-01-05 A | 190FF+47d | 100% |  | 2003-11-07 | 2004-01-05 | 38d |  |  |  |  |  |
| 197 | 1.5.1.4.1.1.3 | Assemble FM 1 Boom Structure Telescoping Assembly | 5d | 2004-02-23 A | 2004-02-27 A | 195, 196 | 100% |  | 2004-02-23 | 2004-02-27 | 5d |  |  | start no earlier than 2004-02-23 |  |  |
| 198 | 1.5.1.4.1.1.4 | Test FM 1 Boom Structure Telescoping Assembly | 2d | 2004-02-28 A | 2004-02-29 A | 197 | 100% |  | 2004-02-28 | 2004-02-29 | 2d |  |  |  | Boom Test Calendar |  |
| 199 | 1.5.1.4.2 | **Harness** | 109d | 2003-09-29 A | 2004-03-08 A |  | 100% |  | 2003-09-29 | 2004-03-08 | 109d |  |  |  |  |  |
| 200 | 1.5.1.4.2.1 | **Fabrication** | 103d | 2003-09-29 A | 2004-02-27 A |  | 100% |  | 2003-09-29 | 2004-02-27 | 103d |  |  |  |  |  |
| 201 | 1.5.1.4.2.1.1 | Machine FM 1 Harness Parts | 103d | 2003-09-29 A | 2004-02-27 A |  | 100% |  | 2003-09-29 | 2004-02-27 | 103d |  |  | start no earlier than 2003-09-29 |  |  |
| 202 | 1.5.1.4.2.2 | **Assembly & Test** | 6d | 2004-03-01 A | 2004-03-08 A |  | 100% |  | 2004-03-01 | 2004-03-08 | 6d |  |  |  |  |  |
| 203 | 1.5.1.4.2.2.1 | Assemble FM 1 Harness subassembly | 7d | 2004-03-01 A | 2004-03-07 A | 201 | 100% |  | 2004-03-01 | 2004-03-07 | 7d |  |  | start no earlier than 2004-03-01 | Boom Test Calendar |  |
| 204 | 1.5.1.4.2.2.2 | FM1 Harness Test | 1d | 2004-03-08 A | 2004-03-08 A | 203 | 100% |  | 2004-03-08 | 2004-03-08 | 1d |  |  |  |  |  |
| 205 | 1.5.1.4.3 | **Mounting** | 38d | 2003-09-29 A | 2003-11-21 A |  | 100% |  | 2003-09-29 | 2003-11-21 | 38d |  |  |  |  |  |
| 206 | 1.5.1.4.3.1 | FM 1Boom Structure Mounting Fabrication | 28d | 2003-09-29 A | 2003-11-06 A |  | 100% |  | 2003-09-29 | 2003-11-06 | 28d |  |  | start no earlier than 2003-09-29 |  |  |
| 207 | 1.5.1.4.3.2 | FM 1Boom Structure Mounting Assembly | 10d | 2003-11-07 A | 2003-11-21 A | 206 | 100% |  | 2003-11-07 | 2003-11-21 | 10d |  |  |  |  |  |
| 208 | 1.5.1.4.4 | **Integration & Test** | 89d | 2004-03-16 A | 2004-07-20 |  | 77% | 20.62d | 2004-03-09 | 2004-05-27 | 58d | -9d | 0d |  |  |  |
| 209 | 1.5.1.4.4.1 | Integrate FM 1 Boom Structure subassemblies & Harness Completion | 60d | 2004-03-16 A | 2004-06-08 A | 198, 204FS+5d | 100% |  | 2004-03-09 | 2004-04-05 | 20d |  |  |  |  | MS-BOOM |
| 210 | 1.5.1.4.4.2 | FM 1 Boom Structure Deployment Test | 3d | 2004-06-09 A | 2004-06-11 A | 209 | 100% |  | 2004-04-06 | 2004-04-19 | 10d |  |  |  |  | MS-BOOM |
| 211 | 1.5.1.4.4.3 | FM 1 Boom Structure Vibration Test | 4d | 2004-06-23 | 2004-06-28 | 210, 347 |  |  | 2004-04-27 | 2004-04-30 | 4d | -9d | 0d |  |  |  |
| 212 | 1.5.1.4.4.4 | FM 1 Boom Structure Themal Vac & Bake Out | 15d | 2004-06-29 | 2004-07-20 | 211 |  |  | 2004-05-03 | 2004-05-21 | 15d | -9d | 0d |  |  |  |

| ID | WBS | Task | Duration | Start | Finish | Predecessors | Complete | Remaining | Baseline start | Baseline finish | Baseline duration | Total slack | Free slack | Text1 |
| --- | --- | --- | --- | --- | --- | --- | --- | --- | --- | --- | --- | --- | --- | --- |
| 213 | 1.5.1.5 | **FM 2** | 239d | 2003-09-29 A | 2004-09-09 |  | 76% | 57.17d | 2003-09-29 | 2004-06-18 | 182d | 17d |  |  |
| 214 | 1.5.1.5.1 | **Telescoping** | 78d | 2003-11-06 A | 2004-03-02 A |  | 100% |  | 2003-11-06 | 2004-03-16 | 88d |  |  |  |
| 215 | 1.5.1.5.1.1 | **Fabrication, Assembly & Test** | 78d | 2003-11-06 A | 2004-03-02 A |  | 100% |  | 2003-11-06 | 2004-03-16 | 88d |  |  |  |
| 216 | 1.5.1.5.1.1.1 | Machine FM 2 Boom Structure Tubes as necessary | 11d | 2003-11-06 A | 2003-11-21 A | 191 | 100% |  | 2003-11-06 | 2003-11-21 | 11d |  |  |  |
| 217 | 1.5.1.5.1.1.2 | Machine FM 2 Boom Structure Parts (Rings) | 38d | 2003-11-07 A | 2004-01-05 A | 196SS | 100% |  | 2003-11-07 | 2004-01-05 | 38d |  |  |  |
| 218 | 1.5.1.5.1.1.3 | Assemble FM 2 Boom Structure Telescoping Assembly | 5d | 2004-02-23 A | 2004-02-27 A | 216, 217, 197SS | 100% |  | 2004-02-23 | 2004-02-27 | 5d |  |  |  |
| 219 | 1.5.1.5.1.1.4 | Test FM 2 Boom Structure Telescoping Assembly | 2d | 2004-03-01 A | 2004-03-02 A | 218 | 100% |  | 2004-03-15 | 2004-03-16 | 2d |  |  |  |
| 220 | 1.5.1.5.2 | **Harness** | 110d | 2003-09-29 A | 2004-03-09 A |  | 100% |  | 2003-09-29 | 2004-03-16 | 115d |  |  |  |
| 221 | 1.5.1.5.2.1 | **Fabrication** | 103d | 2003-09-29 A | 2004-02-27 A |  | 100% |  | 2003-09-29 | 2004-02-27 | 103d |  |  |  |
| 222 | 1.5.1.5.2.1.1 | Machine FM 2 Harness Parts | 103d | 2003-09-29 A | 2004-02-27 A | 201SS | 100% |  | 2003-09-29 | 2004-02-27 | 103d |  |  |  |
| 223 | 1.5.1.5.2.2 | **Assembly & Test** | 7d | 2004-03-01 A | 2004-03-09 A |  | 100% |  | 2004-03-01 | 2004-03-16 | 12d |  |  |  |
| 224 | 1.5.1.5.2.2.1 | Assemble FM 2 Harness subassembly | 6d | 2004-03-01 A | 2004-03-08 A | 222 | 100% |  | 2004-03-01 | 2004-03-15 | 11d |  |  |  |
| 225 | 1.5.1.5.2.2.2 | FM 2 Harness Test | 1d | 2004-03-09 A | 2004-03-09 A | 224 | 100% |  | 2004-03-16 | 2004-03-16 | 1d |  |  |  |
| 226 | 1.5.1.5.3 | **Mounting** | 38d | 2003-09-29 A | 2003-11-21 A |  | 100% |  | 2003-09-29 | 2003-11-21 | 38d |  |  |  |
| 227 | 1.5.1.5.3.1 | FM 2 Boom Structure Mountings Fabrication | 28d | 2003-09-29 A | 2003-11-06 A | 206SS | 100% |  | 2003-09-29 | 2003-11-06 | 28d |  |  |  |
| 228 | 1.5.1.5.3.2 | FM 2 Boom Structure Mountings Assembly | 10d | 2003-11-07 A | 2003-11-21 A | 227 | 100% |  | 2003-11-07 | 2003-11-21 | 10d |  |  |  |
| 229 | 1.5.1.5.4 | **Integration & Test** | 116d | 2004-03-29 A | 2004-09-09 |  | 26% | 86.1d | 2004-03-17 | 2004-06-18 | 67d | 17d |  |  |
| 230 | 1.5.1.5.4.1 | Integrate FM 2 Boom Structure subassemblies & Harness Completion | 75d | 2004-03-29 A | 2004-07-13 | 219, 225, 209SS+10d | 33% | 50d | 2004-03-17 | 2004-04-13 | 20d | 32d | 0d |  |
| 231 | 1.5.1.5.4.2 | FM 2 Boom Structure Deployment Test | 3d | 2004-07-14 | 2004-07-16 | 230 |  |  | 2004-04-14 | 2004-04-27 | 10d | 32d | 15d |  |
| 232 | 1.5.1.5.4.3 | FM 2 Boom Structure Vibration Test | 4d | 2004-08-13 | 2004-08-18 | 231, 352 |  |  | 2004-05-17 | 2004-05-20 | 4d | 17d | 0d |  |
| 233 | 1.5.1.5.4.4 | FM 2 Boom Structure Themal Vac & Bake Out | 15d | 2004-08-19 | 2004-09-09 | 232, 212 |  |  | 2004-05-24 | 2004-06-14 | 15d | 17d | 0d |  |
| 234 | 1.5.2 | **MAG - GSFC** | 63d | 2004-02-20 A | 2004-05-18 A |  | 100% |  | 2004-02-20 | 2004-03-29 | 27d |  |  |  |
| 235 | 1.5.2.1 | **Deliveries** | 15d | 2004-04-28 A | 2004-05-18 A |  | 100% |  | 2004-03-26 | 2004-03-29 | 2d |  |  |  |
| 236 | 1.5.2.1.1 | Deliver MAG FM 1 (to UCB for IDPU/BOOM Suite FM 1 I&T) | 2d | 2004-04-28 A | 2004-04-29 A | 240 | 100% |  | 2004-03-26 | 2004-03-29 | 2d |  |  | MS-BOOM |
| 237 | 1.5.2.1.2 | Deliver MAG FM 2 (to UCB for IDPU/BOOM Suite FM 2 I&T) | 2d | 2004-05-17 A | 2004-05-18 A | 243 | 100% |  | 2004-03-26 | 2004-03-29 | 2d |  |  | MS-BOOM |

| ID | WBS | Task | Type | Duration | Start | Finish | Predecessors | Complete | Remaining | Baseline start | Baseline finish | Baseline duration | Total slack | Free slack | Constraint | Text1 |
| --- | --- | --- | --- | --- | --- | --- | --- | --- | --- | --- | --- | --- | --- | --- | --- | --- |
| 238 | 1.5.2.2 | **FM 1** |  | 48d | 2004-02-20 A | 2004-04-27 A |  | 100% |  | 2004-02-20 | 2004-03-25 | 25d |  |  |  |  |
| 239 | 1.5.2.2.1 | FM 1 MAG Testing |  | 20d | 2004-02-20 A | 2004-03-18 A |  | 100% |  | 2004-02-20 | 2004-03-04 | 10d |  |  | start no earlier than 2004-02-20 |  |
| 240 | 1.5.2.2.2 | MAG FM 1 Calibration |  | 22d | 2004-03-26 A | 2004-04-27 A | 239FS+10d | 100% |  | 2004-03-05 | 2004-03-25 | 15d |  |  |  |  |
| 241 | 1.5.2.3 | **FM 2** |  | 51d | 2004-03-05 A | 2004-05-14 A |  | 100% |  | 2004-02-20 | 2004-03-25 | 25d |  |  |  |  |
| 242 | 1.5.2.3.1 | FM 2 MAG Testing |  | 20d | 2004-03-05 A | 2004-04-01 A | 239FF+10d | 100% |  | 2004-02-20 | 2004-03-04 | 10d |  |  |  |  |
| 243 | 1.5.2.3.2 | MAG FM 2 Calibration |  | 21d | 2004-04-16 A | 2004-05-14 A | 242FS+10d | 100% |  | 2004-03-05 | 2004-03-25 | 15d |  |  |  |  |
| 244 | 1.5.3 | **SWEA - CESR** |  | 126d | 2003-12-08 A | 2004-06-07 A |  | 100% |  | 2003-12-08 | 2004-04-20 | 93d |  |  |  |  |
| 245 | 1.5.3.1 | **Deliveries** |  | 126d | 2003-12-08 A | 2004-06-07 A |  | 100% |  | 2003-12-08 | 2004-04-20 | 93d |  |  |  |  |
| 246 | 1.5.3.1.1 | SWEA FM 1 Delivery to UCB |  | 3d | 2003-12-08 A | 2003-12-10 A |  | 100% |  | 2003-12-08 | 2003-12-10 | 3d |  |  | start no earlier than 2003-12-08 |  |
| 247 | 1.5.3.1.2 | SWEA FM 2 Delivery to UCB |  | 3d | 2004-06-03 A | 2004-06-07 A | 250FS+7d | 100% |  | 2004-04-16 | 2004-04-20 | 3d |  |  |  | MS-BOOM |
| 248 | 1.5.3.2 | **FM 2** |  | 50d | 2004-03-15 A | 2004-05-21 A |  | 100% |  | 2004-02-10 | 2004-04-15 | 47d |  |  |  |  |
| 249 | 1.5.3.2.1 | SWEA FM 2 Final Assembly (Block 2) |  | 5d | 2004-03-15 A | 2004-03-19 A |  | 100% |  | 2004-02-10 | 2004-02-12 | 3d |  |  | start no earlier than 2004-03-15 |  |
| 250 | 1.5.3.2.2 | SWEA FM 2 Calibration |  | 45d | 2004-03-22 A | 2004-05-21 A | 249 | 100% |  | 2004-02-13 | 2004-04-15 | 44d |  |  |  | MS-BOOM |
| 251 | 1.5.4 | **STE - UCB** |  | 236d | 2003-08-29 A | 2004-08-06 |  | 89% | 26.13d | 2003-08-29 | 2004-05-10 | 174d | 17d |  |  |  |
| 252 | 1.5.4.1 | **Deliveries** |  | 38d | 2004-06-14 | 2004-08-06 |  |  |  | 2004-04-14 | 2004-05-10 | 18d | -7d | 0d |  |  |
| 253 | 1.5.4.1.1 | Deliver STE-D FM 1 (stays at UCB for SWEA/STE-D FM 1 I&T) | milestone | 0d | 2004-06-14 | 2004-06-14 | 268 |  |  | 2004-04-14 | 2004-04-14 | 0d | -4d | 0d |  | MS-BOOM |
| 254 | 1.5.4.1.2 | Deliver STE-D FM 2 (stays at UCB for SWEA/STE-D FM 2 I&T) | milestone | 0d | 2004-08-06 | 2004-08-06 | 276 |  |  | 2004-05-10 | 2004-05-10 | 0d | 0d |  |  | MS-BOOM |
| 255 | 1.5.4.1.3 | Deliver STE-U FM 1 (stays at UCB for BOOM Suite FM 1 I&T) | milestone | 0d | 2004-06-16 | 2004-06-16 | 269 |  |  | 2004-04-20 | 2004-04-20 | 0d | -9d | 0d |  | MS-BOOM |
| 256 | 1.5.4.1.4 | Deliver STE-U FM 2 (stays at UCB for BOOM Suite FM 2 I&T) | milestone | 0d | 2004-08-06 | 2004-08-06 | 277 |  |  | 2004-05-10 | 2004-05-10 | 0d | 17d | 0d |  | MS-BOOM |
| 257 | 1.5.4.2 | **STE-U/D Housing** |  | 53d | 2003-11-21 A | 2004-02-09 A |  | 100% |  | 2003-11-21 | 2004-02-09 | 53d |  |  |  |  |
| 258 | 1.5.4.2.1 | Fabricate STE FM 1 Box |  | 53d | 2003-11-21 A | 2004-02-09 A |  | 100% |  | 2003-11-21 | 2004-02-09 | 53d |  |  | start no earlier than 2003-11-21 |  |
| 259 | 1.5.4.2.2 | Fabricate STE FM 2 Box |  | 53d | 2003-11-21 A | 2004-02-09 A |  | 100% |  | 2003-11-21 | 2004-02-09 | 53d |  |  | start no earlier than 2003-11-21 |  |
| 260 | 1.5.4.3 | **STE-U/D Detector Boards** |  | 236d | 2003-08-29 A | 2004-08-06 |  | 86% | 32.23d | 2003-08-29 | 2004-05-10 | 174d | 17d |  |  |  |
| 261 | 1.5.4.3.1 | Coupon Test STE FM 1 & FM 2 Detector Printed Wiring Board |  | 17d | 2003-10-10 A | 2003-11-04 A | 263, 271 | 100% |  | 2003-10-10 | 2003-11-04 | 17d |  |  | start no earlier than 2003-10-10 |  |

| ID | WBS | Task | Type | Duration | Start | Finish | Predecessors | Complete | Remaining | Baseline start | Baseline finish | Baseline duration | Total slack | Free slack | Constraint | Text1 |
| --- | --- | --- | --- | --- | --- | --- | --- | --- | --- | --- | --- | --- | --- | --- | --- | --- |
| 262 | 1.5.4.3.2 | **FM 1** |  | 200d | 2003-08-29 A | 2004-06-16 |  | 98% | 3.6d | 2003-08-29 | 2004-04-20 | 160d | 0d |  |  |  |
| 263 | 1.5.4.3.2.1 | Fabrication STE FM 1 Detector Printed Wiring Board |  | 29d | 2003-08-29 A | 2003-10-09 A |  | 100% |  | 2003-08-29 | 2003-10-09 | 29d |  |  | start no earlier than 2003-08-29 |  |
| 264 | 1.5.4.3.2.2 | Load STE FM 1 Detector Printed Wiring Board |  | 60d | 2003-11-05 A | 2004-02-03 A | 261 | 100% |  | 2003-11-05 | 2004-02-03 | 60d |  |  |  |  |
| 265 | 1.5.4.3.2.3 | Test STE FM 1 Detector Printed Wiring Board |  | 10d | 2004-02-04 A | 2004-02-18 A | 264 | 100% |  | 2004-02-04 | 2004-02-18 | 10d |  |  |  |  |
| 266 | 1.5.4.3.2.4 | **Integration & Test** |  | 84d | 2004-02-19 A | 2004-06-16 |  | 97% | 2.73d | 2004-02-19 | 2004-04-20 | 44d | 0d |  |  |  |
| 267 | 1.5.4.3.2.4.1 | Integrate & Test STE-U/D FM 1 Detectors W/ FM 1 Housings |  | 47d | 2004-02-19 A | 2004-04-23 A | 258, 265 | 100% |  | 2004-02-19 | 2004-03-17 | 20d |  |  |  |  |
| 268 | 1.5.4.3.2.4.2 | Calibrate STE-U/D FM 1 |  | 45d | 2004-04-12 A | 2004-06-14 | 267FS-10d | 98% | 1d | 2004-03-18 | 2004-04-14 | 20d | -4d | 0d |  |  |
| 269 | 1.5.4.3.2.4.3 | STE-U FM 1 Thermal Vacuum/Balance/Bake Out |  | 31d | 2004-04-26 A | 2004-06-16 | 268FS-6d | 90% | 3d | 2004-04-01 | 2004-04-20 | 14d | -9d | 0d |  |  |
| 270 | 1.5.4.3.3 | **FM 2** |  | 236d | 2003-08-29 A | 2004-08-06 |  | 73% | 63.66d | 2003-08-29 | 2004-05-10 | 174d | 17d |  |  |  |
| 271 | 1.5.4.3.3.1 | Fabricate STE FM 2 Detector Printed Wiring Board |  | 29d | 2003-08-29 A | 2003-10-09 A |  | 100% |  | 2003-08-29 | 2003-10-09 | 29d |  |  | start no earlier than 2003-08-29 |  |
| 272 | 1.5.4.3.3.2 | Load STE FM 2 Detector Printed Wiring Board |  | 63d | 2003-11-05 A | 2004-03-12 A | 261, 265FF+17d | 100% |  | 2003-11-05 | 2004-03-17 | 63d |  |  |  |  |
| 273 | 1.5.4.3.3.3 | Test STE FM 2 Detector Printed Wiring Board |  | 65d | 2004-03-15 A | 2004-06-14 A | 272 | 100% |  | 2004-03-18 | 2004-03-31 | 10d |  |  |  |  |
| 274 | 1.5.4.3.3.4 | **Integration & Test** |  | 38d | 2004-06-15 | 2004-08-06 |  |  |  | 2004-04-01 | 2004-05-10 | 28d | 0d |  |  |  |
| 275 | 1.5.4.3.3.4.1 | Integrate & Test STE-U/D FM 2 Detectors W/ FM 2 Housings |  | 20d | 2004-06-15 | 2004-07-13 | 259, 273, 267FS-10d, 268 |  |  | 2004-04-01 | 2004-04-14 | 10d | 0d |  |  |  |
| 276 | 1.5.4.3.3.4.2 | Calibrate STE-U/D FM 2 |  | 28d | 2004-06-29 | 2004-08-06 | 275FS-10d |  |  | 2004-04-15 | 2004-05-10 | 18d | 0d |  |  |  |
| 277 | 1.5.4.3.3.4.3 | STE-U FM 2 Thermal Vacuum/Bake Out |  | 10d | 2004-07-26 | 2004-08-06 | 276FS-10d |  |  | 2004-04-27 | 2004-05-10 | 10d | 17d | 0d |  |  |
| 278 | 1.5.5 | **STE and SWEA - UCB** |  | 335d | 2003-07-01 A | 2004-10-28 |  | 88% | 40.94d | 2003-07-01 | 2004-08-27 | 294d | -17d | 0d |  |  |
| 279 | 1.5.5.1 | **Deliveries** |  | 115d | 2004-05-14 A | 2004-10-28 |  |  | 115d | 2004-02-27 | 2004-08-27 | 129d | -17d | 0d |  |  |
| 280 | 1.5.5.1.1 | Deliver STE-U FM 1 Interface (stays at UCB for IDPU FM 1 I&T) | milestone | 0d | 2004-05-14 A | 2004-05-14 A | 329 | 100% |  | 2004-02-27 | 2004-02-27 | 0d |  |  |  | MS-BOOM |
| 281 | 1.5.5.1.2 | Deliver STE-U FM 2 Interface (stays at UCB for IDPU FM 2 I&T) | milestone | 0d | 2004-06-09 A | 2004-06-09 A | 338 | 100% |  | 2004-03-01 | 2004-03-01 | 0d |  |  |  | MS-BOOM |
| 282 | 1.5.5.1.3 | Deliver SWEA/STE-D FM 1 (stays at UCB for Boom Suite FM 1 I&T) | milestone | 0d | 2004-08-17 | 2004-08-17 | 334 |  |  | 2004-06-11 | 2004-06-11 | 0d | -29d | 0d |  | MS-BOOM |
| 283 | 1.5.5.1.4 | Deliver SWEA/STE-D FM 2 (stays at UCB for Boom Suite FM 2 I&T) | milestone | 0d | 2004-10-28 | 2004-10-28 | 344 |  |  | 2004-08-27 | 2004-08-27 | 0d | -17d | 0d |  | MS-BOOM |
| 284 | 1.5.5.2 | **SWEA Pedestal** |  | 152d | 2003-07-01 A | 2004-02-09 A |  | 100% |  | 2003-07-01 | 2004-02-09 | 152d |  |  |  |  |
| 285 | 1.5.5.2.1 | Fabricate SWEA FM 1 Baseplate |  | 152d | 2003-07-01 A | 2004-02-09 A |  | 100% |  | 2003-07-01 | 2004-02-09 | 152d |  |  | start no earlier than 2003-07-01 |  |
| 286 | 1.5.5.2.2 | Fabricate SWEA FM 2 Baseplate |  | 152d | 2003-07-01 A | 2004-02-09 A |  | 100% |  | 2003-07-01 | 2004-02-09 | 152d |  |  | start no earlier than 2003-07-01 |  |

| ID | WBS | Task | Duration | Start | Finish | Predecessors | Complete | Baseline start | Baseline finish | Baseline duration | Constraint |
| --- | --- | --- | --- | --- | --- | --- | --- | --- | --- | --- | --- |
| 287 | 1.5.5.3 | **STE-D Pre-Amp Board** | 163d | 2003-09-22 A | 2004-05-14 A |  | 100% | 2003-09-22 | 2004-02-23 | 104d |  |
| 288 | 1.5.5.3.1 | **FM 1** | 163d | 2003-09-22 A | 2004-05-14 A |  | 100% | 2003-09-22 | 2004-02-23 | 104d |  |
| 289 | 1.5.5.3.1.1 | Fabricate STE-D FM 1 Preamp Printed Wiring Board | 34d | 2003-09-22 A | 2003-11-07 A |  | 100% | 2003-09-22 | 2003-11-07 | 34d | start no earlier than 2003-09-22 |
| 290 | 1.5.5.3.1.2 | Load STE-D FM 1 Preamp Printed Wiring Board | 49d | 2004-03-09 A | 2004-05-14 A | 294 | 100% | 2004-02-17 | 2004-02-23 | 5d | start no earlier than 2004-03-09 |
| 291 | 1.5.5.3.2 | **FM 2** | 163d | 2003-09-22 A | 2004-05-14 A |  | 100% | 2003-09-22 | 2004-02-23 | 104d |  |
| 292 | 1.5.5.3.2.1 | Fabricate STE-D FM 2 Preamp Printed Wiring Board | 34d | 2003-09-22 A | 2003-11-07 A |  | 100% | 2003-09-22 | 2003-11-07 | 34d | start no earlier than 2003-09-22 |
| 293 | 1.5.5.3.2.2 | Load STE-D FM 2 Preamp Printed Wiring Board | 49d | 2004-03-09 A | 2004-05-14 A | 290SS | 100% | 2004-02-17 | 2004-02-23 | 5d |  |
| 294 | 1.5.5.3.3 | Coupon Test STE-D FM 1 & FM 2 Pre-Amp Printed Wiring Boards | 15d | 2003-11-10 A | 2003-12-02 A | 289, 292 | 100% | 2003-11-10 | 2003-12-02 | 15d |  |
| 295 | 1.5.5.4 | **STE-D Shaper Board** | 118d | 2003-12-04 A | 2004-05-21 A |  | 100% | 2003-12-04 | 2004-05-13 | 112d |  |
| 296 | 1.5.5.4.1 | **FM 1** | 67d | 2003-12-04 A | 2004-03-11 A |  | 100% | 2003-12-04 | 2004-02-20 | 53d |  |
| 297 | 1.5.5.4.1.1 | Fabricate STE-D FM 1 Shaper Printed Wiring Board | 10d | 2003-12-04 A | 2003-12-17 A |  | 100% | 2003-12-04 | 2003-12-17 | 10d | start no earlier than 2003-12-04 |
| 298 | 1.5.5.4.1.2 | Load STE-D FM 1 Shaper Printed Wiring Board | 5d | 2004-03-05 A | 2004-03-11 A | 302 | 100% | 2004-02-13 | 2004-02-20 | 5d | start no earlier than 2004-03-05 |
| 299 | 1.5.5.4.2 | **FM 2** | 118d | 2003-12-04 A | 2004-05-21 A |  | 100% | 2003-12-04 | 2004-05-13 | 112d |  |
| 300 | 1.5.5.4.2.1 | Fabricate STE-D FM 2 Shaper Printed Wiring Board | 10d | 2003-12-04 A | 2003-12-17 A |  | 100% | 2003-12-04 | 2003-12-17 | 10d | start no earlier than 2003-12-04 |
| 301 | 1.5.5.4.2.2 | Load STE-D FM 2 Shaper Printed Wiring Board | 15d | 2004-05-03 A | 2004-05-21 A | 302FS+78d | 100% | 2004-05-07 | 2004-05-13 | 5d |  |
| 302 | 1.5.5.4.3 | Coupon Test STE-D FM 1 & FM 2 Shaper Printed Wiring Boards | 15d | 2003-12-18 A | 2004-01-09 A | 297, 300 | 100% | 2003-12-18 | 2004-01-09 | 15d |  |
| 303 | 1.5.5.5 | **STE-D Interface Board** | 118d | 2003-12-04 A | 2004-05-21 A |  | 100% | 2003-12-04 | 2004-05-13 | 112d |  |
| 304 | 1.5.5.5.1 | **FM 1** | 67d | 2003-12-04 A | 2004-03-11 A |  | 100% | 2003-12-04 | 2004-02-20 | 53d |  |
| 305 | 1.5.5.5.1.1 | Fabricate SWEA / STE-D FM 1 Digital to Analog Converter Printed Wiring Board | 10d | 2003-12-04 A | 2003-12-17 A |  | 100% | 2003-12-04 | 2003-12-17 | 10d | start no earlier than 2003-12-04 |
| 306 | 1.5.5.5.1.2 | Load SWEA / STE-D FM 1 Digital to Analog Converter Printed Wiring Board | 5d | 2004-03-05 A | 2004-03-11 A | 298SS | 100% | 2004-02-13 | 2004-02-20 | 5d |  |
| 307 | 1.5.5.5.2 | **FM 2** | 118d | 2003-12-04 A | 2004-05-21 A |  | 100% | 2003-12-04 | 2004-05-13 | 112d |  |
| 308 | 1.5.5.5.2.1 | Fabricate SWEA / STE-D FM 2 Digital to Analog Converter Printed Wiring Board | 10d | 2003-12-04 A | 2003-12-17 A |  | 100% | 2003-12-04 | 2003-12-17 | 10d | start no earlier than 2003-12-04 |
| 309 | 1.5.5.5.2.2 | Load SWEA / STE-D FM 2 Digital to Analog Converter Printed Wiring Board | 15d | 2004-05-03 A | 2004-05-21 A | 301SS | 100% | 2004-05-07 | 2004-05-13 | 5d |  |
| 310 | 1.5.5.5.3 | Coupon Test STE-D FM 1 & FM 2 D/A Converter Printed Wiring Boards | 15d | 2003-12-18 A | 2004-01-09 A | 305, 308 | 100% | 2003-12-18 | 2004-01-09 | 15d |  |

| ID | WBS | Task | Duration | Start | Finish | Predecessors | Complete | Remaining | Baseline start | Baseline finish | Baseline duration | Total slack | Free slack | Constraint |
| --- | --- | --- | --- | --- | --- | --- | --- | --- | --- | --- | --- | --- | --- | --- |
| 311 | 1.5.5.6 | **STE-U Pre-Amp Board** | 160d | 2003-09-22 A | 2004-05-11 A |  | 100% |  | 2003-09-22 | 2004-02-23 | 104d |  |  |  |
| 312 | 1.5.5.6.1 | **FM 1** | 79d | 2003-09-22 A | 2004-01-15 A |  | 100% |  | 2003-09-22 | 2004-01-15 | 79d |  |  |  |
| 313 | 1.5.5.6.1.1 | Fabricate STE-U FM 1 Preamp Printed Wiring Board | 34d | 2003-09-22 A | 2003-11-07 A |  | 100% |  | 2003-09-22 | 2003-11-07 | 34d |  |  | start no earlier than 2003-09-22 |
| 314 | 1.5.5.6.1.2 | Load STE-U FM 1 Preamp Printed Wiring Board | 4d | 2004-01-12 A | 2004-01-15 A | 318 | 100% |  | 2004-01-12 | 2004-01-15 | 4d |  |  | start no earlier than 2004-01-12 |
| 315 | 1.5.5.6.2 | **FM 2** | 160d | 2003-09-22 A | 2004-05-11 A |  | 100% |  | 2003-09-22 | 2004-02-23 | 104d |  |  |  |
| 316 | 1.5.5.6.2.1 | Fabricate STE-U FM 2 Preamp Printed Wiring Board | 34d | 2003-09-22 A | 2003-11-07 A |  | 100% |  | 2003-09-22 | 2003-11-07 | 34d |  |  | start no earlier than 2003-09-22 |
| 317 | 1.5.5.6.2.2 | Load STE-U FM 2 Preamp Printed Wiring Board | 46d | 2004-03-09 A | 2004-05-11 A | 318 | 100% |  | 2004-02-17 | 2004-02-23 | 5d |  |  | start no earlier than 2004-03-09 |
| 318 | 1.5.5.6.3 | Coupon Test STE-U FM 1 & FM 2 Pre-Amp Printed Wiring Boards | 15d | 2003-11-10 A | 2003-12-02 A | 313, 316 | 100% |  | 2003-11-10 | 2003-12-02 | 15d |  |  |  |
| 319 | 1.5.5.7 | **STE-U Shaper & Interface Board** | 78d | 2003-12-04 A | 2004-03-26 A |  | 100% |  | 2003-12-04 | 2004-02-20 | 53d |  |  |  |
| 320 | 1.5.5.7.1 | **FM 1** | 73d | 2003-12-04 A | 2004-03-19 A |  | 100% |  | 2003-12-04 | 2004-02-20 | 53d |  |  |  |
| 321 | 1.5.5.7.1.1 | Fabricate STE-U FM 1Shaper & Interface Printed Wiring Board | 10d | 2003-12-04 A | 2003-12-17 A |  | 100% |  | 2003-12-04 | 2003-12-17 | 10d |  |  | start no earlier than 2003-12-04 |
| 322 | 1.5.5.7.1.2 | Load STE-U FM 1 Shaper & Interface Printed Wiring Board | 13d | 2004-03-03 A | 2004-03-19 A | 326 | 100% |  | 2004-02-13 | 2004-02-20 | 5d |  |  | start no earlier than 2004-03-03 |
| 323 | 1.5.5.7.2 | **FM 2** | 78d | 2003-12-04 A | 2004-03-26 A |  | 100% |  | 2003-12-04 | 2004-02-20 | 53d |  |  |  |
| 324 | 1.5.5.7.2.1 | Fabricate STE-U FM 2 Shaper & Interface Printed Wiring Board | 10d | 2003-12-04 A | 2003-12-17 A |  | 100% |  | 2003-12-04 | 2003-12-17 | 10d |  |  | start no earlier than 2003-12-04 |
| 325 | 1.5.5.7.2.2 | Load STE-U FM 2 Shaper & Interface Printed Wiring Board | 5d | 2004-03-22 A | 2004-03-26 A | 322 | 100% |  | 2004-02-13 | 2004-02-20 | 5d |  |  |  |
| 326 | 1.5.5.7.3 | Coupon Test STE-U FM 1 & FM 2 Shaper & Interface Printed Wiring Boards | 15d | 2003-12-18 A | 2004-01-09 A | 321, 324 | 100% |  | 2003-12-18 | 2004-01-09 | 15d |  |  |  |
| 327 | 1.5.5.8 | **Integration & Test** | 155d | 2004-03-22 A | 2004-10-28 |  | 42% | 89.74d | 2004-02-23 | 2004-08-27 | 134d | -17d | 0d |  |
| 328 | 1.5.5.8.1 | **FM 1** | 147d | 2004-03-22 A | 2004-10-18 |  | 45% | 80.29d | 2004-02-23 | 2004-07-30 | 114d | -12d | 0d |  |
| 329 | 1.5.5.8.1.1 | Integrate & Test STE-U FM 1 Interface Boards | 40d | 2004-03-22 A | 2004-05-14 A | 314, 322 | 100% |  | 2004-02-23 | 2004-02-27 | 5d |  |  |  |
| 330 | 1.5.5.8.1.2 | Integrate & Test SWEA/STE-D FM 1 Interface Boards | 20d | 2004-05-24 A | 2004-06-21 | 285, 290, 298, 306, 301 | 70% | 6d | 2004-02-24 | 2004-03-22 | 20d | -19d | 0d |  |
| 331 | 1.5.5.8.1.3 | Integrate & Test SWEA/STE-D FM 1 Interface with SWEA/STE-D FM 1 LVPS | 10d | 2004-07-07 | 2004-07-20 | 330, 69 |  |  | 2004-04-16 | 2004-04-29 | 10d | -29d | 0d |  |
| 332 | 1.5.5.8.1.4 | Clean/Coat/Stake SWEA/STE-D Interface | 10d | 2004-06-22 | 2004-07-06 | 330 |  |  | 2004-03-23 | 2004-04-05 | 10d | -19d | 0d |  |
| 333 | 1.5.5.8.1.5 | Integrate & Test SWEA/STE-D FM 1 Combined | 5d | 2004-07-21 | 2004-07-27 | 331, 332, 246, 253 |  |  | 2004-04-30 | 2004-05-06 | 5d | -29d | 0d |  |
| 334 | 1.5.5.8.1.6 | Calibrate SWEA/STE FM 1 | 15d | 2004-07-28 | 2004-08-17 | 333 |  |  | 2004-05-07 | 2004-06-04 | 20d | -29d | 0d |  |
| 335 | 1.5.5.8.1.7 | SWEA/STE FM 1 Vibration | 5d | 2004-09-21 | 2004-09-27 | 334, 19 |  |  | 2004-06-07 | 2004-06-11 | 5d | -12d | 0d |  |
| 336 | 1.5.5.8.1.8 | SWEA/STE-D FM 1 Thermal Vac/Thermal Balance/Bake Out | 14d | 2004-09-28 | 2004-10-18 | 335 |  |  | 2004-07-13 | 2004-07-30 | 14d | -12d | 0d |  |

Notes:
- 329: STE-U FM1 was completed and started thermal vac. Unfortunately we had a problem in thermal vac and STE-U FM1 is currently disassembled while we fix the problem.

| ID | WBS | Task | Duration | Start | Finish | Predecessors | Complete | Remaining | Baseline start | Baseline finish | Baseline duration | Total slack | Free slack | Constraint | Text1 |
| --- | --- | --- | --- | --- | --- | --- | --- | --- | --- | --- | --- | --- | --- | --- | --- |
| 337 | 1.5.5.8.2 | **FM 2** | 118d | 2004-05-12 A | 2004-10-28 |  | 38% | 73.42d | 2004-02-24 | 2004-08-27 | 133d | -17d | 0d |  |  |
| 338 | 1.5.5.8.2.1 | Integrate & Test STE-U FM 2 Interface Boards | 20d | 2004-05-12 A | 2004-06-09 A | 317, 325 | 100% |  | 2004-02-24 | 2004-03-01 | 5d |  |  |  |  |
| 339 | 1.5.5.8.2.2 | Integrate & Test SWEA/STE-D FM 2 Interface Boards | 20d | 2004-05-24 A | 2004-06-21 | 286, 293, 301, 309 | 70% | 6d | 2004-05-14 | 2004-06-11 | 20d | 23d |  |  |  |
| 340 | 1.5.5.8.2.3 | Integrate & Test SWEA/STE-D FM 2 Interface with SWEA/STE-D FM 2 LVPS | 10d | 2004-08-18 | 2004-08-31 | 339, 75 |  |  | 2004-06-14 | 2004-06-25 | 10d | -17d | 0d |  |  |
| 341 | 1.5.5.8.2.4 | Integrate & Test SWEA/STE-D FM 2 Combined | 10d | 2004-09-01 | 2004-09-15 | 340, 247, 254 |  |  | 2004-06-28 | 2004-07-09 | 10d | -17d | 0d |  |  |
| 342 | 1.5.5.8.2.5 | Calibrate SWEA/STE FM 2 | 15d | 2004-09-16 | 2004-10-06 | 341 |  |  | 2004-07-12 | 2004-08-06 | 20d | -17d | 0d |  |  |
| 343 | 1.5.5.8.2.6 | SWEA/STE FM 2 Vibration | 5d | 2004-10-07 | 2004-10-14 | 342 |  |  | 2004-08-09 | 2004-08-13 | 5d | -17d | 0d |  |  |
| 344 | 1.5.5.8.2.7 | SWEA/STE-D FM 2 Thermal Vac & bake Out | 10d | 2004-10-15 | 2004-10-28 | 343 |  |  | 2004-08-16 | 2004-08-27 | 10d | -17d | 0d |  |  |
| 345 | 1.5.6 | **Boom Suite I&T - UCB** | 110d | 2004-06-17 | 2004-11-23 |  |  |  | 2004-04-21 | 2004-09-28 | 113d | -18d | 0d |  |  |
| 346 | 1.5.6.1 | **FM 1** | 90d | 2004-06-17 | 2004-10-25 |  |  |  | 2004-04-21 | 2004-08-13 | 82d | -12d | 0d |  |  |
| 347 | 1.5.6.1.1 | FM 1 Boom/MAG/STE-U I&T | 4d | 2004-06-17 | 2004-06-22 | 210, 236, 255 |  |  | 2004-04-21 | 2004-04-26 | 4d | -9d | 0d |  | MS-BOOM |
| 348 | 1.5.6.1.2 | FM 1 Boom/SWEA/STE/MAG I&T | 2d | 2004-08-18 | 2004-08-19 | 282, 184 |  |  | 2004-06-14 | 2004-06-15 | 2d | -29d | 0d |  |  |
| 349 | 1.5.6.1.3 | FM 1 Integrated Boom/IDPU I&T | 4d | 2004-08-24 | 2004-08-27 | 348, 184, 160 |  |  | 2004-06-16 | 2004-06-21 | 4d | -31d | 0d |  |  |
| 350 | 1.5.6.1.4 | Final BOOM Suite FM 1 I & T | 5d | 2004-10-19 | 2004-10-25 | 349, 336, 175 |  |  | 2004-08-02 | 2004-08-13 | 10d | -12d | 0d |  |  |
| 351 | 1.5.6.2 | **FM 2** | 74d | 2004-08-09 | 2004-11-23 |  |  |  | 2004-05-11 | 2004-09-28 | 99d | -18d | 0d |  |  |
| 352 | 1.5.6.2.1 | FM 2 Boom/MAG/STE-U I&T | 4d | 2004-08-09 | 2004-08-12 | 231, 237, 256 |  |  | 2004-05-11 | 2004-05-14 | 4d | 17d | 0d |  | MS-BOOM |
| 353 | 1.5.6.2.2 | FM 2 Boom/SWEA/STE/MAG I&T | 2d | 2004-10-29 | 2004-11-01 | 283, 185 |  |  | 2004-08-30 | 2004-08-31 | 2d | -17d | 0d |  |  |
| 354 | 1.5.6.2.3 | FM 2 Integrated Boom/IDPU I&T | 4d | 2004-11-03 | 2004-11-08 | 353, 185, 179 |  |  | 2004-09-01 | 2004-09-07 | 4d | -18d | 0d |  |  |
| 355 | 1.5.6.2.4 | Boom Suite FM 2 EMC | 5d | 2004-11-09 | 2004-11-16 | 354 |  |  | 2004-09-08 | 2004-09-14 | 5d | -18d | 0d |  | MS-BOOM |
| 356 | 1.5.6.2.5 | Final BOOM Suite FM 2 I & T | 5d | 2004-11-17 | 2004-11-23 | 355 |  |  | 2004-09-15 | 2004-09-28 | 10d | -18d | 0d |  |  |
| 357 | 1.6 | **SEP Suite - CIT** | 385d | 2003-06-02 A | 2004-12-10 |  | 75% | 96.64d | 2003-06-02 | 2004-10-21 | 352d | -29d | 0d |  |  |
| 358 | 1.6.1 | **SEP Mechanical - Sandy Shuman (GSFC)** | 144d | 2004-01-27 A | 2004-08-18 |  | 67% | 47.2d | 2004-01-27 | 2004-06-02 | 90d | -4d | 0d |  |  |
| 359 | 1.6.1.1 | **SIT Electronics Enclosure (Priority 1)** | 70d | 2004-02-09 A | 2004-05-17 A |  | 100% |  | 2004-02-09 | 2004-03-16 | 26d |  |  |  |  |
| 360 | 1.6.1.1.1 | Complete Design/Drawings for SIT Enclosure | 10d | 2004-02-09 A | 2004-02-23 A |  | 100% |  | 2004-02-09 | 2004-02-23 | 10d |  |  | start no earlier than 2004-02-09 |  |
| 361 | 1.6.1.1.2 | Fabrication of SIT Enclosure | 21d | 2004-04-08 A | 2004-05-06 A | 360FS+32d | 100% |  | 2004-02-24 | 2004-03-08 | 10d |  |  |  |  |
| 362 | 1.6.1.1.3 | Inspection and Final Assembly of SIT Enclosure | 6d | 2004-05-07 A | 2004-05-14 A | 361 | 100% |  | 2004-03-09 | 2004-03-15 | 5d |  |  |  |  |
| 363 | 1.6.1.1.4 | Deliver SIT Enclosure to UMD | 1d | 2004-05-17 A | 2004-05-17 A | 362 | 100% |  | 2004-03-16 | 2004-03-16 | 1d |  |  |  |  |

| ID | WBS | Task | Type | Duration | Start | Finish | Predecessors | Complete | Remaining | Baseline start | Baseline finish | Baseline duration | Total slack | Free slack | Constraint | Text1 |
| --- | --- | --- | --- | --- | --- | --- | --- | --- | --- | --- | --- | --- | --- | --- | --- | --- |
| 364 | 1.6.1.2 | **SEP FM 1 & FM 2 LVPS Boxes (Priority 2)** |  | 53d | 2004-02-09 A | 2004-04-22 A |  | 100% |  | 2004-02-09 | 2004-03-11 | 23d |  |  |  |  |
| 365 | 1.6.1.2.1 | Complete Design/Drawings for SEP LVPS Boxes |  | 5d | 2004-02-09 A | 2004-02-13 A | 360SS | 100% |  | 2004-02-09 | 2004-02-13 | 5d |  |  |  |  |
| 366 | 1.6.1.2.2 | Fabrication of SEP LVPS Boxes |  | 35d | 2004-02-17 A | 2004-04-05 A | 365 | 100% |  | 2004-02-17 | 2004-03-01 | 10d |  |  |  |  |
| 367 | 1.6.1.2.3 | Inspection of SEP LVPS Boxes (Final Assembly at UCB) |  | 10d | 2004-04-06 A | 2004-04-19 A | 366 | 100% |  | 2004-03-02 | 2004-03-08 | 5d |  |  |  |  |
| 368 | 1.6.1.2.4 | Deliver SEP LVPS Boxes to UCB |  | 3d | 2004-04-20 A | 2004-04-22 A | 367 | 100% |  | 2004-03-09 | 2004-03-11 | 3d |  |  | start no earlier than 2004-04-07 |  |
| 369 | 1.6.1.3 | **SEP Electronics Enclosure (Priority 3)** |  | 92d | 2004-02-17 A | 2004-06-24 |  | 91% | 8.54d | 2004-02-17 | 2004-03-30 | 31d | -9d | 0d |  |  |
| 370 | 1.6.1.3.1 | Complete Design/Drawings for SEP Enclosure |  | 73d | 2004-02-17 A | 2004-05-27 A | 365 | 100% |  | 2004-02-17 | 2004-03-04 | 13d |  |  |  |  |
| 371 | 1.6.1.3.2 | Fabrication of SEP Enclosure |  | 15d | 2004-05-21 A | 2004-06-11 A | 370FS-5d | 100% |  | 2004-03-05 | 2004-03-18 | 10d |  |  |  |  |
| 372 | 1.6.1.3.3 | Inspection and Final Assembly of SEP Enclosure |  | 6d | 2004-06-14 | 2004-06-21 | 371 |  |  | 2004-03-19 | 2004-03-25 | 5d | -9d | 0d |  |  |
| 373 | 1.6.1.3.4 | Deliver SEP Enclosure to CIT |  | 3d | 2004-06-22 | 2004-06-24 | 372 |  |  | 2004-03-26 | 2004-03-30 | 3d | -9d | 0d |  | MS-SEP |
| 374 | 1.6.1.4 | **SEP Central Bias Supply Shields (Priority 4)** |  | 20d | 2004-05-25 A | 2004-06-22 |  | 65% | 7d | 2004-03-05 | 2004-04-01 | 20d | 32d |  |  |  |
| 375 | 1.6.1.4.1 | Complete Design/Drawings for Bias Supply Shields |  | 5d | 2004-05-25 A | 2004-06-01 A | 370FS-3d | 100% |  | 2004-03-05 | 2004-03-11 | 5d |  |  |  |  |
| 376 | 1.6.1.4.2 | Fabrication of Bias Supply Shields |  | 10d | 2004-06-02 A | 2004-06-15 | 375 | 80% | 2d | 2004-03-12 | 2004-03-25 | 10d | 32d | 0d |  |  |
| 377 | 1.6.1.4.3 | Inspection and Delivery (to CIT) of Bias Supply Shields |  | 5d | 2004-06-16 | 2004-06-22 | 376 |  |  | 2004-03-26 | 2004-04-01 | 5d | 32d | 23d |  |  |
| 378 | 1.6.1.5 | **LET Telescope (Priority 5)** |  | 26d | 2004-05-25 A | 2004-06-30 |  | 50% | 13d | 2004-03-12 | 2004-04-16 | 26d | -11d | 0d |  |  |
| 379 | 1.6.1.5.1 | Complete Design/Drawings for LET Telescope |  | 5d | 2004-05-25 A | 2004-06-01 A | 375FS-5d | 100% |  | 2004-03-12 | 2004-03-23 | 8d |  |  |  |  |
| 380 | 1.6.1.5.2 | Fabrication of LET Telescope |  | 10d | 2004-06-02 A | 2004-06-15 | 379 | 80% | 2d | 2004-03-24 | 2004-04-06 | 10d | -15d | 0d |  |  |
| 381 | 1.6.1.5.3 | Inspection and Final Assembly of LET Telescope (CIT has detectors) |  | 8d | 2004-06-16 | 2004-06-25 | 380 |  |  | 2004-04-07 | 2004-04-13 | 5d | -15d | 0d |  |  |
| 382 | 1.6.1.5.4 | Deliver LET Telescope to CIT |  | 3d | 2004-06-28 | 2004-06-30 | 381 |  |  | 2004-04-14 | 2004-04-16 | 3d | -15d | 0d |  |  |
| 383 | 1.6.1.6 | **HET Electronics Enclosure (Priority 6)** |  | 67d | 2004-03-22 A | 2004-06-23 |  | 79% | 14.11d | 2004-03-24 | 2004-04-23 | 23d | -5d | 0d |  |  |
| 384 | 1.6.1.6.1 | Complete Design/Drawings for HET Enclosure |  | 23d | 2004-03-22 A | 2004-06-02 A | 379FS-14d | 100% |  | 2004-03-24 | 2004-04-02 | 8d |  |  |  |  |
| 385 | 1.6.1.6.2 | Fabrication of HET Enclosure |  | 10d | 2004-06-03 A | 2004-06-16 | 384 | 70% | 3d | 2004-04-05 | 2004-04-16 | 10d | -7d | 0d |  |  |
| 386 | 1.6.1.6.3 | Inspection and Final Assembly of HET Enclosure |  | 5d | 2004-06-17 | 2004-06-23 | 385 |  |  | 2004-04-19 | 2004-04-23 | 5d | -7d | 0d |  |  |
| 387 | 1.6.1.6.4 | Deliver HET Enclosure (stays at GSFC) | milestone | 0d | 2004-06-23 | 2004-06-23 | 386 |  |  | 2004-04-23 | 2004-04-23 | 0d | -7d | 0d |  |  |

| ID | WBS | Task | Type | Duration | Start | Finish | Predecessors | Complete | Remaining | Baseline start | Baseline finish | Baseline duration | Total slack | Free slack | Constraint | Text1 |
| --- | --- | --- | --- | --- | --- | --- | --- | --- | --- | --- | --- | --- | --- | --- | --- | --- |
| 388 | 1.6.1.7 | **HET Telescope (Priority 7)** |  | 102d | 2004-01-27 A | 2004-06-18 |  | 95% | 4.9d | 2004-01-27 | 2004-04-30 | 68d | -5d | 0d |  |  |
| 389 | 1.6.1.7.1 | On Going work for HET Telescope (Complete Design/Drawings & Prep for Fab) |  | 89d | 2004-01-27 A | 2004-06-02 A | 384FF | 100% |  | 2004-01-27 | 2004-03-31 | 46d |  |  | finish no earlier than 2004-06-01 |  |
| 390 | 1.6.1.7.2 | Fabrication of HET Telescope |  | 10d | 2004-05-28 A | 2004-06-11 A | 389FS-3d | 100% |  | 2004-04-01 | 2004-04-14 | 10d |  |  |  |  |
| 391 | 1.6.1.7.3 | Inspection and Final Assembly of HET Telescope |  | 5d | 2004-06-14 | 2004-06-18 | 390, 386SS-3d, 387FS-8d |  |  | 2004-04-26 | 2004-04-30 | 5d | -7d | 0d |  | MS-SEP |
| 392 | 1.6.1.7.4 | Deliver HET Telescope (stays at GSFC) | milestone | 0d | 2004-06-18 | 2004-06-18 | 391 |  |  | 2004-04-30 | 2004-04-30 | 0d | -7d | 0d |  | MS-SEP |
| 393 | 1.6.1.8 | **SIT Telescope (Priority 8)** |  | 39d | 2004-06-03 A | 2004-07-28 |  | 18% | 32d | 2004-04-01 | 2004-05-18 | 34d | -21d | 0d |  |  |
| 394 | 1.6.1.8.1 | Complete Design/Drawings for SIT Telescope |  | 18d | 2004-06-03 A | 2004-06-28 | 389 | 39% | 11d | 2004-04-01 | 2004-04-26 | 18d | -29d | 0d |  |  |
| 395 | 1.6.1.8.2 | Fabrication of SIT Telescope |  | 10d | 2004-06-29 | 2004-07-13 | 394 |  |  | 2004-04-27 | 2004-05-10 | 10d | -29d | 0d |  |  |
| 396 | 1.6.1.8.3 | Inspection and Final Assembly of SIT Telescope |  | 10d | 2004-07-14 | 2004-07-27 | 395 |  |  | 2004-05-11 | 2004-05-17 | 5d | -29d | 0d |  |  |
| 397 | 1.6.1.8.4 | Deliver SIT Telescope to UMD (Includes the Foils and Detectors) |  | 1d | 2004-07-28 | 2004-07-28 | 396 |  |  | 2004-05-18 | 2004-05-18 | 1d | -29d | 0d |  |  |
| 398 | 1.6.1.9 | **Shipping Containers for HET, SIT & SEP Central (Priority 9)** |  | 33d | 2004-05-10 A | 2004-06-24 |  | 71% | 9.71d | 2004-04-27 | 2004-05-27 | 23d | 17d |  |  |  |
| 399 | 1.6.1.9.1 | Design |  | 15d | 2004-05-10 A | 2004-05-28 A |  | 100% |  | 2004-04-27 | 2004-05-03 | 5d |  |  | start no earlier than 2004-05-10 |  |
| 400 | 1.6.1.9.2 | Fabrication/Machining |  | 10d | 2004-06-01 A | 2004-06-14 | 399 | 90% | 1d | 2004-05-04 | 2004-05-17 | 10d | -6d | 0d |  |  |
| 401 | 1.6.1.9.3 | Inspection and Assembly |  | 5d | 2004-06-15 | 2004-06-21 | 400 |  |  | 2004-05-18 | 2004-05-24 | 5d | -6d | 0d |  |  |
| 402 | 1.6.1.9.4 | HET Container stays at GSFC | milestone | 0d | 2004-06-21 | 2004-06-21 | 401 |  |  | 2004-05-24 | 2004-05-24 | 0d | -3d | 0d |  |  |
| 403 | 1.6.1.9.5 | SIT Container to UMD |  | 1d | 2004-06-22 | 2004-06-22 | 401 |  |  | 2004-05-25 | 2004-05-25 | 1d | 19d |  |  |  |
| 404 | 1.6.1.9.6 | SEP Central Container to CIT |  | 3d | 2004-06-22 | 2004-06-24 | 401 |  |  | 2004-05-25 | 2004-05-27 | 3d | -6d | 0d |  |  |
| 405 | 1.6.1.10 | **SIT Door (Priority 10)** |  | 27d | 2004-06-29 | 2004-08-05 |  |  |  | 2004-05-18 | 2004-06-24 | 27d | -22d | 0d |  |  |
| 406 | 1.6.1.10.1 | Complete Design/Drawings for SIT Door |  | 10d | 2004-06-29 | 2004-07-13 | 394 |  |  | 2004-05-18 | 2004-06-01 | 10d | -22d | 0d |  |  |
| 407 | 1.6.1.10.2 | Fabrication |  | 10d | 2004-07-14 | 2004-07-27 | 406 |  |  | 2004-06-02 | 2004-06-15 | 10d | 5d | 0d |  |  |
| 408 | 1.6.1.10.3 | Inspection |  | 5d | 2004-07-28 | 2004-08-03 | 407 |  |  | 2004-06-16 | 2004-06-22 | 5d | 5d | 0d |  |  |
| 409 | 1.6.1.10.4 | Final Assembly |  | 1d | 2004-08-04 | 2004-08-04 | 408 |  |  | 2004-06-23 | 2004-06-23 | 1d | 5d | 0d |  |  |
| 410 | 1.6.1.10.5 | Deliver SIT Door (stay at GSFC for Environmental Testing) |  | 1d | 2004-08-05 | 2004-08-05 | 409 |  |  | 2004-06-24 | 2004-06-24 | 1d | 5d |  |  |  |
| 411 | 1.6.1.11 | **Remaining HET Housing** |  | 20d | 2004-07-06 | 2004-08-02 |  |  |  |  |  |  | -15d | 0d |  |  |
| 412 | 1.6.1.11.1 | Complete Design/Drawings for Remaining HET Housing |  | 5d | 2004-07-06 | 2004-07-12 |  |  |  | 2004-03-24 | 2004-04-02 | 8d | -15d | 0d | start no earlier than 2004-07-06 |  |
| 413 | 1.6.1.11.2 | Fabrication of Remaining HET Housing |  | 10d | 2004-07-13 | 2004-07-26 | 412 |  |  | 2004-04-05 | 2004-04-16 | 10d | -15d | 0d |  |  |
| 414 | 1.6.1.11.3 | Inspection and Final Assembly of Remaining HET Housing |  | 5d | 2004-07-27 | 2004-08-02 | 413 |  |  | 2004-04-19 | 2004-04-23 | 5d | -15d | 0d |  |  |
| 415 | 1.6.1.11.4 | Deliver HET Enclosure (stays at GSFC) | milestone | 0d | 2004-08-02 | 2004-08-02 | 414 |  |  | 2004-04-23 | 2004-04-23 | 0d | -15d | 0d |  |  |

| ID | WBS | Task | Type | Duration | Start | Finish | Predecessors | Complete | Remaining | Baseline start | Baseline finish | Baseline duration | Total slack | Free slack | Constraint | Text1 |
| --- | --- | --- | --- | --- | --- | --- | --- | --- | --- | --- | --- | --- | --- | --- | --- | --- |
| 416 | 1.6.1.12 | **Remaining LET Brackets** |  | 21d | 2004-07-07 | 2004-08-04 |  |  |  |  |  |  | -15d | 0d |  |  |
| 417 | 1.6.1.12.1 | Complete Design/Drawings for Remaining LET Brackets |  | 5d | 2004-07-07 | 2004-07-13 | 412SS+1d |  |  | 2004-03-24 | 2004-04-02 | 8d | -15d | 0d |  |  |
| 418 | 1.6.1.12.2 | Fabrication of Remaining LET Brackets |  | 10d | 2004-07-14 | 2004-07-27 | 417 |  |  | 2004-04-05 | 2004-04-16 | 10d | -15d | 0d |  |  |
| 419 | 1.6.1.12.3 | Inspection and Final Assembly of Remaining LET Brackets |  | 5d | 2004-07-28 | 2004-08-03 | 418 |  |  | 2004-04-19 | 2004-04-23 | 5d | -15d | 0d |  |  |
| 420 | 1.6.1.12.4 | Deliver Remaining LET Brackets to CIT for SEP I&T |  | 1d | 2004-08-04 | 2004-08-04 | 419 |  |  | 2004-04-23 | 2004-04-23 | 0d | -15d | 0d |  |  |
| 421 | 1.6.1.13 | **LET Radiation Test Fixture (Priority 11)** |  | 26d | 2004-07-14 | 2004-08-18 |  |  |  | 2004-05-04 | 2004-06-02 | 21d | -22d | 0d |  |  |
| 422 | 1.6.1.13.1 | Design |  | 5d | 2004-07-14 | 2004-07-20 | 406 |  |  | 2004-05-04 | 2004-05-10 | 5d | -22d | 0d |  |  |
| 423 | 1.6.1.13.2 | Fabrication |  | 10d | 2004-07-21 | 2004-08-03 | 422 |  |  | 2004-05-11 | 2004-05-24 | 10d | -22d | 0d |  |  |
| 424 | 1.6.1.13.3 | Inspection and Assembly |  | 10d | 2004-08-04 | 2004-08-17 | 423 |  |  | 2004-05-25 | 2004-06-01 | 5d | -22d | 0d |  |  |
| 425 | 1.6.1.13.4 | Deliver to CIT for SEP I&T |  | 1d | 2004-08-18 | 2004-08-18 | 424 |  |  | 2004-06-02 | 2004-06-02 | 1d | -22d | 0d |  |  |
| 426 | 1.6.2 | **SEP Central - CIT** |  | 265d | 2003-08-01 A | 2004-08-19 |  | 81% | 49.25d | 2003-08-01 | 2004-06-03 | 211d | -9d | 0d |  |  |
| 427 | 1.6.2.1 | **Deliveries** |  | 37d | 2004-06-28 | 2004-08-19 |  |  |  | 2004-04-14 | 2004-06-03 | 35d | -11d | 0d |  |  |
| 428 | 1.6.2.1.1 | Deliver all SEP Cen FM 1 Boards to SEP I&T (stays at CIT) | milestone | 0d | 2004-06-28 | 2004-06-28 | 437, 440, 447, 68FS+19d |  |  | 2004-05-10 | 2004-05-10 | 0d | -11d | 0d |  | MS-SEP |
| 429 | 1.6.2.1.2 | Deliver all SEP Cen FM 2 Boards & FM 2 LVPS to SEP I&T (stays at CIT) | milestone | 0d | 2004-07-26 | 2004-07-26 | 74, 377, 438, 441, 448 |  |  | 2004-05-10 | 2004-05-10 | 0d | 9d | 0d |  | MS-SEP |
| 430 | 1.6.2.1.3 | SEP Central Build 3 Software Complete | milestone | 0d | 2004-06-30 | 2004-06-30 | 454 |  |  | 2004-04-14 | 2004-04-14 | 0d | -13d | 0d |  |  |
| 431 | 1.6.2.1.4 | Final SEP Central Flight Software Complete | milestone | 0d | 2004-08-19 | 2004-08-19 | 455 |  |  | 2004-06-03 | 2004-06-03 | 0d | -20d | 0d |  |  |
| 432 | 1.6.2.2 | **Logic Board** |  | 75d | 2004-02-13 A | 2004-05-28 A |  | 100% |  | 2004-02-13 | 2004-03-26 | 30d |  |  |  |  |
| 433 | 1.6.2.2.1 | **Assembly** |  | 10d | 2004-02-13 A | 2004-02-27 A |  | 100% |  | 2004-02-13 | 2004-02-27 | 10d |  |  |  |  |
| 434 | 1.6.2.2.1.1 | Assemble FM 1 SEP Central Logic board |  | 10d | 2004-02-13 A | 2004-02-27 A |  | 100% |  | 2004-02-13 | 2004-02-27 | 10d |  |  | start no earlier than 2004-02-13 | MS-SEP |
| 435 | 1.6.2.2.1.2 | Assemble FM 2 SEP Central Logic board |  | 10d | 2004-02-13 A | 2004-02-27 A | 434SS | 100% |  | 2004-02-13 | 2004-02-27 | 10d |  |  |  | MS-SEP |
| 436 | 1.6.2.2.2 | **Test** |  | 65d | 2004-03-01 A | 2004-05-28 A |  | 100% |  | 2004-03-01 | 2004-03-26 | 20d |  |  |  |  |
| 437 | 1.6.2.2.2.1 | Test FM 1 SEP Central Logic board (initial) |  | 20d | 2004-03-01 A | 2004-03-26 A | 434 | 100% |  | 2004-03-01 | 2004-03-26 | 20d |  |  |  |  |
| 438 | 1.6.2.2.2.2 | Test FM 2 SEP Central Logic board (initial) |  | 65d | 2004-03-01 A | 2004-05-28 A | 435 | 100% |  | 2004-03-01 | 2004-03-26 | 20d |  |  |  |  |
| 439 | 1.6.2.3 | **Analog/Post-Reg Board** |  | 0d | 2004-01-27 A | 2004-01-27 A |  | 100% |  | 2004-01-27 | 2004-01-27 | 0d |  |  |  |  |
| 440 | 1.6.2.3.1 | FM 1 Analog/Post-Reg Board Complete Test and awaiting Conformal Coat with other SEP Central Boards | milestone | 0d | 2004-01-27 A | 2004-01-27 A |  | 100% |  | 2004-01-27 | 2004-01-27 | 0d |  |  | start no earlier than 2004-01-27 |  |
| 441 | 1.6.2.3.2 | FM 2 Analog/Post-Reg Board Complete Test and awaiting Conformal Coat with other SEP Central Boards | milestone | 0d | 2004-01-27 A | 2004-01-27 A |  | 100% |  | 2004-01-27 | 2004-01-27 | 0d |  |  | start no earlier than 2004-01-27 |  |

| ID | WBS | Task | Duration | Start | Finish | Predecessors | Complete | Remaining | Baseline start | Baseline finish | Baseline duration | Total slack | Free slack | Constraint | Text1 |
| --- | --- | --- | --- | --- | --- | --- | --- | --- | --- | --- | --- | --- | --- | --- | --- |
| 442 | 1.6.2.4 | **SEP Solid State Detector Bias Supply Board** | 55d | 2004-01-20 A | 2004-04-06 A |  | 100% |  | 2004-01-20 | 2004-04-15 | 62d |  |  |  |  |
| 443 | 1.6.2.4.1 | **Assembly & Initial Test** | 40d | 2004-01-20 A | 2004-03-16 A |  | 100% |  | 2004-01-20 | 2004-03-16 | 40d |  |  |  |  |
| 444 | 1.6.2.4.1.1 | Assemble and Initial Test FM 1 SSD Bias Supply Board | 40d | 2004-01-20 A | 2004-03-16 A |  | 100% |  | 2004-01-20 | 2004-03-16 | 40d |  |  | start no earlier than 2004-01-20 |  |
| 445 | 1.6.2.4.1.2 | Assemble and Initial Test FM 2 SSD Bias Supply Board | 40d | 2004-01-20 A | 2004-03-16 A | 444SS | 100% |  | 2004-01-20 | 2004-03-16 | 40d |  |  |  |  |
| 446 | 1.6.2.4.2 | **Final Test** | 15d | 2004-03-17 A | 2004-04-06 A |  | 100% |  | 2004-04-02 | 2004-04-15 | 10d |  |  |  |  |
| 447 | 1.6.2.4.2.1 | Final Test FM 1 SSD Bias Supply Board | 15d | 2004-03-17 A | 2004-04-06 A | 444 | 100% |  | 2004-04-02 | 2004-04-15 | 10d |  |  |  |  |
| 448 | 1.6.2.4.2.2 | Final Test FM 2 SSD Bias Supply Board | 15d | 2004-03-17 A | 2004-04-06 A | 445 | 100% |  | 2004-04-02 | 2004-04-15 | 10d |  |  |  |  |
| 449 | 1.6.2.5 | **Conformal Coat, Mass Properties and Bake Out (SEP Central, LET, SEP LVPS)** | 15d | 2004-07-14 | 2004-08-03 |  |  |  | 2004-04-16 | 2004-05-10 | 17d | -14d | 0d |  |  |
| 450 | 1.6.2.5.1 | Stake/Conformal Coat All SEP Central and LET Boards | 8d | 2004-07-14 | 2004-07-23 | 839 |  |  | 2004-04-16 | 2004-04-29 | 10d | -14d | 0d |  |  |
| 451 | 1.6.2.5.2 | Mass Properties/Photo All SEP Central and LET Boards | 4d | 2004-07-26 | 2004-07-29 | 450 |  |  | 2004-04-30 | 2004-05-05 | 4d | -14d | 0d |  |  |
| 452 | 1.6.2.5.3 | Bake Out All SEP Central/LET Boards and SEP LVPS FM 1 | 3d | 2004-07-30 | 2004-08-03 | 451, 68 |  |  | 2004-05-06 | 2004-05-10 | 3d | -14d | 0d |  |  |
| 453 | 1.6.2.6 | **Flight Software** | 265d | 2003-08-01 A | 2004-08-19 |  | 71% | 77d | 2003-08-01 | 2004-06-03 | 211d | -20d | 0d |  |  |
| 454 | 1.6.2.6.1 | SEP Central Build 3 | 230d | 2003-08-01 A | 2004-06-30 |  | 82% | 42d | 2003-08-01 | 2004-04-14 | 176d | -20d | 0d | start no earlier than 2003-08-01 |  |
| 455 | 1.6.2.6.2 | Final Flight S/W Build | 35d | 2004-07-01 | 2004-08-19 | 454 |  |  | 2004-04-15 | 2004-06-03 | 35d | -20d | 0d |  |  |
| 456 | 1.6.3 | **HET - Tycho (GSFC)** | 148d | 2004-01-06 A | 2004-08-04 |  | 80% | 29.6d | 2004-01-06 | 2004-06-23 | 119d | 0d |  |  |  |
| 457 | 1.6.3.1 | **Deliveries** | 25d | 2004-06-30 | 2004-08-04 |  |  |  | 2004-04-30 | 2004-06-23 | 38d | -9d | 0d |  |  |
| 458 | 1.6.3.1.1 | Deliver HET FM 1w/o replacement detectors (to CIT for SEP Suite I&T) | 2d | 2004-06-30 | 2004-07-01 | 402, 503 |  |  | 2004-06-01 | 2004-06-02 | 2d | -9d | 0d |  | MS-SEP |
| 459 | 1.6.3.1.2 | Deliver HET FM 1 w/ replacement detectors & FM 2 after coating (to CIT for SEP Suite I&T) | 2d | 2004-08-03 | 2004-08-04 | 485, 489, 415 |  |  | 2004-07-19 | 2004-07-20 | 2d | -15d | 0d |  |  |
| 460 | 1.6.3.1.3 | Deliver HET FM 2 w/ replacement detectors (to CIT for SEP Suite I&T) | 2d | 2004-07-19 | 2004-07-20 | 402, 511 |  |  | 2004-06-22 | 2004-06-23 | 2d | 11d | 0d |  | MS-SEP |
| 461 | 1.6.3.1.4 | Deliver Final HET Flight Software to SEP I&T | 2d | 2004-07-08 | 2004-07-09 | 499 |  |  | 2004-04-30 | 2004-05-03 | 2d | -14d | 0d |  |  |
| 462 | 1.6.3.2 | **Detectors (Batch 1)** | 40d | 2004-01-06 A | 2004-03-03 A |  | 100% |  | 2004-01-06 | 2004-03-31 | 60d |  |  |  |  |
| 463 | 1.6.3.2.1 | Receive & Inspect HET Flight Detectors | 40d | 2004-01-06 A | 2004-03-03 A |  | 100% |  | 2004-01-06 | 2004-03-03 | 40d |  |  | start no earlier than 2004-01-06 |  |
| 464 | 1.6.3.2.2 | **Detector Testing** | 40d | 2004-01-06 A | 2004-03-03 A |  | 100% |  | 2004-01-06 | 2004-03-31 | 60d |  |  |  |  |
| 465 | 1.6.3.2.2.1 | Capacitance, Current, Depletion, Alpha Resolution Testing | 40d | 2004-01-06 A | 2004-03-03 A | 463SS | 100% |  | 2004-01-06 | 2004-03-31 | 60d |  |  |  | MS-SEP |
| 466 | 1.6.3.2.2.2 | Life Test HET Detectors | 40d | 2004-01-06 A | 2004-03-03 A | 465SS | 100% |  | 2004-01-06 | 2004-03-31 | 60d |  |  |  | MS-SEP |

Notes:
- 452: SEP FM 2 LVPS Bakeout will occur at Berkley prior to delivery 6/18. This allows LET to proceed, which has more to do before I&T than SEP Central.

| ID | WBS | Task | Type | Duration | Start | Finish | Predecessors | Complete | Remaining | Baseline start | Baseline finish | Baseline duration | Total slack | Free slack | Constraint | Text1 |
| --- | --- | --- | --- | --- | --- | --- | --- | --- | --- | --- | --- | --- | --- | --- | --- | --- |
| 467 | 1.6.3.3 | **Replacement HET Detectors (Batch 2)** |  | 66d | 2004-03-12 A | 2004-06-14 |  | 23% | 50.77d | 2004-03-12 | 2004-06-14 | 66d | 9d |  |  |  |
| 468 | 1.6.3.3.1 | Receive H1 Detector Mounts | milestone | 0d | 2004-03-12 A | 2004-03-12 A |  | 100% |  | 2004-03-12 | 2004-03-12 | 0d |  |  | start no earlier than 2004-03-12 |  |
| 469 | 1.6.3.3.2 | Receive H3 Detector Mounts | milestone | 0d | 2004-03-26 A | 2004-03-26 A |  | 100% |  | 2004-03-26 | 2004-03-26 | 0d |  |  | start no earlier than 2004-03-26 |  |
| 470 | 1.6.3.3.3 | Detector Mounting at Micron |  | 20d | 2004-04-15 A | 2004-05-12 | 468, 469 | 60% | 8d | 2004-04-15 | 2004-05-12 | 20d | 9d | 0d | start no earlier than 2004-04-15 |  |
| 471 | 1.6.3.3.4 | Detector Delivery to GSFC |  | 12d | 2004-05-13 | 2004-05-28 | 470 |  |  | 2004-05-13 | 2004-05-14 | 2d | 9d | 0d |  |  |
| 472 | 1.6.3.3.5 | Detector Testing at GSFC |  | 20d | 2004-05-17 | 2004-06-14 | 471FS-10d |  |  | 2004-05-17 | 2004-06-14 | 20d | 9d |  |  |  |
| 473 | 1.6.3.4 | **Electronics Board** |  | 133d | 2004-01-22 A | 2004-07-29 |  | 78% | 29.56d | 2004-01-22 | 2004-05-13 | 80d | -13d | 0d |  | MS-SEP |
| 474 | 1.6.3.4.1 | **Assembly** |  | 38d | 2004-01-22 A | 2004-03-16 A |  | 100% |  | 2004-01-22 | 2004-03-12 | 36d |  |  |  |  |
| 475 | 1.6.3.4.1.1 | Install Socket on HET Electronics FM 1 Board for ETU ACTEL |  | 1d | 2004-01-22 A | 2004-01-22 A |  | 100% |  | 2004-01-22 | 2004-01-22 | 1d |  |  | start no earlier than 2004-01-22 |  |
| 476 | 1.6.3.4.1.2 | Complete Population of HET Electronics FM 1 Board (ETU ACTEL) |  | 1d | 2004-01-23 A | 2004-01-23 A | 475 | 100% |  | 2004-01-23 | 2004-01-23 | 1d |  |  |  |  |
| 477 | 1.6.3.4.1.3 | Complete Population of HET Electronics FM 2 Board (Flight ACTEL) |  | 2d | 2004-03-15 A | 2004-03-16 A | 476, 483, 520 | 100% |  | 2004-03-11 | 2004-03-12 | 2d |  |  |  |  |
| 478 | 1.6.3.4.2 | **Test** |  | 131d | 2004-01-26 A | 2004-07-29 |  | 77% | 30.62d | 2004-01-26 | 2004-05-13 | 78d | -13d | 0d |  |  |
| 479 | 1.6.3.4.2.1 | **FM 1** |  | 131d | 2004-01-26 A | 2004-07-29 |  | 81% | 24.95d | 2004-01-26 | 2004-03-22 | 40d | -13d | 0d |  |  |
| 480 | 1.6.3.4.2.1.1 | Test HET FM 1 Electronics Board w/ETU ACTEL |  | 23d | 2004-01-26 A | 2004-02-26 A | 476 | 100% |  | 2004-01-26 | 2004-02-23 | 20d |  |  |  |  |
| 481 | 1.6.3.4.2.1.2 | Remove ETU ACTEL and socket from HET FM 1 Electronics Board |  | 0.5d | 2004-02-27 A | 2004-02-27 A | 480 | 100% |  | 2004-02-24 | 2004-02-24 | 1d |  |  |  |  |
| 482 | 1.6.3.4.2.1.3 | Install Flight ACTEL on HET FM 1 Electronics Board |  | 0.5d | 2004-02-27 A | 2004-02-27 A | 481 | 100% |  | 2004-02-25 | 2004-02-25 | 1d |  |  |  |  |
| 483 | 1.6.3.4.2.1.4 | Retest HET FM 1 Electronics Board w/Flight ACTEL |  | 10d | 2004-03-01 A | 2004-03-12 A | 482 | 100% |  | 2004-02-26 | 2004-03-10 | 10d |  |  |  |  |
| 484 | 1.6.3.4.2.1.5 | Clean, Bake, Conformal Coat HET FM 1 Electronics Board |  | 3d | 2004-07-20 | 2004-07-22 | 483FS+61d, 506 |  |  | 2004-03-11 | 2004-03-12 | 2d | -13d | 0d |  |  |
| 485 | 1.6.3.4.2.1.6 | Retest Conformal Coated HET FM 1 Electronics Board |  | 5d | 2004-07-23 | 2004-07-29 | 484 |  |  | 2004-03-15 | 2004-03-16 | 2d | -13d | 0d |  |  |
| 486 | 1.6.3.4.2.2 | **FM 2** |  | 95d | 2004-03-17 A | 2004-07-29 |  | 71% | 27.14d | 2004-03-23 | 2004-05-13 | 38d | -13d | 0d |  |  |
| 487 | 1.6.3.4.2.2.1 | Test HET FM 2 Electronics Board |  | 25d | 2004-03-17 A | 2004-04-20 A | 477, 480 | 100% |  | 2004-03-23 | 2004-05-03 | 30d |  |  |  |  |
| 488 | 1.6.3.4.2.2.2 | Clean, Bake, Conformal Coat HET FM 2 Electronics Board |  | 5d | 2004-07-16 | 2004-07-22 | 840 |  |  | 2004-05-04 | 2004-05-05 | 2d | -13d | 0d |  |  |
| 489 | 1.6.3.4.2.2.3 | Retest Conformal Coated HET FM 2 Electronics Board |  | 5d | 2004-07-23 | 2004-07-29 | 488 |  |  | 2004-05-06 | 2004-05-07 | 2d | -13d | 0d |  |  |
| 490 | 1.6.3.5 | **Flight Software** |  | 117d | 2004-01-22 A | 2004-07-07 |  | 92% | 9.47d | 2004-01-22 | 2004-04-29 | 70d | -12d | 0d |  |  |
| 491 | 1.6.3.5.1 | **Design** |  | 71d | 2004-01-22 A | 2004-04-30 A |  | 100% |  | 2004-01-22 | 2004-02-04 | 10d |  |  |  |  |
| 492 | 1.6.3.5.1.1 | Complete Definition of HET PH Event Processing |  | 22d | 2004-01-22 A | 2004-02-23 A |  | 100% |  | 2004-01-22 | 2004-02-04 | 10d |  |  | start no earlier than 2004-01-22 |  |
| 493 | 1.6.3.5.1.2 | Design Change of HET PH Event Processing |  | 20d | 2004-04-05 A | 2004-04-30 A |  | 100% |  | 2004-04-05 | 2004-04-23 | 15d |  |  | start no earlier than 2004-04-05 |  |

Notes:
- 484: Questioning when to begin the process of Conformally Coating these boards due to part issues. Expect Answer by 4/30/04. / Engineer is out on Leave until June 9th. Cleaning will begin after this date.
- 487: During removal of a temporary commercial ACTEL (U200) several pads(29) were lifted. We will build a new board, and repair the other board. One will become a Flight Spare. Continue with testing and switch out boards later on. 5d hit to the schedule.
- 493: The scientist needed to make changes to the HET PH Event Processing design due to issues found after the developer completed the majority of the software. Coding and testing can not finish until the design chagne is complete.

| ID | WBS | Task | Type | Duration | Start | Finish | Predecessors | Complete | Remaining | Baseline start | Baseline finish | Baseline duration | Total slack | Free slack | Constraint | Text1 |
| --- | --- | --- | --- | --- | --- | --- | --- | --- | --- | --- | --- | --- | --- | --- | --- | --- |
| 494 | 1.6.3.5.2 | **Coding** |  | 64d | 2004-02-24 A | 2004-05-21 A |  | 100% |  | 2004-02-05 | 2004-03-04 | 20d |  |  |  |  |
| 495 | 1.6.3.5.2.1 | Code HET PH Event Processing Update for Flight |  | 59d | 2004-02-24 A | 2004-05-14 A | 492 | 100% |  | 2004-02-05 | 2004-02-19 | 10d |  |  |  |  |
| 496 | 1.6.3.5.2.2 | Code HET Telemetry Formatting Update for Flight |  | 34d | 2004-03-12 A | 2004-05-21 A | 495FS-15d | 100% |  | 2004-02-20 | 2004-03-04 | 10d |  |  |  |  |
| 497 | 1.6.3.5.3 | **Test** |  | 75d | 2004-03-23 A | 2004-07-07 |  | 77% | 17d | 2004-03-05 | 2004-04-29 | 40d | -12d | 0d |  |  |
| 498 | 1.6.3.5.3.1 | Test Integrated HET S/W with Simulated Data |  | 63d | 2004-03-23 A | 2004-06-18 |  | 92% | 5d | 2004-03-05 | 2004-03-25 | 15d | -14d | 0d | start no later than 2004-03-23 |  |
| 499 | 1.6.3.5.3.2 | Verify HET On-Board Software |  | 12d | 2004-06-21 | 2004-07-07 | 493, 498 |  |  | 2004-03-26 | 2004-04-29 | 25d | -14d | 0d |  |  |
| 500 | 1.6.3.6 | **Integration & Test** |  | 18d | 2004-06-23 | 2004-07-19 |  |  |  | 2004-05-03 | 2004-06-21 | 35d | -9d | 0d |  |  |
| 501 | 1.6.3.6.1 | **FM 1** |  | 18d | 2004-06-23 | 2004-07-19 |  |  |  | 2004-05-03 | 2004-05-28 | 20d | -13d | 0d |  |  |
| 502 | 1.6.3.6.1.1 | Integrate HET FM 1 Electronics Telescope (Ahead) |  | 3d | 2004-06-23 | 2004-06-25 | 466, 499FS-10d, 392 |  |  | 2004-05-03 | 2004-05-07 | 5d | -9d | 0d |  |  |
| 503 | 1.6.3.6.1.2 | Test HET FM 1 Telescope (Ahead) |  | 2d | 2004-06-28 | 2004-06-29 | 502 |  |  | 2004-05-10 | 2004-05-28 | 15d | -9d | 0d |  |  |
| 504 | 1.6.3.6.1.3 | Receive HET FM1 from CIT | milestone | 0d | 2004-07-15 | 2004-07-15 | 838 |  |  | 2004-07-14 | 2004-07-14 | 0d | -13d | 0d |  |  |
| 505 | 1.6.3.6.1.4 | Install new HET Flight Detectors in FM 1 |  | 1d | 2004-07-16 | 2004-07-16 | 472, 504 |  |  | 2004-06-16 | 2004-06-16 | 1d | -13d | 0d |  |  |
| 506 | 1.6.3.6.1.5 | Performance Test FM 1 with New Flight Detectors |  | 1d | 2004-07-19 | 2004-07-19 | 505, 496 |  |  | 2004-06-17 | 2004-06-17 | 1d | -13d | 0d |  |  |
| 507 | 1.6.3.6.2 | **FM 2** |  | 7d | 2004-07-08 | 2004-07-16 |  |  |  | 2004-05-14 | 2004-06-21 | 26d | 11d |  |  |  |
| 508 | 1.6.3.6.2.1 | Integrate HET FM 2 Electronics Telescope (Behind) |  | 3d | 2004-07-08 | 2004-07-12 | 466, 499, 392, 487 |  |  | 2004-05-14 | 2004-05-20 | 5d | 11d | 0d |  |  |
| 509 | 1.6.3.6.2.2 | Test HET FM 2 Telescope (Behind) |  | 2d | 2004-07-13 | 2004-07-14 | 508 |  |  | 2004-06-01 | 2004-06-21 | 15d | 11d | 0d |  |  |
| 510 | 1.6.3.6.2.3 | Install new HET Flight Detectors in FM 2 |  | 1d | 2004-07-15 | 2004-07-15 | 472, 509 |  |  | 2004-06-17 | 2004-06-17 | 1d | 11d | 0d |  |  |
| 511 | 1.6.3.6.2.4 | Performance Test FM 2 with New Flight Detectors |  | 1d | 2004-07-16 | 2004-07-16 | 510 |  |  | 2004-07-16 | 2004-07-16 | 1d | 11d | 0d |  |  |
| 512 | 1.6.4 | **LET - CIT** |  | 248d | 2003-07-14 A | 2004-07-07 |  | 94% | 13.89d | 2003-07-14 | 2004-06-08 | 228d | -6d | 0d |  |  |
| 513 | 1.6.4.1 | **Deliveries** |  | 7d | 2004-06-25 | 2004-07-07 |  |  |  | 2004-05-04 | 2004-06-08 | 24d | -15d | 0d |  |  |
| 514 | 1.6.4.1.1 | Deliver LET FM 1 (stays at CIT for SEP I&T) | milestone | 0d | 2004-07-07 | 2004-07-07 | 532 |  |  | 2004-06-08 | 2004-06-08 | 0d | -15d | 0d |  | MS-SEP |
| 515 | 1.6.4.1.2 | Deliver LET FM 2 (stays at CIT for SEP I&T) | milestone | 0d | 2004-07-07 | 2004-07-07 | 534 |  |  | 2004-06-08 | 2004-06-08 | 0d | -15d | 0d |  | MS-SEP |
| 516 | 1.6.4.1.3 | Deliver LET Flight Software Build 3 | milestone | 0d | 2004-06-25 | 2004-06-25 | 529 |  |  | 2004-05-04 | 2004-05-04 | 0d | -8d | 0d |  |  |
| 517 | 1.6.4.2 | **Detectors** |  | 167d | 2003-07-14 A | 2004-03-12 A |  | 100% |  | 2003-07-14 | 2004-03-12 | 167d |  |  |  |  |
| 518 | 1.6.4.2.1 | Complete LET Flight Detector Testing |  | 167d | 2003-07-14 A | 2004-03-12 A |  | 100% |  | 2003-07-14 | 2004-03-12 | 167d |  |  | start no earlier than 2003-07-14 | MS-SEP |

| ID | WBS | Task | Duration | Start | Finish | Predecessors | Complete | Remaining | Baseline start | Baseline finish | Baseline duration | Total slack | Free slack | Constraint | Text1 |
| --- | --- | --- | --- | --- | --- | --- | --- | --- | --- | --- | --- | --- | --- | --- | --- |
| 519 | 1.6.4.3 | **Hybrids** | 144d | 2003-08-01 A | 2004-03-01 A |  | 100% |  | 2003-08-01 | 2004-03-01 | 144d |  |  |  |  |
| 520 | 1.6.4.3.1 | Complete Test of Flight Hybrids (LET and to GSFC for HET FM 2) | 144d | 2003-08-01 A | 2004-03-01 A |  | 100% |  | 2003-08-01 | 2004-03-01 | 144d |  |  | start no earlier than 2003-08-01 |  |
| 521 | 1.6.4.4 | **Detector/Misc Board** | 84d | 2004-03-02 A | 2004-06-28 |  | 87% | 11d | 2004-03-02 | 2004-03-30 | 21d | 0d |  |  |  |
| 522 | 1.6.4.4.1 | **Assembly** | 10d | 2004-03-02 A | 2004-03-15 A |  | 100% |  | 2004-03-02 | 2004-03-15 | 10d |  |  |  |  |
| 523 | 1.6.4.4.1.1 | Assemble LET FM 1 Detector Board | 10d | 2004-03-02 A | 2004-03-15 A | 520 | 100% |  | 2004-03-02 | 2004-03-15 | 10d |  |  |  |  |
| 524 | 1.6.4.4.1.2 | Assemble LET FM 2 Detector Board | 10d | 2004-03-02 A | 2004-03-15 A | 520 | 100% |  | 2004-03-02 | 2004-03-15 | 10d |  |  |  |  |
| 525 | 1.6.4.4.2 | **Test** | 74d | 2004-03-16 A | 2004-06-28 |  | 85% | 11d | 2004-03-16 | 2004-03-30 | 11d | 0d |  |  |  |
| 526 | 1.6.4.4.2.1 | Test LET FM 1 Detector Board | 74d | 2004-03-16 A | 2004-06-28 | 523 | 85% | 11d | 2004-03-16 | 2004-03-30 | 11d | -13d | 0d |  |  |
| 527 | 1.6.4.4.2.2 | Test LET FM 2 Detector Board | 74d | 2004-03-16 A | 2004-06-28 | 524 | 85% | 11d | 2004-03-16 | 2004-03-30 | 11d | -13d | 0d |  |  |
| 528 | 1.6.4.5 | **Flight Software** | 227d | 2003-08-01 A | 2004-06-25 |  | 96% | 10d | 2003-08-01 | 2004-05-04 | 190d | 0d |  |  |  |
| 529 | 1.6.4.5.1 | Let Flight Software Build 3 | 227d | 2003-08-01 A | 2004-06-25 |  | 96% | 10d | 2003-08-01 | 2004-05-04 | 190d | -8d | 0d | start no earlier than 2003-08-01 |  |
| 530 | 1.6.4.6 | **Integration & Test** | 4d | 2004-07-01 | 2004-07-07 |  |  |  | 2004-05-11 | 2004-06-08 | 20d | -15d | 0d |  |  |
| 531 | 1.6.4.6.1 | **FM 1** | 4d | 2004-07-01 | 2004-07-07 |  |  |  | 2004-05-11 | 2004-06-08 | 20d | -15d | 0d |  |  |
| 532 | 1.6.4.6.1.1 | Integrate LET FM 1 Housing With Detectors | 4d | 2004-07-01 | 2004-07-07 | 518, 382, 526 |  |  | 2004-05-11 | 2004-06-08 | 20d | -15d | 0d |  | MS-SEP |
| 533 | 1.6.4.6.2 | **FM 2** | 4d | 2004-07-01 | 2004-07-07 |  |  |  | 2004-05-11 | 2004-06-08 | 20d | -15d | 0d |  |  |
| 534 | 1.6.4.6.2.1 | Integrate LET FM 2 Housing With Detectors | 4d | 2004-07-01 | 2004-07-07 | 518, 382, 527 |  |  | 2004-05-11 | 2004-06-08 | 20d | -15d | 0d |  | MS-SEP |
| 535 | 1.6.5 | **SEPT - Kiel/ESTEC** | 328d | 2003-08-08 A | 2004-11-29 |  | 70% | 97.45d | 2003-08-08 | 2004-07-28 | 245d | -21d | 0d |  |  |
| 536 | 1.6.5.1 | **Deliveries** | 67d | 2004-08-23 | 2004-11-29 |  |  |  | 2004-03-11 | 2004-07-28 | 99d | -31d | 0d |  |  |
| 537 | 1.6.5.1.1 | Deliver SEPT-NS FM 1 to CIT for SEP I&T and Suite EMC | 5d | 2004-08-23 | 2004-08-27 | 585 |  |  | 2004-03-11 | 2004-03-17 | 5d | -31d | 0d |  | MS-SEP |
| 538 | 1.6.5.1.2 | Deliver SEPT-E FM 1 to CIT for SEP I&T and Suite EMC | 5d | 2004-08-23 | 2004-08-27 | 601 |  |  | 2004-03-11 | 2004-03-17 | 5d | -31d | 0d |  | MS-SEP |
| 539 | 1.6.5.1.3 | Final Delivery of SEPT FM 1 to APL | 2d | 2004-11-26 | 2004-11-29 | 571, 589, 605 |  |  | 2004-07-27 | 2004-07-28 | 2d | -35d | 0d |  |  |
| 540 | 1.6.5.1.4 | Deliver SEPT-NS FM 2 to CIT for SEP I&T and Suite EMC | 5d | 2004-08-23 | 2004-08-27 | 618 |  |  | 2004-03-22 | 2004-03-26 | 5d | -11d | 0d |  | MS-SEP |
| 541 | 1.6.5.1.5 | Deliver SEPT-E FM 2 to CIT for SEP I&T and Suite EMC | 5d | 2004-08-23 | 2004-08-27 | 635 |  |  | 2004-03-22 | 2004-03-26 | 5d | -11d | 0d |  | MS-SEP |
| 542 | 1.6.5.1.6 | Final Delivery of SEPT FM 2 to APL | 2d | 2004-11-26 | 2004-11-29 | 623, 640 |  |  | 2004-07-27 | 2004-07-28 | 2d | -21d | 0d |  |  |

| ID | WBS | Task | Duration | Start | Finish | Predecessors | Complete | Remaining | Baseline start | Baseline finish | Baseline duration | Total slack | Free slack | Constraint |
| --- | --- | --- | --- | --- | --- | --- | --- | --- | --- | --- | --- | --- | --- | --- |
| 543 | 1.6.5.2 | **Mechanical Assembly** | 46d | 2003-12-22 A | 2004-02-27 A |  | 100% |  | 2003-12-22 | 2004-02-27 | 46d |  |  |  |
| 544 | 1.6.5.2.1 | **FM 1** | 13d | 2003-12-22 A | 2004-01-09 A |  | 100% |  | 2003-12-22 | 2004-01-09 | 13d |  |  |  |
| 545 | 1.6.5.2.1.1 | Assemble SEPT-NS FM 1 Sensor and E-Box Housing | 13d | 2003-12-22 A | 2004-01-09 A |  | 100% |  | 2003-12-22 | 2004-01-09 | 13d |  |  | start no earlier than 2003-12-22 |
| 546 | 1.6.5.2.1.2 | Assemble SEPT-E FM 1 Sensor and E-Box Housing | 13d | 2003-12-22 A | 2004-01-09 A |  | 100% |  | 2003-12-22 | 2004-01-09 | 13d |  |  | start no earlier than 2003-12-22 |
| 547 | 1.6.5.2.2 | **FM 2** | 14d | 2003-12-29 A | 2004-01-16 A |  | 100% |  | 2003-12-29 | 2004-01-16 | 14d |  |  |  |
| 548 | 1.6.5.2.2.1 | Assemble SEPT-NS FM 2 Sensor and E-Box Housing | 14d | 2003-12-29 A | 2004-01-16 A | 545SS+4d | 100% |  | 2003-12-29 | 2004-01-16 | 14d |  |  |  |
| 549 | 1.6.5.2.2.2 | Assemble SEPT-E FM 2 Sensor and E-Box Housing | 14d | 2003-12-29 A | 2004-01-16 A | 546SS+4d | 100% |  | 2003-12-29 | 2004-01-16 | 14d |  |  |  |
| 550 | 1.6.5.2.3 | **Spare** | 28d | 2004-01-20 A | 2004-02-27 A |  | 100% |  | 2004-01-20 | 2004-02-27 | 28d |  |  |  |
| 551 | 1.6.5.2.3.1 | Assemble SEPT Spare Sensor and E-Box Housing | 28d | 2004-01-20 A | 2004-02-27 A | 548, 549 | 100% |  | 2004-01-20 | 2004-02-27 | 28d |  |  |  |
| 552 | 1.6.5.3 | **Electronics** | 221d | 2003-08-08 A | 2004-06-24 |  | 98% | 4.49d | 2003-08-08 | 2004-05-21 | 198d | 70d |  |  |
| 553 | 1.6.5.3.1 | **Assembly** | 172d | 2003-08-08 A | 2004-04-15 A |  | 100% |  | 2003-08-08 | 2004-04-15 | 172d |  |  |  |
| 554 | 1.6.5.3.1.1 | **FM 2** | 106d | 2003-08-08 A | 2004-01-12 A |  | 100% |  | 2003-08-08 | 2004-01-12 | 106d |  |  |  |
| 555 | 1.6.5.3.1.1.1 | Assemble SEPT-NS FM 2 Electronics | 106d | 2003-08-08 A | 2004-01-12 A |  | 100% |  | 2003-08-08 | 2004-01-12 | 106d |  |  | start no earlier than 2003-08-08 |
| 556 | 1.6.5.3.1.1.2 | Assemble SEPT-E FM 2 Electronics | 92d | 2003-08-08 A | 2003-12-19 A |  | 100% |  | 2003-08-08 | 2003-12-19 | 92d |  |  | start no earlier than 2003-08-08 |
| 557 | 1.6.5.3.1.2 | **Spare** | 172d | 2003-08-08 A | 2004-04-15 A |  | 100% |  | 2003-08-08 | 2004-04-15 | 172d |  |  |  |
| 558 | 1.6.5.3.1.2.1 | Assemble SEPT FS Electronics | 172d | 2003-08-08 A | 2004-04-15 A | 555SS | 100% |  | 2003-08-08 | 2004-04-15 | 172d |  |  |  |
| 559 | 1.6.5.3.2 | **Test** | 136d | 2003-12-11 A | 2004-06-24 |  | 92% | 11.15d | 2003-12-11 | 2004-05-21 | 113d | 70d |  |  |
| 560 | 1.6.5.3.2.1 | **FM 2** | 128d | 2003-12-11 A | 2004-06-14 |  | 99% | 1.52d | 2003-12-11 | 2004-01-30 | 34d | 74d |  |  |
| 561 | 1.6.5.3.2.1.1 | SEPT-NS FM 2 Electronics Test | 4d | 2004-01-13 A | 2004-01-16 A | 555 | 100% |  | 2004-01-13 | 2004-01-16 | 4d |  |  |  |
| 562 | 1.6.5.3.2.1.2 | SEPT-E FM 2 Electronics Test | 4d | 2003-12-11 A | 2003-12-16 A | 556FS-7d | 100% |  | 2003-12-11 | 2003-12-16 | 4d |  |  |  |
| 563 | 1.6.5.3.2.1.3 | Coat SEPT-NS FM 2 Electronics Board | 4d | 2004-01-20 A | 2004-01-23 A | 561 | 100% |  | 2004-01-20 | 2004-01-23 | 4d |  |  |  |
| 564 | 1.6.5.3.2.1.4 | Coat SEPT-E FM 2 Electronics Board | 5d | 2003-12-17 A | 2003-12-23 A | 562 | 100% |  | 2003-12-17 | 2003-12-23 | 5d |  |  |  |
| 565 | 1.6.5.3.2.1.5 | SEPT-NS FM 2 Mechanical Integration | 5d | 2004-01-26 A | 2004-01-30 A | 563 | 100% |  | 2004-01-26 | 2004-01-30 | 5d |  |  |  |
| 566 | 1.6.5.3.2.1.6 | SEPT-E FM 2 Mechanical Integration | 13d | 2003-12-24 A | 2004-01-13 A | 564 | 100% |  | 2003-12-24 | 2004-01-13 | 13d |  |  |  |
| 567 | 1.6.5.3.2.1.7 | Repair SEPT-NS FM 2 Electronic Board for use as Spare | 49d | 2004-04-06 A | 2004-06-14 | 613SS | 98% | 1d | 2004-04-06 | 2004-06-14 | 49d | 74d | 4d |  |

Notes:
- 567: The repair task duration is not determined yet and is waiting for the new Actel Programming software to get to Europe. (after May 19th)

| ID | WBS | Task | Duration | Start | Finish | Predecessors | Complete | Remaining | Baseline start | Baseline finish | Baseline duration | Total slack | Free slack | Constraint | Calendar | Text1 |
| --- | --- | --- | --- | --- | --- | --- | --- | --- | --- | --- | --- | --- | --- | --- | --- | --- |
| 568 | 1.6.5.3.2.2 | **Spare** | 43d | 2004-04-26 A | 2004-06-24 |  | 76% | 10.18d | 2004-04-26 | 2004-05-21 | 20d | 70d |  |  |  |  |
| 569 | 1.6.5.3.2.2.1 | SEPT Flight Spare Electronics Test | 5d | 2004-04-26 A | 2004-04-30 A | 558 | 100% |  | 2004-04-26 | 2004-04-30 | 5d |  |  | start no earlier than 2004-04-26 |  |  |
| 570 | 1.6.5.3.2.2.2 | Coat SEPT FS Electronics Board | 29d | 2004-05-10 A | 2004-06-18 | 569 | 83% | 5d | 2004-05-10 | 2004-05-14 | 5d | 3d | 0d | start no earlier than 2004-05-10 |  |  |
| 571 | 1.6.5.3.2.2.3 | SEPT FS Mechanical Integration | 4d | 2004-06-21 | 2004-06-24 | 570, 567 |  |  | 2004-05-17 | 2004-05-21 | 5d | 70d |  |  |  |  |
| 572 | 1.6.5.4 | **Integration & Test** | 221d | 2004-01-12 A | 2004-11-24 |  | 46% | 120.41d | 2004-01-12 | 2004-07-26 | 138d | -21d | 0d |  |  |  |
| 573 | 1.6.5.4.1 | **FM 1** | 221d | 2004-01-12 A | 2004-11-24 |  | 46% | 119.71d | 2004-01-12 | 2004-07-26 | 138d | -35d | 0d |  |  |  |
| 574 | 1.6.5.4.1.1 | **SEPT-NS** | 212d | 2004-01-26 A | 2004-11-24 |  | 46% | 114.83d | 2004-01-26 | 2004-07-26 | 129d | -35d | 0d |  |  |  |
| 575 | 1.6.5.4.1.1.1 | SEPT-NS FM 1 Integration & Test | 5d | 2004-01-26 A | 2004-01-30 A | 545 | 100% |  | 2004-01-26 | 2004-01-30 | 5d |  |  | start no earlier than 2004-01-26 |  |  |
| 576 | 1.6.5.4.1.1.2 | Muon and Radioactive Source Test | 5d | 2004-02-02 A | 2004-02-06 A | 575 | 100% |  | 2004-02-02 | 2004-02-06 | 5d |  |  |  |  |  |
| 577 | 1.6.5.4.1.1.3 | SEPT-NS FM 1 Vibration | 4d | 2004-02-19 A | 2004-02-24 A | 576 | 100% |  | 2004-02-17 | 2004-02-20 | 4d |  |  | start no earlier than 2004-02-19 |  | MS-SEP |
| 578 | 1.6.5.4.1.1.4 | SEPT-NS FM 1 Thermal Vac | 11d | 2004-02-27 A | 2004-03-12 A | 577FS+2d | 100% |  | 2004-02-25 | 2004-03-08 | 9d |  |  |  |  |  |
| 579 | 1.6.5.4.1.1.5 | SEPT-NS FM 1 Bake Out | 2d | 2004-03-05 A | 2004-03-08 A | 578FS-6d | 100% |  | 2004-03-09 | 2004-03-10 | 2d |  |  |  |  |  |
| 580 | 1.6.5.4.1.1.6 | **SEPT-NS FM 1 Repair** | 82d | 2004-04-06 A | 2004-07-30 | 579FS+20d | 48% | 43d |  |  |  | -31d | 0d |  |  |  |
| 581 | 1.6.5.4.1.1.6.1 | SEPT-NS FM 1 Initial Repair | 45d | 2004-04-06 A | 2004-06-08 |  | 87% | 6d | 2004-04-06 | 2004-06-08 | 45d | -31d | 0d |  |  |  |
| 582 | 1.6.5.4.1.1.6.2 | SEPT-NS FM 1 Titanium Parts Repair (GSFC) | 17d | 2004-06-09 | 2004-07-01 | 581 |  |  | 2004-06-09 | 2004-07-01 | 17d | -31d | 0d |  |  |  |
| 583 | 1.6.5.4.1.1.6.3 | SEPT-NS FM 1 Final Repair | 20d | 2004-07-02 | 2004-07-30 | 582 |  |  | 2004-07-02 | 2004-07-30 | 20d | -31d | 0d |  |  |  |
| 584 | 1.6.5.4.1.1.7 | SEPT-NS FM 1 Post Repair Integration & Test | 5d | 2004-08-02 | 2004-08-06 | 580 |  |  | 2004-08-02 | 2004-08-06 | 5d | -31d | 0d |  |  |  |
| 585 | 1.6.5.4.1.1.8 | Cleaning, Packing, Customs, Transport | 5d | 2004-08-16 | 2004-08-20 | 584, 618SS |  |  | 2004-08-16 | 2004-08-20 | 5d | -31d | 0d |  |  |  |
| 586 | 1.6.5.4.1.1.9 | SEPT-NS FM 1 Install Thermal H/W (GSFC) | 4d | 2004-09-21 | 2004-09-24 | 19 |  |  | 2004-09-21 | 2004-09-24 | 4d | -15d | 0d |  |  |  |
| 587 | 1.6.5.4.1.1.10 | SEPT-NS FM 1 Thermal Balance (at GSFC after Suite EMC) | 10d | 2004-10-26 | 2004-11-08 | 586, 621SS |  |  | 2004-07-13 | 2004-07-26 | 10d | -35d | 0d |  |  |  |
| 588 | 1.6.5.4.1.1.11 | SEPT-NS FM 1 Post Repair Vibration (ESTEC) | 5d | 2004-11-09 | 2004-11-16 | 587 |  |  | 2004-11-09 | 2004-11-16 | 5d | -35d | 0d |  |  |  |
| 589 | 1.6.5.4.1.1.12 | SEPT-NSFM 1 Post Repair Thermal Vac (ESTEC) | 6d | 2004-11-17 | 2004-11-24 | 588 |  |  | 2004-11-17 | 2004-11-24 | 6d | -36d | 0d |  | Internation Work Schedule |  |
| 590 | 1.6.5.4.1.2 | **SEPT-E** | 201d | 2004-01-12 A | 2004-10-26 |  | 46% | 108.88d | 2004-01-12 | 2004-07-26 | 138d | -15d | 0d |  |  |  |
| 591 | 1.6.5.4.1.2.1 | SEPT-E FM 1 Integration & Test | 5d | 2004-01-12 A | 2004-01-16 A | 546 | 100% |  | 2004-01-12 | 2004-01-16 | 5d |  |  |  |  |  |
| 592 | 1.6.5.4.1.2.2 | Muon and Radioactive Source Test | 5d | 2004-01-29 A | 2004-02-04 A | 591 | 100% |  | 2004-01-29 | 2004-02-04 | 5d |  |  | start no earlier than 2004-01-29 |  |  |
| 593 | 1.6.5.4.1.2.3 | SEPT-E FM 1 Vibration | 4d | 2004-02-19 A | 2004-02-24 A | 592, 577SS | 100% |  | 2004-02-21 | 2004-02-24 | 4d |  |  |  |  |  |
| 594 | 1.6.5.4.1.2.4 | SEPT-E FM 1 Thermal Vac | 11d | 2004-02-27 A | 2004-03-12 A | 593, 578SS | 100% |  | 2004-02-25 | 2004-03-08 | 9d |  |  |  |  |  |
| 595 | 1.6.5.4.1.2.5 | SEPT-E FM 1 Bake Out | 2d | 2004-03-05 A | 2004-03-08 A | 594FS-6d | 100% |  | 2004-03-09 | 2004-03-10 | 2d |  |  |  |  |  |

Notes:
- 577: There was a failure on the SEPT door during Vibration Test. Vibration Test will be repeated once the fix to the door is implemented. Time and place is TBD.
- 593: There was a failure on the SEPT door during Vibration Test. Vibration Test will be repeated once the fix to the door is implemented. Time and place is TBD.

| ID | WBS | Task | Duration | Start | Finish | Predecessors | Complete | Remaining | Baseline start | Baseline finish | Baseline duration | Total slack | Free slack | Constraint | Calendar |
| --- | --- | --- | --- | --- | --- | --- | --- | --- | --- | --- | --- | --- | --- | --- | --- |
| 596 | 1.6.5.4.1.2.6 | **SEPT-E FM 1 Repair** | 82d | 2004-04-06 A | 2004-07-30 | 595FS+20d | 48% | 43d |  |  |  | -31d | 0d |  |  |
| 597 | 1.6.5.4.1.2.6.1 | SEPT-E FM 1 Initial Repair | 45d | 2004-04-06 A | 2004-06-08 |  | 87% | 6d | 2004-04-06 | 2004-06-08 | 45d | -31d | 0d |  |  |
| 598 | 1.6.5.4.1.2.6.2 | SEPT-E FM 1 Titanium Parts Repair (at GSFC then shipped back to Kiel) | 17d | 2004-06-09 | 2004-07-01 | 597 |  |  | 2004-06-09 | 2004-07-01 | 17d | -31d | 0d |  |  |
| 599 | 1.6.5.4.1.2.6.3 | SEPT-E FM 1 Final Repair | 20d | 2004-07-02 | 2004-07-30 | 598 |  |  | 2004-07-02 | 2004-07-30 | 20d | -31d | 0d |  |  |
| 600 | 1.6.5.4.1.2.7 | SEPT-E FM 1 Post Repair Integration & Test | 5d | 2004-08-02 | 2004-08-06 | 596 |  |  | 2004-08-02 | 2004-08-06 | 5d | -31d | 0d |  |  |
| 601 | 1.6.5.4.1.2.8 | Cleaning, Packing, Customs, Transport | 5d | 2004-08-16 | 2004-08-20 | 600, 635SS |  |  | 2004-08-16 | 2004-08-20 | 5d | -31d | 0d |  |  |
| 602 | 1.6.5.4.1.2.9 | SEPT-E FM 1 Install Thermal H/W (GSFC) | 4d | 2004-09-21 | 2004-09-24 | 19 |  |  | 2004-09-21 | 2004-09-24 | 4d | -15d | 0d |  |  |
| 603 | 1.6.5.4.1.2.10 | SEPT-E FM 1 Thermal Balance (at GSFC after Suite EMC) | 10d | 2004-09-27 | 2004-10-08 | 602 |  |  | 2004-07-13 | 2004-07-26 | 10d | -15d | 0d |  |  |
| 604 | 1.6.5.4.1.2.11 | SEPT-E FM1 Post Repair Vibration (ESTEC) | 5d | 2004-10-12 | 2004-10-18 | 603 |  |  | 2004-10-12 | 2004-10-18 | 5d | -15d | 0d |  |  |
| 605 | 1.6.5.4.1.2.12 | SEPT-E FM1 Post Repair Thermal Vac (ESTEC) | 6d | 2004-10-19 | 2004-10-26 | 604 |  |  | 2004-10-19 | 2004-10-26 | 6d | -16d | 0d |  | Internation Work Schedule |
| 606 | 1.6.5.4.2 | **FM 2** | 221d | 2004-01-12 A | 2004-11-24 |  | 45% | 121.1d | 2004-01-12 | 2004-03-19 | 48d | -21d | 0d |  |  |
| 607 | 1.6.5.4.2.1 | **SEPT-NS** | 216d | 2004-01-20 A | 2004-11-24 |  | 46% | 116.76d | 2004-01-20 | 2004-03-19 | 43d | -21d | 0d |  |  |
| 608 | 1.6.5.4.2.1.1 | SEPT-NS FM 2 Integration & Test | 8d | 2004-01-20 A | 2004-01-29 A | 548 | 100% |  | 2004-01-20 | 2004-01-29 | 8d |  |  |  |  |
| 609 | 1.6.5.4.2.1.2 | Muon and Radioactive Source Test | 6d | 2004-01-30 A | 2004-02-06 A | 608 | 100% |  | 2004-01-30 | 2004-02-06 | 6d |  |  |  |  |
| 610 | 1.6.5.4.2.1.3 | SEPT-NS FM 2 Vibration | 4d | 2004-02-19 A | 2004-02-24 A | 609, 577SS | 100% |  | 2004-02-17 | 2004-02-20 | 4d |  |  |  |  |
| 611 | 1.6.5.4.2.1.4 | SEPT-NS FM 2 Thermal Vac | 9d | 2004-03-05 A | 2004-03-17 A | 610 | 100% |  | 2004-03-09 | 2004-03-17 | 9d |  |  | start no earlier than 2004-03-05 |  |
| 612 | 1.6.5.4.2.1.5 | SEPT-NS FM 2 Bake Out | 2d | 2004-03-12 A | 2004-03-15 A | 611FS-4d | 100% |  | 2004-03-18 | 2004-03-19 | 2d |  |  |  |  |
| 613 | 1.6.5.4.2.1.6 | **SEPT-NS FM 2 Repair** | 82d | 2004-04-06 A | 2004-07-30 | 612FS+15d | 48% | 43d |  |  |  | -26d | 0d |  |  |
| 614 | 1.6.5.4.2.1.6.1 | SEPT-NS FM 2 Initial Repair | 45d | 2004-04-06 A | 2004-06-08 |  | 87% | 6d | 2004-04-06 | 2004-06-08 | 45d | -26d | 0d |  |  |
| 615 | 1.6.5.4.2.1.6.2 | SEPT-NS FM 2 Titanium Parts Repair (at GSFC then shipped back to Kiel) | 17d | 2004-06-09 | 2004-07-01 | 614 |  |  | 2004-06-09 | 2004-07-01 | 17d | -26d | 0d |  |  |
| 616 | 1.6.5.4.2.1.6.3 | SEPT-NS FM 2 Final Repair | 20d | 2004-07-02 | 2004-07-30 | 615 |  |  | 2004-07-02 | 2004-07-30 | 20d | -26d | 0d |  |  |
| 617 | 1.6.5.4.2.1.7 | SEPT-NS FM 2 Post Repair Integration & Test | 5d | 2004-08-09 | 2004-08-13 | 570, 613, 584 |  |  | 2004-08-09 | 2004-08-13 | 5d | -31d | 0d |  |  |
| 618 | 1.6.5.4.2.1.8 | Cleaning, Packing, Customs, Transport | 5d | 2004-08-16 | 2004-08-20 | 617 |  |  | 2004-08-16 | 2004-08-20 | 5d | -31d | 0d |  |  |
| 619 | 1.6.5.4.2.1.9 | Receive SEPT-NS FM 2 after Suite EMC | 2d | 2004-10-18 | 2004-10-19 | 827 |  |  | 2004-10-18 | 2004-10-19 | 2d | -35d | 0d |  |  |
| 620 | 1.6.5.4.2.1.10 | SEPT-NS FM 2 Install Thermal H/W (GSFC) | 4d | 2004-10-20 | 2004-10-25 | 619 |  |  | 2004-10-20 | 2004-10-25 | 4d | -35d | 0d |  |  |
| 621 | 1.6.5.4.2.1.11 | SEPT-NS FM 1 Thermal Balance (GSFC) | 10d | 2004-10-26 | 2004-11-08 | 620 |  |  | 2004-07-13 | 2004-07-26 | 10d | -35d | 0d |  |  |
| 622 | 1.6.5.4.2.1.12 | SEPT-NS FM 2 Post Repair Vibration (ESTEC) | 5d | 2004-11-09 | 2004-11-16 | 621 |  |  | 2004-11-09 | 2004-11-16 | 5d | -21d | 0d |  |  |
| 623 | 1.6.5.4.2.1.13 | SEPT-NS FM 2 Post Repair Thermal Vac (ESTEC) | 6d | 2004-11-17 | 2004-11-24 | 622 |  |  | 2004-11-17 | 2004-11-24 | 6d | -21d | 0d |  |  |

Notes:
- 610: There was a failure on the SEPT door during Vibration Test. Vibration Test will be repeated once the fix to the door is implemented. Time and place is TBD.

| ID | WBS | Task | Duration | Start | Finish | Predecessors | Complete | Remaining | Baseline start | Baseline finish | Baseline duration | Total slack | Free slack | Text1 |
| --- | --- | --- | --- | --- | --- | --- | --- | --- | --- | --- | --- | --- | --- | --- |
| 624 | 1.6.5.4.2.2 | **SEPT-E** | 221d | 2004-01-12 A | 2004-11-24 |  | 44% | 122.78d | 2004-01-12 | 2004-03-19 | 48d | -21d | 0d |  |
| 625 | 1.6.5.4.2.2.1 | SEPT-E FM 2 Integration & Test | 5d | 2004-01-12 A | 2004-01-16 A | 591SS | 100% |  | 2004-01-12 | 2004-01-16 | 5d |  |  |  |
| 626 | 1.6.5.4.2.2.2 | Muon and Radioactive Source Test | 5d | 2004-01-29 A | 2004-02-04 A | 625, 592SS | 100% |  | 2004-01-29 | 2004-02-04 | 5d |  |  |  |
| 627 | 1.6.5.4.2.2.3 | SEPT-E FM 2 Vibration | 4d | 2004-02-19 A | 2004-02-24 A | 626, 577SS | 100% |  | 2004-02-21 | 2004-02-24 | 4d |  |  |  |
| 628 | 1.6.5.4.2.2.4 | SEPT-E FM 2 Thermal Vac | 9d | 2004-03-05 A | 2004-03-17 A | 627, 611SS | 100% |  | 2004-03-09 | 2004-03-17 | 9d |  |  |  |
| 629 | 1.6.5.4.2.2.5 | SEPT-E FM 2 Bake Out | 2d | 2004-03-12 A | 2004-03-15 A | 628FS-4d | 100% |  | 2004-03-18 | 2004-03-19 | 2d |  |  |  |
| 630 | 1.6.5.4.2.2.6 | **SEPT-E FM 2 Repair** | 82d | 2004-04-06 A | 2004-07-30 | 629FS+15d | 48% | 43d |  |  |  | -26d | 0d |  |
| 631 | 1.6.5.4.2.2.6.1 | SEPT-E FM 2 Initial Repair | 45d | 2004-04-06 A | 2004-06-08 |  | 87% | 6d | 2004-04-06 | 2004-06-08 | 45d | -26d | 0d |  |
| 632 | 1.6.5.4.2.2.6.2 | SEPT-E FM 2 Titanium Parts Repair (at GSFC then shipped back to Kiel) | 17d | 2004-06-09 | 2004-07-01 | 631 |  |  | 2004-06-09 | 2004-07-01 | 17d | -26d | 0d |  |
| 633 | 1.6.5.4.2.2.6.3 | SEPT-E FM 2 Final Repair | 20d | 2004-07-02 | 2004-07-30 | 632 |  |  | 2004-07-02 | 2004-07-30 | 20d | -26d | 0d |  |
| 634 | 1.6.5.4.2.2.7 | SEPT-E FM 2 Post Repair Integration & Test | 5d | 2004-08-09 | 2004-08-13 | 632, 630, 600 |  |  | 2004-08-09 | 2004-08-13 | 5d | -31d | 0d |  |
| 635 | 1.6.5.4.2.2.8 | Cleaning, Packing, Customs, Transport | 5d | 2004-08-16 | 2004-08-20 | 634 |  |  | 2004-08-16 | 2004-08-20 | 5d | -31d | 0d |  |
| 636 | 1.6.5.4.2.2.9 | Receive SEPT-E FM 2 after Suite EMC | 2d | 2004-10-18 | 2004-10-19 | 827 |  |  | 2004-10-18 | 2004-10-19 | 2d | -21d | 0d |  |
| 637 | 1.6.5.4.2.2.10 | SEPT-E FM 2 Install Thermal H/W (GSFC) | 4d | 2004-10-20 | 2004-10-25 | 636 |  |  | 2004-10-20 | 2004-10-25 | 4d | -21d | 0d |  |
| 638 | 1.6.5.4.2.2.11 | SEPT-E FM 1 Thermal Balance (GSFC) | 10d | 2004-10-26 | 2004-11-08 | 637 |  |  | 2004-07-13 | 2004-07-26 | 10d | -21d | 0d |  |
| 639 | 1.6.5.4.2.2.12 | SEPT-E FM 2 Post Repair Vibration (ESTEC) | 5d | 2004-11-09 | 2004-11-16 | 638 |  |  | 2004-11-09 | 2004-11-16 | 5d | -21d | 0d |  |
| 640 | 1.6.5.4.2.2.13 | SEPT-E FM 2 Post Repair Thermal Vac (ESTEC) | 6d | 2004-11-17 | 2004-11-24 | 639 |  |  | 2004-11-17 | 2004-11-24 | 6d | -21d | 0d |  |
| 641 | 1.6.6 | **SIT - UMD** | 385d | 2003-06-02 A | 2004-12-10 |  | 79% | 79.02d | 2003-06-02 | 2004-10-20 | 351d | -30d | 0d |  |
| 642 | 1.6.6.1 | **Deliveries** | 80d | 2004-08-17 | 2004-12-10 |  |  |  | 2004-06-18 | 2004-10-12 | 81d | -30d | 0d |  |
| 643 | 1.6.6.1.1 | Deliver SIT FM 1 to CIT for SEP I&T and Suite EMC | 2d | 2004-08-17 | 2004-08-18 | 403, 728 |  |  | 2004-06-18 | 2004-06-21 | 2d | -19d | 0d | MS-SEP |
| 644 | 1.6.6.1.2 | Deliver SIT FM 1 back to GSFC for Environmental Testing (after EMC Test) | 2d | 2004-09-21 | 2004-09-22 | 19, 410 |  |  | 2004-07-13 | 2004-07-14 | 2d | -26d | 0d | MS-SEP |
| 645 | 1.6.6.1.3 | Final Delivery of SIT FM 1 to APL | 1d | 2004-11-15 | 2004-11-15 | 762 |  |  | 2004-09-01 | 2004-09-01 | 1d | -26d | 0d | MS-SEP |
| 646 | 1.6.6.1.4 | Deliver SIT FM 2 to CIT for SEP I&T | 2d | 2004-09-24 | 2004-09-27 | 733, 403 |  |  | 2004-07-23 | 2004-07-26 | 2d | -29d | 0d | MS-SEP |
| 647 | 1.6.6.1.5 | Deliver SIT FM 2 back to GSFC for Environmental Testing | 2d | 2004-10-18 | 2004-10-19 | 827 |  |  | 2004-08-19 | 2004-08-20 | 2d | -30d | 0d | MS-SEP |
| 648 | 1.6.6.1.6 | Final Delivery of SIT FM 2 to APL | 1d | 2004-12-10 | 2004-12-10 | 771, 777 |  |  | 2004-10-12 | 2004-10-12 | 1d | -30d | 0d | MS-SEP |

Notes:
- 627: There was a failure on the SEPT door during Vibration Test. Vibration Test will be repeated once the fix to the door is implemented. Time and place is TBD.

| ID | WBS | Task | Type | Duration | Start | Finish | Predecessors | Complete | Remaining | Baseline start | Baseline finish | Baseline duration | Total slack | Free slack | Constraint |
| --- | --- | --- | --- | --- | --- | --- | --- | --- | --- | --- | --- | --- | --- | --- | --- |
| 649 | 1.6.6.2 | **ACTEL - for SIT Logic Board** |  | 1d | 2004-05-24 A | 2004-05-24 A |  | 100% |  | 2004-02-27 | 2004-03-12 | 11d |  |  |  |
| 650 | 1.6.6.2.1 | Burn Final SIT ACTEL Chip w/latest algorithm (at GSFC) |  | 1d | 2004-05-24 A | 2004-05-24 A |  | 100% |  | 2004-02-27 | 2004-02-27 | 1d |  |  | start no earlier than 2004-05-24 |
| 651 | 1.6.6.2.2 | Evaluate (Test) SIT Final ACTEL Chip | milestone | 0d | 2004-05-24 A | 2004-05-24 A | 650 | 100% |  | 2004-03-01 | 2004-03-12 | 10d |  |  |  |
| 652 | 1.6.6.3 | **TOF Boards** |  | 95d | 2004-02-12 A | 2004-06-25 |  | 79% | 19.79d | 2004-02-12 | 2004-03-11 | 20d | -4d | 0d |  |
| 653 | 1.6.6.3.1 | Receive Analog and Digital TOF Boards (FM 1) | milestone | 0d | 2004-02-12 A | 2004-02-12 A |  | 100% |  | 2004-02-12 | 2004-02-12 | 0d |  |  | start no earlier than 2004-02-12 |
| 654 | 1.6.6.3.2 | Receive Analog and Digital TOF Boards (FM 2) |  | 20d | 2004-03-25 A | 2004-05-28 A | 657FS+32d | 100% |  | 2004-03-15 | 2004-04-09 | 20d |  |  |  |
| 655 | 1.6.6.3.3 | **Test** |  | 84d | 2004-03-01 A | 2004-06-25 |  | 64% | 30d | 2004-02-12 | 2004-03-11 | 20d | -4d | 0d |  |
| 656 | 1.6.6.3.3.1 | **FM 1** |  | 18d | 2004-03-01 A | 2004-03-24 A |  | 100% |  | 2004-02-12 | 2004-02-26 | 10d |  |  |  |
| 657 | 1.6.6.3.3.1.1 | FM 1 TOF Boards Functional Test |  | 18d | 2004-03-01 A | 2004-03-24 A | 653 | 100% |  | 2004-02-12 | 2004-02-26 | 10d |  |  | start no earlier than 2004-03-01 |
| 658 | 1.6.6.3.3.2 | **FM 2** |  | 10d | 2004-06-14 | 2004-06-25 |  |  |  | 2004-02-27 | 2004-03-11 | 10d | -4d | 0d |  |
| 659 | 1.6.6.3.3.2.1 | FM 2 TOF Boards Functional Test |  | 10d | 2004-06-14 | 2004-06-25 | 653, 654FS+9d |  |  | 2004-02-27 | 2004-03-11 | 10d | -4d | 0d |  |
| 660 | 1.6.6.4 | **Energy Board** |  | 143d | 2003-11-10 A | 2004-06-04 A |  | 100% |  | 2003-11-10 | 2004-04-02 | 99d |  |  |  |
| 661 | 1.6.6.4.1 | **Assembly** |  | 114d | 2003-11-10 A | 2004-04-23 A |  | 100% |  | 2003-11-10 | 2004-02-20 | 69d |  |  |  |
| 662 | 1.6.6.4.1.1 | **FM 1** |  | 92d | 2003-11-10 A | 2004-03-24 A |  | 100% |  | 2003-11-10 | 2004-02-20 | 69d |  |  |  |
| 663 | 1.6.6.4.1.1.1 | Assemble FM 1 Energy Board |  | 92d | 2003-11-10 A | 2004-03-24 A |  | 100% |  | 2003-11-10 | 2004-02-20 | 69d |  |  | start no earlier than 2003-11-10 |
| 664 | 1.6.6.4.1.2 | **FM 2** |  | 114d | 2003-11-10 A | 2004-04-23 A |  | 100% |  | 2003-11-10 | 2004-02-20 | 69d |  |  |  |
| 665 | 1.6.6.4.1.2.1 | Assemble FM 2 Energy Board |  | 82d | 2003-11-10 A | 2004-04-23 A | 663FF+22d | 100% |  | 2003-11-10 | 2004-02-20 | 69d |  |  |  |
| 666 | 1.6.6.4.2 | **Test** |  | 51d | 2004-03-25 A | 2004-06-04 A |  | 100% |  | 2004-02-23 | 2004-04-02 | 30d |  |  |  |
| 667 | 1.6.6.4.2.1 | **FM 1** |  | 50d | 2004-03-25 A | 2004-06-03 A |  | 100% |  | 2004-02-23 | 2004-03-12 | 15d |  |  |  |
| 668 | 1.6.6.4.2.1.1 | Bench Test/Calibration |  | 47d | 2004-03-25 A | 2004-05-28 A | 663 | 100% |  | 2004-02-23 | 2004-03-05 | 10d |  |  |  |
| 669 | 1.6.6.4.2.1.2 | Thermal |  | 3d | 2004-06-01 A | 2004-06-03 A | 668 | 100% |  | 2004-03-08 | 2004-03-10 | 3d |  |  |  |
| 670 | 1.6.6.4.2.1.3 | Voltage Margin |  | 2d | 2004-06-01 A | 2004-06-02 A | 669SS | 100% |  | 2004-03-11 | 2004-03-12 | 2d |  |  |  |
| 671 | 1.6.6.4.2.2 | **FM 2** |  | 7d | 2004-05-26 A | 2004-06-04 A |  | 100% |  | 2004-03-15 | 2004-04-02 | 15d |  |  |  |
| 672 | 1.6.6.4.2.2.1 | FM 2 Energy Board Functional Test |  | 7d | 2004-05-26 A | 2004-06-04 A | 665, 670FS-5d | 100% |  | 2004-03-15 | 2004-04-02 | 15d |  |  |  |

Notes:
- 650: SIT Actel design review held 4/30 by Rod Barto. Relayout of the board possible. Reccomend performing a funtional test on FM1 with the Flight ACTEL to analyze possible ground bounce issues. Tech can not burn chip until the new algorithm is released after 5/19.

| ID | WBS | Task | Duration | Start | Finish | Predecessors | Complete | Remaining | Baseline start | Baseline finish | Baseline duration | Total slack | Free slack | Constraint |
| --- | --- | --- | --- | --- | --- | --- | --- | --- | --- | --- | --- | --- | --- | --- |
| 673 | 1.6.6.5 | **Logic Board** | 168d | 2003-11-10 A | 2004-07-12 |  | 85% | 25.26d | 2003-11-10 | 2004-07-09 | 168d | -14d | 0d |  |
| 674 | 1.6.6.5.1 | **Design** | 3d | 2003-11-17 A | 2003-11-19 A |  | 100% |  | 2003-11-17 | 2003-11-19 | 3d |  |  |  |
| 675 | 1.6.6.5.1.1 | Layout new Logic Board Design | 3d | 2003-11-17 A | 2003-11-19 A |  | 100% |  | 2003-11-17 | 2003-11-19 | 3d |  |  | start no earlier than 2003-11-17 |
| 676 | 1.6.6.5.2 | **Fabrication** | 10d | 2004-03-08 A | 2004-03-19 A |  | 100% |  | 2004-02-09 | 2004-02-23 | 10d |  |  |  |
| 677 | 1.6.6.5.2.1 | FM 1 & FM 2 Logic Board Fabrication | 10d | 2004-03-08 A | 2004-03-19 A | 675, 685 | 100% |  | 2004-02-09 | 2004-02-23 | 10d |  |  | start no earlier than 2004-02-02 |
| 678 | 1.6.6.5.3 | **Assembly** | 23d | 2004-05-25 A | 2004-06-25 |  | 62% | 8.85d | 2004-03-09 | 2004-07-07 | 86d | -14d | 0d |  |
| 679 | 1.6.6.5.3.1 | **FM 1** | 8d | 2004-05-25 A | 2004-06-04 A |  | 100% |  | 2004-03-09 | 2004-05-27 | 58d |  |  |  |
| 680 | 1.6.6.5.3.1.1 | Assemble FM 1 Logic Board with Flight ACTELs | 8d | 2004-05-25 A | 2004-06-04 A | 687, 651 | 100% |  | 2004-03-09 | 2004-03-23 | 11d |  |  |  |
| 681 | 1.6.6.5.3.2 | **FM 2** | 5d | 2004-06-21 | 2004-06-25 |  |  |  | 2004-03-09 | 2004-07-07 | 86d | -14d | 0d |  |
| 682 | 1.6.6.5.3.2.1 | Assemble FM 2 Logic Board with Flight ACTELS | 5d | 2004-06-21 | 2004-06-25 | 687, 651, 689 |  |  | 2004-03-09 | 2004-03-23 | 11d | -14d | 0d |  |
| 683 | 1.6.6.5.4 | **Test** | 168d | 2003-11-10 A | 2004-07-12 |  | 86% | 23.55d | 2003-11-10 | 2004-07-09 | 168d | -14d | 0d |  |
| 684 | 1.6.6.5.4.1 | **ETU** | 79d | 2003-11-10 A | 2004-03-05 A |  | 100% |  | 2003-11-10 | 2004-02-06 | 60d |  |  |  |
| 685 | 1.6.6.5.4.1.1 | Test New ETU Logic Board | 79d | 2003-11-10 A | 2004-03-05 A |  | 100% |  | 2003-11-10 | 2004-02-06 | 60d |  |  | start no earlier than 2003-11-10 |
| 686 | 1.6.6.5.4.2 | **FM1 & FM 2** | 8d | 2004-03-22 A | 2004-03-31 A |  | 100% |  | 2004-02-24 | 2004-03-08 | 10d |  |  |  |
| 687 | 1.6.6.5.4.2.1 | Coupon Testing | 8d | 2004-03-22 A | 2004-03-31 A | 677 | 100% |  | 2004-02-24 | 2004-03-08 | 10d |  |  |  |
| 688 | 1.6.6.5.4.3 | **FM 1** | 10d | 2004-06-07 A | 2004-06-18 |  | 50% | 5d | 2004-03-24 | 2004-06-01 | 49d | 0d |  |  |
| 689 | 1.6.6.5.4.3.1 | Functional Test of FM 1 Logic Board w/Flight ACTELS | 10d | 2004-06-07 A | 2004-06-18 | 680 | 50% | 5d | 2004-03-24 | 2004-04-13 | 15d | -19d | 0d |  |
| 690 | 1.6.6.5.4.4 | **FM 2** | 10d | 2004-06-28 | 2004-07-12 |  |  |  | 2004-04-14 | 2004-07-09 | 62d | -14d | 0d |  |
| 691 | 1.6.6.5.4.4.1 | Functional Test of FM 2 Logic Board w/Flight ACTELS | 10d | 2004-06-28 | 2004-07-12 | 682 |  |  | 2004-04-14 | 2004-05-04 | 15d | -14d | 0d |  |
| 692 | 1.6.6.6 | **Mother Board** | 126d | 2003-12-22 A | 2004-06-21 |  | 91% | 10.77d | 2003-12-22 | 2004-03-25 | 65d | -13d | 0d |  |
| 693 | 1.6.6.6.1 | **Design** | 67d | 2003-12-22 A | 2004-03-29 A |  | 100% |  | 2003-12-22 | 2004-02-04 | 30d |  |  |  |
| 694 | 1.6.6.6.1.1 | **FM 1 & FM 2** | 67d | 2003-12-22 A | 2004-03-29 A |  | 100% |  | 2003-12-22 | 2004-02-04 | 30d |  |  |  |
| 695 | 1.6.6.6.1.1.1 | Finalize Mother Board Layout | 30d | 2003-12-22 A | 2004-02-04 A |  | 100% |  | 2003-12-22 | 2004-02-04 | 30d |  |  | start no earlier than 2003-12-22 |
| 696 | 1.6.6.6.1.1.2 | Redesign Mother Board Layout | 17d | 2004-03-05 A | 2004-03-29 A | 695, 706 | 100% |  | 2004-03-05 | 2004-03-29 | 17d |  |  |  |

Notes:
- 680: SIT Actel design review held 4/30 by Rod Barto. Relayout of the board possible. SRAM adhesive issue will be resolved soon and will not ad to the relayout delay.

| ID | WBS | Task | Duration | Start | Finish | Predecessors | Complete | Remaining | Baseline start | Baseline finish | Baseline duration | Total slack | Free slack | Constraint |
| --- | --- | --- | --- | --- | --- | --- | --- | --- | --- | --- | --- | --- | --- | --- |
| 697 | 1.6.6.6.2 | **Fabrication** | 52d | 2004-02-05 A | 2004-04-19 A |  | 100% |  | 2004-02-05 | 2004-02-26 | 15d |  |  |  |
| 698 | 1.6.6.6.2.1 | **FM 1 & FM 2** | 52d | 2004-02-05 A | 2004-04-19 A |  | 100% |  | 2004-02-05 | 2004-02-26 | 15d |  |  |  |
| 699 | 1.6.6.6.2.1.1 | Fabricate FM 1 & FM 2 Mother Boards | 15d | 2004-02-05 A | 2004-02-26 A |  | 100% |  | 2004-02-05 | 2004-02-26 | 15d |  |  |  |
| 700 | 1.6.6.6.2.1.2 | Refabricate FM1 & FM2 Mother Boards | 15d | 2004-03-30 A | 2004-04-19 A | 706, 696 | 100% |  | 2004-03-30 | 2004-04-19 | 15d |  |  |  |
| 701 | 1.6.6.6.3 | **Assembly** | 10d | 2004-05-10 A | 2004-05-21 A |  | 100% |  | 2004-02-27 | 2004-03-11 | 10d |  |  |  |
| 702 | 1.6.6.6.3.1 | Assemble FM 1 Mother Board | 10d | 2004-05-10 A | 2004-05-21 A | 699, 707FS+9d | 100% |  | 2004-02-27 | 2004-03-11 | 10d |  |  | start no earlier than 2004-03-15 |
| 703 | 1.6.6.6.3.2 | Assemble FM 2 Mother Board | 10d | 2004-05-10 A | 2004-05-21 A | 702SS | 100% |  | 2004-02-27 | 2004-03-11 | 10d |  |  |  |
| 704 | 1.6.6.6.4 | **Test** | 81d | 2004-02-27 A | 2004-06-21 |  | 50% | 40.5d | 2004-02-27 | 2004-03-25 | 20d | -13d | 0d |  |
| 705 | 1.6.6.6.4.1 | **FM 1 & FM 2** | 42d | 2004-02-27 A | 2004-04-26 A |  | 100% |  | 2004-02-27 | 2004-03-18 | 15d |  |  |  |
| 706 | 1.6.6.6.4.1.1 | Coupon Testing of Mother Boards | 5d | 2004-02-27 A | 2004-03-04 A |  | 100% |  | 2004-02-27 | 2004-03-18 | 15d |  |  |  |
| 707 | 1.6.6.6.4.1.2 | Coupon Testing of 2nd Mother Boards | 5d | 2004-04-20 A | 2004-04-26 A | 700 | 100% |  | 2004-04-20 | 2004-04-26 | 5d |  |  |  |
| 708 | 1.6.6.6.4.2 | **FM 1** | 5d | 2004-06-14 | 2004-06-18 |  |  |  | 2004-03-12 | 2004-03-18 | 5d | -19d | 0d |  |
| 709 | 1.6.6.6.4.2.1 | Functional Test FM 1 Mother Board | 5d | 2004-06-14 | 2004-06-18 | 702FS+14d |  |  | 2004-03-12 | 2004-03-18 | 5d | -19d | 0d |  |
| 710 | 1.6.6.6.4.3 | **FM 2** | 5d | 2004-06-15 | 2004-06-21 |  |  |  | 2004-03-19 | 2004-03-25 | 5d | -13d | 0d |  |
| 711 | 1.6.6.6.4.3.1 | Functional Test FM 2 Mother Board | 5d | 2004-06-15 | 2004-06-21 | 703, 709SS+1d |  |  | 2004-03-19 | 2004-03-25 | 5d | -13d | 0d |  |
| 712 | 1.6.6.7 | **HVPS** | 135d | 2004-01-12 A | 2004-07-22 |  | 75% | 33.75d | 2004-01-12 | 2004-04-27 | 75d | -25d | 0d |  |
| 713 | 1.6.6.7.1 | **Test** | 135d | 2004-01-12 A | 2004-07-22 |  | 75% | 33.75d | 2004-01-12 | 2004-04-27 | 75d | -25d | 0d |  |
| 714 | 1.6.6.7.1.1 | **FM 1** | 30d | 2004-01-12 A | 2004-02-24 A |  | 100% |  | 2004-01-12 | 2004-02-09 | 20d |  |  |  |
| 715 | 1.6.6.7.1.1.1 | Functional Test SIT FM 1 HVPS | 30d | 2004-01-12 A | 2004-02-24 A | 71 | 100% |  | 2004-01-12 | 2004-02-09 | 20d |  |  | start no earlier than 2004-01-12 |
| 716 | 1.6.6.7.1.2 | **FM 2** | 10d | 2004-07-09 | 2004-07-22 |  |  |  | 2004-04-14 | 2004-04-27 | 10d | -25d | 0d |  |
| 717 | 1.6.6.7.1.2.1 | Functional Test SIT FM 2 HVPS | 10d | 2004-07-09 | 2004-07-22 | 77, 711 |  |  | 2004-04-14 | 2004-04-27 | 10d | -25d | 0d |  |
| 718 | 1.6.6.8 | **Flight Software** | 235d | 2003-06-02 A | 2004-05-06 A |  | 100% |  | 2003-06-02 | 2004-04-01 | 210d |  |  |  |
| 719 | 1.6.6.8.1 | **Test** | 235d | 2003-06-02 A | 2004-05-06 A |  | 100% |  | 2003-06-02 | 2004-04-01 | 210d |  |  |  |
| 720 | 1.6.6.8.1.1 | **FM 1 & FM 2** | 235d | 2003-06-02 A | 2004-05-06 A |  | 100% |  | 2003-06-02 | 2004-04-01 | 210d |  |  |  |
| 721 | 1.6.6.8.1.1.1 | Validate SIT On-Board Code | 235d | 2003-06-02 A | 2004-05-06 A |  | 100% |  | 2003-06-02 | 2004-04-01 | 210d |  |  | start no earlier than 2003-06-02 |

Notes:
- 706: After Coupon testing a Mechnical Interface error was found in the board. The design was changed and sent out for Fabrication again.

| ID | WBS | Task | Duration | Start | Finish | Predecessors | Complete | Remaining | Baseline start | Baseline finish | Baseline duration | Total slack | Free slack | Text1 |
| --- | --- | --- | --- | --- | --- | --- | --- | --- | --- | --- | --- | --- | --- | --- |
| 722 | 1.6.6.9 | **Integration & Test (using ETU Telescope for FM 1)** | 149d | 2004-02-25 A | 2004-09-23 |  | 4% | 143.61d | 2004-03-31 | 2004-07-22 | 81d | -29d | 0d |  |
| 723 | 1.6.6.9.1 | **FM 1 (Flight Telescope)** | 12d | 2004-07-30 | 2004-08-16 |  |  |  | 2004-06-02 | 2004-06-17 | 12d | -19d | 0d |  |
| 724 | 1.6.6.9.1.1 | Disassemble SIT FM 1 | 1d | 2004-07-30 | 2004-07-30 | 742 |  |  | 2004-06-02 | 2004-06-02 | 1d | -19d | 0d |  |
| 725 | 1.6.6.9.1.2 | Conformal Coat SIT FM 1 Boards (includes FM 1 LVPS) | 2d | 2004-08-02 | 2004-08-03 | 724 |  |  | 2004-06-03 | 2004-06-04 | 2d | -19d | 0d |  |
| 726 | 1.6.6.9.1.3 | Reassemble SIT FM 1 with Flight Telescope | 1d | 2004-08-04 | 2004-08-04 | 725, 397, 363 |  |  | 2004-06-07 | 2004-06-07 | 1d | -19d | 0d |  |
| 727 | 1.6.6.9.1.4 | Bench Calibration SIT FM 1 w/Flight Telescope | 3d | 2004-08-05 | 2004-08-09 | 726 |  |  | 2004-06-08 | 2004-06-10 | 3d | -19d | 0d |  |
| 728 | 1.6.6.9.1.5 | Vacuum Test SIT FM 1 w/Flight Telescope | 5d | 2004-08-10 | 2004-08-16 | 727 |  |  | 2004-06-11 | 2004-06-17 | 5d | -19d | 0d |  |
| 729 | 1.6.6.9.2 | **FM 2** | 9d | 2004-09-13 | 2004-09-23 |  |  |  | 2004-07-12 | 2004-07-22 | 9d | -29d | 0d |  |
| 730 | 1.6.6.9.2.1 | Disassemble SIT FM 2 | 1d | 2004-09-13 | 2004-09-13 | 751 |  |  | 2004-07-12 | 2004-07-12 | 1d | -29d | 0d |  |
| 731 | 1.6.6.9.2.2 | Conformal Coat SIT FM 2 Boards | 2d | 2004-09-14 | 2004-09-15 | 730 |  |  | 2004-07-13 | 2004-07-14 | 2d | -29d | 0d |  |
| 732 | 1.6.6.9.2.3 | Reassemble SIT FM 2 | 1d | 2004-09-16 | 2004-09-16 | 731 |  |  | 2004-07-15 | 2004-07-15 | 1d | -29d | 0d |  |
| 733 | 1.6.6.9.2.4 | Post-Coat Retest SIT FM 2 | 5d | 2004-09-17 | 2004-09-23 | 732 |  |  | 2004-07-16 | 2004-07-22 | 5d | -29d | 0d |  |
| 734 | 1.6.6.9.3 | **FM 1 (ETU Telescope)** | 110d | 2004-02-25 A | 2004-07-29 |  | 10% | 99.35d | 2004-03-31 | 2004-05-21 | 38d | -19d | 0d |  |
| 735 | 1.6.6.9.3.1 | Integrate SIT FM 1 HVPS and SIT ETU Telescope Without Electronics | 3d | 2004-02-25 A | 2004-02-27 A | 715 | 100% |  | 2004-03-31 | 2004-04-02 | 3d |  |  | MS-SEP |
| 736 | 1.6.6.9.3.2 | Integrate Electronics to SIT ETU Telescope | 2d | 2004-06-21 | 2004-06-22 | 689, 657, 709, 670, 735 |  |  | 2004-04-14 | 2004-04-15 | 2d | -19d | 0d |  |
| 737 | 1.6.6.9.3.3 | SIT FM 1 Debug | 5d | 2004-06-23 | 2004-06-29 | 736 |  |  | 2004-04-16 | 2004-04-22 | 5d | -19d | 0d |  |
| 738 | 1.6.6.9.3.4 | SIT FM 1 Bench Test | 5d | 2004-06-30 | 2004-07-07 | 737 |  |  | 2004-04-23 | 2004-04-29 | 5d | -19d | 0d |  |
| 739 | 1.6.6.9.3.5 | SIT FM 1 Alpha TEST | 5d | 2004-07-08 | 2004-07-14 | 738 |  |  | 2004-04-30 | 2004-05-06 | 5d | -19d | 0d |  |
| 740 | 1.6.6.9.3.6 | SIT FM 1 Noise Removal | 5d | 2004-07-15 | 2004-07-21 | 739 |  |  | 2004-05-07 | 2004-05-13 | 5d | -19d | 0d |  |
| 741 | 1.6.6.9.3.7 | SIT FM 1 Thermal Test | 5d | 2004-07-22 | 2004-07-28 | 740 |  |  | 2004-05-14 | 2004-05-20 | 5d | -19d | 0d |  |
| 742 | 1.6.6.9.3.8 | SIT FM 1 Functional Test | 1d | 2004-07-29 | 2004-07-29 | 741, 721 |  |  | 2004-05-21 | 2004-05-21 | 1d | -19d | 0d |  |
| 743 | 1.6.6.9.4 | **FM 2** | 31d | 2004-07-29 | 2004-09-10 |  |  |  | 2004-05-19 | 2004-07-01 | 31d | -29d | 0d |  |
| 744 | 1.6.6.9.4.1 | Integrate SIT FM 2 HVPS and SIT FM 2 Telescope Without Electronics | 3d | 2004-07-29 | 2004-08-02 | 717, 397, 363 |  |  | 2004-05-19 | 2004-05-21 | 3d | -29d | 0d | MS-SEP |
| 745 | 1.6.6.9.4.2 | Integrate Electronics to SIT FM 2 Telescope | 2d | 2004-08-03 | 2004-08-04 | 691, 659, 711, 672, 744 |  |  | 2004-05-24 | 2004-05-25 | 2d | -29d | 0d |  |
| 746 | 1.6.6.9.4.3 | SIT FM 2 Debug | 5d | 2004-08-05 | 2004-08-11 | 745 |  |  | 2004-05-26 | 2004-06-02 | 5d | -29d | 0d |  |
| 747 | 1.6.6.9.4.4 | SIT FM 2 Bench Test | 5d | 2004-08-12 | 2004-08-18 | 746 |  |  | 2004-06-03 | 2004-06-09 | 5d | -29d | 0d |  |
| 748 | 1.6.6.9.4.5 | SIT FM 2 Alpha Test | 5d | 2004-08-19 | 2004-08-25 | 747 |  |  | 2004-06-10 | 2004-06-16 | 5d | -29d | 0d |  |
| 749 | 1.6.6.9.4.6 | SIT FM 2 Noise Removal | 5d | 2004-08-26 | 2004-09-01 | 748, 740 |  |  | 2004-06-17 | 2004-06-23 | 5d | -29d | 0d |  |
| 750 | 1.6.6.9.4.7 | SIT FM 2 Thermal Test | 5d | 2004-09-02 | 2004-09-09 | 749 |  |  | 2004-06-24 | 2004-06-30 | 5d | -29d | 0d |  |
| 751 | 1.6.6.9.4.8 | SIT FM 2 Functional Test | 1d | 2004-09-10 | 2004-09-10 | 750 |  |  | 2004-07-01 | 2004-07-01 | 1d | -29d | 0d |  |
| 752 | 1.6.6.10 | Integrate SIT Door FM 1 | 1d | 2004-09-23 | 2004-09-23 | 644, 410 |  |  | 2004-08-20 | 2004-08-20 | 1d | -26d | 0d |  |
| 753 | 1.6.6.11 | Integrate SIT Door FM 2 | 1d | 2004-10-20 | 2004-10-20 | 647, 752 |  |  | 2004-09-01 | 2004-09-01 | 1d | -30d | 0d |  |

| ID | WBS | Task | Duration | Start | Finish | Predecessors | Complete | Remaining | Baseline start | Baseline finish | Baseline duration | Total slack | Free slack | Constraint |
| --- | --- | --- | --- | --- | --- | --- | --- | --- | --- | --- | --- | --- | --- | --- |
| 754 | 1.6.6.12 | **Environmental Testing at GSFC (FM 1)** | 34d | 2004-09-24 | 2004-11-12 |  |  |  | 2004-07-15 | 2004-08-31 | 34d | -26d | 0d |  |
| 755 | 1.6.6.12.1 | SIT FM 1 Vibration and Acoustics | 10d | 2004-09-24 | 2004-10-07 | 644, 752 |  |  | 2004-07-15 | 2004-07-28 | 10d | -26d | 0d | start no earlier than 2004-08-23 |
| 756 | 1.6.6.12.2 | Functional Test | 1d | 2004-10-08 | 2004-10-08 | 755 |  |  | 2004-07-29 | 2004-07-29 | 1d | -26d | 0d |  |
| 757 | 1.6.6.12.3 | SIT FM 1 Thermal Balance | 5d | 2004-10-12 | 2004-10-18 | 756 |  |  | 2004-07-30 | 2004-08-05 | 5d | -26d | 0d |  |
| 758 | 1.6.6.12.4 | SIT FM 1 Thermal Vac | 10d | 2004-10-19 | 2004-11-01 | 757 |  |  | 2004-08-06 | 2004-08-19 | 10d | -26d | 0d |  |
| 759 | 1.6.6.12.5 | Disassemble SIT Instruments | 2d | 2004-11-02 | 2004-11-03 | 758 |  |  | 2004-08-20 | 2004-08-23 | 2d | -26d | 0d |  |
| 760 | 1.6.6.12.6 | Bake Out | 3d | 2004-11-04 | 2004-11-08 | 759 |  |  | 2004-08-24 | 2004-08-26 | 3d | -26d | 0d |  |
| 761 | 1.6.6.12.7 | Reassemble Instruments | 2d | 2004-11-09 | 2004-11-10 | 760 |  |  | 2004-08-27 | 2004-08-30 | 2d | -26d | 0d |  |
| 762 | 1.6.6.12.8 | Functional Test | 1d | 2004-11-12 | 2004-11-12 | 761 |  |  | 2004-08-31 | 2004-08-31 | 1d | -26d | 0d |  |
| 763 | 1.6.6.13 | **Environmental Testing at GSFC (FM 2)** | 34d | 2004-10-21 | 2004-12-09 |  |  |  | 2004-08-23 | 2004-10-08 | 34d | -30d | 0d |  |
| 764 | 1.6.6.13.1 | SIT FM 2 Vibration and Acoustics | 10d | 2004-10-21 | 2004-11-03 | 647, 753 |  |  | 2004-08-23 | 2004-09-03 | 10d | -30d | 0d | start no earlier than 2004-09-02 |
| 765 | 1.6.6.13.2 | Functional Test | 1d | 2004-11-04 | 2004-11-04 | 764 |  |  | 2004-09-07 | 2004-09-07 | 1d | -30d | 0d |  |
| 766 | 1.6.6.13.3 | SIT FM 2 Thermal Balance | 5d | 2004-11-05 | 2004-11-12 | 765 |  |  | 2004-09-08 | 2004-09-14 | 5d | -30d | 0d |  |
| 767 | 1.6.6.13.4 | SIT FM 2 Thermal Vac | 10d | 2004-11-15 | 2004-11-29 | 766 |  |  | 2004-09-15 | 2004-09-28 | 10d | -30d | 0d |  |
| 768 | 1.6.6.13.5 | Disassemble SIT Instruments | 2d | 2004-11-30 | 2004-12-01 | 767 |  |  | 2004-09-29 | 2004-09-30 | 2d | -30d | 0d |  |
| 769 | 1.6.6.13.6 | Bake Out | 3d | 2004-12-02 | 2004-12-06 | 768 |  |  | 2004-10-01 | 2004-10-05 | 3d | -30d | 0d |  |
| 770 | 1.6.6.13.7 | Reassemble Instruments | 2d | 2004-12-07 | 2004-12-08 | 769 |  |  | 2004-10-06 | 2004-10-07 | 2d | -30d | 0d |  |
| 771 | 1.6.6.13.8 | Functional Test | 1d | 2004-12-09 | 2004-12-09 | 770 |  |  | 2004-10-08 | 2004-10-08 | 1d | -30d | 0d |  |
| 772 | 1.6.6.14 | **Emulators/Simulators/GSE** | 237d | 2003-12-17 A | 2004-11-24 |  | 84% | 38.23d | 2003-12-17 | 2004-10-20 | 214d | -20d | 0d |  |
| 773 | 1.6.6.14.1 | **Simulators** | 104d | 2003-12-17 A | 2004-05-14 A |  | 100% |  | 2003-12-17 | 2004-04-12 | 80d |  |  |  |
| 774 | 1.6.6.14.1.1 | Labview CPU Ready | 104d | 2003-12-17 A | 2004-05-14 A |  | 100% |  | 2003-12-17 | 2004-04-12 | 80d |  |  | must start on 2003-12-17 |
| 775 | 1.6.6.14.1.2 | Test Simulator | 104d | 2003-12-17 A | 2004-05-14 A | 774SS | 100% |  | 2003-12-17 | 2004-04-12 | 80d |  |  |  |
| 776 | 1.6.6.14.2 | **GSE** | 40d | 2004-09-28 | 2004-11-24 |  |  |  | 2004-07-27 | 2004-10-20 | 60d | -20d | 0d |  |
| 777 | 1.6.6.14.2.1 | Pulse Generator | 40d | 2004-09-28 | 2004-11-24 | 643, 646, 775 |  |  | 2004-07-27 | 2004-10-20 | 60d | -20d | 0d |  |

| ID | WBS | Task | Duration | Start | Finish | Predecessors | Complete | Remaining | Baseline start | Baseline finish | Baseline duration | Total slack | Free slack | Constraint | Text1 |
| --- | --- | --- | --- | --- | --- | --- | --- | --- | --- | --- | --- | --- | --- | --- | --- |
| 778 | 1.6.7 | **SEP Suite I&T - CIT** | 339d | 2003-08-01 A | 2004-12-07 |  | 56% | 149.16d | 2003-08-01 | 2004-10-21 | 309d | -26d | 0d |  |  |
| 779 | 1.6.7.1 | **ETU** | 5d | 2004-01-26 A | 2004-01-30 A |  | 100% |  | 2004-01-26 | 2004-01-30 | 5d |  |  |  |  |
| 780 | 1.6.7.1.1 | Complete Integration/Test of SEP Central EM with Sensors | 5d | 2004-01-26 A | 2004-01-30 A |  | 100% |  | 2004-01-26 | 2004-01-30 | 5d |  |  | start no earlier than 2004-01-26 |  |
| 781 | 1.6.7.2 | **FM 1 & FM 2** | 44d | 2004-06-22 | 2004-08-23 |  |  |  | 2004-03-05 | 2004-10-21 | 162d | -21d | 0d |  |  |
| 782 | 1.6.7.2.1 | Generate HET integration & test procedure | 5d | 2004-06-28 | 2004-07-02 | 791FS-10d |  |  | 2004-05-20 | 2004-05-26 | 5d | -14d | 0d |  |  |
| 783 | 1.6.7.2.2 | Generate LET integration & test procedure | 5d | 2004-06-22 | 2004-06-28 | 792FS-10d |  |  | 2004-05-05 | 2004-05-11 | 5d | -9d | 0d |  |  |
| 784 | 1.6.7.2.3 | Generate SEPT integration & test procedure | 5d | 2004-08-17 | 2004-08-23 | 800FS-10d |  |  | 2004-03-05 | 2004-03-11 | 5d | -26d | 0d |  |  |
| 785 | 1.6.7.2.4 | Generate SEP-IDPU integration procedure | 5d | 2004-07-23 | 2004-07-29 | 794FS-10d |  |  | 2004-05-27 | 2004-06-03 | 5d | -14d | 0d |  |  |
| 786 | 1.6.7.2.5 | Generate SEP-IDPU test procedure | 5d | 2004-07-30 | 2004-08-05 | 785 |  |  | 2004-06-04 | 2004-06-10 | 5d | -14d | 0d |  |  |
| 787 | 1.6.7.2.6 | Generate SIT integration & test procedure | 5d | 2004-08-06 | 2004-08-12 | 798FS-10d |  |  | 2004-06-09 | 2004-06-15 | 5d | -14d | 0d |  |  |
| 788 | 1.6.7.2.7 | Generate SEP system test procedure | 5d | 2004-08-09 | 2004-08-13 | 799FS-10d |  |  | 2004-06-10 | 2004-06-16 | 5d | -19d | 0d |  |  |
| 789 | 1.6.7.3 | **FM 1** | 46d | 2004-07-01 | 2004-09-03 |  |  |  | 2004-03-18 | 2004-06-28 | 72d | -29d | 0d |  | MS-SEP |
| 790 | 1.6.7.3.1 | Integrate/test SEP Central FM 1 | 5d | 2004-07-01 | 2004-07-08 | 428, 430, 373 |  |  | 2004-05-11 | 2004-05-17 | 5d | -13d | 0d |  |  |
| 791 | 1.6.7.3.2 | Receive & inspect HET FM 1 | 1d | 2004-07-12 | 2004-07-12 | 458, 461 |  |  | 2004-06-03 | 2004-06-03 | 1d | -14d | 0d |  |  |
| 792 | 1.6.7.3.3 | Integrate & test HET FM 1 | 1d | 2004-07-06 | 2004-07-06 | 782, 790FS-4d |  |  | 2004-06-10 | 2004-06-10 | 1d | -14d | 0d |  |  |
| 793 | 1.6.7.3.4 | Integrate & test LET FM 1 | 1d | 2004-07-08 | 2004-07-08 | 792, 783, 514 |  |  | 2004-06-09 | 2004-06-09 | 1d | -15d | 0d |  |  |
| 794 | 1.6.7.3.5 | Re-integrate & test HET FM 1 w/ Flight detectors | 1d | 2004-08-05 | 2004-08-05 | 459, 834 |  |  | 2004-08-05 | 2004-08-05 | 1d | -15d | 0d |  |  |
| 795 | 1.6.7.3.6 | Re-integrate & Test LET/SEP Central FM 1 | 1d | 2004-08-05 | 2004-08-05 | 452, 420 |  |  | 2004-08-05 | 2004-08-05 | 1d | -15d | 0d |  |  |
| 796 | 1.6.7.3.7 | Integrate SEP FM 1 - IDPU FM 1 | 1d | 2004-08-30 | 2004-08-30 | 785, 349, 795 |  |  | 2004-06-11 | 2004-06-11 | 1d | -31d | 0d |  |  |
| 797 | 1.6.7.3.8 | Test SEP FM 1 - IDPU FM 1 | 1d | 2004-08-31 | 2004-08-31 | 796, 786 |  |  | 2004-06-22 | 2004-06-22 | 1d | -31d | 0d |  |  |
| 798 | 1.6.7.3.9 | Receive & inspect SIT FM 1 | 1d | 2004-08-19 | 2004-08-19 | 643 |  |  | 2004-06-22 | 2004-06-22 | 1d | -19d | 0d |  |  |
| 799 | 1.6.7.3.10 | Integrate & test SIT FM 1 | 1d | 2004-08-20 | 2004-08-20 | 798, 787 |  |  | 2004-06-23 | 2004-06-23 | 1d | -19d | 0d |  |  |
| 800 | 1.6.7.3.11 | Receive & inspect SEPT FM 1 | 1d | 2004-08-30 | 2004-08-30 | 537, 538, 794 |  |  | 2004-03-18 | 2004-03-18 | 1d | -31d | 0d |  |  |
| 801 | 1.6.7.3.12 | Integrate & test SEPT FM 1 | 1d | 2004-08-31 | 2004-08-31 | 800, 784 |  |  | 2004-05-18 | 2004-05-18 | 1d | -31d | 0d |  |  |
| 802 | 1.6.7.3.13 | SEP system test FM 1 | 3d | 2004-09-01 | 2004-09-03 | 425, 788, 801, 797 |  |  | 2004-06-24 | 2004-06-28 | 3d | -31d | 0d |  |  |

| ID | WBS | Task | Duration | Start | Finish | Predecessors | Baseline start | Baseline finish | Baseline duration | Total slack | Free slack | Constraint | Text1 |
| --- | --- | --- | --- | --- | --- | --- | --- | --- | --- | --- | --- | --- | --- |
| 803 | 1.6.7.4 | **FM 2** | 68d | 2004-07-08 | 2004-10-13 |  | 2004-03-29 | 2004-08-11 | 97d | -35d | 0d |  | MS-SEP |
| 804 | 1.6.7.4.1 | Receive & inspect HET FM 2 | 1d | 2004-07-21 | 2004-07-21 | 460 | 2004-06-24 | 2004-06-24 | 1d | 11d | 0d |  |  |
| 805 | 1.6.7.4.2 | Integrate & test HET FM 2 | 1d | 2004-07-22 | 2004-07-22 | 804, 782 | 2004-06-25 | 2004-06-25 | 1d | 11d | 2d |  |  |
| 806 | 1.6.7.4.3 | Integrate & test LET FM 2 | 1d | 2004-07-08 | 2004-07-08 | 515, 516, 783 | 2004-06-09 | 2004-06-09 | 1d | -15d | 0d |  |  |
| 807 | 1.6.7.4.4 | Integrate/testSEP Central FM 2 | 5d | 2004-07-27 | 2004-08-02 | 429, 430, 373, 806, 805 | 2004-05-11 | 2004-05-17 | 5d | 9d |  |  |  |
| 808 | 1.6.7.4.5 | Re-integrate HET FM 2 after Confromal Coating | 1d | 2004-08-05 | 2004-08-05 | 459 | 2004-08-05 | 2004-08-05 | 1d | 5d |  |  |  |
| 809 | 1.6.7.4.6 | Receive & inspect SEPT FM 2 | 1d | 2004-08-30 | 2004-08-30 | 540, 541, 808 | 2004-03-29 | 2004-03-29 | 1d | -11d | 0d |  |  |
| 810 | 1.6.7.4.7 | Integrate & test SEPT FM 2 | 1d | 2004-08-31 | 2004-08-31 | 809, 807, 784 | 2004-05-18 | 2004-05-18 | 1d | -11d | 0d |  |  |
| 811 | 1.6.7.4.8 | Integrate SEP FM 2 - IDPU FM 2 | 1d | 2004-10-06 | 2004-10-06 | 161, 785 | 2004-06-28 | 2004-06-28 | 1d | -35d | 0d |  |  |
| 812 | 1.6.7.4.9 | Test SEP FM 2 - IDPU FM 2 | 1d | 2004-10-07 | 2004-10-07 | 811, 786 | 2004-06-29 | 2004-06-29 | 1d | -35d | 0d |  |  |
| 813 | 1.6.7.4.10 | Receive & inspect SIT FM 2 | 1d | 2004-09-28 | 2004-09-28 | 646, 810 | 2004-07-27 | 2004-07-27 | 1d | -29d | 0d |  |  |
| 814 | 1.6.7.4.11 | Integrate & test SIT FM 2 | 1d | 2004-09-29 | 2004-09-29 | 813, 787 | 2004-08-06 | 2004-08-06 | 1d | -29d | 0d |  |  |
| 815 | 1.6.7.4.12 | SEP FM 2 system test | 3d | 2004-10-08 | 2004-10-13 | 814, 788, 812 | 2004-08-09 | 2004-08-11 | 3d | -35d | 0d |  |  |
| 816 | 1.6.7.5 | **Environmental Test (at JPL)** | 141d | 2004-05-17 | 2004-12-07 |  | 2004-05-17 | 2004-09-24 | 93d | -26d | 0d |  |  |
| 817 | 1.6.7.5.1 | Generate Environmental Test Procedures | 15d | 2004-05-17 | 2004-06-07 |  | 2004-05-17 | 2004-06-07 | 15d | 45d |  | start no earlier than 2004-05-17 |  |
| 818 | 1.6.7.5.2 | Manufacture test cables (JPL) | 20d | 2004-06-01 | 2004-06-28 |  | 2004-06-01 | 2004-06-28 | 20d | 30d |  | start no earlier than 2004-06-01 |  |
| 819 | 1.6.7.5.3 | **FM 1** | 41d | 2004-09-23 | 2004-11-22 |  | 2004-07-23 | 2004-09-24 | 45d | -30d | 0d |  |  |
| 820 | 1.6.7.5.3.1 | FM 1 LET/HET/SEP Central Vibration/Acoustics Test | 10d | 2004-09-24 | 2004-10-07 | 19FS+3d, 817, 818, 834FS+3d | 2004-07-23 | 2004-08-05 | 10d | -31d | 0d |  |  |
| 821 | 1.6.7.5.3.2 | FM 1 LET/HET/SEP Central Thermal Balance Test | 5d | 2004-10-08 | 2004-10-15 | 820 | 2004-08-06 | 2004-08-12 | 5d | -31d | 0d |  |  |
| 822 | 1.6.7.5.3.3 | FM 1 LET/HET/SEP Central T/V Test | 15d | 2004-10-18 | 2004-11-05 | 821, 827 | 2004-08-19 | 2004-09-09 | 15d | -31d | 0d |  |  |
| 823 | 1.6.7.5.3.4 | Evaluate SEP performance | 10d | 2004-11-08 | 2004-11-22 | 822 | 2004-09-10 | 2004-09-23 | 10d | -31d | 0d |  |  |
| 824 | 1.6.7.5.3.5 | Generate test reports | 11d | 2004-09-23 | 2004-10-07 | 823SS | 2004-09-10 | 2004-09-24 | 11d | -31d | 0d | finish no later than 2004-10-07 |  |
| 825 | 1.6.7.5.3.6 | Bakeout Clean SEP exterior & prepare for delivery | 3d | 2004-11-08 | 2004-11-10 | 822 | 2004-09-10 | 2004-09-14 | 3d | -24d | 0d |  |  |
| 826 | 1.6.7.5.4 | **FM 2** | 37d | 2004-10-14 | 2004-12-07 |  | 2004-07-23 | 2004-09-24 | 45d | -35d | 0d |  |  |
| 827 | 1.6.7.5.4.1 | FM 2 EMI/EMC Test at CalTech | 2d | 2004-10-14 | 2004-10-15 | 815 | 2004-08-12 | 2004-08-18 | 5d | -35d | 0d |  | MS-SEP |
| 828 | 1.6.7.5.4.2 | FM 2 LET/HET/SEP Central Vibration/Acoustics Test | 10d | 2004-10-18 | 2004-10-29 | 827 | 2004-07-23 | 2004-08-05 | 10d | -27d | 0d |  |  |
| 829 | 1.6.7.5.4.3 | FM 2 LET/HET/SEP Central T/V Test | 15d | 2004-11-01 | 2004-11-22 | 827, 828 | 2004-08-19 | 2004-09-09 | 15d | -27d | 0d |  |  |
| 830 | 1.6.7.5.4.4 | Evaluate SEP performance | 10d | 2004-11-23 | 2004-12-07 | 829 | 2004-09-10 | 2004-09-23 | 10d | -27d | 0d |  |  |
| 831 | 1.6.7.5.4.5 | Generate test reports | 11d | 2004-10-14 | 2004-10-28 | 830SS | 2004-09-10 | 2004-09-24 | 11d | -27d | 0d | finish no later than 2004-10-28 |  |
| 832 | 1.6.7.5.4.6 | Bakeout Clean SEP exterior & prepare for delivery | 3d | 2004-11-23 | 2004-11-26 | 829 | 2004-09-10 | 2004-09-14 | 3d | -20d | 0d |  |  |

| ID | WBS | Task | Type | Duration | Start | Finish | Predecessors | Complete | Remaining | Baseline start | Baseline finish | Baseline duration | Total slack | Free slack | Constraint | Calendar |
| --- | --- | --- | --- | --- | --- | --- | --- | --- | --- | --- | --- | --- | --- | --- | --- | --- |
| 833 | 1.6.7.6 | **Accelerator Test (at MSU)** |  | 4d | 2004-07-10 | 2004-07-15 |  |  |  | 2004-07-13 | 2004-07-19 | 5d | -16d | 0d |  |  |
| 834 | 1.6.7.6.1 | FM 1 LET-HET/SEP Cen end-to-end test at Accelerator |  | 3d | 2004-07-10 | 2004-07-12 | 845, 404, 793 |  |  | 2004-07-13 | 2004-07-19 | 5d | -17d | 0d | start no earlier than 2004-07-10 | Weekend |
| 835 | 1.6.7.6.2 | FM 2 LET/SEP Cen end-to-end test at Accelerator |  | 3d | 2004-07-10 | 2004-07-12 | 845, 806 |  |  | 2004-07-13 | 2004-07-19 | 5d | -17d | 0d | start no earlier than 2004-07-10 | Weekend |
| 836 | 1.6.7.6.3 | **Continue I&T for HET, LET and SEP Cen** |  | 3d | 2004-07-13 | 2004-07-15 | 835 |  |  | 2004-07-12 | 2004-07-12 | 1d | -14d | 0d |  |  |
| 837 | 1.6.7.6.3.1 | Detach HET LET and SEP Cen from SEP Suite |  | 1d | 2004-07-13 | 2004-07-13 | 834 |  |  | 2004-07-12 | 2004-07-12 | 1d | -14d | 0d |  |  |
| 838 | 1.6.7.6.3.2 | Deliver HET FM 1 (Rplcmnt Detectors and Conformal Coating @ GSFC) |  | 2d | 2004-07-14 | 2004-07-15 | 837 |  |  | 2004-07-13 | 2004-07-14 | 2d | -13d | 0d |  |  |
| 839 | 1.6.7.6.3.3 | Deliver LET and SEP Central (Conformal Coating @ CIT) | milestone | 0d | 2004-07-13 | 2004-07-13 | 837 |  |  | 2004-07-13 | 2004-07-13 | 0d | -14d | 0d |  |  |
| 840 | 1.6.7.6.3.4 | Deliver HET FM 2 (Conformal Coating @ GSFC) |  | 2d | 2004-07-14 | 2004-07-15 | 837, 835 |  |  | 2004-07-13 | 2004-07-14 | 2d | -13d | 0d |  |  |
| 841 | 1.6.7.7 | **GSE** |  | 305d | 2003-08-01 A | 2004-10-18 |  | 77% | 71.52d | 2003-08-01 | 2004-10-15 | 305d | 8d |  |  |  |
| 842 | 1.6.7.7.1 | **End-to-End Test Equipment** |  | 218d | 2003-08-11 A | 2004-06-22 |  | 97% | 7d | 2003-08-11 | 2004-06-22 | 218d | -4d | 0d |  |  |
| 843 | 1.6.7.7.1.1 | Design |  | 192d | 2003-08-11 A | 2004-05-14 A |  | 100% |  | 2003-08-11 | 2004-05-14 | 192d |  |  | start no earlier than 2003-08-11 |  |
| 844 | 1.6.7.7.1.2 | Assemble |  | 21d | 2004-05-17 A | 2004-06-15 | 843 | 90% | 2d | 2004-05-17 | 2004-06-15 | 21d | -4d | 0d |  |  |
| 845 | 1.6.7.7.1.3 | Test |  | 5d | 2004-06-16 | 2004-06-22 | 844 |  |  | 2004-06-16 | 2004-06-22 | 5d | -4d | 0d |  |  |
| 846 | 1.6.7.7.2 | **GSE software** |  | 305d | 2003-08-01 A | 2004-10-18 |  | 65% | 107.03d | 2003-08-01 | 2004-10-15 | 305d | 8d |  |  |  |
| 847 | 1.6.7.7.2.1 | Build GSE software release 2 |  | 232d | 2003-08-01 A | 2004-07-02 |  | 94% | 15d | 2003-08-01 | 2004-03-18 | 157d | 0d |  | must start on 2003-08-01 |  |
| 848 | 1.6.7.7.2.2 | Write user's guide |  | 10d | 2004-06-21 | 2004-07-02 | 847FS-10d |  |  | 2004-03-22 | 2004-03-31 | 8d | 38d | 0d | start no earlier than 2004-03-22 |  |
| 849 | 1.6.7.7.2.3 | Build GSE software release 3 |  | 117d | 2004-05-03 A | 2004-10-18 | 848FS-45d | 25% | 88d | 2004-05-03 | 2004-10-15 | 117d | 8d | 0d | start no earlier than 2004-05-03 |  |
| 850 | 1.6.7.7.2.4 | Write user's guide supplement |  | 20d | 2004-09-20 | 2004-10-18 | 849FS-20d |  |  | 2004-09-15 | 2004-10-15 | 22d | 8d |  | finish no later than 2004-10-28 |  |
| 851 | 1.7 | **SWEA and SIT Refurbishment (after S/C Environmental Testing)** |  | 40d | 2005-09-27 | 2005-11-21 |  |  |  | 2005-09-27 | 2005-11-18 | 39d | 0d |  |  |  |
| 852 | 1.7.1 | Ship SWEA FM 1 to UCB |  | 3d | 2005-09-27 | 2005-09-29 |  |  |  | 2005-09-27 | 2005-09-29 | 3d | 25d | 0d | start no earlier than 2005-09-27 |  |
| 853 | 1.7.2 | Ship (Hand Carry) SIT FM 1 to UMD |  | 1d | 2005-09-27 | 2005-09-27 |  |  |  | 2005-09-27 | 2005-09-27 | 1d | 27d | 0d | start no earlier than 2005-09-27 |  |
| 854 | 1.7.3 | Ship SWEA FM 2 to UCB |  | 3d | 2005-10-04 | 2005-10-06 |  |  |  | 2005-10-04 | 2005-10-06 | 3d | 20d | 0d | start no earlier than 2005-10-04 |  |
| 855 | 1.7.4 | Ship (Hand Carry) SIT FM 2 to UMD |  | 1d | 2005-10-04 | 2005-10-04 |  |  |  | 2005-10-04 | 2005-10-04 | 1d | 22d | 0d | start no earlier than 2005-10-04 |  |
| 856 | 1.7.5 | Vacuum Testing of SWEA FM 1 @ UCB |  | 5d | 2005-09-30 | 2005-10-06 | 852 |  |  | 2005-09-30 | 2005-10-06 | 5d | 25d | 5d |  |  |
| 857 | 1.7.6 | Vacuum Testing of SIT FM 1 @ UMD |  | 5d | 2005-09-28 | 2005-10-04 | 853 |  |  | 2005-09-28 | 2005-10-04 | 5d | 27d | 5d |  |  |
| 858 | 1.7.7 | Vacuum Testing of SWEA FM 2 @ UCB |  | 5d | 2005-10-07 | 2005-10-13 | 854 |  |  | 2005-10-07 | 2005-10-13 | 5d | 20d | 0d |  |  |
| 859 | 1.7.8 | Vacuum Testing of SIT FM 2 @ UMD |  | 5d | 2005-10-05 | 2005-10-11 | 855 |  |  | 2005-10-05 | 2005-10-11 | 5d | 22d | 0d |  |  |
| 860 | 1.7.9 | Ship SWEA FM 1 & 2 to Launch Site for Re-integration to S/C |  | 3d | 2005-10-14 | 2005-10-18 | 856, 858 |  |  | 2005-10-07 | 2005-10-11 | 3d | 20d | 0d |  |  |
| 861 | 1.7.10 | Ship SIT FM 1 & 2 to Launch Site for Re-integration to S/C |  | 3d | 2005-10-12 | 2005-10-14 | 857, 859 |  |  | 2005-10-05 | 2005-10-07 | 3d | 22d | 2d |  |  |
| 862 | 1.7.11 | Reintegration of SWEA and SIT to S/C (at Launch Site) |  | 3d | 2005-10-19 | 2005-10-21 | 860, 861 |  |  | 2005-10-12 | 2005-10-14 | 3d | 20d |  |  |  |
| 863 | 1.7.12 | Target Date for Reintegration to S/C |  | 1d | 2005-11-19 | 2005-11-21 | 862 |  |  | 2005-11-18 | 2005-11-18 | 1d | 0d |  | must start on 2005-11-19 |  |
