# IMPACT Master Schedule

Schedule from MS Project, 2003-02-26 to 2005-11-21, status date 2004-04-30, A marks actual dates.
IMPACT Instrument Suites
NASA GSFC - STEREO
This is the IMPACT Consolidated Schedule. Creation began in October 2003 and was then put on hold and subsequently completed in January 2004. Completed tasks, redundant milestones, contingency blocks and obsolete tasks were deleted from this schedule. / Schedule was baselined on 2/18/04 with status through January 31, 2004. / Maintenance of this Schedule was transferred from Jim Rodgers to Tabitha Merchant on 03/22/04

## Calendars

- Standard: Mon-Fri 08:00-12:00, 13:00-17:00; Sat-Sun off. Exceptions (off unless hours are given): 2003-05-26, 2003-07-04, 2003-09-01, 2003-10-13, 2003-11-11, 2003-11-27, 2003-12-25, 2004-01-01, 2004-01-19, 2004-02-16, 2004-05-31, 2004-07-05, 2004-09-06, 2004-10-11, 2004-11-11, 2004-11-25.
- Boom Test Calendar: Mon-Fri 08:00-12:00, 13:00-17:00; Sat-Sun off. Exceptions (off unless hours are given): 2003-05-26, 2003-07-04, 2003-09-01, 2003-10-13, 2003-11-11, 2003-11-27, 2003-12-25, 2004-01-01, 2004-01-19, 2004-02-16, 2004-02-28 to 2004-02-29 08:00-12:00, 13:00-17:00, 2004-03-06 to 2004-03-07 08:00-12:00, 13:00-17:00, 2004-05-31, 2004-09-06, 2004-10-11, 2004-11-11, 2004-11-25.
- Weekend: Mon-Fri 08:00-12:00, 13:00-17:00; Sat-Sun off. Exceptions (off unless hours are given): 2004-07-10 to 2004-07-11 08:00-12:00, 13:00-17:00.

## Schedule

| ID | WBS | Task | Type | Duration | Start | Finish | Predecessors | Complete | Remaining | Baseline start | Baseline finish | Baseline duration | Total slack | Free slack | Constraint | Text1 |
| --- | --- | --- | --- | --- | --- | --- | --- | --- | --- | --- | --- | --- | --- | --- | --- | --- |
| 1 | 1 | **IMPACT - Dave Curtis (UCB) & Lil Reichenthal (GSFC)** |  | 698d | 2003-02-26 A | 2005-11-21 |  | 69% | 213.06d | 2003-02-26 | 2005-11-18 | 698d | 0d |  |  |  |
| 2 | 1.1 | **Suite Deliveries to APL** |  | 40d | 2004-10-04 | 2004-12-02 |  |  |  | 2004-08-13 | 2004-10-28 | 51d | -24d | 0d |  |  |
| 3 | 1.1.1 | FM 1 Target Delivery Date | milestone | 0d | 2004-10-07 | 2004-10-07 | 5, 7 |  |  | 2004-10-07 | 2004-10-07 | 0d | -18d | 0d | must start on 2004-10-07 | MS-BOOM |
| 4 | 1.1.2 | FM 2 Target Delivery Date | milestone | 0d | 2004-10-28 | 2004-10-28 | 8, 6 |  |  | 2004-10-28 | 2004-10-28 | 0d | -24d | 0d | must start on 2004-10-28 | MS-BOOM |
| 5 | 1.1.3 | Boom Suite FM 1 Ready for Delivery to APL | milestone | 0d | 2004-10-04 | 2004-10-04 | 352 |  |  | 2004-08-13 | 2004-08-13 | 0d | 2d |  |  | MS-BOOM |
| 6 | 1.1.4 | Boom Suite FM 2 Ready for Delivery to APL | milestone | 0d | 2004-10-15 | 2004-10-15 | 358 |  |  | 2004-09-28 | 2004-09-28 | 0d | 8d |  |  | MS-BOOM |
| 7 | 1.1.5 | SEP Suite FM 1 Ready for Delivery to APL | milestone | 0d | 2004-11-02 | 2004-11-02 | 790, 612, 531 |  |  | 2004-09-14 | 2004-09-14 | 0d | -18d | 0d |  | MS-SEP |
| 8 | 1.1.6 | SEP Suite FM 2 Ready for Delivery to APL | milestone | 0d | 2004-12-02 | 2004-12-02 | 797, 615 |  |  | 2004-10-12 | 2004-10-12 | 0d | -24d | 0d |  | MS-SEP |
| 9 | 1.2 | **Environmental Testing - PER, Impact Suite EMC, Snapshots of Boom & SEP Suite Test Flows** |  | 290d | 2003-10-01 A | 2004-11-26 |  | 13% | 253.64d | 2004-01-14 | 2004-10-05 | 186d | 256d |  |  |  |
| 10 | 1.2.1 | **Reviews (PER and TRR's) - TRR Dates are Tentative** |  | 164d | 2004-01-14 A | 2004-09-03 |  | 50% | 82d | 2004-01-14 | 2004-07-08 | 124d | 312d |  |  |  |
| 11 | 1.2.1.1 | Instrument PER at UCB |  | 1d | 2004-01-14 A | 2004-01-14 A |  | 100% |  | 2004-01-14 | 2004-01-14 | 1d |  |  | start no earlier than 2004-01-14 |  |
| 12 | 1.2.1.2 | TRR 1 - Prior to FM 1 SEPT Thermal Vac |  | 1d | 2004-02-13 A | 2004-02-13 A | 39SS-6d | 100% |  | 2004-02-13 | 2004-02-13 | 1d |  |  |  |  |
| 13 | 1.2.1.3 | TRR 2 - Prior to FM 1 STE-U Thermal Vac/Thermal Balance |  | 1d | 2004-04-19 A | 2004-04-19 A | 21SS-6d | 100% |  | 2004-03-25 | 2004-03-25 | 1d |  |  | start no earlier than 2004-04-19 |  |
| 14 | 1.2.1.4 | TRR 3 - Prior to FM 1 Boom Structure Vibration |  | 1d | 2004-04-19 A | 2004-04-19 A | 22SS-19d | 100% |  | 2004-04-20 | 2004-04-20 | 1d |  |  |  |  |
| 15 | 1.2.1.5 | TRR 4 - Prior to FM 1 IDPU Vibration |  | 1d | 2004-06-03 | 2004-06-03 | 23SS-5d |  |  | 2004-04-26 | 2004-04-26 | 1d | 377d |  |  |  |
| 16 | 1.2.1.6 | TRR 5 - Prior to FM 1 SWEA Vibration |  | 1d | 2004-07-28 | 2004-07-28 | 26SS-5d |  |  | 2004-05-28 | 2004-05-28 | 1d | 339d |  |  |  |
| 17 | 1.2.1.7 | TRR 6 - Prior to FM 1 Impact Suite EMC (for Boom and SEP) |  | 1d | 2004-08-17 | 2004-08-17 | 19SS-5d |  |  | 2004-06-22 | 2004-06-22 | 1d | 325d |  |  |  |
| 18 | 1.2.1.8 | TRR 7 - Prior to FM 1 SIT Vibration |  | 1d | 2004-09-03 | 2004-09-03 | 43SS-5d |  |  | 2004-07-08 | 2004-07-08 | 1d | 312d |  |  |  |
| 19 | 1.2.2 | IMPACT Suite FM 1 EMC Testing at UCB |  | 10d | 2004-08-24 | 2004-09-07 | 351, 768, 423 |  |  | 2004-06-29 | 2004-07-12 | 10d | -22d | 0d |  | MS-BOOM |
| 20 | 1.2.3 | **Boom Suite FM 1 Environmental Test Flow Snapshot - UCB** |  | 108d | 2004-04-26 A | 2004-09-27 |  | 7% | 99.94d | 2004-04-01 | 2004-07-30 | 86d | 297d |  |  |  |
| 21 | 1.2.3.1 | STE-U Thermal Vac/Thermal Balance/Bake Out |  | 14d | 2004-04-26 A | 2004-05-13 | 271SS | 36% | 9d | 2004-04-01 | 2004-04-20 | 14d | 391d | 0d |  |  |
| 22 | 1.2.3.2 | Boom Structure Vibration |  | 4d | 2004-06-07 | 2004-06-10 | 211SS |  |  | 2004-04-27 | 2004-04-30 | 4d | 372d | 0d |  |  |
| 23 | 1.2.3.3 | IDPU Vibration |  | 5d | 2004-06-10 | 2004-06-16 | 174SS |  |  | 2004-05-03 | 2004-05-07 | 5d | 368d | 0d |  |  |
| 24 | 1.2.3.4 | Boom Structure Thermal Vac & Bake Out |  | 15d | 2004-06-11 | 2004-07-01 | 212SS |  |  | 2004-05-03 | 2004-05-21 | 15d | 357d |  |  |  |
| 25 | 1.2.3.5 | IDPU Thermal Vac & Bake Out |  | 10d | 2004-06-17 | 2004-06-30 | 175SS |  |  | 2004-05-10 | 2004-05-21 | 10d | 358d |  |  |  |
| 26 | 1.2.3.6 | SWEA/STE Vibration |  | 5d | 2004-08-04 | 2004-08-10 | 337SS |  |  | 2004-06-07 | 2004-06-11 | 5d | 330d | 0d |  |  |
| 27 | 1.2.3.7 | SWEA/STE Thermal Vac/Thermal Balance/Bake Out |  | 14d | 2004-09-08 | 2004-09-27 | 338SS |  |  | 2004-07-13 | 2004-07-30 | 14d | 297d |  |  |  |

Notes:
- 1: This is the new IMPACT Consolidated Schedule. Creation began in October 2003 and was then put on hold and subsequently completed in January 2004. Completed tasks, redundant milestones, contingency blocks and obsolete tasks were deleted from this schedule. / Schedule was baselined on 2/18/04 with status through January 31, 2004.
- 7: The SEPT (FM 1) and SIT (FM 1 & 2) instruments are being delivered directly to APL after their environmental testing at GSFC and seperate from the other SEP Suite instruments (SEP Central, LET and HET).
- 8: The SEPT (FM 1) and SIT (FM 1 & 2) instruments are being delivered directly to APL after their environmental testing at GSFC and seperate from the other SEP Suite instruments (SEP Central, LET and HET).
- 11: This is the initial IMPACT PER. Additional TRR's (Test Readiness Reviews) will be scheduled and held as the suite instruments become ready for their environmental testing.
- 20: This section is a "snapshot" of the environmental test flow for the FM 1 Boom Suite. It reflects the details of the testing activities found within the body of the schedule. It was placed in the schedule to allow someone to get a quick look at the test flow and the associated dates. The tasks contained within this section are not tied to any other activities (and do not drive any other activities) and so therefore you will see large float values associated with them. It is simply a quick look at the test flow so that one does not have to filter through the schedule to locate the environmental test activities.

| ID | WBS | Task | Duration | Start | Finish | Predecessors | Complete | Remaining | Baseline start | Baseline finish | Baseline duration | Total slack | Free slack | Calendar |
| --- | --- | --- | --- | --- | --- | --- | --- | --- | --- | --- | --- | --- | --- | --- |
| 28 | 1.2.4 | **Boom Suite FM 2 Environmental Test Flow Snapshot - UCB** | 73d | 2004-06-25 | 2004-10-07 |  |  |  | 2004-04-27 | 2004-09-14 | 99d | 289d |  |  |
| 29 | 1.2.4.1 | STE-U Thermal Vac/Bake Out | 10d | 2004-06-25 | 2004-07-09 | 279SS |  |  | 2004-04-27 | 2004-05-10 | 10d | 352d |  |  |
| 30 | 1.2.4.2 | IDPU Vibration | 5d | 2004-07-23 | 2004-07-29 | 178SS |  |  | 2004-05-10 | 2004-05-14 | 5d | 338d |  |  |
| 31 | 1.2.4.3 | Boom Structure Vibration | 4d | 2004-07-23 | 2004-07-28 | 233SS |  |  | 2004-05-17 | 2004-05-20 | 4d | 339d |  |  |
| 32 | 1.2.4.4 | IDPU Thermal Vac & Bake Out | 10d | 2004-07-30 | 2004-08-12 | 179SS |  |  | 2004-05-17 | 2004-05-28 | 10d | 328d |  |  |
| 33 | 1.2.4.5 | Boom Structure Thermal Vac & Bake Out | 15d | 2004-07-29 | 2004-08-18 | 234SS |  |  | 2004-05-24 | 2004-06-14 | 15d | 324d |  |  |
| 34 | 1.2.4.6 | SWEA/STE Vibration | 5d | 2004-09-01 | 2004-09-08 | 345SS |  |  | 2004-08-09 | 2004-08-13 | 5d | 310d |  |  |
| 35 | 1.2.4.7 | SWEA/STE Thermal Vac & Bake Out | 10d | 2004-09-09 | 2004-09-22 | 346SS |  |  | 2004-08-16 | 2004-08-27 | 10d | 300d |  |  |
| 36 | 1.2.4.8 | Boom Suite FM 2 EMC | 5d | 2004-10-01 | 2004-10-07 | 357SS |  |  | 2004-09-08 | 2004-09-14 | 5d | 289d |  |  |
| 37 | 1.2.5 | **SEP Suite FM 1 Environmental Test Flow Snapshot** | 180d | 2004-02-19 A | 2004-11-02 |  | 19% | 146.37d | 2004-02-17 | 2004-09-14 | 149d | 272d |  |  |
| 38 | 1.2.5.1 | SEPT (NS & E) Vibration (in Europe) | 4d | 2004-02-19 A | 2004-02-24 A | 568SS | 100% |  | 2004-02-17 | 2004-02-24 | 8d |  |  |  |
| 39 | 1.2.5.2 | SEPT (NS & E) Thermal Vac (in Europe) | 11d | 2004-02-27 A | 2004-03-12 A | 569SS, 580SS | 100% |  | 2004-02-25 | 2004-03-08 | 9d |  |  |  |
| 40 | 1.2.5.3 | SEPT (NS & E) Bake Out (in Europe) | 2d | 2004-03-05 A | 2004-03-08 A | 570SS, 581SS | 100% |  | 2004-03-09 | 2004-03-10 | 2d |  |  |  |
| 41 | 1.2.5.4 | SEPT (NS & E) Thermal Balance (at GSFC) | 10d | 2004-09-08 | 2004-09-21 | 575SS, 586SS |  |  | 2004-07-13 | 2004-07-26 | 10d | 301d |  |  |
| 42 | 1.2.5.5 | LET/HET/SEP Cen Accelerator Test (at MSU) | 3d | 2004-07-10 | 2004-07-12 | 799SS |  |  | 2004-07-13 | 2004-07-27 | 11d | 355d |  | Weekend |
| 43 | 1.2.5.6 | SIT Vibe and Acoustics (at GSFC) | 10d | 2004-09-13 | 2004-09-24 | 722SS |  |  | 2004-07-15 | 2004-07-28 | 10d | 298d | 0d |  |
| 44 | 1.2.5.7 | LET/HET/SEP Cen Vibe and Acoustics (at JPL) | 10d | 2004-09-13 | 2004-09-24 | 785SS |  |  | 2004-07-23 | 2004-08-05 | 10d | 298d |  |  |
| 45 | 1.2.5.8 | SIT Thermal Balance (at GSFC) | 5d | 2004-09-28 | 2004-10-04 | 724SS |  |  | 2004-07-30 | 2004-08-05 | 5d | 292d |  |  |
| 46 | 1.2.5.9 | LET/HET/SEP Cen Thermal Balance (at JPL) | 5d | 2004-09-27 | 2004-10-01 | 786SS |  |  | 2004-08-06 | 2004-08-12 | 5d | 293d |  |  |
| 47 | 1.2.5.10 | SIT Thermal Vac (at GSFC) | 10d | 2004-10-05 | 2004-10-19 | 725SS |  |  | 2004-08-06 | 2004-08-19 | 10d | 282d |  |  |
| 48 | 1.2.5.11 | LET/HET/SEP Cen Thermal Vac (at JPL) | 15d | 2004-10-07 | 2004-10-28 | 787SS |  |  | 2004-08-19 | 2004-09-09 | 15d | 275d |  |  |
| 49 | 1.2.5.12 | SIT Bake Out (at GSFC) | 3d | 2004-10-22 | 2004-10-26 | 727SS |  |  | 2004-08-24 | 2004-08-26 | 3d | 277d |  |  |
| 50 | 1.2.5.13 | LET/HET/SEP Cen Bake Out (at JPL) | 3d | 2004-10-29 | 2004-11-02 | 790SS |  |  | 2004-09-10 | 2004-09-14 | 3d | 272d |  |  |
| 51 | 1.2.6 | **SEP Suite FM 2 Environmental Test Flow Snapshot** | 290d | 2003-10-01 A | 2004-11-26 |  | 17% | 240d | 2004-02-17 | 2004-10-05 | 164d | 256d |  |  |
| 52 | 1.2.6.1 | SEPT (NS & E) Vibe and Acoustics (in Europe) | 4d | 2004-02-19 A | 2004-02-24 A | 591SS | 100% |  | 2004-02-17 | 2004-02-24 | 8d |  |  |  |
| 53 | 1.2.6.2 | SEPT (NS & E) Thermal Vac (in Europe) | 9d | 2004-03-05 A | 2004-03-17 A | 592SS, 602SS | 100% |  | 2004-03-09 | 2004-03-17 | 9d |  |  |  |
| 54 | 1.2.6.3 | SEPT (NS & E) Bake Out (in Europe) | 2d | 2004-03-12 A | 2004-03-15 A | 593SS, 603SS | 100% |  | 2004-03-18 | 2004-03-19 | 2d |  |  |  |
| 55 | 1.2.6.4 | LET/HET/SEP Cen Accelerator Test (at MSU) | 11d | 2003-10-01 | 2003-10-16 |  |  |  | 2004-07-13 | 2004-07-27 | 11d | 535d |  |  |
| 56 | 1.2.6.5 | LET/HET/SEP Cen Vibe and Acoustics (at JPL) | 10d | 2004-10-07 | 2004-10-21 | 793SS |  |  | 2004-07-23 | 2004-08-05 | 10d | 280d |  |  |
| 57 | 1.2.6.6 | SEP Suite FM 2 EMC (at Caltech) | 5d | 2004-10-05 | 2004-10-12 | 792SS |  |  | 2004-08-12 | 2004-08-18 | 5d | 287d |  |  |
| 58 | 1.2.6.7 | LET/HET/SEP Cen Thermal Vac (at JPL) | 15d | 2004-10-22 | 2004-11-12 | 794SS |  |  | 2004-08-19 | 2004-09-09 | 15d | 265d |  |  |
| 59 | 1.2.6.8 | SIT Vibe and Acoustics (at GSFC) | 10d | 2004-10-13 | 2004-10-26 | 731SS |  |  | 2004-08-23 | 2004-09-03 | 10d | 277d |  |  |
| 60 | 1.2.6.9 | SIT Thermal Balance (at GSFC) | 5d | 2004-10-28 | 2004-11-03 | 733SS |  |  | 2004-09-08 | 2004-09-14 | 5d | 271d |  |  |
| 61 | 1.2.6.10 | LET/HET/SEP Cen Bake Out (at JPL) | 3d | 2004-11-15 | 2004-11-17 | 797SS |  |  | 2004-09-10 | 2004-09-14 | 3d | 262d |  |  |
| 62 | 1.2.6.11 | SIT Thermal Vac (at GSFC) | 10d | 2004-11-04 | 2004-11-18 | 734SS |  |  | 2004-09-15 | 2004-09-28 | 10d | 261d |  |  |
| 63 | 1.2.6.12 | SIT Bake Out (at GSFC) | 3d | 2004-11-23 | 2004-11-26 | 736SS |  |  | 2004-10-01 | 2004-10-05 | 3d | 256d |  |  |

Notes:
- 28: This section is a "snapshot" of the environmental test flow for the FM 2 Boom Suite. It reflects the details of the testing activities found within the body of the schedule. It was placed in the schedule to allow someone to get a quick look at the test flow and the associated dates. The tasks contained within this section are not tied to any other activities (and do not drive any other activities) and so therefore you will see large float values associated with them. It is simply a quick look at the test flow so that one does not have to filter through the schedule to locate the environmental test activities.
- 37: This section is a "snapshot" of the environmental test flow for the FM 1 SEP Suite. It reflects the details of the testing activities found within the body of the schedule. It was placed in the schedule to allow someone to get a quick look at the test flow and the associated dates. The tasks contained within this section are not tied to any other activities (and do not drive any other activities) and so therefore you will see large float values associated with them. It is simply a quick look at the test flow so that one does not have to filter through the schedule to locate the environmental test activities.
- 38: There was a failure on the SEPT door during Vibration Test. Vibration Test will be repeated once the fix to the door is implemented. Time and place is TBD.
- 51: This section is a "snapshot" of the environmental test flow for the FM 2 SEP Suite. It reflects the details of the testing activities found within the body of the schedule. It was placed in the schedule to allow someone to get a quick look at the test flow and the associated dates. The tasks contained within this section are not tied to any other activities (and do not drive any other activities) and so therefore you will see large float values associated with them. It is simply a quick look at the test flow so that one does not have to filter through the schedule to locate the environmental test activities.
- 52: There was a failure on the SEPT door during Vibration Test. Vibration Test will be repeated once the fix to the door is implemented. Time and place is TBD.

| ID | WBS | Task | Type | Duration | Start | Finish | Predecessors | Complete | Remaining | Baseline start | Baseline finish | Baseline duration | Total slack | Free slack | Constraint | Text1 |
| --- | --- | --- | --- | --- | --- | --- | --- | --- | --- | --- | --- | --- | --- | --- | --- | --- |
| 64 | 1.3 | **Power Converters - UCB** |  | 357d | 2003-02-26 A | 2004-07-26 |  | 72% | 100.04d | 2003-02-26 | 2004-06-23 | 335d | 41d |  |  |  |
| 65 | 1.3.1 | **Deliveries** |  | 159d | 2003-12-09 A | 2004-07-26 |  | 20% | 127.2d | 2003-12-09 | 2004-04-30 | 100d | 41d |  |  |  |
| 66 | 1.3.1.1 | **FM 1** |  | 122d | 2003-12-09 A | 2004-06-02 |  | 40% | 73.2d | 2003-12-09 | 2004-04-23 | 95d | 13d |  |  |  |
| 67 | 1.3.1.1.1 | Deliver IDPU FM 1 LVPS (stays at UCB) | milestone | 0d | 2004-06-02 | 2004-06-02 | 121 |  |  | 2004-04-23 | 2004-04-23 | 0d | 9d | 0d |  | MS-BOOM |
| 68 | 1.3.1.1.2 | Deliver SEP FM 1 LVPS (to Caltech) |  | 1d | 2004-06-01 | 2004-06-01 | 125 |  |  | 2004-04-06 | 2004-04-06 | 1d | 14d | 13d |  | MS-SEP |
| 69 | 1.3.1.1.3 | Deliver SWEA/STE FM 1 LVPS (stays at UCB) | milestone | 0d | 2004-06-02 | 2004-06-02 | 129 |  |  | 2004-04-15 | 2004-04-15 | 0d | -8d | 0d |  | MS-BOOM |
| 70 | 1.3.1.1.4 | Deliver PLASTIC FM 1 LVPS (to UNH) |  | 2d | 2004-05-24 | 2004-05-25 | 133 |  |  | 2004-03-24 | 2004-03-25 | 2d | 11d |  | finish no later than 2004-06-10 |  |
| 71 | 1.3.1.1.5 | Deliver SIT FM 1 HVPS (to UMD) |  | 2d | 2003-12-09 A | 2003-12-10 A | 135 | 100% |  | 2003-12-09 | 2003-12-10 | 2d |  |  |  |  |
| 72 | 1.3.1.2 | **FM 2** |  | 25d | 2004-06-21 | 2004-07-26 |  |  |  | 2004-04-12 | 2004-04-30 | 15d | -10d | 0d |  |  |
| 73 | 1.3.1.2.1 | Deliver IDPU FM 2 LVPS (stays at UCB) | milestone | 0d | 2004-07-15 | 2004-07-15 | 140 |  |  | 2004-04-30 | 2004-04-30 | 0d | 36d | 0d |  | MS-BOOM |
| 74 | 1.3.1.2.2 | Deliver SEP FM 2 LVPS (to Caltech) |  | 1d | 2004-07-26 | 2004-07-26 | 145 |  |  | 2004-04-19 | 2004-04-19 | 1d | 41d | 0d |  | MS-SEP |
| 75 | 1.3.1.2.3 | Deliver SWEA/STE FM 2 LVPS (stays at UCB) | milestone | 0d | 2004-07-13 | 2004-07-13 | 149 |  |  | 2004-04-26 | 2004-04-26 | 0d | 8d | 0d |  | MS-BOOM |
| 76 | 1.3.1.2.4 | Deliver PLASTIC FM 2 LVPS (to UNH) |  | 2d | 2004-07-06 | 2004-07-07 | 153 |  |  | 2004-04-12 | 2004-04-13 | 2d | 10d |  | finish no later than 2004-07-21 |  |
| 77 | 1.3.1.2.5 | Deliver SIT FM 2 HVPS (to UMD) |  | 2d | 2004-06-21 | 2004-06-22 | 157 |  |  | 2004-04-12 | 2004-04-13 | 2d | -10d | 0d |  | MS-SEP |
| 78 | 1.3.2 | **Remaining Flight Procurements** |  | 95d | 2003-10-24 A | 2004-03-12 A |  | 100% |  | 2003-10-24 | 2004-02-19 | 79d |  |  |  |  |
| 79 | 1.3.2.1 | Procure IDPU Flight Printed Wiring Board |  | 10d | 2004-03-01 A | 2004-03-12 A | 85 | 100% |  | 2004-02-05 | 2004-02-19 | 10d |  |  | start no earlier than 2004-03-01 |  |
| 80 | 1.3.2.2 | Procure SEP Flight Printed Wiring Board |  | 10d | 2003-11-24 A | 2003-12-08 A | 86 | 100% |  | 2003-11-24 | 2003-12-08 | 10d |  |  | start no earlier than 2003-11-24 |  |
| 81 | 1.3.2.3 | Procure SWEA Flight Printed Wiring Board |  | 10d | 2003-12-04 A | 2003-12-17 A | 87 | 100% |  | 2003-12-04 | 2003-12-17 | 10d |  |  |  |  |
| 82 | 1.3.2.4 | Procure PLASTIC Flight Printed Wiring Board |  | 10d | 2003-10-24 A | 2003-11-06 A |  | 100% |  | 2003-10-24 | 2003-11-06 | 10d |  |  | start no earlier than 2003-10-24 |  |
| 83 | 1.3.3 | **Fabrication** |  | 239d | 2003-02-26 A | 2004-02-06 A |  | 100% |  | 2003-02-26 | 2004-02-06 | 239d |  |  |  |  |
| 84 | 1.3.3.1 | **FM 1 & FM 2** |  | 195d | 2003-02-26 A | 2003-12-03 A |  | 100% |  | 2003-02-26 | 2003-12-03 | 195d |  |  |  |  |
| 85 | 1.3.3.1.1 | Re-layout IDPU LVPS Flight Printed Wiring Board |  | 186d | 2003-02-26 A | 2003-11-19 A |  | 100% |  | 2003-02-26 | 2003-11-19 | 186d |  |  | start no earlier than 2003-02-26 |  |
| 86 | 1.3.3.1.2 | Re-layout SEP LVPS Flight Printed Wiring Board |  | 32d | 2003-09-24 A | 2003-11-07 A |  | 100% |  | 2003-09-24 | 2003-11-07 | 32d |  |  | start no earlier than 2003-09-24 |  |
| 87 | 1.3.3.1.3 | Re-layout SWEA LVPS Flight Printed Wiring Board |  | 5d | 2003-11-26 A | 2003-12-03 A |  | 100% |  | 2003-11-26 | 2003-12-03 | 5d |  |  | start no earlier than 2003-11-26 |  |

| ID | WBS | Task | Duration | Start | Finish | Predecessors | Complete | Remaining | Baseline start | Baseline finish | Baseline duration | Total slack | Free slack | Constraint |
| --- | --- | --- | --- | --- | --- | --- | --- | --- | --- | --- | --- | --- | --- | --- |
| 88 | 1.3.3.2 | **FM 1** | 45d | 2003-09-29 A | 2003-12-03 A |  | 100% |  | 2003-09-29 | 2003-12-03 | 45d |  |  |  |
| 89 | 1.3.3.2.1 | Wind IDPU LVPS FM 1 Magnets | 10d | 2003-10-17 A | 2003-10-30 A |  | 100% |  | 2003-10-17 | 2003-10-30 | 10d |  |  | start no earlier than 2003-10-17 |
| 90 | 1.3.3.2.2 | Wind SEP LVPS FM 1 Magnets | 15d | 2003-09-29 A | 2003-10-20 A |  | 100% |  | 2003-09-29 | 2003-10-20 | 15d |  |  | start no earlier than 2003-09-29 |
| 91 | 1.3.3.2.3 | Wind SWEA LVPS FM 1 Magnets | 5d | 2003-11-26 A | 2003-12-03 A |  | 100% |  | 2003-11-26 | 2003-12-03 | 5d |  |  | start no earlier than 2003-11-26 |
| 92 | 1.3.3.2.4 | Wind PLASTIC LVPS FM 1 Magnets | 45d | 2003-09-29 A | 2003-12-03 A |  | 100% |  | 2003-09-29 | 2003-12-03 | 45d |  |  | start no earlier than 2003-09-29 |
| 93 | 1.3.3.3 | **FM 2** | 28d | 2003-12-29 A | 2004-02-06 A |  | 100% |  | 2003-12-29 | 2004-02-06 | 28d |  |  |  |
| 94 | 1.3.3.3.1 | Wind HVPS FM 2 Magnets | 28d | 2003-12-29 A | 2004-02-06 A |  | 100% |  | 2003-12-29 | 2004-02-06 | 28d |  |  | start no earlier than 2003-12-29 |
| 95 | 1.3.3.3.2 | Wind IDPU LVPS FM 2 Magnets | 28d | 2003-12-29 A | 2004-02-06 A | 94SS | 100% |  | 2003-12-29 | 2004-02-06 | 28d |  |  |  |
| 96 | 1.3.3.3.3 | Wind SEP LVPS FM 2 Magnets | 28d | 2003-12-29 A | 2004-02-06 A | 94SS | 100% |  | 2003-12-29 | 2004-02-06 | 28d |  |  |  |
| 97 | 1.3.3.3.4 | Wind SWEA LVPS FM 2 Magnets | 28d | 2003-12-29 A | 2004-02-06 A | 94SS | 100% |  | 2003-12-29 | 2004-02-06 | 28d |  |  |  |
| 98 | 1.3.3.3.5 | Wind PLASTIC LVPS FM 2 Magnets | 28d | 2003-12-29 A | 2004-02-06 A | 94SS | 100% |  | 2003-12-29 | 2004-02-06 | 28d |  |  |  |
| 99 | 1.3.4 | **Assembly** | 117d | 2003-12-29 A | 2004-06-14 |  | 53% | 55.31d | 2003-12-29 | 2004-03-19 | 57d | 41d |  |  |
| 100 | 1.3.4.1 | **FM 1** | 84d | 2003-12-29 A | 2004-04-27 A |  | 100% |  | 2003-12-29 | 2004-03-12 | 52d |  |  |  |
| 101 | 1.3.4.1.1 | Assemble IDPU FM 1 LVPS | 17d | 2004-04-05 A | 2004-04-27 A | 89, 113FS+2d | 100% |  | 2004-02-26 | 2004-03-12 | 12d |  |  |  |
| 102 | 1.3.4.1.2 | Assemble SEP FM 1 LVPS | 40d | 2004-01-12 A | 2004-03-09 A | 114, 90 | 100% |  | 2004-01-12 | 2004-02-23 | 29d |  |  | start no earlier than 2004-01-12 |
| 103 | 1.3.4.1.3 | Assemble SWEA FM 1 LVPS | 30d | 2004-02-13 A | 2004-03-26 A | 91, 115 | 100% |  | 2004-02-13 | 2004-03-04 | 14d |  |  | start no earlier than 2004-02-13 |
| 104 | 1.3.4.1.4 | Assemble PLASTIC FM 1 LVPS | 29d | 2003-12-29 A | 2004-02-09 A | 116, 92 | 100% |  | 2003-12-29 | 2004-02-09 | 29d |  |  | start no earlier than 2003-12-29 |
| 105 | 1.3.4.2 | **FM 2** | 55d | 2004-03-29 | 2004-06-14 |  |  |  | 2004-02-09 | 2004-03-19 | 29d | 0d |  |  |
| 106 | 1.3.4.2.1 | Assemble IDPU FM 2 LVPS | 15d | 2004-05-19 | 2004-06-09 | 95, 119 |  |  | 2004-03-01 | 2004-03-19 | 15d | 36d | 0d | start no earlier than 2004-03-01 |
| 107 | 1.3.4.2.2 | Assemble SEP FM 2 LVPS | 15d | 2004-05-24 | 2004-06-14 | 96, 123FS+5d |  |  | 2004-02-13 | 2004-03-05 | 15d | 41d | 0d | start no earlier than 2004-02-13 |
| 108 | 1.3.4.2.3 | Assemble SWEA FM 2 LVPS | 15d | 2004-05-17 | 2004-06-07 | 97, 127 |  |  | 2004-02-24 | 2004-03-15 | 15d | 8d | 0d | start no earlier than 2004-02-24 |
| 109 | 1.3.4.2.4 | Assemble PLASTIC FM 2 LVPS | 14d | 2004-05-10 | 2004-05-27 | 98, 131 |  |  | 2004-02-09 | 2004-02-27 | 14d | 10d | 0d | start no earlier than 2004-02-09 |
| 110 | 1.3.4.2.5 | Assemble SIT FM 2 HVPS | 45d | 2004-03-29 | 2004-05-28 | 94, 103 |  |  | 2004-02-09 | 2004-02-27 | 14d | 0d |  |  |
| 111 | 1.3.5 | **Testing** | 183d | 2003-10-31 A | 2004-07-23 |  | 49% | 92.45d | 2003-10-31 | 2004-06-23 | 162d | 41d |  |  |
| 112 | 1.3.5.1 | **FM 1 & FM 2** | 88d | 2003-11-24 A | 2004-03-31 A |  | 100% |  | 2003-11-24 | 2004-02-25 | 63d |  |  |  |
| 113 | 1.3.5.1.1 | Coupon Test IDPU Flight Printed Wiring Board | 4d | 2004-03-26 A | 2004-03-31 A | 79FS+9d | 100% |  | 2004-02-20 | 2004-02-25 | 4d |  |  |  |
| 114 | 1.3.5.1.2 | Coupon Test SEP Flight Printed Wiring Board | 5d | 2003-12-09 A | 2003-12-15 A | 80 | 100% |  | 2003-12-09 | 2003-12-15 | 5d |  |  |  |
| 115 | 1.3.5.1.3 | Coupon Test SWEA Flight Printed Wiring Board | 6d | 2004-01-09 A | 2004-01-16 A | 81 | 100% |  | 2004-01-09 | 2004-01-16 | 6d |  |  | start no earlier than 2004-01-09 |
| 116 | 1.3.5.1.4 | Coupon Test PLASTIC Flight Printed Wiring Board | 5d | 2003-11-24 A | 2003-12-01 A | 82 | 100% |  | 2003-11-24 | 2003-12-01 | 5d |  |  | start no earlier than 2003-11-24 |

Notes:
- 110: Stuck in the technician backlog

| ID | WBS | Task | Duration | Start | Finish | Predecessors | Complete | Remaining | Baseline start | Baseline finish | Baseline duration | Total slack | Free slack | Constraint |
| --- | --- | --- | --- | --- | --- | --- | --- | --- | --- | --- | --- | --- | --- | --- |
| 117 | 1.3.5.2 | **FM 1** | 147d | 2003-10-31 A | 2004-06-02 |  | 67% | 47.96d | 2003-10-31 | 2004-06-23 | 162d | 12d |  |  |
| 118 | 1.3.5.2.1 | **IDPU** | 25d | 2004-04-28 A | 2004-06-02 |  | 12% | 22d | 2004-03-15 | 2004-04-23 | 30d | 9d |  |  |
| 119 | 1.3.5.2.1.1 | Test IDPU FM 1 LVPS | 15d | 2004-04-28 A | 2004-05-18 | 101 | 20% | 12d | 2004-03-15 | 2004-04-02 | 15d | 9d | 0d |  |
| 120 | 1.3.5.2.1.2 | Coat & Stake IDPU LVPS FM 1 Boards | 5d | 2004-05-19 | 2004-05-25 | 119 |  |  | 2004-04-05 | 2004-04-09 | 5d | 9d | 0d |  |
| 121 | 1.3.5.2.1.3 | Retest IDPU LVPS FM 1 Boards | 5d | 2004-05-26 | 2004-06-02 | 120 |  |  | 2004-04-12 | 2004-04-23 | 10d | 9d | 0d |  |
| 122 | 1.3.5.2.2 | **SEP** | 58d | 2004-03-10 A | 2004-05-28 |  | 66% | 20d | 2004-02-24 | 2004-04-05 | 30d | 14d |  |  |
| 123 | 1.3.5.2.2.1 | Test SEP FM 1 LVPS | 48d | 2004-03-10 A | 2004-05-14 | 102 | 79% | 10d | 2004-02-24 | 2004-03-15 | 15d | 14d | 0d |  |
| 124 | 1.3.5.2.2.2 | Coat & Stake SEP LVPS FM 1 Boards | 5d | 2004-05-17 | 2004-05-21 | 123 |  |  | 2004-03-16 | 2004-03-22 | 5d | 14d | 0d |  |
| 125 | 1.3.5.2.2.3 | Retest SEP LVPS FM 1 Boards | 5d | 2004-05-24 | 2004-05-28 | 124, 370 |  |  | 2004-03-23 | 2004-04-05 | 10d | 14d | 0d |  |
| 126 | 1.3.5.2.3 | **SWEA** | 57d | 2004-03-15 A | 2004-06-02 |  | 64% | 20.73d | 2004-03-05 | 2004-04-15 | 30d | -8d | 0d |  |
| 127 | 1.3.5.2.3.1 | Test SWEA FM 1 LVPS | 45d | 2004-03-15 A | 2004-05-14 | 103 | 78% | 10d | 2004-03-05 | 2004-03-25 | 15d | -8d | 0d |  |
| 128 | 1.3.5.2.3.2 | Coat & Stake SWEA LVPS FM 1 Boards | 5d | 2004-05-19 | 2004-05-25 | 127FS+2d |  |  | 2004-03-26 | 2004-04-01 | 5d | -8d | 0d |  |
| 129 | 1.3.5.2.3.3 | Retest SWEA LVPS FM 1 Boards | 5d | 2004-05-26 | 2004-06-02 | 128 |  |  | 2004-04-02 | 2004-04-15 | 10d | -8d | 0d |  |
| 130 | 1.3.5.2.4 | **PLASTIC** | 73d | 2004-02-10 A | 2004-05-21 |  | 79% | 15d | 2004-02-10 | 2004-03-23 | 30d | 11d |  |  |
| 131 | 1.3.5.2.4.1 | Test PLASTIC FM 1 LVPS | 63d | 2004-02-10 A | 2004-05-07 | 104 | 92% | 5d | 2004-02-10 | 2004-03-02 | 15d | 10d | 0d |  |
| 132 | 1.3.5.2.4.2 | Coat & Stake PLASTIC LVPS FM 1 Boards | 5d | 2004-05-10 | 2004-05-14 | 131 |  |  | 2004-03-03 | 2004-03-09 | 5d | 11d | 0d |  |
| 133 | 1.3.5.2.4.3 | Retest PLASTIC LVPS FM 1 Boards | 5d | 2004-05-17 | 2004-05-21 | 132 |  |  | 2004-03-10 | 2004-03-23 | 10d | 11d | 0d |  |
| 134 | 1.3.5.2.5 | **SIT** | 25d | 2003-10-31 A | 2003-12-08 A |  | 100% |  | 2003-10-31 | 2004-06-23 | 162d |  |  |  |
| 135 | 1.3.5.2.5.1 | Test SIT FM 1 HVPS | 25d | 2003-10-31 A | 2003-12-08 A |  | 100% |  | 2003-10-31 | 2003-12-08 | 25d |  |  | start no earlier than 2003-10-31 |
| 136 | 1.3.5.3 | **FM 2** | 69d | 2004-04-16 A | 2004-07-23 |  | 9% | 63.07d | 2004-03-01 | 2004-04-30 | 45d | 41d |  |  |
| 137 | 1.3.5.3.1 | **IDPU** | 25d | 2004-06-10 | 2004-07-15 |  |  |  | 2004-03-22 | 2004-04-30 | 30d | 36d |  |  |
| 138 | 1.3.5.3.1.1 | Test IDPU FM 2 LVPS | 15d | 2004-06-10 | 2004-06-30 | 106 |  |  | 2004-03-22 | 2004-04-09 | 15d | 36d | 0d |  |
| 139 | 1.3.5.3.1.2 | Coat & Stake IDPU LVPS FM 2 Boards | 5d | 2004-07-01 | 2004-07-08 | 138 |  |  | 2004-04-12 | 2004-04-16 | 5d | 36d | 0d |  |
| 140 | 1.3.5.3.1.3 | Retest IDPU LVPS FM 2 Boards | 5d | 2004-07-09 | 2004-07-15 | 139 |  |  | 2004-04-19 | 2004-04-30 | 10d | 36d | 0d |  |

| ID | WBS | Task | Type | Duration | Start | Finish | Predecessors | Complete | Remaining | Baseline start | Baseline finish | Baseline duration | Total slack | Free slack | Constraint | Text1 |
| --- | --- | --- | --- | --- | --- | --- | --- | --- | --- | --- | --- | --- | --- | --- | --- | --- |
| 141 | 1.3.5.3.2 | **SEP** |  | 28d | 2004-06-15 | 2004-07-23 |  |  |  | 2004-03-08 | 2004-04-16 | 30d | 41d |  |  |  |
| 142 | 1.3.5.3.2.1 | Test SEP FM 2 LVPS |  | 15d | 2004-06-15 | 2004-07-06 | 107 |  |  | 2004-03-08 | 2004-03-26 | 15d | 41d | 0d |  |  |
| 143 | 1.3.5.3.2.2 | Coat & Stake SEP LVPS FM 2 Boards |  | 5d | 2004-07-07 | 2004-07-13 | 142 |  |  | 2004-03-29 | 2004-04-02 | 5d | 41d | 0d |  |  |
| 144 | 1.3.5.3.2.3 | Retest SEP LVPS FM 2 Boards |  | 5d | 2004-07-14 | 2004-07-20 | 143, 370 |  |  | 2004-04-05 | 2004-04-16 | 10d | 41d | 0d |  |  |
| 145 | 1.3.5.3.2.4 | Bakeout SEP LVPS FM 2 Boards |  | 3d | 2004-07-21 | 2004-07-23 | 144 |  |  | 2004-06-22 | 2004-06-24 | 3d | 41d | 0d |  |  |
| 146 | 1.3.5.3.3 | **SWEA** |  | 25d | 2004-06-08 | 2004-07-13 |  |  |  | 2004-03-16 | 2004-04-26 | 30d | 8d |  |  |  |
| 147 | 1.3.5.3.3.1 | Test SWEA FM 2 LVPS |  | 15d | 2004-06-08 | 2004-06-28 | 108 |  |  | 2004-03-16 | 2004-04-05 | 15d | 8d | 0d |  |  |
| 148 | 1.3.5.3.3.2 | Coat & Stake SWEA LVPS FM 2 Boards |  | 5d | 2004-06-29 | 2004-07-06 | 147 |  |  | 2004-04-06 | 2004-04-12 | 5d | 8d | 0d |  |  |
| 149 | 1.3.5.3.3.3 | Retest SWEA LVPS FM 2 Boards |  | 5d | 2004-07-07 | 2004-07-13 | 148 |  |  | 2004-04-13 | 2004-04-26 | 10d | 8d | 0d |  |  |
| 150 | 1.3.5.3.4 | **PLASTIC** |  | 25d | 2004-05-28 | 2004-07-02 |  |  |  | 2004-03-01 | 2004-04-09 | 30d | 10d |  |  |  |
| 151 | 1.3.5.3.4.1 | Test PLASTIC FM 2 LVPS |  | 15d | 2004-05-28 | 2004-06-18 | 109 |  |  | 2004-03-01 | 2004-03-19 | 15d | 10d | 0d |  |  |
| 152 | 1.3.5.3.4.2 | Coat & Stake PLASTIC LVPS FM 2 Boards |  | 5d | 2004-06-21 | 2004-06-25 | 151 |  |  | 2004-03-22 | 2004-03-26 | 5d | 10d | 0d |  |  |
| 153 | 1.3.5.3.4.3 | Retest PLASTIC LVPS FM 2 Boards |  | 5d | 2004-06-28 | 2004-07-02 | 152 |  |  | 2004-03-29 | 2004-04-09 | 10d | 10d | 0d |  |  |
| 154 | 1.3.5.3.5 | **SIT** |  | 45d | 2004-04-16 A | 2004-06-18 |  | 44% | 25.2d | 2004-03-01 | 2004-04-09 | 30d | -10d | 0d |  |  |
| 155 | 1.3.5.3.5.1 | Test SIT FM 2 HVPS |  | 15d | 2004-04-16 A | 2004-06-04 | 110 | 73% | 4d | 2004-03-01 | 2004-03-19 | 15d | -10d | 0d |  |  |
| 156 | 1.3.5.3.5.2 | Coat & Stake SIT FM 2 HVPS Boards |  | 5d | 2004-06-07 | 2004-06-11 | 155 |  |  | 2004-03-22 | 2004-03-26 | 5d | -10d | 0d |  |  |
| 157 | 1.3.5.3.5.3 | Retest SIT FM 2 HVPS Boards |  | 5d | 2004-06-14 | 2004-06-18 | 156 |  |  | 2004-03-29 | 2004-04-09 | 10d | -10d | 0d |  |  |
| 158 | 1.4 | **IDPU - UCB** |  | 340d | 2003-05-05 A | 2004-09-08 |  | 83% | 57.7d | 2003-05-05 | 2004-09-07 | 340d | 18d |  |  |  |
| 159 | 1.4.1 | **Deliveries** |  | 30d | 2004-06-30 | 2004-08-12 |  |  |  | 2004-04-13 | 2004-05-28 | 33d | 9d |  |  |  |
| 160 | 1.4.1.1 | IDPU FM 1 Complete (to UCB for Boom I&T, then to CIT for SEP I&T, Suite EMC, BO & Final Boom I&T) | milestone | 0d | 2004-06-30 | 2004-06-30 | 175 |  |  | 2004-05-21 | 2004-05-21 | 0d | 9d |  |  | MS-BOOM |
| 161 | 1.4.1.2 | IDPU FM 2 Complete (to CIT for SEP I&T, then to UCB for Boom I&T, Boom EMC, BO & Final Boom I&T) | milestone | 0d | 2004-08-12 | 2004-08-12 | 179 |  |  | 2004-05-28 | 2004-05-28 | 0d | 36d | 0d |  | MS-BOOM |
| 162 | 1.4.2 | **Flight Software** |  | 269d | 2003-05-05 A | 2004-05-27 |  | 94% | 15.58d | 2003-05-05 | 2004-04-13 | 237d | 79d |  |  |  |
| 163 | 1.4.2.1 | IDPU S/W Build #2.5 |  | 131d | 2003-05-05 A | 2003-11-07 A |  | 100% |  | 2003-05-05 | 2003-11-07 | 131d |  |  | start no earlier than 2003-05-05 |  |
| 164 | 1.4.2.2 | IDPU S/W Build #3 (also goes to UNH) |  | 197d | 2003-08-15 A | 2004-05-27 |  | 90% | 19d | 2003-08-15 | 2004-04-13 | 165d | 79d | 43d | start no earlier than 2003-08-15 | MS-BOOM |

| ID | WBS | Task | Type | Duration | Start | Finish | Predecessors | Complete | Remaining | Baseline start | Baseline finish | Baseline duration | Total slack | Free slack | Constraint | Text1 |
| --- | --- | --- | --- | --- | --- | --- | --- | --- | --- | --- | --- | --- | --- | --- | --- | --- |
| 165 | 1.4.3 | **GSE** |  | 301d | 2003-06-30 A | 2004-09-08 |  | 81% | 55.86d | 2003-06-30 | 2004-09-07 | 301d | 0d |  |  |  |
| 166 | 1.4.3.1 | STE Science Display |  | 27d | 2003-10-23 A | 2003-12-02 A |  | 100% |  | 2003-10-23 | 2003-12-02 | 27d |  |  | start no earlier than 2003-10-23 |  |
| 167 | 1.4.3.2 | SWEA Science Display |  | 167d | 2003-06-30 A | 2004-03-01 A |  | 100% |  | 2003-06-30 | 2004-02-23 | 162d |  |  | start no earlier than 2003-06-30 |  |
| 168 | 1.4.3.3 | GSE Continued Development (LOE) |  | 291d | 2003-07-15 A | 2004-09-08 |  | 69% | 90d | 2003-07-15 | 2004-09-07 | 291d | 0d |  | must start on 2003-07-15 |  |
| 169 | 1.4.4 | **Integration & Test** |  | 214d | 2003-10-07 A | 2004-08-12 |  | 38% | 131.69d | 2003-10-07 | 2004-05-28 | 162d | 36d |  |  |  |
| 170 | 1.4.4.1 | IDPU DCB FM 2 Board Level Testing |  | 15d | 2003-10-07 A | 2003-10-28 A |  | 100% |  | 2003-10-07 | 2003-10-28 | 15d |  |  | start no earlier than 2003-10-07 |  |
| 171 | 1.4.4.2 | IDPU DCB Clean/Stake/Coat (FM 1 & FM 2) |  | 10d | 2003-12-26 A | 2004-01-09 A | 170 | 100% |  | 2003-12-26 | 2004-01-09 | 10d |  |  | start no earlier than 2003-12-26 |  |
| 172 | 1.4.4.3 | **FM 1** |  | 20d | 2004-06-03 | 2004-06-30 |  |  |  | 2004-04-26 | 2004-05-21 | 20d | 9d |  |  |  |
| 173 | 1.4.4.3.1 | IDPU FM 1 I & T |  | 5d | 2004-06-03 | 2004-06-09 | 163, 67, 238, 282, 171 |  |  | 2004-04-26 | 2004-04-30 | 5d | 9d | 0d |  | MS-BOOM |
| 174 | 1.4.4.3.2 | IDPU FM 1 Vibration |  | 5d | 2004-06-10 | 2004-06-16 | 173 |  |  | 2004-05-03 | 2004-05-07 | 5d | 9d | 0d |  |  |
| 175 | 1.4.4.3.3 | IDPU FM 1 Thermal Vacuum & Bake Out |  | 10d | 2004-06-17 | 2004-06-30 | 174 |  |  | 2004-05-10 | 2004-05-21 | 10d | 9d | 0d |  |  |
| 176 | 1.4.4.4 | **FM 2** |  | 20d | 2004-07-16 | 2004-08-12 |  |  |  | 2004-05-03 | 2004-05-28 | 20d | 36d |  |  |  |
| 177 | 1.4.4.4.1 | IDPU FM 2 I & T |  | 5d | 2004-07-16 | 2004-07-22 | 73, 239, 283, 170, 171 |  |  | 2004-05-03 | 2004-05-07 | 5d | 36d | 0d |  |  |
| 178 | 1.4.4.4.2 | IDPU FM 2 Vibration |  | 5d | 2004-07-23 | 2004-07-29 | 177 |  |  | 2004-05-10 | 2004-05-14 | 5d | 36d | 0d |  |  |
| 179 | 1.4.4.4.3 | IDPU FM 2 Thermal Vacuum & Bake Out |  | 10d | 2004-07-30 | 2004-08-12 | 164, 178 |  |  | 2004-05-17 | 2004-05-28 | 10d | 36d | 0d |  |  |
| 180 | 1.5 | **BOOM Suite - UCB** |  | 326d | 2003-07-01 A | 2004-10-15 |  | 80% | 66.62d | 2003-07-01 | 2004-09-28 | 315d | 8d |  |  |  |
| 181 | 1.5.1 | **BOOM Structure - UCB** |  | 241d | 2003-09-10 A | 2004-08-24 |  | 84% | 39.13d | 2003-09-10 | 2004-06-18 | 195d | 28d |  |  |  |
| 182 | 1.5.1.1 | **Deliveries** |  | 158d | 2004-01-09 A | 2004-08-24 |  |  | 158d | 2004-01-09 | 2004-06-18 | 112d | 28d |  |  |  |
| 183 | 1.5.1.1.1 | Protoflight Boom available for I&T (if needed) | milestone | 0d | 2004-01-09 A | 2004-01-09 A | 188 | 100% |  | 2004-01-09 | 2004-01-09 | 0d |  |  |  |  |
| 184 | 1.5.1.1.2 | Deliver Boom Structure FM 1 (stays at UCB for Boom Suite FM 1 I&T) | milestone | 0d | 2004-07-08 | 2004-07-08 | 213 |  |  | 2004-05-27 | 2004-05-27 | 0d | 2d |  |  | MS-BOOM |
| 185 | 1.5.1.1.3 | Deliver Boom Structure FM 2 (stays at UCB for Boom Suite FM 2 I&T) | milestone | 0d | 2004-08-24 | 2004-08-24 | 235 |  |  | 2004-06-18 | 2004-06-18 | 0d | 28d | 20d |  | MS-BOOM |
| 186 | 1.5.1.2 | **Protoflight** |  | 79d | 2003-09-16 A | 2004-01-09 A |  | 100% |  | 2003-09-16 | 2004-01-09 | 79d |  |  |  |  |
| 187 | 1.5.1.2.1 | Protoflight Boom Post Environmental Deployment Test |  | 35d | 2003-09-16 A | 2003-11-04 A |  | 100% |  | 2003-09-16 | 2003-11-04 | 35d |  |  | start no earlier than 2003-09-16 |  |
| 188 | 1.5.1.2.2 | Document Protoflight Boom Test Results |  | 44d | 2003-11-05 A | 2004-01-09 A | 187 | 100% |  | 2003-11-05 | 2004-01-09 | 44d |  |  |  |  |

| ID | WBS | Task | Duration | Start | Finish | Predecessors | Complete | Remaining | Baseline start | Baseline finish | Baseline duration | Total slack | Free slack | Constraint | Calendar | Text1 |
| --- | --- | --- | --- | --- | --- | --- | --- | --- | --- | --- | --- | --- | --- | --- | --- | --- |
| 189 | 1.5.1.3 | **Flight Procurements** | 40d | 2003-09-10 A | 2003-11-05 A |  | 100% |  | 2003-09-10 | 2003-11-05 | 40d |  |  |  |  |  |
| 190 | 1.5.1.3.1 | Receive and Inspect Flight Boom Structure Tubes (FM 1) | 32d | 2003-09-10 A | 2003-10-24 A |  | 100% |  | 2003-09-10 | 2003-10-24 | 32d |  |  | start no earlier than 2003-09-10 |  |  |
| 191 | 1.5.1.3.2 | Receive and Inspect Flight Boom Structure Tubes (FM 2) | 40d | 2003-09-10 A | 2003-11-05 A |  | 100% |  | 2003-09-10 | 2003-11-05 | 40d |  |  | start no earlier than 2003-09-10 |  |  |
| 192 | 1.5.1.4 | **FM 1** | 195d | 2003-09-29 A | 2004-07-08 |  | 84% | 30.27d | 2003-09-29 | 2004-05-27 | 167d | 2d |  |  |  |  |
| 193 | 1.5.1.4.1 | **Telescoping** | 84d | 2003-10-27 A | 2004-02-29 A |  | 100% |  | 2003-10-27 | 2004-02-29 | 84d |  |  |  |  |  |
| 194 | 1.5.1.4.1.1 | **Fabrication, Assembly & Test** | 84d | 2003-10-27 A | 2004-02-29 A |  | 100% |  | 2003-10-27 | 2004-02-29 | 84d |  |  |  |  |  |
| 195 | 1.5.1.4.1.1.1 | Machine FM 1 Boom Structure Tubes as necessary | 5d | 2003-10-27 A | 2003-10-31 A | 190 | 100% |  | 2003-10-27 | 2003-10-31 | 5d |  |  |  |  |  |
| 196 | 1.5.1.4.1.1.2 | Machine FM 1 Boom Structure Parts (Rings) | 38d | 2003-11-07 A | 2004-01-05 A | 190FF+47d | 100% |  | 2003-11-07 | 2004-01-05 | 38d |  |  |  |  |  |
| 197 | 1.5.1.4.1.1.3 | Assemble FM 1 Boom Structure Telescoping Assembly | 5d | 2004-02-23 A | 2004-02-27 A | 195, 196 | 100% |  | 2004-02-23 | 2004-02-27 | 5d |  |  | start no earlier than 2004-02-23 |  |  |
| 198 | 1.5.1.4.1.1.4 | Test FM 1 Boom Structure Telescoping Assembly | 2d | 2004-02-28 A | 2004-02-29 A | 197 | 100% |  | 2004-02-28 | 2004-02-29 | 2d |  |  |  | Boom Test Calendar |  |
| 199 | 1.5.1.4.2 | **Harness** | 109d | 2003-09-29 A | 2004-03-08 A |  | 100% |  | 2003-09-29 | 2004-03-08 | 109d |  |  |  |  |  |
| 200 | 1.5.1.4.2.1 | **Fabrication** | 103d | 2003-09-29 A | 2004-02-27 A |  | 100% |  | 2003-09-29 | 2004-02-27 | 103d |  |  |  |  |  |
| 201 | 1.5.1.4.2.1.1 | Machine FM 1 Harness Parts | 103d | 2003-09-29 A | 2004-02-27 A |  | 100% |  | 2003-09-29 | 2004-02-27 | 103d |  |  | start no earlier than 2003-09-29 |  |  |
| 202 | 1.5.1.4.2.2 | **Assembly & Test** | 6d | 2004-03-01 A | 2004-03-08 A |  | 100% |  | 2004-03-01 | 2004-03-08 | 6d |  |  |  |  |  |
| 203 | 1.5.1.4.2.2.1 | Assemble FM 1 Harness subassembly | 7d | 2004-03-01 A | 2004-03-07 A | 201 | 100% |  | 2004-03-01 | 2004-03-07 | 7d |  |  | start no earlier than 2004-03-01 | Boom Test Calendar |  |
| 204 | 1.5.1.4.2.2.2 | FM1 Harness Test | 1d | 2004-03-08 A | 2004-03-08 A | 203 | 100% |  | 2004-03-08 | 2004-03-08 | 1d |  |  |  |  |  |
| 205 | 1.5.1.4.3 | **Mounting** | 38d | 2003-09-29 A | 2003-11-21 A |  | 100% |  | 2003-09-29 | 2003-11-21 | 38d |  |  |  |  |  |
| 206 | 1.5.1.4.3.1 | FM 1Boom Structure Mounting Fabrication | 28d | 2003-09-29 A | 2003-11-06 A |  | 100% |  | 2003-09-29 | 2003-11-06 | 28d |  |  | start no earlier than 2003-09-29 |  |  |
| 207 | 1.5.1.4.3.2 | FM 1Boom Structure Mounting Assembly | 10d | 2003-11-07 A | 2003-11-21 A | 206 | 100% |  | 2003-11-07 | 2003-11-21 | 10d |  |  |  |  |  |
| 208 | 1.5.1.4.4 | **Integration & Test** | 82d | 2004-03-15 A | 2004-07-08 |  | 45% | 45.2d | 2004-03-09 | 2004-05-27 | 58d | 2d |  |  |  |  |
| 209 | 1.5.1.4.4.1 | Integrate FM 1 Boom Structure subassemblies & Harness Completion | 52d | 2004-03-15 A | 2004-05-25 | 198, 204FS+5d | 67% | 17d | 2004-03-09 | 2004-04-05 | 20d | 2d | 0d |  |  | MS-BOOM |
| 210 | 1.5.1.4.4.2 | FM 1 Boom Structure Deployment Test | 3d | 2004-05-26 | 2004-05-28 | 209 |  |  | 2004-04-06 | 2004-04-19 | 10d | 2d | 0d |  |  | MS-BOOM |
| 211 | 1.5.1.4.4.3 | FM 1 Boom Structure Vibration Test | 4d | 2004-06-07 | 2004-06-10 | 210, 349 |  |  | 2004-04-27 | 2004-04-30 | 4d | 2d | 0d |  |  |  |
| 212 | 1.5.1.4.4.4 | FM 1 Boom Structure Themal Vac & Bake Out | 15d | 2004-06-11 | 2004-07-01 | 211 |  |  | 2004-05-03 | 2004-05-21 | 15d | 2d | 0d |  |  |  |
| 213 | 1.5.1.4.4.5 | FM 1 Boom Structure Post Environmental Deployment Test | 4d | 2004-07-02 | 2004-07-08 | 212 |  |  | 2004-05-24 | 2004-05-27 | 4d | 2d | 0d |  |  |  |

| ID | WBS | Task | Duration | Start | Finish | Predecessors | Complete | Remaining | Baseline start | Baseline finish | Baseline duration | Total slack | Free slack | Text1 |
| --- | --- | --- | --- | --- | --- | --- | --- | --- | --- | --- | --- | --- | --- | --- |
| 214 | 1.5.1.5 | **FM 2** | 228d | 2003-09-29 A | 2004-08-24 |  | 75% | 56.81d | 2003-09-29 | 2004-06-18 | 182d | 28d |  |  |
| 215 | 1.5.1.5.1 | **Telescoping** | 78d | 2003-11-06 A | 2004-03-02 A |  | 100% |  | 2003-11-06 | 2004-03-16 | 88d |  |  |  |
| 216 | 1.5.1.5.1.1 | **Fabrication, Assembly & Test** | 78d | 2003-11-06 A | 2004-03-02 A |  | 100% |  | 2003-11-06 | 2004-03-16 | 88d |  |  |  |
| 217 | 1.5.1.5.1.1.1 | Machine FM 2 Boom Structure Tubes as necessary | 11d | 2003-11-06 A | 2003-11-21 A | 191 | 100% |  | 2003-11-06 | 2003-11-21 | 11d |  |  |  |
| 218 | 1.5.1.5.1.1.2 | Machine FM 2 Boom Structure Parts (Rings) | 38d | 2003-11-07 A | 2004-01-05 A | 196SS | 100% |  | 2003-11-07 | 2004-01-05 | 38d |  |  |  |
| 219 | 1.5.1.5.1.1.3 | Assemble FM 2 Boom Structure Telescoping Assembly | 5d | 2004-02-23 A | 2004-02-27 A | 217, 218, 197SS | 100% |  | 2004-02-23 | 2004-02-27 | 5d |  |  |  |
| 220 | 1.5.1.5.1.1.4 | Test FM 2 Boom Structure Telescoping Assembly | 2d | 2004-03-01 A | 2004-03-02 A | 219 | 100% |  | 2004-03-15 | 2004-03-16 | 2d |  |  |  |
| 221 | 1.5.1.5.2 | **Harness** | 110d | 2003-09-29 A | 2004-03-09 A |  | 100% |  | 2003-09-29 | 2004-03-16 | 115d |  |  |  |
| 222 | 1.5.1.5.2.1 | **Fabrication** | 103d | 2003-09-29 A | 2004-02-27 A |  | 100% |  | 2003-09-29 | 2004-02-27 | 103d |  |  |  |
| 223 | 1.5.1.5.2.1.1 | Machine FM 2 Harness Parts | 103d | 2003-09-29 A | 2004-02-27 A | 201SS | 100% |  | 2003-09-29 | 2004-02-27 | 103d |  |  |  |
| 224 | 1.5.1.5.2.2 | **Assembly & Test** | 7d | 2004-03-01 A | 2004-03-09 A |  | 100% |  | 2004-03-01 | 2004-03-16 | 12d |  |  |  |
| 225 | 1.5.1.5.2.2.1 | Assemble FM 2 Harness subassembly | 6d | 2004-03-01 A | 2004-03-08 A | 223 | 100% |  | 2004-03-01 | 2004-03-15 | 11d |  |  |  |
| 226 | 1.5.1.5.2.2.2 | FM 2 Harness Test | 1d | 2004-03-09 A | 2004-03-09 A | 225 | 100% |  | 2004-03-16 | 2004-03-16 | 1d |  |  |  |
| 227 | 1.5.1.5.3 | **Mounting** | 38d | 2003-09-29 A | 2003-11-21 A |  | 100% |  | 2003-09-29 | 2003-11-21 | 38d |  |  |  |
| 228 | 1.5.1.5.3.1 | FM 2 Boom Structure Mountings Fabrication | 28d | 2003-09-29 A | 2003-11-06 A | 206SS | 100% |  | 2003-09-29 | 2003-11-06 | 28d |  |  |  |
| 229 | 1.5.1.5.3.2 | FM 2 Boom Structure Mountings Assembly | 10d | 2003-11-07 A | 2003-11-21 A | 228 | 100% |  | 2003-11-07 | 2003-11-21 | 10d |  |  |  |
| 230 | 1.5.1.5.4 | **Integration & Test** | 105d | 2004-03-29 A | 2004-08-24 |  | 25% | 79.01d | 2004-03-17 | 2004-06-18 | 67d | 28d |  |  |
| 231 | 1.5.1.5.4.1 | Integrate FM 2 Boom Structure subassemblies & Harness Completion | 75d | 2004-03-29 A | 2004-07-13 | 220, 226, 209SS+10d | 33% | 50d | 2004-03-17 | 2004-04-13 | 20d | 28d | 0d |  |
| 232 | 1.5.1.5.4.2 | FM 2 Boom Structure Deployment Test | 3d | 2004-07-14 | 2004-07-16 | 231 |  |  | 2004-04-14 | 2004-04-27 | 10d | 28d | 0d |  |
| 233 | 1.5.1.5.4.3 | FM 2 Boom Structure Vibration Test | 4d | 2004-07-23 | 2004-07-28 | 232, 354 |  |  | 2004-05-17 | 2004-05-20 | 4d | 28d | 0d |  |
| 234 | 1.5.1.5.4.4 | FM 2 Boom Structure Themal Vac & Bake Out | 15d | 2004-07-29 | 2004-08-18 | 233, 212 |  |  | 2004-05-24 | 2004-06-14 | 15d | 28d | 0d |  |
| 235 | 1.5.1.5.4.5 | FM 2 Boom Structure Post Environmental Deployment Test | 4d | 2004-08-19 | 2004-08-24 | 234 |  |  | 2004-06-15 | 2004-06-18 | 4d | 28d | 0d |  |
| 236 | 1.5.2 | **MAG - GSFC** | 63d | 2004-02-20 A | 2004-05-18 |  | 86% | 8.69d | 2004-02-20 | 2004-03-29 | 27d | 69d |  |  |
| 237 | 1.5.2.1 | **Deliveries** | 15d | 2004-04-28 A | 2004-05-18 |  | 50% | 7.5d | 2004-03-26 | 2004-03-29 | 2d | 69d |  |  |
| 238 | 1.5.2.1.1 | Deliver MAG FM 1 (to UCB for IDPU/BOOM Suite FM 1 I&T) | 2d | 2004-04-28 A | 2004-04-29 A | 242 | 100% |  | 2004-03-26 | 2004-03-29 | 2d |  |  | MS-BOOM |
| 239 | 1.5.2.1.2 | Deliver MAG FM 2 (to UCB for IDPU/BOOM Suite FM 2 I&T) | 2d | 2004-05-17 | 2004-05-18 | 245 |  |  | 2004-03-26 | 2004-03-29 | 2d | 69d | 40d | MS-BOOM |

| ID | WBS | Task | Type | Duration | Start | Finish | Predecessors | Complete | Remaining | Baseline start | Baseline finish | Baseline duration | Total slack | Free slack | Constraint | Text1 |
| --- | --- | --- | --- | --- | --- | --- | --- | --- | --- | --- | --- | --- | --- | --- | --- | --- |
| 240 | 1.5.2.2 | **FM 1** |  | 48d | 2004-02-20 A | 2004-04-27 A |  | 100% |  | 2004-02-20 | 2004-03-25 | 25d |  |  |  |  |
| 241 | 1.5.2.2.1 | FM 1 MAG Testing |  | 20d | 2004-02-20 A | 2004-03-18 A |  | 100% |  | 2004-02-20 | 2004-03-04 | 10d |  |  | start no earlier than 2004-02-20 |  |
| 242 | 1.5.2.2.2 | MAG FM 1 Calibration |  | 22d | 2004-03-26 A | 2004-04-27 A | 241FS+10d | 100% |  | 2004-03-05 | 2004-03-25 | 15d |  |  |  |  |
| 243 | 1.5.2.3 | **FM 2** |  | 51d | 2004-03-05 A | 2004-05-14 |  | 76% | 12.44d | 2004-02-20 | 2004-03-25 | 25d | 69d |  |  |  |
| 244 | 1.5.2.3.1 | FM 2 MAG Testing |  | 20d | 2004-03-05 A | 2004-04-01 A | 241FF+10d | 100% |  | 2004-02-20 | 2004-03-04 | 10d |  |  |  |  |
| 245 | 1.5.2.3.2 | MAG FM 2 Calibration |  | 21d | 2004-04-16 A | 2004-05-14 | 244FS+10d | 52% | 10d | 2004-03-05 | 2004-03-25 | 15d | 69d | 0d |  |  |
| 246 | 1.5.3 | **SWEA - CESR** |  | 126d | 2003-12-08 A | 2004-06-07 |  | 68% | 40.5d | 2003-12-08 | 2004-04-20 | 93d | 43d |  |  |  |
| 247 | 1.5.3.1 | **Deliveries** |  | 126d | 2003-12-08 A | 2004-06-07 |  | 50% | 63d | 2003-12-08 | 2004-04-20 | 93d | 43d |  |  |  |
| 248 | 1.5.3.1.1 | SWEA FM 1 Delivery to UCB |  | 3d | 2003-12-08 A | 2003-12-10 A |  | 100% |  | 2003-12-08 | 2003-12-10 | 3d |  |  | start no earlier than 2003-12-08 |  |
| 249 | 1.5.3.1.2 | SWEA FM 2 Delivery to UCB |  | 3d | 2004-06-03 | 2004-06-07 | 252FS+7d |  |  | 2004-04-16 | 2004-04-20 | 3d | 43d | 35d |  | MS-BOOM |
| 250 | 1.5.3.2 | **FM 2** |  | 50d | 2004-03-15 A | 2004-05-21 |  | 70% | 15d | 2004-02-10 | 2004-04-15 | 47d | 43d |  |  |  |
| 251 | 1.5.3.2.1 | SWEA FM 2 Final Assembly (Block 2) |  | 5d | 2004-03-15 A | 2004-03-19 A |  | 100% |  | 2004-02-10 | 2004-02-12 | 3d |  |  | start no earlier than 2004-03-15 |  |
| 252 | 1.5.3.2.2 | SWEA FM 2 Calibration |  | 45d | 2004-03-22 A | 2004-05-21 | 251 | 67% | 15d | 2004-02-13 | 2004-04-15 | 44d | 43d | 0d |  | MS-BOOM |
| 253 | 1.5.4 | **STE - UCB** |  | 216d | 2003-08-29 A | 2004-07-09 |  | 82% | 38.77d | 2003-08-29 | 2004-05-10 | 174d | 33d |  |  |  |
| 254 | 1.5.4.1 | **Deliveries** |  | 38d | 2004-05-14 | 2004-07-09 |  |  |  | 2004-04-14 | 2004-05-10 | 18d | 12d |  |  |  |
| 255 | 1.5.4.1.1 | Deliver STE-D FM 1 (stays at UCB for SWEA/STE-D FM 1 I&T) | milestone | 0d | 2004-05-14 | 2004-05-14 | 270 |  |  | 2004-04-14 | 2004-04-14 | 0d | 14d |  |  | MS-BOOM |
| 256 | 1.5.4.1.2 | Deliver STE-D FM 2 (stays at UCB for SWEA/STE-D FM 2 I&T) | milestone | 0d | 2004-07-09 | 2004-07-09 | 278 |  |  | 2004-05-10 | 2004-05-10 | 0d | 20d | 12d |  | MS-BOOM |
| 257 | 1.5.4.1.3 | Deliver STE-U FM 1 (stays at UCB for BOOM Suite FM 1 I&T) | milestone | 0d | 2004-05-21 | 2004-05-21 | 271 |  |  | 2004-04-20 | 2004-04-20 | 0d | 7d | 5d |  | MS-BOOM |
| 258 | 1.5.4.1.4 | Deliver STE-U FM 2 (stays at UCB for BOOM Suite FM 2 I&T) | milestone | 0d | 2004-07-09 | 2004-07-09 | 279 |  |  | 2004-05-10 | 2004-05-10 | 0d | 33d | 5d |  | MS-BOOM |
| 259 | 1.5.4.2 | **STE-U/D Housing** |  | 53d | 2003-11-21 A | 2004-02-09 A |  | 100% |  | 2003-11-21 | 2004-02-09 | 53d |  |  |  |  |
| 260 | 1.5.4.2.1 | Fabricate STE FM 1 Box |  | 53d | 2003-11-21 A | 2004-02-09 A |  | 100% |  | 2003-11-21 | 2004-02-09 | 53d |  |  | start no earlier than 2003-11-21 |  |
| 261 | 1.5.4.2.2 | Fabricate STE FM 2 Box |  | 53d | 2003-11-21 A | 2004-02-09 A |  | 100% |  | 2003-11-21 | 2004-02-09 | 53d |  |  | start no earlier than 2003-11-21 |  |
| 262 | 1.5.4.3 | **STE-U/D Detector Boards** |  | 216d | 2003-08-29 A | 2004-07-09 |  | 77% | 49.02d | 2003-08-29 | 2004-05-10 | 174d | 33d |  |  |  |
| 263 | 1.5.4.3.1 | Coupon Test STE FM 1 & FM 2 Detector Printed Wiring Board |  | 17d | 2003-10-10 A | 2003-11-04 A | 265, 273 | 100% |  | 2003-10-10 | 2003-11-04 | 17d |  |  | start no earlier than 2003-10-10 |  |

| ID | WBS | Task | Type | Duration | Start | Finish | Predecessors | Complete | Remaining | Baseline start | Baseline finish | Baseline duration | Total slack | Free slack | Constraint | Text1 |
| --- | --- | --- | --- | --- | --- | --- | --- | --- | --- | --- | --- | --- | --- | --- | --- | --- |
| 264 | 1.5.4.3.2 | **FM 1** |  | 183d | 2003-08-29 A | 2004-05-21 |  | 88% | 22.27d | 2003-08-29 | 2004-04-20 | 160d | 7d |  |  |  |
| 265 | 1.5.4.3.2.1 | Fabrication STE FM 1 Detector Printed Wiring Board |  | 29d | 2003-08-29 A | 2003-10-09 A |  | 100% |  | 2003-08-29 | 2003-10-09 | 29d |  |  | start no earlier than 2003-08-29 |  |
| 266 | 1.5.4.3.2.2 | Load STE FM 1 Detector Printed Wiring Board |  | 60d | 2003-11-05 A | 2004-02-03 A | 263 | 100% |  | 2003-11-05 | 2004-02-03 | 60d |  |  |  |  |
| 267 | 1.5.4.3.2.3 | Test STE FM 1 Detector Printed Wiring Board |  | 10d | 2004-02-04 A | 2004-02-18 A | 266 | 100% |  | 2004-02-04 | 2004-02-18 | 10d |  |  |  |  |
| 268 | 1.5.4.3.2.4 | **Integration & Test** |  | 67d | 2004-02-19 A | 2004-05-21 |  | 74% | 17.12d | 2004-02-19 | 2004-04-20 | 44d | 7d |  |  |  |
| 269 | 1.5.4.3.2.4.1 | Integrate & Test STE-U/D FM 1 Detectors W/ FM 1 Housings |  | 47d | 2004-02-19 A | 2004-04-23 A | 260, 267 | 100% |  | 2004-02-19 | 2004-03-17 | 20d |  |  |  |  |
| 270 | 1.5.4.3.2.4.2 | Calibrate STE-U/D FM 1 |  | 25d | 2004-04-12 A | 2004-05-14 | 269FS-10d | 60% | 10d | 2004-03-18 | 2004-04-14 | 20d | 7d | 0d |  |  |
| 271 | 1.5.4.3.2.4.3 | STE-U FM 1 Thermal Vacuum/Balance/Bake Out |  | 18d | 2004-04-26 A | 2004-05-21 | 270FS-8d | 28% | 13d | 2004-04-01 | 2004-04-20 | 14d | 7d | 0d |  |  |
| 272 | 1.5.4.3.3 | **FM 2** |  | 216d | 2003-08-29 A | 2004-07-09 |  | 65% | 75.32d | 2003-08-29 | 2004-05-10 | 174d | 33d |  |  |  |
| 273 | 1.5.4.3.3.1 | Fabricate STE FM 2 Detector Printed Wiring Board |  | 29d | 2003-08-29 A | 2003-10-09 A |  | 100% |  | 2003-08-29 | 2003-10-09 | 29d |  |  | start no earlier than 2003-08-29 |  |
| 274 | 1.5.4.3.3.2 | Load STE FM 2 Detector Printed Wiring Board |  | 63d | 2003-11-05 A | 2004-03-12 A | 263, 267FF+17d | 100% |  | 2003-11-05 | 2004-03-17 | 63d |  |  |  |  |
| 275 | 1.5.4.3.3.3 | Test STE FM 2 Detector Printed Wiring Board |  | 45d | 2004-03-15 A | 2004-05-14 | 274 | 78% | 10d | 2004-03-18 | 2004-03-31 | 10d | 20d | 0d |  |  |
| 276 | 1.5.4.3.3.4 | **Integration & Test** |  | 38d | 2004-05-17 | 2004-07-09 |  |  |  | 2004-04-01 | 2004-05-10 | 28d | 20d |  |  |  |
| 277 | 1.5.4.3.3.4.1 | Integrate & Test STE-U/D FM 2 Detectors W/ FM 2 Housings |  | 20d | 2004-05-17 | 2004-06-14 | 261, 275, 269FS-10d, 270 |  |  | 2004-04-01 | 2004-04-14 | 10d | 20d | 0d |  |  |
| 278 | 1.5.4.3.3.4.2 | Calibrate STE-U/D FM 2 |  | 28d | 2004-06-01 | 2004-07-09 | 277FS-10d |  |  | 2004-04-15 | 2004-05-10 | 18d | 20d | 0d |  |  |
| 279 | 1.5.4.3.3.4.3 | STE-U FM 2 Thermal Vacuum/Bake Out |  | 10d | 2004-06-25 | 2004-07-09 | 278FS-10d |  |  | 2004-04-27 | 2004-05-10 | 10d | 33d | 0d |  |  |
| 280 | 1.5.5 | **STE and SWEA - UCB** |  | 313d | 2003-07-01 A | 2004-09-27 |  | 78% | 68.7d | 2003-07-01 | 2004-08-27 | 294d | 5d |  |  |  |
| 281 | 1.5.5.1 | **Deliveries** |  | 90d | 2004-05-14 | 2004-09-22 |  |  |  | 2004-02-27 | 2004-08-27 | 129d | 8d |  |  |  |
| 282 | 1.5.5.1.1 | Deliver STE-U FM 1 Interface (stays at UCB for IDPU FM 1 I&T) | milestone | 0d | 2004-05-14 | 2004-05-14 | 331 |  |  | 2004-02-27 | 2004-02-27 | 0d | 21d | 12d |  | MS-BOOM |
| 283 | 1.5.5.1.2 | Deliver STE-U FM 2 Interface (stays at UCB for IDPU FM 2 I&T) | milestone | 0d | 2004-05-18 | 2004-05-18 | 340 |  |  | 2004-03-01 | 2004-03-01 | 0d | 76d | 40d |  | MS-BOOM |
| 284 | 1.5.5.1.3 | Deliver SWEA/STE-D FM 1 (stays at UCB for Boom Suite FM 1 I&T) | milestone | 0d | 2004-08-10 | 2004-08-10 | 337 |  |  | 2004-06-11 | 2004-06-11 | 0d | -21d | 0d |  | MS-BOOM |
| 285 | 1.5.5.1.4 | Deliver SWEA/STE-D FM 2 (stays at UCB for Boom Suite FM 2 I&T) | milestone | 0d | 2004-09-22 | 2004-09-22 | 346 |  |  | 2004-08-27 | 2004-08-27 | 0d | 8d | 0d |  | MS-BOOM |
| 286 | 1.5.5.2 | **SWEA Pedestal** |  | 152d | 2003-07-01 A | 2004-02-09 A |  | 100% |  | 2003-07-01 | 2004-02-09 | 152d |  |  |  |  |
| 287 | 1.5.5.2.1 | Fabricate SWEA FM 1 Baseplate |  | 152d | 2003-07-01 A | 2004-02-09 A |  | 100% |  | 2003-07-01 | 2004-02-09 | 152d |  |  | start no earlier than 2003-07-01 |  |
| 288 | 1.5.5.2.2 | Fabricate SWEA FM 2 Baseplate |  | 152d | 2003-07-01 A | 2004-02-09 A |  | 100% |  | 2003-07-01 | 2004-02-09 | 152d |  |  | start no earlier than 2003-07-01 |  |

| ID | WBS | Task | Duration | Start | Finish | Predecessors | Complete | Remaining | Baseline start | Baseline finish | Baseline duration | Total slack | Free slack | Constraint |
| --- | --- | --- | --- | --- | --- | --- | --- | --- | --- | --- | --- | --- | --- | --- |
| 289 | 1.5.5.3 | **STE-D Pre-Amp Board** | 163d | 2003-09-22 A | 2004-05-14 |  | 89% | 18.01d | 2003-09-22 | 2004-02-23 | 104d | 28d |  |  |
| 290 | 1.5.5.3.1 | **FM 1** | 163d | 2003-09-22 A | 2004-05-14 |  | 88% | 19.64d | 2003-09-22 | 2004-02-23 | 104d | 0d |  |  |
| 291 | 1.5.5.3.1.1 | Fabricate STE-D FM 1 Preamp Printed Wiring Board | 34d | 2003-09-22 A | 2003-11-07 A |  | 100% |  | 2003-09-22 | 2003-11-07 | 34d |  |  | start no earlier than 2003-09-22 |
| 292 | 1.5.5.3.1.2 | Load STE-D FM 1 Preamp Printed Wiring Board | 49d | 2004-03-09 A | 2004-05-14 | 296 | 80% | 10d | 2004-02-17 | 2004-02-23 | 5d | -16d | 0d | start no earlier than 2004-03-09 |
| 293 | 1.5.5.3.2 | **FM 2** | 163d | 2003-09-22 A | 2004-05-14 |  | 88% | 19.64d | 2003-09-22 | 2004-02-23 | 104d | 28d |  |  |
| 294 | 1.5.5.3.2.1 | Fabricate STE-D FM 2 Preamp Printed Wiring Board | 34d | 2003-09-22 A | 2003-11-07 A |  | 100% |  | 2003-09-22 | 2003-11-07 | 34d |  |  | start no earlier than 2003-09-22 |
| 295 | 1.5.5.3.2.2 | Load STE-D FM 2 Preamp Printed Wiring Board | 49d | 2004-03-09 A | 2004-05-14 | 292SS | 80% | 10d | 2004-02-17 | 2004-02-23 | 5d | 28d | 5d |  |
| 296 | 1.5.5.3.3 | Coupon Test STE-D FM 1 & FM 2 Pre-Amp Printed Wiring Boards | 15d | 2003-11-10 A | 2003-12-02 A | 291, 294 | 100% |  | 2003-11-10 | 2003-12-02 | 15d |  |  |  |
| 297 | 1.5.5.4 | **STE-D Shaper Board** | 118d | 2003-12-04 A | 2004-05-21 |  | 73% | 32.18d | 2003-12-04 | 2004-05-13 | 112d | -21d | 0d |  |
| 298 | 1.5.5.4.1 | **FM 1** | 67d | 2003-12-04 A | 2004-03-11 A |  | 100% |  | 2003-12-04 | 2004-02-20 | 53d |  |  |  |
| 299 | 1.5.5.4.1.1 | Fabricate STE-D FM 1 Shaper Printed Wiring Board | 10d | 2003-12-04 A | 2003-12-17 A |  | 100% |  | 2003-12-04 | 2003-12-17 | 10d |  |  | start no earlier than 2003-12-04 |
| 300 | 1.5.5.4.1.2 | Load STE-D FM 1 Shaper Printed Wiring Board | 5d | 2004-03-05 A | 2004-03-11 A | 304 | 100% |  | 2004-02-13 | 2004-02-20 | 5d |  |  | start no earlier than 2004-03-05 |
| 301 | 1.5.5.4.2 | **FM 2** | 118d | 2003-12-04 A | 2004-05-21 |  | 40% | 70.8d | 2003-12-04 | 2004-05-13 | 112d | -21d | 0d |  |
| 302 | 1.5.5.4.2.1 | Fabricate STE-D FM 2 Shaper Printed Wiring Board | 10d | 2003-12-04 A | 2003-12-17 A |  | 100% |  | 2003-12-04 | 2003-12-17 | 10d |  |  | start no earlier than 2003-12-04 |
| 303 | 1.5.5.4.2.2 | Load STE-D FM 2 Shaper Printed Wiring Board | 15d | 2004-05-03 | 2004-05-21 | 304FS+78d |  |  | 2004-05-07 | 2004-05-13 | 5d | -21d | 0d |  |
| 304 | 1.5.5.4.3 | Coupon Test STE-D FM 1 & FM 2 Shaper Printed Wiring Boards | 15d | 2003-12-18 A | 2004-01-09 A | 299, 302 | 100% |  | 2003-12-18 | 2004-01-09 | 15d |  |  |  |
| 305 | 1.5.5.5 | **STE-D Interface Board** | 118d | 2003-12-04 A | 2004-05-21 |  | 73% | 32.18d | 2003-12-04 | 2004-05-13 | 112d | 23d |  |  |
| 306 | 1.5.5.5.1 | **FM 1** | 67d | 2003-12-04 A | 2004-03-11 A |  | 100% |  | 2003-12-04 | 2004-02-20 | 53d |  |  |  |
| 307 | 1.5.5.5.1.1 | Fabricate SWEA / STE-D FM 1 Digital to Analog Converter Printed Wiring Board | 10d | 2003-12-04 A | 2003-12-17 A |  | 100% |  | 2003-12-04 | 2003-12-17 | 10d |  |  | start no earlier than 2003-12-04 |
| 308 | 1.5.5.5.1.2 | Load SWEA / STE-D FM 1 Digital to Analog Converter Printed Wiring Board | 5d | 2004-03-05 A | 2004-03-11 A | 300SS | 100% |  | 2004-02-13 | 2004-02-20 | 5d |  |  |  |
| 309 | 1.5.5.5.2 | **FM 2** | 118d | 2003-12-04 A | 2004-05-21 |  | 40% | 70.8d | 2003-12-04 | 2004-05-13 | 112d | 23d |  |  |
| 310 | 1.5.5.5.2.1 | Fabricate SWEA / STE-D FM 2 Digital to Analog Converter Printed Wiring Board | 10d | 2003-12-04 A | 2003-12-17 A |  | 100% |  | 2003-12-04 | 2003-12-17 | 10d |  |  | start no earlier than 2003-12-04 |
| 311 | 1.5.5.5.2.2 | Load SWEA / STE-D FM 2 Digital to Analog Converter Printed Wiring Board | 15d | 2004-05-03 | 2004-05-21 | 303SS |  |  | 2004-05-07 | 2004-05-13 | 5d | 23d | 0d |  |
| 312 | 1.5.5.5.3 | Coupon Test STE-D FM 1 & FM 2 D/A Converter Printed Wiring Boards | 15d | 2003-12-18 A | 2004-01-09 A | 307, 310 | 100% |  | 2003-12-18 | 2004-01-09 | 15d |  |  |  |

| ID | WBS | Task | Duration | Start | Finish | Predecessors | Complete | Remaining | Baseline start | Baseline finish | Baseline duration | Total slack | Free slack | Constraint |
| --- | --- | --- | --- | --- | --- | --- | --- | --- | --- | --- | --- | --- | --- | --- |
| 313 | 1.5.5.6 | **STE-U Pre-Amp Board** | 160d | 2003-09-22 A | 2004-05-11 A |  | 100% |  | 2003-09-22 | 2004-02-23 | 104d |  |  |  |
| 314 | 1.5.5.6.1 | **FM 1** | 79d | 2003-09-22 A | 2004-01-15 A |  | 100% |  | 2003-09-22 | 2004-01-15 | 79d |  |  |  |
| 315 | 1.5.5.6.1.1 | Fabricate STE-U FM 1 Preamp Printed Wiring Board | 34d | 2003-09-22 A | 2003-11-07 A |  | 100% |  | 2003-09-22 | 2003-11-07 | 34d |  |  | start no earlier than 2003-09-22 |
| 316 | 1.5.5.6.1.2 | Load STE-U FM 1 Preamp Printed Wiring Board | 4d | 2004-01-12 A | 2004-01-15 A | 320 | 100% |  | 2004-01-12 | 2004-01-15 | 4d |  |  | start no earlier than 2004-01-12 |
| 317 | 1.5.5.6.2 | **FM 2** | 160d | 2003-09-22 A | 2004-05-11 A |  | 100% |  | 2003-09-22 | 2004-02-23 | 104d |  |  |  |
| 318 | 1.5.5.6.2.1 | Fabricate STE-U FM 2 Preamp Printed Wiring Board | 34d | 2003-09-22 A | 2003-11-07 A |  | 100% |  | 2003-09-22 | 2003-11-07 | 34d |  |  | start no earlier than 2003-09-22 |
| 319 | 1.5.5.6.2.2 | Load STE-U FM 2 Preamp Printed Wiring Board | 46d | 2004-03-09 A | 2004-05-11 A | 320 | 100% |  | 2004-02-17 | 2004-02-23 | 5d |  |  | start no earlier than 2004-03-09 |
| 320 | 1.5.5.6.3 | Coupon Test STE-U FM 1 & FM 2 Pre-Amp Printed Wiring Boards | 15d | 2003-11-10 A | 2003-12-02 A | 315, 318 | 100% |  | 2003-11-10 | 2003-12-02 | 15d |  |  |  |
| 321 | 1.5.5.7 | **STE-U Shaper & Interface Board** | 78d | 2003-12-04 A | 2004-03-26 A |  | 100% |  | 2003-12-04 | 2004-02-20 | 53d |  |  |  |
| 322 | 1.5.5.7.1 | **FM 1** | 73d | 2003-12-04 A | 2004-03-19 A |  | 100% |  | 2003-12-04 | 2004-02-20 | 53d |  |  |  |
| 323 | 1.5.5.7.1.1 | Fabricate STE-U FM 1Shaper & Interface Printed Wiring Board | 10d | 2003-12-04 A | 2003-12-17 A |  | 100% |  | 2003-12-04 | 2003-12-17 | 10d |  |  | start no earlier than 2003-12-04 |
| 324 | 1.5.5.7.1.2 | Load STE-U FM 1 Shaper & Interface Printed Wiring Board | 13d | 2004-03-03 A | 2004-03-19 A | 328 | 100% |  | 2004-02-13 | 2004-02-20 | 5d |  |  | start no earlier than 2004-03-03 |
| 325 | 1.5.5.7.2 | **FM 2** | 78d | 2003-12-04 A | 2004-03-26 A |  | 100% |  | 2003-12-04 | 2004-02-20 | 53d |  |  |  |
| 326 | 1.5.5.7.2.1 | Fabricate STE-U FM 2 Shaper & Interface Printed Wiring Board | 10d | 2003-12-04 A | 2003-12-17 A |  | 100% |  | 2003-12-04 | 2003-12-17 | 10d |  |  | start no earlier than 2003-12-04 |
| 327 | 1.5.5.7.2.2 | Load STE-U FM 2 Shaper & Interface Printed Wiring Board | 5d | 2004-03-22 A | 2004-03-26 A | 324 | 100% |  | 2004-02-13 | 2004-02-20 | 5d |  |  |  |
| 328 | 1.5.5.7.3 | Coupon Test STE-U FM 1 & FM 2 Shaper & Interface Printed Wiring Boards | 15d | 2003-12-18 A | 2004-01-09 A | 323, 326 | 100% |  | 2003-12-18 | 2004-01-09 | 15d |  |  |  |
| 329 | 1.5.5.8 | **Integration & Test** | 133d | 2004-03-22 A | 2004-09-27 |  | 15% | 112.43d | 2004-02-23 | 2004-08-27 | 134d | 5d |  |  |
| 330 | 1.5.5.8.1 | **FM 1** | 133d | 2004-03-22 A | 2004-09-27 |  | 25% | 99.47d | 2004-02-23 | 2004-07-30 | 114d | 2d |  |  |
| 331 | 1.5.5.8.1.1 | Integrate & Test STE-U FM 1 Interface Boards | 40d | 2004-03-22 A | 2004-05-14 | 316, 324 | 75% | 10d | 2004-02-23 | 2004-02-27 | 5d | 21d | 0d |  |
| 332 | 1.5.5.8.1.2 | Integrate & Test SWEA/STE-D FM 1 Interface Boards | 20d | 2004-05-24 | 2004-06-21 | 287, 292, 300, 308, 303 |  |  | 2004-02-24 | 2004-03-22 | 20d | -21d | 0d |  |
| 333 | 1.5.5.8.1.3 | Integrate & Test SWEA/STE-D FM 1 Interface with SWEA/STE-D FM 1 LVPS | 10d | 2004-06-22 | 2004-07-06 | 332, 69 |  |  | 2004-04-16 | 2004-04-29 | 10d | -21d | 0d |  |
| 334 | 1.5.5.8.1.4 | Clean/Coat/Stake SWEA/STE-D Interface | 10d | 2004-06-22 | 2004-07-06 | 332 |  |  | 2004-03-23 | 2004-04-05 | 10d | -21d | 0d |  |
| 335 | 1.5.5.8.1.5 | Integrate & Test SWEA/STE-D FM 1 Combined | 5d | 2004-07-07 | 2004-07-13 | 333, 334, 248, 255 |  |  | 2004-04-30 | 2004-05-06 | 5d | -21d | 0d |  |
| 336 | 1.5.5.8.1.6 | Calibrate SWEA/STE FM 1 | 15d | 2004-07-14 | 2004-08-03 | 335 |  |  | 2004-05-07 | 2004-06-04 | 20d | -21d | 0d |  |
| 337 | 1.5.5.8.1.7 | SWEA/STE FM 1 Vibration | 5d | 2004-08-04 | 2004-08-10 | 336 |  |  | 2004-06-07 | 2004-06-11 | 5d | -21d | 0d |  |
| 338 | 1.5.5.8.1.8 | SWEA/STE-D FM 1 Thermal Vac/Thermal Balance/Bake Out | 14d | 2004-09-08 | 2004-09-27 | 337, 19 |  |  | 2004-07-13 | 2004-07-30 | 14d | 2d | 0d |  |

Notes:
- 331: STE-U FM1 was completed and started thermal vac. Unfortunately we had a problem in thermal vac and STE-U FM1 is currently disassembled while we fix the problem.

| ID | WBS | Task | Duration | Start | Finish | Predecessors | Complete | Remaining | Baseline start | Baseline finish | Baseline duration | Total slack | Free slack | Constraint | Text1 |
| --- | --- | --- | --- | --- | --- | --- | --- | --- | --- | --- | --- | --- | --- | --- | --- |
| 339 | 1.5.5.8.2 | **FM 2** | 93d | 2004-05-12 | 2004-09-22 |  |  |  | 2004-02-24 | 2004-08-27 | 133d | 8d |  |  |  |
| 340 | 1.5.5.8.2.1 | Integrate & Test STE-U FM 2 Interface Boards | 5d | 2004-05-12 | 2004-05-18 | 319, 327 |  |  | 2004-02-24 | 2004-03-01 | 5d | 76d | 0d |  |  |
| 341 | 1.5.5.8.2.2 | Integrate & Test SWEA/STE-D FM 2 Interface Boards | 20d | 2004-05-24 | 2004-06-21 | 288, 295, 303, 311 |  |  | 2004-05-14 | 2004-06-11 | 20d | 23d | 15d |  |  |
| 342 | 1.5.5.8.2.3 | Integrate & Test SWEA/STE-D FM 2 Interface with SWEA/STE-D FM 2 LVPS | 10d | 2004-07-14 | 2004-07-27 | 341, 75 |  |  | 2004-06-14 | 2004-06-25 | 10d | 8d | 0d |  |  |
| 343 | 1.5.5.8.2.4 | Integrate & Test SWEA/STE-D FM 2 Combined | 10d | 2004-07-28 | 2004-08-10 | 342, 249, 256 |  |  | 2004-06-28 | 2004-07-09 | 10d | 8d | 0d |  |  |
| 344 | 1.5.5.8.2.5 | Calibrate SWEA/STE FM 2 | 15d | 2004-08-11 | 2004-08-31 | 343 |  |  | 2004-07-12 | 2004-08-06 | 20d | 8d | 0d |  |  |
| 345 | 1.5.5.8.2.6 | SWEA/STE FM 2 Vibration | 5d | 2004-09-01 | 2004-09-08 | 344 |  |  | 2004-08-09 | 2004-08-13 | 5d | 8d | 0d |  |  |
| 346 | 1.5.5.8.2.7 | SWEA/STE-D FM 2 Thermal Vac & bake Out | 10d | 2004-09-09 | 2004-09-22 | 345 |  |  | 2004-08-16 | 2004-08-27 | 10d | 8d | 0d |  |  |
| 347 | 1.5.6 | **Boom Suite I&T - UCB** | 96d | 2004-06-01 | 2004-10-15 |  |  |  | 2004-04-21 | 2004-09-28 | 113d | 2d |  |  |  |
| 348 | 1.5.6.1 | **FM 1** | 88d | 2004-06-01 | 2004-10-04 |  |  |  | 2004-04-21 | 2004-08-13 | 82d | 2d |  |  |  |
| 349 | 1.5.6.1.1 | FM 1 Boom/MAG/STE-U I&T | 4d | 2004-06-01 | 2004-06-04 | 210, 238, 257 |  |  | 2004-04-21 | 2004-04-26 | 4d | 2d | 0d |  | MS-BOOM |
| 350 | 1.5.6.1.2 | FM 1 Boom/SWEA/STE/MAG I&T | 2d | 2004-08-11 | 2004-08-12 | 284, 184 |  |  | 2004-06-14 | 2004-06-15 | 2d | -21d | 0d |  |  |
| 351 | 1.5.6.1.3 | FM 1 Integrated Boom/IDPU I&T | 4d | 2004-08-13 | 2004-08-18 | 350, 184, 160 |  |  | 2004-06-16 | 2004-06-21 | 4d | -21d | 0d |  |  |
| 352 | 1.5.6.1.4 | Final BOOM Suite FM 1 I & T | 5d | 2004-09-28 | 2004-10-04 | 351, 338 |  |  | 2004-08-02 | 2004-08-13 | 10d | 2d | 0d |  |  |
| 353 | 1.5.6.2 | **FM 2** | 63d | 2004-07-19 | 2004-10-15 |  |  |  | 2004-05-11 | 2004-09-28 | 99d | 8d |  |  |  |
| 354 | 1.5.6.2.1 | FM 2 Boom/MAG/STE-U I&T | 4d | 2004-07-19 | 2004-07-22 | 232, 239, 258 |  |  | 2004-05-11 | 2004-05-14 | 4d | 28d | 0d |  | MS-BOOM |
| 355 | 1.5.6.2.2 | FM 2 Boom/SWEA/STE/MAG I&T | 2d | 2004-09-23 | 2004-09-24 | 285, 185 |  |  | 2004-08-30 | 2004-08-31 | 2d | 8d | 0d |  |  |
| 356 | 1.5.6.2.3 | FM 2 Integrated Boom/IDPU I&T | 4d | 2004-09-27 | 2004-09-30 | 355, 185, 777 |  |  | 2004-09-01 | 2004-09-07 | 4d | 8d | 0d |  |  |
| 357 | 1.5.6.2.4 | Boom Suite FM 2 EMC | 5d | 2004-10-01 | 2004-10-07 | 356 |  |  | 2004-09-08 | 2004-09-14 | 5d | 8d | 0d |  | MS-BOOM |
| 358 | 1.5.6.2.5 | Final BOOM Suite FM 2 I & T | 5d | 2004-10-08 | 2004-10-15 | 357 |  |  | 2004-09-15 | 2004-09-28 | 10d | 8d | 0d |  |  |
| 359 | 1.6 | **SEP Suite - CIT** | 379d | 2003-06-02 A | 2004-12-02 |  | 66% | 128.5d | 2003-06-02 | 2004-10-21 | 352d | -23d | 0d |  |  |
| 360 | 1.6.1 | **SEP Mechanical - Sandy Shuman (GSFC)** | 144d | 2004-01-27 A | 2004-08-18 |  | 43% | 82.54d | 2004-01-27 | 2004-06-02 | 90d | 24d |  |  |  |
| 361 | 1.6.1.1 | **SIT Electronics Enclosure (Priority 1)** | 70d | 2004-02-09 A | 2004-05-17 |  | 71% | 20.26d | 2004-02-09 | 2004-03-16 | 26d | 25d |  |  |  |
| 362 | 1.6.1.1.1 | Complete Design/Drawings for SIT Enclosure | 10d | 2004-02-09 A | 2004-02-23 A |  | 100% |  | 2004-02-09 | 2004-02-23 | 10d |  |  | start no earlier than 2004-02-09 |  |
| 363 | 1.6.1.1.2 | Fabrication of SIT Enclosure | 21d | 2004-04-08 A | 2004-05-06 | 362FS+32d | 81% | 4d | 2004-02-24 | 2004-03-08 | 10d | 25d | 0d |  |  |
| 364 | 1.6.1.1.3 | Inspection and Final Assembly of SIT Enclosure | 6d | 2004-05-07 | 2004-05-14 | 363 |  |  | 2004-03-09 | 2004-03-15 | 5d | 25d | 0d |  |  |
| 365 | 1.6.1.1.4 | Deliver SIT Enclosure to UMD | 1d | 2004-05-17 | 2004-05-17 | 364 |  |  | 2004-03-16 | 2004-03-16 | 1d | 25d |  |  |  |

| ID | WBS | Task | Type | Duration | Start | Finish | Predecessors | Complete | Remaining | Baseline start | Baseline finish | Baseline duration | Total slack | Free slack | Constraint | Text1 |
| --- | --- | --- | --- | --- | --- | --- | --- | --- | --- | --- | --- | --- | --- | --- | --- | --- |
| 366 | 1.6.1.2 | **SEP FM 1 & FM 2 LVPS Boxes (Priority 2)** |  | 53d | 2004-02-09 A | 2004-04-22 A |  | 100% |  | 2004-02-09 | 2004-03-11 | 23d |  |  |  |  |
| 367 | 1.6.1.2.1 | Complete Design/Drawings for SEP LVPS Boxes |  | 5d | 2004-02-09 A | 2004-02-13 A | 362SS | 100% |  | 2004-02-09 | 2004-02-13 | 5d |  |  |  |  |
| 368 | 1.6.1.2.2 | Fabrication of SEP LVPS Boxes |  | 35d | 2004-02-17 A | 2004-04-05 A | 367 | 100% |  | 2004-02-17 | 2004-03-01 | 10d |  |  |  |  |
| 369 | 1.6.1.2.3 | Inspection of SEP LVPS Boxes (Final Assembly at UCB) |  | 10d | 2004-04-06 A | 2004-04-19 A | 368 | 100% |  | 2004-03-02 | 2004-03-08 | 5d |  |  |  |  |
| 370 | 1.6.1.2.4 | Deliver SEP LVPS Boxes to UCB |  | 3d | 2004-04-20 A | 2004-04-22 A | 369 | 100% |  | 2004-03-09 | 2004-03-11 | 3d |  |  | start no earlier than 2004-04-07 |  |
| 371 | 1.6.1.3 | **SEP Electronics Enclosure (Priority 3)** |  | 92d | 2004-02-17 A | 2004-06-24 |  | 56% | 40.78d | 2004-02-17 | 2004-03-30 | 31d | 2d |  |  |  |
| 372 | 1.6.1.3.1 | Complete Design/Drawings for SEP Enclosure |  | 73d | 2004-02-17 A | 2004-05-27 | 367 | 74% | 19d | 2004-02-17 | 2004-03-04 | 13d | -4d | 0d |  |  |
| 373 | 1.6.1.3.2 | Fabrication of SEP Enclosure |  | 15d | 2004-05-21 | 2004-06-11 | 372FS-5d |  |  | 2004-03-05 | 2004-03-18 | 10d | 2d | 0d |  |  |
| 374 | 1.6.1.3.3 | Inspection and Final Assembly of SEP Enclosure |  | 6d | 2004-06-14 | 2004-06-21 | 373 |  |  | 2004-03-19 | 2004-03-25 | 5d | 2d | 0d |  |  |
| 375 | 1.6.1.3.4 | Deliver SEP Enclosure to CIT |  | 3d | 2004-06-22 | 2004-06-24 | 374 |  |  | 2004-03-26 | 2004-03-30 | 3d | 2d |  |  | MS-SEP |
| 376 | 1.6.1.4 | **SEP Central Bias Supply Shields (Priority 4)** |  | 20d | 2004-05-25 | 2004-06-22 |  |  |  | 2004-03-05 | 2004-04-01 | 20d | -4d | 0d |  |  |
| 377 | 1.6.1.4.1 | Complete Design/Drawings for Bias Supply Shields |  | 5d | 2004-05-25 | 2004-06-01 | 372FS-3d |  |  | 2004-03-05 | 2004-03-11 | 5d | -4d | 0d |  |  |
| 378 | 1.6.1.4.2 | Fabrication of Bias Supply Shields |  | 10d | 2004-06-02 | 2004-06-15 | 377 |  |  | 2004-03-12 | 2004-03-25 | 10d | 64d | 0d |  |  |
| 379 | 1.6.1.4.3 | Inspection and Delivery (to CIT) of Bias Supply Shields |  | 5d | 2004-06-16 | 2004-06-22 | 378 |  |  | 2004-03-26 | 2004-04-01 | 5d | 64d | 23d |  |  |
| 380 | 1.6.1.5 | **LET Telescope (Priority 5)** |  | 26d | 2004-05-25 | 2004-06-30 |  |  |  | 2004-03-12 | 2004-04-16 | 26d | -4d | 0d |  |  |
| 381 | 1.6.1.5.1 | Complete Design/Drawings for LET Telescope |  | 5d | 2004-05-25 | 2004-06-01 | 377FS-5d |  |  | 2004-03-12 | 2004-03-23 | 8d | -4d | 0d |  |  |
| 382 | 1.6.1.5.2 | Fabrication of LET Telescope |  | 10d | 2004-06-02 | 2004-06-15 | 381 |  |  | 2004-03-24 | 2004-04-06 | 10d | -4d | 0d |  |  |
| 383 | 1.6.1.5.3 | Inspection and Final Assembly of LET Telescope (CIT has detectors) |  | 8d | 2004-06-16 | 2004-06-25 | 382 |  |  | 2004-04-07 | 2004-04-13 | 5d | -4d | 0d |  |  |
| 384 | 1.6.1.5.4 | Deliver LET Telescope to CIT |  | 3d | 2004-06-28 | 2004-06-30 | 383 |  |  | 2004-04-14 | 2004-04-16 | 3d | -4d | 0d |  |  |
| 385 | 1.6.1.6 | **HET Electronics Enclosure (Priority 6)** |  | 67d | 2004-03-22 A | 2004-06-23 |  | 21% | 52.89d | 2004-03-24 | 2004-04-23 | 23d | 4d |  |  |  |
| 386 | 1.6.1.6.1 | Complete Design/Drawings for HET Enclosure |  | 23d | 2004-03-22 A | 2004-06-02 | 381FS-14d | 35% | 15d | 2004-03-24 | 2004-04-02 | 8d | -1d | 0d |  |  |
| 387 | 1.6.1.6.2 | Fabrication of HET Enclosure |  | 10d | 2004-06-03 | 2004-06-16 | 386 |  |  | 2004-04-05 | 2004-04-16 | 10d | 1d | 0d |  |  |
| 388 | 1.6.1.6.3 | Inspection and Final Assembly of HET Enclosure |  | 5d | 2004-06-17 | 2004-06-23 | 387 |  |  | 2004-04-19 | 2004-04-23 | 5d | 1d | 0d |  |  |
| 389 | 1.6.1.6.4 | Deliver HET Enclosure (stays at GSFC) | milestone | 0d | 2004-06-23 | 2004-06-23 | 388 |  |  | 2004-04-23 | 2004-04-23 | 0d | 4d | 0d |  |  |

| ID | WBS | Task | Type | Duration | Start | Finish | Predecessors | Complete | Remaining | Baseline start | Baseline finish | Baseline duration | Total slack | Free slack | Constraint | Text1 |
| --- | --- | --- | --- | --- | --- | --- | --- | --- | --- | --- | --- | --- | --- | --- | --- | --- |
| 390 | 1.6.1.7 | **HET Telescope (Priority 7)** |  | 102d | 2004-01-27 A | 2004-06-18 |  | 65% | 35.31d | 2004-01-27 | 2004-04-30 | 68d | 4d |  |  |  |
| 391 | 1.6.1.7.1 | On Going work for HET Telescope (Complete Design/Drawings & Prep for Fab) |  | 89d | 2004-01-27 A | 2004-06-02 | 386FF | 76% | 21d | 2004-01-27 | 2004-03-31 | 46d | -1d | 0d | finish no earlier than 2004-06-01 |  |
| 392 | 1.6.1.7.2 | Fabrication of HET Telescope |  | 10d | 2004-05-28 | 2004-06-11 | 391FS-3d |  |  | 2004-04-01 | 2004-04-14 | 10d | 4d | 0d |  |  |
| 393 | 1.6.1.7.3 | Inspection and Final Assembly of HET Telescope |  | 5d | 2004-06-14 | 2004-06-18 | 392, 388SS-3d, 389FS-8d |  |  | 2004-04-26 | 2004-04-30 | 5d | 4d | 0d |  | MS-SEP |
| 394 | 1.6.1.7.4 | Deliver HET Telescope (stays at GSFC) | milestone | 0d | 2004-06-18 | 2004-06-18 | 393 |  |  | 2004-04-30 | 2004-04-30 | 0d | 4d | 0d |  | MS-SEP |
| 395 | 1.6.1.8 | **SIT Telescope (Priority 8)** |  | 39d | 2004-06-03 | 2004-07-28 |  |  |  | 2004-04-01 | 2004-05-18 | 34d | -25d | 0d |  |  |
| 396 | 1.6.1.8.1 | Complete Design/Drawings for SIT Telescope |  | 18d | 2004-06-03 | 2004-06-28 | 391 |  |  | 2004-04-01 | 2004-04-26 | 18d | -25d | 0d |  |  |
| 397 | 1.6.1.8.2 | Fabrication of SIT Telescope |  | 10d | 2004-06-29 | 2004-07-13 | 396 |  |  | 2004-04-27 | 2004-05-10 | 10d | -25d | 0d |  |  |
| 398 | 1.6.1.8.3 | Inspection and Final Assembly of SIT Telescope |  | 10d | 2004-07-14 | 2004-07-27 | 397 |  |  | 2004-05-11 | 2004-05-17 | 5d | -25d | 0d |  |  |
| 399 | 1.6.1.8.4 | Deliver SIT Telescope to UMD (Includes the Foils and Detectors) |  | 1d | 2004-07-28 | 2004-07-28 | 398 |  |  | 2004-05-18 | 2004-05-18 | 1d | -25d | 0d |  |  |
| 400 | 1.6.1.9 | **Shipping Containers for HET, SIT & SEP Central (Priority 9)** |  | 23d | 2004-05-10 | 2004-06-10 |  |  |  | 2004-04-27 | 2004-05-27 | 23d | 15d |  |  |  |
| 401 | 1.6.1.9.1 | Design |  | 5d | 2004-05-10 | 2004-05-14 |  |  |  | 2004-04-27 | 2004-05-03 | 5d | 15d | 0d | start no earlier than 2004-05-10 |  |
| 402 | 1.6.1.9.2 | Fabrication/Machining |  | 10d | 2004-05-17 | 2004-05-28 | 401 |  |  | 2004-05-04 | 2004-05-17 | 10d | 15d | 0d |  |  |
| 403 | 1.6.1.9.3 | Inspection and Assembly |  | 5d | 2004-06-01 | 2004-06-07 | 402 |  |  | 2004-05-18 | 2004-05-24 | 5d | 15d | 0d |  |  |
| 404 | 1.6.1.9.4 | HET Container stays at GSFC | milestone | 0d | 2004-06-07 | 2004-06-07 | 403 |  |  | 2004-05-24 | 2004-05-24 | 0d | 18d | 14d |  |  |
| 405 | 1.6.1.9.5 | SIT Container to UMD |  | 1d | 2004-06-08 | 2004-06-08 | 403 |  |  | 2004-05-25 | 2004-05-25 | 1d | 29d |  |  |  |
| 406 | 1.6.1.9.6 | SEP Central Container to CIT |  | 3d | 2004-06-08 | 2004-06-10 | 403 |  |  | 2004-05-25 | 2004-05-27 | 3d | 15d |  |  |  |
| 407 | 1.6.1.10 | **SIT Door (Priority 10)** |  | 27d | 2004-06-29 | 2004-08-05 |  |  |  | 2004-05-18 | 2004-06-24 | 27d | -22d | 0d |  |  |
| 408 | 1.6.1.10.1 | Complete Design/Drawings for SIT Door |  | 10d | 2004-06-29 | 2004-07-13 | 396 |  |  | 2004-05-18 | 2004-06-01 | 10d | -22d | 0d |  |  |
| 409 | 1.6.1.10.2 | Fabrication |  | 10d | 2004-07-14 | 2004-07-27 | 408 |  |  | 2004-06-02 | 2004-06-15 | 10d | 5d | 0d |  |  |
| 410 | 1.6.1.10.3 | Inspection |  | 5d | 2004-07-28 | 2004-08-03 | 409 |  |  | 2004-06-16 | 2004-06-22 | 5d | 5d | 0d |  |  |
| 411 | 1.6.1.10.4 | Final Assembly |  | 1d | 2004-08-04 | 2004-08-04 | 410 |  |  | 2004-06-23 | 2004-06-23 | 1d | 5d | 0d |  |  |
| 412 | 1.6.1.10.5 | Deliver SIT Door (stay at GSFC for Environmental Testing) |  | 1d | 2004-08-05 | 2004-08-05 | 411 |  |  | 2004-06-24 | 2004-06-24 | 1d | 5d |  |  |  |
| 413 | 1.6.1.11 | **LET Radiation Test Fixture (Priority 11)** |  | 26d | 2004-07-14 | 2004-08-18 |  |  |  | 2004-05-04 | 2004-06-02 | 21d | -22d | 0d |  |  |
| 414 | 1.6.1.11.1 | Design |  | 5d | 2004-07-14 | 2004-07-20 | 408 |  |  | 2004-05-04 | 2004-05-10 | 5d | -22d | 0d |  |  |
| 415 | 1.6.1.11.2 | Fabrication |  | 10d | 2004-07-21 | 2004-08-03 | 414 |  |  | 2004-05-11 | 2004-05-24 | 10d | -22d | 0d |  |  |
| 416 | 1.6.1.11.3 | Inspection and Assembly |  | 10d | 2004-08-04 | 2004-08-17 | 415 |  |  | 2004-05-25 | 2004-06-01 | 5d | -22d | 0d |  |  |
| 417 | 1.6.1.11.4 | Deliver to CIT for SEP I&T |  | 1d | 2004-08-18 | 2004-08-18 | 416 |  |  | 2004-06-02 | 2004-06-02 | 1d | -22d | 0d |  |  |

| ID | WBS | Task | Type | Duration | Start | Finish | Predecessors | Complete | Remaining | Baseline start | Baseline finish | Baseline duration | Total slack | Free slack | Constraint | Text1 |
| --- | --- | --- | --- | --- | --- | --- | --- | --- | --- | --- | --- | --- | --- | --- | --- | --- |
| 418 | 1.6.2 | **SEP Central - CIT** |  | 265d | 2003-08-01 A | 2004-08-19 |  | 77% | 60.78d | 2003-08-01 | 2004-06-03 | 211d | 23d |  |  |  |
| 419 | 1.6.2.1 | **Deliveries** |  | 40d | 2004-06-23 | 2004-08-19 |  |  |  | 2004-04-14 | 2004-06-03 | 35d | 3d |  |  |  |
| 420 | 1.6.2.1.1 | Deliver all SEP Cen FM 1 Boards to SEP I&T (stays at CIT) | milestone | 0d | 2004-06-23 | 2004-06-23 | 444 |  |  | 2004-05-10 | 2004-05-10 | 0d | 3d |  |  | MS-SEP |
| 421 | 1.6.2.1.2 | Deliver all SEP Cen FM 2 Boards & FM 2 LVPS to SEP I&T (stays at CIT) | milestone | 0d | 2004-07-26 | 2004-07-26 | 444, 74, 379 |  |  | 2004-05-10 | 2004-05-10 | 0d | 41d | 0d |  | MS-SEP |
| 422 | 1.6.2.1.3 | SEP Central Build 3 Software Complete | milestone | 0d | 2004-06-30 | 2004-06-30 | 446 |  |  | 2004-04-14 | 2004-04-14 | 0d | -2d | 0d |  |  |
| 423 | 1.6.2.1.4 | Final SEP Central Flight Software Complete | milestone | 0d | 2004-08-19 | 2004-08-19 | 447 |  |  | 2004-06-03 | 2004-06-03 | 0d | -20d | 0d |  |  |
| 424 | 1.6.2.2 | **Logic Board** |  | 75d | 2004-02-13 A | 2004-05-28 |  | 81% | 14.29d | 2004-02-13 | 2004-03-26 | 30d | 1d |  |  |  |
| 425 | 1.6.2.2.1 | **Assembly** |  | 10d | 2004-02-13 A | 2004-02-27 A |  | 100% |  | 2004-02-13 | 2004-02-27 | 10d |  |  |  |  |
| 426 | 1.6.2.2.1.1 | Assemble FM 1 SEP Central Logic board |  | 10d | 2004-02-13 A | 2004-02-27 A |  | 100% |  | 2004-02-13 | 2004-02-27 | 10d |  |  | start no earlier than 2004-02-13 | MS-SEP |
| 427 | 1.6.2.2.1.2 | Assemble FM 2 SEP Central Logic board |  | 10d | 2004-02-13 A | 2004-02-27 A | 426SS | 100% |  | 2004-02-13 | 2004-02-27 | 10d |  |  |  | MS-SEP |
| 428 | 1.6.2.2.2 | **Test** |  | 65d | 2004-03-01 A | 2004-05-28 |  | 76% | 15.29d | 2004-03-01 | 2004-03-26 | 20d | 1d |  |  |  |
| 429 | 1.6.2.2.2.1 | Test FM 1 SEP Central Logic board (initial) |  | 20d | 2004-03-01 A | 2004-03-26 A | 426 | 100% |  | 2004-03-01 | 2004-03-26 | 20d |  |  |  |  |
| 430 | 1.6.2.2.2.2 | Test FM 2 SEP Central Logic board (initial) |  | 65d | 2004-03-01 A | 2004-05-28 | 427 | 69% | 20d | 2004-03-01 | 2004-03-26 | 20d | 1d | 0d |  |  |
| 431 | 1.6.2.3 | **Analog/Post-Reg Board** |  | 0d | 2004-01-27 A | 2004-01-27 A |  | 100% |  | 2004-01-27 | 2004-01-27 | 0d |  |  |  |  |
| 432 | 1.6.2.3.1 | FM 1 Analog/Post-Reg Board Complete Test and awaiting Conformal Coat with other SEP Central Boards | milestone | 0d | 2004-01-27 A | 2004-01-27 A |  | 100% |  | 2004-01-27 | 2004-01-27 | 0d |  |  | start no earlier than 2004-01-27 |  |
| 433 | 1.6.2.3.2 | FM 2 Analog/Post-Reg Board Complete Test and awaiting Conformal Coat with other SEP Central Boards | milestone | 0d | 2004-01-27 A | 2004-01-27 A |  | 100% |  | 2004-01-27 | 2004-01-27 | 0d |  |  | start no earlier than 2004-01-27 |  |
| 434 | 1.6.2.4 | **SEP Solid State Detector Bias Supply Board** |  | 55d | 2004-01-20 A | 2004-04-06 A |  | 100% |  | 2004-01-20 | 2004-04-15 | 62d |  |  |  |  |
| 435 | 1.6.2.4.1 | **Assembly & Initial Test** |  | 40d | 2004-01-20 A | 2004-03-16 A |  | 100% |  | 2004-01-20 | 2004-03-16 | 40d |  |  |  |  |
| 436 | 1.6.2.4.1.1 | Assemble and Initial Test FM 1 SSD Bias Supply Board |  | 40d | 2004-01-20 A | 2004-03-16 A |  | 100% |  | 2004-01-20 | 2004-03-16 | 40d |  |  | start no earlier than 2004-01-20 |  |
| 437 | 1.6.2.4.1.2 | Assemble and Initial Test FM 2 SSD Bias Supply Board |  | 40d | 2004-01-20 A | 2004-03-16 A | 436SS | 100% |  | 2004-01-20 | 2004-03-16 | 40d |  |  |  |  |
| 438 | 1.6.2.4.2 | **Final Test** |  | 15d | 2004-03-17 A | 2004-04-06 A |  | 100% |  | 2004-04-02 | 2004-04-15 | 10d |  |  |  |  |
| 439 | 1.6.2.4.2.1 | Final Test FM 1 SSD Bias Supply Board |  | 15d | 2004-03-17 A | 2004-04-06 A | 436 | 100% |  | 2004-04-02 | 2004-04-15 | 10d |  |  |  |  |
| 440 | 1.6.2.4.2.2 | Final Test FM 2 SSD Bias Supply Board |  | 15d | 2004-03-17 A | 2004-04-06 A | 437 | 100% |  | 2004-04-02 | 2004-04-15 | 10d |  |  |  |  |
| 441 | 1.6.2.5 | **Conformal Coat, Mass Properties and Bake Out (SEP Central, LET, SEP LVPS)** |  | 17d | 2004-06-01 | 2004-06-23 |  |  |  | 2004-04-16 | 2004-05-10 | 17d | 1d |  |  |  |
| 442 | 1.6.2.5.1 | Stake/Conformal Coat All SEP Central and LET Boards |  | 10d | 2004-06-01 | 2004-06-14 | 429, 430, 432, 433, 439, 440, 518, 519 |  |  | 2004-04-16 | 2004-04-29 | 10d | 1d | 0d |  |  |
| 443 | 1.6.2.5.2 | Mass Properties/Photo All SEP Central and LET Boards |  | 4d | 2004-06-15 | 2004-06-18 | 442 |  |  | 2004-04-30 | 2004-05-05 | 4d | 1d | 0d |  |  |
| 444 | 1.6.2.5.3 | Bake Out All SEP Central/LET Boards and SEP LVPS FM 1 |  | 3d | 2004-06-21 | 2004-06-23 | 443, 68 |  |  | 2004-05-06 | 2004-05-10 | 3d | 1d | 0d |  |  |

Notes:
- 444: SEP FM 2 LVPS Bakeout will occur at Berkley prior to delivery 6/18. This allows LET to proceed, which has more to do before I&T than SEP Central.

| ID | WBS | Task | Type | Duration | Start | Finish | Predecessors | Complete | Remaining | Baseline start | Baseline finish | Baseline duration | Total slack | Free slack | Constraint | Text1 |
| --- | --- | --- | --- | --- | --- | --- | --- | --- | --- | --- | --- | --- | --- | --- | --- | --- |
| 445 | 1.6.2.6 | **Flight Software** |  | 265d | 2003-08-01 A | 2004-08-19 |  | 71% | 77d | 2003-08-01 | 2004-06-03 | 211d | -20d | 0d |  |  |
| 446 | 1.6.2.6.1 | SEP Central Build 3 |  | 230d | 2003-08-01 A | 2004-06-30 |  | 82% | 42d | 2003-08-01 | 2004-04-14 | 176d | -20d | 0d | start no earlier than 2003-08-01 |  |
| 447 | 1.6.2.6.2 | Final Flight S/W Build |  | 35d | 2004-07-01 | 2004-08-19 | 446 |  |  | 2004-04-15 | 2004-06-03 | 35d | -20d | 0d |  |  |
| 448 | 1.6.3 | **HET - Tycho (GSFC)** |  | 148d | 2004-01-06 A | 2004-08-04 |  | 70% | 44.8d | 2004-01-06 | 2004-06-23 | 119d | 40d |  |  |  |
| 449 | 1.6.3.1 | **Deliveries** |  | 31d | 2004-06-22 | 2004-08-04 |  |  |  | 2004-04-30 | 2004-06-23 | 38d | 8d |  |  |  |
| 450 | 1.6.3.1.1 | Deliver HET FM 1w/o replacement detectors (to CIT for SEP Suite I&T) |  | 2d | 2004-06-28 | 2004-06-29 | 404, 495 |  |  | 2004-06-01 | 2004-06-02 | 2d | 4d | 0d |  | MS-SEP |
| 451 | 1.6.3.1.2 | Deliver HET FM 1 w/ replacement detectors (to CIT for SEP Suite I&T) |  | 2d | 2004-07-20 | 2004-07-21 | 498 |  |  | 2004-07-19 | 2004-07-20 | 2d | -4d | 0d |  |  |
| 452 | 1.6.3.1.3 | Deliver HET FM 2 w/ replacement detectors (to CIT for SEP Suite I&T) |  | 2d | 2004-08-03 | 2004-08-04 | 404, 503 |  |  | 2004-06-22 | 2004-06-23 | 2d | 40d | 0d |  | MS-SEP |
| 453 | 1.6.3.1.4 | Deliver Final HET Flight Software to SEP I&T |  | 2d | 2004-06-22 | 2004-06-23 | 491 |  |  | 2004-04-30 | 2004-05-03 | 2d | 8d | 4d |  |  |
| 454 | 1.6.3.2 | **Detectors (Batch 1)** |  | 40d | 2004-01-06 A | 2004-03-03 A |  | 100% |  | 2004-01-06 | 2004-03-31 | 60d |  |  |  |  |
| 455 | 1.6.3.2.1 | Receive & Inspect HET Flight Detectors |  | 40d | 2004-01-06 A | 2004-03-03 A |  | 100% |  | 2004-01-06 | 2004-03-03 | 40d |  |  | start no earlier than 2004-01-06 |  |
| 456 | 1.6.3.2.2 | **Detector Testing** |  | 40d | 2004-01-06 A | 2004-03-03 A |  | 100% |  | 2004-01-06 | 2004-03-31 | 60d |  |  |  |  |
| 457 | 1.6.3.2.2.1 | Capacitance, Current, Depletion, Alpha Resolution Testing |  | 40d | 2004-01-06 A | 2004-03-03 A | 455SS | 100% |  | 2004-01-06 | 2004-03-31 | 60d |  |  |  | MS-SEP |
| 458 | 1.6.3.2.2.2 | Life Test HET Detectors |  | 40d | 2004-01-06 A | 2004-03-03 A | 457SS | 100% |  | 2004-01-06 | 2004-03-31 | 60d |  |  |  | MS-SEP |
| 459 | 1.6.3.3 | **Replacement HET Detectors (Batch 2)** |  | 66d | 2004-03-12 A | 2004-06-14 |  | 29% | 47.14d | 2004-03-12 | 2004-06-14 | 66d | 18d |  |  |  |
| 460 | 1.6.3.3.1 | Receive H1 Detector Mounts | milestone | 0d | 2004-03-12 A | 2004-03-12 A |  | 100% |  | 2004-03-12 | 2004-03-12 | 0d |  |  | start no earlier than 2004-03-12 |  |
| 461 | 1.6.3.3.2 | Receive H3 Detector Mounts | milestone | 0d | 2004-03-26 A | 2004-03-26 A |  | 100% |  | 2004-03-26 | 2004-03-26 | 0d |  |  | start no earlier than 2004-03-26 |  |
| 462 | 1.6.3.3.3 | Detector Mounting at Micron |  | 20d | 2004-04-15 A | 2004-05-12 | 460, 461 | 60% | 8d | 2004-04-15 | 2004-05-12 | 20d | 18d | 0d | start no earlier than 2004-04-15 |  |
| 463 | 1.6.3.3.4 | Detector Delivery to GSFC |  | 2d | 2004-05-13 | 2004-05-14 | 462 |  |  | 2004-05-13 | 2004-05-14 | 2d | 18d | 0d |  |  |
| 464 | 1.6.3.3.5 | Detector Testing at GSFC |  | 20d | 2004-05-17 | 2004-06-14 | 463 |  |  | 2004-05-17 | 2004-06-14 | 20d | 18d |  |  |  |
| 465 | 1.6.3.4 | **Electronics Board** |  | 113d | 2004-01-22 A | 2004-06-30 |  | 78% | 25.11d | 2004-01-22 | 2004-05-13 | 80d | 40d |  |  | MS-SEP |
| 466 | 1.6.3.4.1 | **Assembly** |  | 38d | 2004-01-22 A | 2004-03-16 A |  | 100% |  | 2004-01-22 | 2004-03-12 | 36d |  |  |  |  |
| 467 | 1.6.3.4.1.1 | Install Socket on HET Electronics FM 1 Board for ETU ACTEL |  | 1d | 2004-01-22 A | 2004-01-22 A |  | 100% |  | 2004-01-22 | 2004-01-22 | 1d |  |  | start no earlier than 2004-01-22 |  |
| 468 | 1.6.3.4.1.2 | Complete Population of HET Electronics FM 1 Board (ETU ACTEL) |  | 1d | 2004-01-23 A | 2004-01-23 A | 467 | 100% |  | 2004-01-23 | 2004-01-23 | 1d |  |  |  |  |
| 469 | 1.6.3.4.1.3 | Complete Population of HET Electronics FM 2 Board (Flight ACTEL) |  | 2d | 2004-03-15 A | 2004-03-16 A | 468, 475, 512 | 100% |  | 2004-03-11 | 2004-03-12 | 2d |  |  |  |  |

| ID | WBS | Task | Type | Duration | Start | Finish | Predecessors | Complete | Remaining | Baseline start | Baseline finish | Baseline duration | Total slack | Free slack | Constraint |
| --- | --- | --- | --- | --- | --- | --- | --- | --- | --- | --- | --- | --- | --- | --- | --- |
| 470 | 1.6.3.4.2 | **Test** |  | 111d | 2004-01-26 A | 2004-06-30 |  | 77% | 25.95d | 2004-01-26 | 2004-05-13 | 78d | 40d |  |  |
| 471 | 1.6.3.4.2.1 | **FM 1** |  | 103d | 2004-01-26 A | 2004-06-18 |  | 81% | 19.62d | 2004-01-26 | 2004-03-22 | 40d | 4d |  |  |
| 472 | 1.6.3.4.2.1.1 | Test HET FM 1 Electronics Board w/ETU ACTEL |  | 23d | 2004-01-26 A | 2004-02-26 A | 468 | 100% |  | 2004-01-26 | 2004-02-23 | 20d |  |  |  |
| 473 | 1.6.3.4.2.1.2 | Remove ETU ACTEL and socket from HET FM 1 Electronics Board |  | 0.5d | 2004-02-27 A | 2004-02-27 A | 472 | 100% |  | 2004-02-24 | 2004-02-24 | 1d |  |  |  |
| 474 | 1.6.3.4.2.1.3 | Install Flight ACTEL on HET FM 1 Electronics Board |  | 0.5d | 2004-02-27 A | 2004-02-27 A | 473 | 100% |  | 2004-02-25 | 2004-02-25 | 1d |  |  |  |
| 475 | 1.6.3.4.2.1.4 | Retest HET FM 1 Electronics Board w/Flight ACTEL |  | 10d | 2004-03-01 A | 2004-03-12 A | 474 | 100% |  | 2004-02-26 | 2004-03-10 | 10d |  |  |  |
| 476 | 1.6.3.4.2.1.5 | Clean, Bake, Conformal Coat HET FM 1 Electronics Board |  | 3d | 2004-06-09 | 2004-06-11 | 475FS+61d |  |  | 2004-03-11 | 2004-03-12 | 2d | 4d | 0d |  |
| 477 | 1.6.3.4.2.1.6 | Retest Conformal Coated HET FM 1 Electronics Board |  | 5d | 2004-06-14 | 2004-06-18 | 476 |  |  | 2004-03-15 | 2004-03-16 | 2d | 4d | 0d |  |
| 478 | 1.6.3.4.2.2 | **FM 2** |  | 75d | 2004-03-17 A | 2004-06-30 |  | 71% | 21.43d | 2004-03-23 | 2004-05-13 | 38d | 40d |  |  |
| 479 | 1.6.3.4.2.2.1 | Test HET FM 2 Electronics Board |  | 25d | 2004-03-17 A | 2004-04-20 A | 469, 472 | 100% |  | 2004-03-23 | 2004-05-03 | 30d |  |  |  |
| 480 | 1.6.3.4.2.2.2 | Clean, Bake, Conformal Coat HET FM 2 Electronics Board |  | 5d | 2004-06-17 | 2004-06-23 | 479FS+40d |  |  | 2004-05-04 | 2004-05-05 | 2d | 40d | 0d |  |
| 481 | 1.6.3.4.2.2.3 | Retest Conformal Coated HET FM 2 Electronics Board |  | 5d | 2004-06-24 | 2004-06-30 | 480, 477 |  |  | 2004-05-06 | 2004-05-07 | 2d | 40d | 0d |  |
| 482 | 1.6.3.5 | **Flight Software** |  | 106d | 2004-01-22 A | 2004-06-21 |  | 70% | 31.96d | 2004-01-22 | 2004-04-29 | 70d | 14d |  |  |
| 483 | 1.6.3.5.1 | **Design** |  | 71d | 2004-01-22 A | 2004-04-30 A |  | 100% |  | 2004-01-22 | 2004-02-04 | 10d |  |  |  |
| 484 | 1.6.3.5.1.1 | Complete Definition of HET PH Event Processing |  | 22d | 2004-01-22 A | 2004-02-23 A |  | 100% |  | 2004-01-22 | 2004-02-04 | 10d |  |  | start no earlier than 2004-01-22 |
| 485 | 1.6.3.5.1.2 | Design Change of HET PH Event Processing |  | 20d | 2004-04-05 A | 2004-04-30 A |  | 100% |  | 2004-04-05 | 2004-04-23 | 15d |  |  | start no earlier than 2004-04-05 |
| 486 | 1.6.3.5.2 | **Coding** |  | 64d | 2004-02-24 A | 2004-05-21 |  | 73% | 17.2d | 2004-02-05 | 2004-03-04 | 20d | 34d |  |  |
| 487 | 1.6.3.5.2.1 | Code HET PH Event Processing Update for Flight |  | 59d | 2004-02-24 A | 2004-05-14 | 484 | 83% | 10d | 2004-02-05 | 2004-02-19 | 10d | 39d | 0d |  |
| 488 | 1.6.3.5.2.2 | Code HET Telemetry Formatting Update for Flight |  | 34d | 2004-03-12 A | 2004-05-21 | 487FS-15d | 56% | 15d | 2004-02-20 | 2004-03-04 | 10d | 34d |  |  |
| 489 | 1.6.3.5.3 | **Test** |  | 64d | 2004-03-23 A | 2004-06-21 |  | 45% | 35d | 2004-03-05 | 2004-04-29 | 40d | 8d |  |  |
| 490 | 1.6.3.5.3.1 | Test Integrated HET S/W with Simulated Data |  | 52d | 2004-03-23 A | 2004-06-03 |  | 56% | 23d | 2004-03-05 | 2004-03-25 | 15d | 8d | 0d | start no later than 2004-03-23 |
| 491 | 1.6.3.5.3.2 | Verify HET On-Board Software |  | 12d | 2004-06-04 | 2004-06-21 | 485, 490 |  |  | 2004-03-26 | 2004-04-29 | 25d | 8d | 0d |  |
| 492 | 1.6.3.6 | **Integration & Test** |  | 30d | 2004-06-21 | 2004-08-02 |  |  |  | 2004-05-03 | 2004-06-21 | 35d | 4d |  |  |
| 493 | 1.6.3.6.1 | **FM 1** |  | 20d | 2004-06-21 | 2004-07-19 |  |  |  | 2004-05-03 | 2004-05-28 | 20d | -4d | 0d |  |
| 494 | 1.6.3.6.1.1 | Integrate HET FM 1 Electronics Telescope (Ahead) |  | 3d | 2004-06-21 | 2004-06-23 | 458, 491FS-10d, 394, 477 |  |  | 2004-05-03 | 2004-05-07 | 5d | 4d | 0d |  |
| 495 | 1.6.3.6.1.2 | Test HET FM 1 Telescope (Ahead) |  | 2d | 2004-06-24 | 2004-06-25 | 494 |  |  | 2004-05-10 | 2004-05-28 | 15d | 4d | 0d |  |
| 496 | 1.6.3.6.1.3 | Receive HET FM1 from CIT | milestone | 0d | 2004-07-15 | 2004-07-15 | 801 |  |  | 2004-07-14 | 2004-07-14 | 0d | -4d | 0d |  |
| 497 | 1.6.3.6.1.4 | Install new HET Flight Detectors in FM 1 |  | 1d | 2004-07-16 | 2004-07-16 | 464, 496 |  |  | 2004-06-16 | 2004-06-16 | 1d | -4d | 0d |  |
| 498 | 1.6.3.6.1.5 | Performance Test FM 1 with New Flight Detectors |  | 1d | 2004-07-19 | 2004-07-19 | 497, 488 |  |  | 2004-06-17 | 2004-06-17 | 1d | -4d | 0d |  |

Notes:
- 476: Questioning when to begin the process of Conformally Coating these boards due to part issues. Expect Answer by 4/30/04. / Engineer is out on Leave until June 9th. Cleaning will begin after this date.
- 479: During removal of a temporary commercial ACTEL (U200) several pads(29) were lifted. We will build a new board, and repair the other board. One will become a Flight Spare. Continue with testing and switch out boards later on. 5d hit to the schedule.
- 485: The scientist needed to make changes to the HET PH Event Processing design due to issues found after the developer completed the majority of the software. Coding and testing can not finish until the design chagne is complete.

| ID | WBS | Task | Type | Duration | Start | Finish | Predecessors | Complete | Remaining | Baseline start | Baseline finish | Baseline duration | Total slack | Free slack | Constraint | Text1 |
| --- | --- | --- | --- | --- | --- | --- | --- | --- | --- | --- | --- | --- | --- | --- | --- | --- |
| 499 | 1.6.3.6.2 | **FM 2** |  | 22d | 2004-07-01 | 2004-08-02 |  |  |  | 2004-05-14 | 2004-06-21 | 26d | 40d |  |  |  |
| 500 | 1.6.3.6.2.1 | Integrate HET FM 2 Electronics Telescope (Behind) |  | 5d | 2004-07-01 | 2004-07-08 | 494, 458, 491, 394, 481 |  |  | 2004-05-14 | 2004-05-20 | 5d | 40d | 0d |  |  |
| 501 | 1.6.3.6.2.2 | Test HET FM 2 Telescope (Behind) |  | 15d | 2004-07-09 | 2004-07-29 | 500 |  |  | 2004-06-01 | 2004-06-21 | 15d | 40d | 0d |  |  |
| 502 | 1.6.3.6.2.3 | Install new HET Flight Detectors in FM 2 |  | 1d | 2004-07-30 | 2004-07-30 | 464, 501 |  |  | 2004-06-17 | 2004-06-17 | 1d | 40d | 0d |  |  |
| 503 | 1.6.3.6.2.4 | Performance Test FM 2 with New Flight Detectors |  | 1d | 2004-08-02 | 2004-08-02 | 502 |  |  |  |  |  | 40d | 0d |  |  |
| 504 | 1.6.4 | **LET - CIT** |  | 248d | 2003-07-14 A | 2004-07-07 |  | 87% | 32.01d | 2003-07-14 | 2004-06-08 | 228d | 60d |  |  |  |
| 505 | 1.6.4.1 | **Deliveries** |  | 7d | 2004-06-25 | 2004-07-07 |  |  |  | 2004-05-04 | 2004-06-08 | 24d | 3d |  |  |  |
| 506 | 1.6.4.1.1 | Deliver LET FM 1 (stays at CIT for SEP I&T) | milestone | 0d | 2004-07-07 | 2004-07-07 | 524 |  |  | 2004-06-08 | 2004-06-08 | 0d | -4d | 0d |  | MS-SEP |
| 507 | 1.6.4.1.2 | Deliver LET FM 2 (stays at CIT for SEP I&T) | milestone | 0d | 2004-07-07 | 2004-07-07 | 526 |  |  | 2004-06-08 | 2004-06-08 | 0d | 60d | 20d |  | MS-SEP |
| 508 | 1.6.4.1.3 | Deliver LET Flight Software Build 3 | milestone | 0d | 2004-06-25 | 2004-06-25 | 521 |  |  | 2004-05-04 | 2004-05-04 | 0d | 67d | 27d |  |  |
| 509 | 1.6.4.2 | **Detectors** |  | 167d | 2003-07-14 A | 2004-03-12 A |  | 100% |  | 2003-07-14 | 2004-03-12 | 167d |  |  |  |  |
| 510 | 1.6.4.2.1 | Complete LET Flight Detector Testing |  | 167d | 2003-07-14 A | 2004-03-12 A |  | 100% |  | 2003-07-14 | 2004-03-12 | 167d |  |  | start no earlier than 2003-07-14 | MS-SEP |
| 511 | 1.6.4.3 | **Hybrids** |  | 144d | 2003-08-01 A | 2004-03-01 A |  | 100% |  | 2003-08-01 | 2004-03-01 | 144d |  |  |  |  |
| 512 | 1.6.4.3.1 | Complete Test of Flight Hybrids (LET and to GSFC for HET FM 2) |  | 144d | 2003-08-01 A | 2004-03-01 A |  | 100% |  | 2003-08-01 | 2004-03-01 | 144d |  |  | start no earlier than 2003-08-01 |  |
| 513 | 1.6.4.4 | **Detector/Misc Board** |  | 64d | 2004-03-02 A | 2004-05-28 |  | 69% | 20d | 2004-03-02 | 2004-03-30 | 21d | 1d |  |  |  |
| 514 | 1.6.4.4.1 | **Assembly** |  | 10d | 2004-03-02 A | 2004-03-15 A |  | 100% |  | 2004-03-02 | 2004-03-15 | 10d |  |  |  |  |
| 515 | 1.6.4.4.1.1 | Assemble LET FM 1 Detector Board |  | 10d | 2004-03-02 A | 2004-03-15 A | 512 | 100% |  | 2004-03-02 | 2004-03-15 | 10d |  |  |  |  |
| 516 | 1.6.4.4.1.2 | Assemble LET FM 2 Detector Board |  | 10d | 2004-03-02 A | 2004-03-15 A | 512 | 100% |  | 2004-03-02 | 2004-03-15 | 10d |  |  |  |  |
| 517 | 1.6.4.4.2 | **Test** |  | 54d | 2004-03-16 A | 2004-05-28 |  | 63% | 20d | 2004-03-16 | 2004-03-30 | 11d | 1d |  |  |  |
| 518 | 1.6.4.4.2.1 | Test LET FM 1 Detector Board |  | 54d | 2004-03-16 A | 2004-05-28 | 515 | 63% | 20d | 2004-03-16 | 2004-03-30 | 11d | 1d | 0d |  |  |
| 519 | 1.6.4.4.2.2 | Test LET FM 2 Detector Board |  | 54d | 2004-03-16 A | 2004-05-28 | 516 | 63% | 20d | 2004-03-16 | 2004-03-30 | 11d | 1d | 0d |  |  |
| 520 | 1.6.4.5 | **Flight Software** |  | 227d | 2003-08-01 A | 2004-06-25 |  | 83% | 39d | 2003-08-01 | 2004-05-04 | 190d | 67d |  |  |  |
| 521 | 1.6.4.5.1 | Let Flight Software Build 3 |  | 227d | 2003-08-01 A | 2004-06-25 |  | 83% | 39d | 2003-08-01 | 2004-05-04 | 190d | 67d | 0d | start no earlier than 2003-08-01 |  |
| 522 | 1.6.4.6 | **Integration & Test** |  | 4d | 2004-07-01 | 2004-07-07 |  |  |  | 2004-05-11 | 2004-06-08 | 20d | -4d | 0d |  |  |
| 523 | 1.6.4.6.1 | **FM 1** |  | 4d | 2004-07-01 | 2004-07-07 |  |  |  | 2004-05-11 | 2004-06-08 | 20d | -4d | 0d |  |  |
| 524 | 1.6.4.6.1.1 | Integrate LET FM 1 Housing With Detectors |  | 4d | 2004-07-01 | 2004-07-07 | 510, 444, 384 |  |  | 2004-05-11 | 2004-06-08 | 20d | -4d | 0d |  | MS-SEP |

| ID | WBS | Task | Duration | Start | Finish | Predecessors | Complete | Remaining | Baseline start | Baseline finish | Baseline duration | Total slack | Free slack | Constraint | Text1 |
| --- | --- | --- | --- | --- | --- | --- | --- | --- | --- | --- | --- | --- | --- | --- | --- |
| 525 | 1.6.4.6.2 | **FM 2** | 4d | 2004-07-01 | 2004-07-07 |  |  |  | 2004-05-11 | 2004-06-08 | 20d | 60d |  |  |  |
| 526 | 1.6.4.6.2.1 | Integrate LET FM 2 Housing With Detectors | 4d | 2004-07-01 | 2004-07-07 | 510, 444, 384 |  |  | 2004-05-11 | 2004-06-08 | 20d | 60d | 0d |  | MS-SEP |
| 527 | 1.6.5 | **SEPT - Kiel/ESTEC** | 284d | 2003-08-08 A | 2004-09-23 |  | 69% | 87.21d | 2003-08-08 | 2004-07-28 | 245d | 9d |  |  |  |
| 528 | 1.6.5.1 | **Deliveries** | 42d | 2004-07-27 | 2004-09-23 |  |  |  | 2004-03-11 | 2004-07-28 | 99d | -11d | 0d |  |  |
| 529 | 1.6.5.1.1 | Deliver SEPT-NS FM 1 to CIT for SEP I&T and Suite EMC | 5d | 2004-07-27 | 2004-08-02 | 574, 573 |  |  | 2004-03-11 | 2004-03-17 | 5d | -11d | 0d |  | MS-SEP |
| 530 | 1.6.5.1.2 | Deliver SEPT-E FM 1 to CIT for SEP I&T and Suite EMC | 5d | 2004-07-27 | 2004-08-02 | 585, 584 |  |  | 2004-03-11 | 2004-03-17 | 5d | -11d | 0d |  | MS-SEP |
| 531 | 1.6.5.1.3 | Final Delivery of SEPT FM 1 to APL (after Therm Bal @ GSFC) | 2d | 2004-09-22 | 2004-09-23 | 575, 586, 562 |  |  | 2004-07-27 | 2004-07-28 | 2d | 9d |  |  |  |
| 532 | 1.6.5.1.4 | Deliver SEPT-NS FM 2 to CIT for SEP I&T and Suite EMC | 5d | 2004-07-27 | 2004-08-02 | 596, 597 |  |  | 2004-03-22 | 2004-03-26 | 5d | 40d | 0d |  | MS-SEP |
| 533 | 1.6.5.1.5 | Deliver SEPT-E FM 2 to CIT for SEP I&T and Suite EMC | 5d | 2004-07-27 | 2004-08-02 | 606, 607 |  |  | 2004-03-22 | 2004-03-26 | 5d | 40d | 0d |  | MS-SEP |
| 534 | 1.6.5.2 | **Mechanical Assembly** | 46d | 2003-12-22 A | 2004-02-27 A |  | 100% |  | 2003-12-22 | 2004-02-27 | 46d |  |  |  |  |
| 535 | 1.6.5.2.1 | **FM 1** | 13d | 2003-12-22 A | 2004-01-09 A |  | 100% |  | 2003-12-22 | 2004-01-09 | 13d |  |  |  |  |
| 536 | 1.6.5.2.1.1 | Assemble SEPT-NS FM 1 Sensor and E-Box Housing | 13d | 2003-12-22 A | 2004-01-09 A |  | 100% |  | 2003-12-22 | 2004-01-09 | 13d |  |  | start no earlier than 2003-12-22 |  |
| 537 | 1.6.5.2.1.2 | Assemble SEPT-E FM 1 Sensor and E-Box Housing | 13d | 2003-12-22 A | 2004-01-09 A |  | 100% |  | 2003-12-22 | 2004-01-09 | 13d |  |  | start no earlier than 2003-12-22 |  |
| 538 | 1.6.5.2.2 | **FM 2** | 14d | 2003-12-29 A | 2004-01-16 A |  | 100% |  | 2003-12-29 | 2004-01-16 | 14d |  |  |  |  |
| 539 | 1.6.5.2.2.1 | Assemble SEPT-NS FM 2 Sensor and E-Box Housing | 14d | 2003-12-29 A | 2004-01-16 A | 536SS+4d | 100% |  | 2003-12-29 | 2004-01-16 | 14d |  |  |  |  |
| 540 | 1.6.5.2.2.2 | Assemble SEPT-E FM 2 Sensor and E-Box Housing | 14d | 2003-12-29 A | 2004-01-16 A | 537SS+4d | 100% |  | 2003-12-29 | 2004-01-16 | 14d |  |  |  |  |
| 541 | 1.6.5.2.3 | **Spare** | 28d | 2004-01-20 A | 2004-02-27 A |  | 100% |  | 2004-01-20 | 2004-02-27 | 28d |  |  |  |  |
| 542 | 1.6.5.2.3.1 | Assemble SEPT Spare Sensor and E-Box Housing | 28d | 2004-01-20 A | 2004-02-27 A | 539, 540 | 100% |  | 2004-01-20 | 2004-02-27 | 28d |  |  |  |  |
| 543 | 1.6.5.3 | **Electronics** | 208d | 2003-08-08 A | 2004-06-07 |  | 93% | 13.59d | 2003-08-08 | 2004-05-21 | 198d | 83d |  |  |  |
| 544 | 1.6.5.3.1 | **Assembly** | 172d | 2003-08-08 A | 2004-04-15 A |  | 100% |  | 2003-08-08 | 2004-04-15 | 172d |  |  |  |  |
| 545 | 1.6.5.3.1.1 | **FM 2** | 106d | 2003-08-08 A | 2004-01-12 A |  | 100% |  | 2003-08-08 | 2004-01-12 | 106d |  |  |  |  |
| 546 | 1.6.5.3.1.1.1 | Assemble SEPT-NS FM 2 Electronics | 106d | 2003-08-08 A | 2004-01-12 A |  | 100% |  | 2003-08-08 | 2004-01-12 | 106d |  |  | start no earlier than 2003-08-08 |  |
| 547 | 1.6.5.3.1.1.2 | Assemble SEPT-E FM 2 Electronics | 92d | 2003-08-08 A | 2003-12-19 A |  | 100% |  | 2003-08-08 | 2003-12-19 | 92d |  |  | start no earlier than 2003-08-08 |  |
| 548 | 1.6.5.3.1.2 | **Spare** | 172d | 2003-08-08 A | 2004-04-15 A |  | 100% |  | 2003-08-08 | 2004-04-15 | 172d |  |  |  |  |
| 549 | 1.6.5.3.1.2.1 | Assemble SEPT FS Electronics | 172d | 2003-08-08 A | 2004-04-15 A | 546SS | 100% |  | 2003-08-08 | 2004-04-15 | 172d |  |  |  |  |

| ID | WBS | Task | Duration | Start | Finish | Predecessors | Complete | Remaining | Baseline start | Baseline finish | Baseline duration | Total slack | Free slack | Constraint | Text1 |
| --- | --- | --- | --- | --- | --- | --- | --- | --- | --- | --- | --- | --- | --- | --- | --- |
| 550 | 1.6.5.3.2 | **Test** | 123d | 2003-12-11 A | 2004-06-07 |  | 66% | 41.46d | 2003-12-11 | 2004-05-21 | 113d | 83d |  |  |  |
| 551 | 1.6.5.3.2.1 | **FM 2** | 118d | 2003-12-11 A | 2004-05-28 |  | 73% | 31.89d | 2003-12-11 | 2004-01-30 | 34d | 83d |  |  |  |
| 552 | 1.6.5.3.2.1.1 | SEPT-NS FM 2 Electronics Test | 4d | 2004-01-13 A | 2004-01-16 A | 546 | 100% |  | 2004-01-13 | 2004-01-16 | 4d |  |  |  |  |
| 553 | 1.6.5.3.2.1.2 | SEPT-E FM 2 Electronics Test | 4d | 2003-12-11 A | 2003-12-16 A | 547FS-7d | 100% |  | 2003-12-11 | 2003-12-16 | 4d |  |  |  |  |
| 554 | 1.6.5.3.2.1.3 | Coat SEPT-NS FM 2 Electronics Board | 4d | 2004-01-20 A | 2004-01-23 A | 552 | 100% |  | 2004-01-20 | 2004-01-23 | 4d |  |  |  |  |
| 555 | 1.6.5.3.2.1.4 | Coat SEPT-E FM 2 Electronics Board | 5d | 2003-12-17 A | 2003-12-23 A | 553 | 100% |  | 2003-12-17 | 2003-12-23 | 5d |  |  |  |  |
| 556 | 1.6.5.3.2.1.5 | SEPT-NS FM 2 Mechanical Integration | 5d | 2004-01-26 A | 2004-01-30 A | 554 | 100% |  | 2004-01-26 | 2004-01-30 | 5d |  |  |  |  |
| 557 | 1.6.5.3.2.1.6 | SEPT-E FM 2 Mechanical Integration | 13d | 2003-12-24 A | 2004-01-13 A | 555 | 100% |  | 2003-12-24 | 2004-01-13 | 13d |  |  |  |  |
| 558 | 1.6.5.3.2.1.7 | Repair SEPT-NS FM 2 Electronic Board for use as Spare | 39d | 2004-04-06 A | 2004-05-28 | 594SS | 49% | 20d |  |  |  | 83d | 0d |  |  |
| 559 | 1.6.5.3.2.2 | **Spare** | 30d | 2004-04-26 A | 2004-06-07 |  | 33% | 20d | 2004-04-26 | 2004-05-21 | 20d | 83d |  |  |  |
| 560 | 1.6.5.3.2.2.1 | SEPT Flight Spare Electronics Test | 5d | 2004-04-26 A | 2004-04-30 A | 549 | 100% |  | 2004-04-26 | 2004-04-30 | 5d |  |  | start no earlier than 2004-04-26 |  |
| 561 | 1.6.5.3.2.2.2 | Coat SEPT FS Electronics Board | 5d | 2004-05-10 | 2004-05-14 | 560 |  |  | 2004-05-10 | 2004-05-14 | 5d | 69d | 10d | start no earlier than 2004-05-10 |  |
| 562 | 1.6.5.3.2.2.3 | SEPT FS Mechanical Integration | 5d | 2004-06-01 | 2004-06-07 | 561, 558 |  |  | 2004-05-17 | 2004-05-21 | 5d | 83d | 74d |  |  |
| 563 | 1.6.5.4 | **Integration & Test** | 177d | 2004-01-12 A | 2004-09-21 |  | 42% | 102.98d | 2004-01-12 | 2004-07-26 | 138d | 9d |  |  |  |
| 564 | 1.6.5.4.1 | **FM 1** | 177d | 2004-01-12 A | 2004-09-21 |  | 40% | 106.2d | 2004-01-12 | 2004-07-26 | 138d | 9d |  |  |  |
| 565 | 1.6.5.4.1.1 | **SEPT-NS** | 168d | 2004-01-26 A | 2004-09-21 |  | 40% | 100.8d | 2004-01-26 | 2004-07-26 | 129d | 9d |  |  |  |
| 566 | 1.6.5.4.1.1.1 | SEPT-NS FM 1 Integration & Test | 5d | 2004-01-26 A | 2004-01-30 A | 536 | 100% |  | 2004-01-26 | 2004-01-30 | 5d |  |  | start no earlier than 2004-01-26 |  |
| 567 | 1.6.5.4.1.1.2 | Muon and Radioactive Source Test | 5d | 2004-02-02 A | 2004-02-06 A | 566 | 100% |  | 2004-02-02 | 2004-02-06 | 5d |  |  |  |  |
| 568 | 1.6.5.4.1.1.3 | SEPT-NS FM 1 Vibration | 4d | 2004-02-19 A | 2004-02-24 A | 567 | 100% |  | 2004-02-17 | 2004-02-20 | 4d |  |  | start no earlier than 2004-02-19 | MS-SEP |
| 569 | 1.6.5.4.1.1.4 | SEPT-NS FM 1 Thermal Vac | 11d | 2004-02-27 A | 2004-03-12 A | 568FS+2d | 100% |  | 2004-02-25 | 2004-03-08 | 9d |  |  |  |  |
| 570 | 1.6.5.4.1.1.5 | SEPT-NS FM 1 Bake Out | 2d | 2004-03-05 A | 2004-03-08 A | 569FS-6d | 100% |  | 2004-03-09 | 2004-03-10 | 2d |  |  |  |  |
| 571 | 1.6.5.4.1.1.6 | SEPT-NS FM 1 Repair | 58d | 2004-04-06 A | 2004-06-25 | 570FS+20d | 33% | 39d |  |  |  | -11d | 0d |  |  |
| 572 | 1.6.5.4.1.1.7 | SEPT-NS FM 1 Post Repair Integration & Test | 5d | 2004-06-28 | 2004-07-02 | 571 |  |  |  |  |  | -11d | 0d |  |  |
| 573 | 1.6.5.4.1.1.8 | SEPT-NS Post Repair Vibration | 4d | 2004-07-06 | 2004-07-09 | 572 |  |  |  |  |  | -11d | 0d |  |  |
| 574 | 1.6.5.4.1.1.9 | SEPT-NS Post Repair Thermal Vac | 11d | 2004-07-12 | 2004-07-26 | 573 |  |  |  |  |  | -11d | 0d |  |  |
| 575 | 1.6.5.4.1.1.10 | SEPT-NS FM 1 Thermal Balance (at GSFC after Suite EMC) | 10d | 2004-09-08 | 2004-09-21 | 19 |  |  | 2004-07-13 | 2004-07-26 | 10d | 9d | 0d |  |  |

Notes:
- 558: The repair task duration is not determined yet and is waiting for the new Actel Programming software to get to Europe. (after May 19th)
- 568: There was a failure on the SEPT door during Vibration Test. Vibration Test will be repeated once the fix to the door is implemented. Time and place is TBD.

| ID | WBS | Task | Duration | Start | Finish | Predecessors | Complete | Remaining | Baseline start | Baseline finish | Baseline duration | Total slack | Free slack | Constraint |
| --- | --- | --- | --- | --- | --- | --- | --- | --- | --- | --- | --- | --- | --- | --- |
| 576 | 1.6.5.4.1.2 | **SEPT-E** | 177d | 2004-01-12 A | 2004-09-21 |  | 40% | 106.2d | 2004-01-12 | 2004-07-26 | 138d | 9d |  |  |
| 577 | 1.6.5.4.1.2.1 | SEPT-E FM 1 Integration & Test | 5d | 2004-01-12 A | 2004-01-16 A | 537 | 100% |  | 2004-01-12 | 2004-01-16 | 5d |  |  |  |
| 578 | 1.6.5.4.1.2.2 | Muon and Radioactive Source Test | 5d | 2004-01-29 A | 2004-02-04 A | 577 | 100% |  | 2004-01-29 | 2004-02-04 | 5d |  |  | start no earlier than 2004-01-29 |
| 579 | 1.6.5.4.1.2.3 | SEPT-E FM 1 Vibration | 4d | 2004-02-19 A | 2004-02-24 A | 578, 568SS | 100% |  | 2004-02-21 | 2004-02-24 | 4d |  |  |  |
| 580 | 1.6.5.4.1.2.4 | SEPT-E FM 1 Thermal Vac | 11d | 2004-02-27 A | 2004-03-12 A | 579, 569SS | 100% |  | 2004-02-25 | 2004-03-08 | 9d |  |  |  |
| 581 | 1.6.5.4.1.2.5 | SEPT-E FM 1 Bake Out | 2d | 2004-03-05 A | 2004-03-08 A | 580FS-6d | 100% |  | 2004-03-09 | 2004-03-10 | 2d |  |  |  |
| 582 | 1.6.5.4.1.2.6 | SEPT-E FM 1 Repair | 58d | 2004-04-06 A | 2004-06-25 | 581FS+20d | 33% | 39d |  |  |  | -11d | 0d |  |
| 583 | 1.6.5.4.1.2.7 | SEPT-E FM 1 Post Repair Integration & Test | 5d | 2004-06-28 | 2004-07-02 | 582 |  |  |  |  |  | -11d | 0d |  |
| 584 | 1.6.5.4.1.2.8 | SEPT-E FM1 Post Repair Vibration | 4d | 2004-07-06 | 2004-07-09 | 583 |  |  |  |  |  | -11d | 0d |  |
| 585 | 1.6.5.4.1.2.9 | SEPT-E FM1 Post Repair Thermal Vac | 11d | 2004-07-12 | 2004-07-26 | 584 |  |  |  |  |  | -11d | 0d |  |
| 586 | 1.6.5.4.1.2.10 | SEPT-E FM 1 Thermal Balance (at GSFC after Suite EMC) | 10d | 2004-09-08 | 2004-09-21 | 19 |  |  | 2004-07-13 | 2004-07-26 | 10d | 9d | 0d |  |
| 587 | 1.6.5.4.2 | **FM 2** | 137d | 2004-01-12 A | 2004-07-26 |  | 44% | 76.98d | 2004-01-12 | 2004-03-19 | 48d | 40d |  |  |
| 588 | 1.6.5.4.2.1 | **SEPT-NS** | 132d | 2004-01-20 A | 2004-07-26 |  | 45% | 72.78d | 2004-01-20 | 2004-03-19 | 43d | 40d |  |  |
| 589 | 1.6.5.4.2.1.1 | SEPT-NS FM 2 Integration & Test | 8d | 2004-01-20 A | 2004-01-29 A | 539 | 100% |  | 2004-01-20 | 2004-01-29 | 8d |  |  |  |
| 590 | 1.6.5.4.2.1.2 | Muon and Radioactive Source Test | 6d | 2004-01-30 A | 2004-02-06 A | 589 | 100% |  | 2004-01-30 | 2004-02-06 | 6d |  |  |  |
| 591 | 1.6.5.4.2.1.3 | SEPT-NS FM 2 Vibration | 4d | 2004-02-19 A | 2004-02-24 A | 590, 568SS | 100% |  | 2004-02-17 | 2004-02-20 | 4d |  |  |  |
| 592 | 1.6.5.4.2.1.4 | SEPT-NS FM 2 Thermal Vac | 9d | 2004-03-05 A | 2004-03-17 A | 591 | 100% |  | 2004-03-09 | 2004-03-17 | 9d |  |  | start no earlier than 2004-03-05 |
| 593 | 1.6.5.4.2.1.5 | SEPT-NS FM 2 Bake Out | 2d | 2004-03-12 A | 2004-03-15 A | 592FS-4d | 100% |  | 2004-03-18 | 2004-03-19 | 2d |  |  |  |
| 594 | 1.6.5.4.2.1.6 | SEPT-NS FM 2 Repair | 58d | 2004-04-06 A | 2004-06-25 | 593FS+15d | 33% | 39d |  |  |  | 40d | 0d |  |
| 595 | 1.6.5.4.2.1.7 | SEPT-NS FM 2 Post Repair Integration & Test | 5d | 2004-06-28 | 2004-07-02 | 594, 561 |  |  |  |  |  | 40d | 0d |  |
| 596 | 1.6.5.4.2.1.8 | SEPT-NS FM 2 Post Repair Vibration | 4d | 2004-07-06 | 2004-07-09 | 595 |  |  |  |  |  | 40d | 0d |  |
| 597 | 1.6.5.4.2.1.9 | SEPT-NS FM 2 Post Repair Thermal Vac | 11d | 2004-07-12 | 2004-07-26 | 596 |  |  |  |  |  | 40d | 0d |  |
| 598 | 1.6.5.4.2.2 | **SEPT-E** | 137d | 2004-01-12 A | 2004-07-26 |  | 43% | 78.48d | 2004-01-12 | 2004-03-19 | 48d | 40d |  |  |
| 599 | 1.6.5.4.2.2.1 | SEPT-E FM 2 Integration & Test | 5d | 2004-01-12 A | 2004-01-16 A | 577SS | 100% |  | 2004-01-12 | 2004-01-16 | 5d |  |  |  |
| 600 | 1.6.5.4.2.2.2 | Muon and Radioactive Source Test | 5d | 2004-01-29 A | 2004-02-04 A | 599, 578SS | 100% |  | 2004-01-29 | 2004-02-04 | 5d |  |  |  |
| 601 | 1.6.5.4.2.2.3 | SEPT-E FM 2 Vibration | 4d | 2004-02-19 A | 2004-02-24 A | 600, 568SS | 100% |  | 2004-02-21 | 2004-02-24 | 4d |  |  |  |
| 602 | 1.6.5.4.2.2.4 | SEPT-E FM 2 Thermal Vac | 9d | 2004-03-05 A | 2004-03-17 A | 601, 592SS | 100% |  | 2004-03-09 | 2004-03-17 | 9d |  |  |  |
| 603 | 1.6.5.4.2.2.5 | SEPT-E FM 2 Bake Out | 2d | 2004-03-12 A | 2004-03-15 A | 602FS-4d | 100% |  | 2004-03-18 | 2004-03-19 | 2d |  |  |  |
| 604 | 1.6.5.4.2.2.6 | SEPT-NS FM 2 Repair | 58d | 2004-04-06 A | 2004-06-25 | 603FS+15d | 33% | 39d |  |  |  | 40d | 0d |  |
| 605 | 1.6.5.4.2.2.7 | SEPT-NS FM 2 Post Repair Integration & Test | 5d | 2004-06-28 | 2004-07-02 | 604 |  |  |  |  |  | 40d | 0d |  |
| 606 | 1.6.5.4.2.2.8 | SEPT-NS FM 2 Post Repair Vibration | 4d | 2004-07-06 | 2004-07-09 | 605 |  |  |  |  |  | 40d | 0d |  |
| 607 | 1.6.5.4.2.2.9 | SEPT-NS FM 2 Post Repair Thermal Vac | 11d | 2004-07-12 | 2004-07-26 | 606 |  |  |  |  |  | 40d | 0d |  |

Notes:
- 579: There was a failure on the SEPT door during Vibration Test. Vibration Test will be repeated once the fix to the door is implemented. Time and place is TBD.
- 591: There was a failure on the SEPT door during Vibration Test. Vibration Test will be repeated once the fix to the door is implemented. Time and place is TBD.
- 601: There was a failure on the SEPT door during Vibration Test. Vibration Test will be repeated once the fix to the door is implemented. Time and place is TBD.

| ID | WBS | Task | Type | Duration | Start | Finish | Predecessors | Complete | Remaining | Baseline start | Baseline finish | Baseline duration | Total slack | Free slack | Constraint | Text1 |
| --- | --- | --- | --- | --- | --- | --- | --- | --- | --- | --- | --- | --- | --- | --- | --- | --- |
| 608 | 1.6.6 | **SIT - UMD** |  | 379d | 2003-06-02 A | 2004-12-02 |  | 69% | 117.52d | 2003-06-02 | 2004-10-20 | 351d | -24d | 0d |  |  |
| 609 | 1.6.6.1 | **Deliveries** |  | 77d | 2004-08-12 | 2004-12-02 |  |  |  | 2004-06-18 | 2004-10-12 | 81d | -24d | 0d |  |  |
| 610 | 1.6.6.1.1 | Deliver SIT FM 1 to CIT for SEP I&T and Suite EMC |  | 2d | 2004-08-12 | 2004-08-13 | 405, 695 |  |  | 2004-06-18 | 2004-06-21 | 2d | -16d | 0d |  | MS-SEP |
| 611 | 1.6.6.1.2 | Deliver SIT FM 1 back to GSFC for Environmental Testing (after EMC Test) |  | 2d | 2004-09-08 | 2004-09-09 | 19, 412 |  |  | 2004-07-13 | 2004-07-14 | 2d | -17d | 0d |  | MS-SEP |
| 612 | 1.6.6.1.3 | Final Delivery of SIT FM 1 to APL |  | 1d | 2004-11-01 | 2004-11-01 | 729 |  |  | 2004-09-01 | 2004-09-01 | 1d | -17d | 0d |  | MS-SEP |
| 613 | 1.6.6.1.4 | Deliver SIT FM 2 to CIT for SEP I&T |  | 2d | 2004-09-24 | 2004-09-27 | 700, 405 |  |  | 2004-07-23 | 2004-07-26 | 2d | -25d | 0d |  | MS-SEP |
| 614 | 1.6.6.1.5 | Deliver SIT FM 2 back to GSFC for Environmental Testing |  | 2d | 2004-10-07 | 2004-10-08 | 792 |  |  | 2004-08-19 | 2004-08-20 | 2d | -24d | 0d |  | MS-SEP |
| 615 | 1.6.6.1.6 | Final Delivery of SIT FM 2 to APL |  | 1d | 2004-12-02 | 2004-12-02 | 738, 744 |  |  | 2004-10-12 | 2004-10-12 | 1d | -24d | 0d |  | MS-SEP |
| 616 | 1.6.6.2 | **ACTEL - for SIT Logic Board** |  | 1d | 2004-05-24 | 2004-05-24 |  |  |  | 2004-02-27 | 2004-03-12 | 11d | -16d | 0d |  |  |
| 617 | 1.6.6.2.1 | Burn Final SIT ACTEL Chip w/latest algorithm (at GSFC) |  | 1d | 2004-05-24 | 2004-05-24 |  |  |  | 2004-02-27 | 2004-02-27 | 1d | -16d | 0d | start no earlier than 2004-05-24 |  |
| 618 | 1.6.6.2.2 | Evaluate (Test) SIT Final ACTEL Chip | milestone | 0d | 2004-05-24 | 2004-05-24 | 617 |  |  | 2004-03-01 | 2004-03-12 | 10d | -16d | 0d |  |  |
| 619 | 1.6.6.3 | **TOF Boards** |  | 82d | 2004-02-12 A | 2004-06-08 |  | 52% | 39.14d | 2004-02-12 | 2004-03-11 | 20d | 13d |  |  |  |
| 620 | 1.6.6.3.1 | Receive Analog and Digital TOF Boards (FM 1) | milestone | 0d | 2004-02-12 A | 2004-02-12 A |  | 100% |  | 2004-02-12 | 2004-02-12 | 0d |  |  | start no earlier than 2004-02-12 |  |
| 621 | 1.6.6.3.2 | Receive Analog and Digital TOF Boards (FM 2) |  | 16d | 2004-03-25 A | 2004-05-24 | 624FS+32d | 31% | 11d | 2004-03-15 | 2004-04-09 | 20d | 13d | 0d |  |  |
| 622 | 1.6.6.3.3 | **Test** |  | 71d | 2004-03-01 A | 2004-06-08 |  | 64% | 25.36d | 2004-02-12 | 2004-03-11 | 20d | 13d |  |  |  |
| 623 | 1.6.6.3.3.1 | **FM 1** |  | 18d | 2004-03-01 A | 2004-03-24 A |  | 100% |  | 2004-02-12 | 2004-02-26 | 10d |  |  |  |  |
| 624 | 1.6.6.3.3.1.1 | FM 1 TOF Boards Functional Test |  | 18d | 2004-03-01 A | 2004-03-24 A | 620 | 100% |  | 2004-02-12 | 2004-02-26 | 10d |  |  | start no earlier than 2004-03-01 |  |
| 625 | 1.6.6.3.3.2 | **FM 2** |  | 10d | 2004-05-25 | 2004-06-08 |  |  |  | 2004-02-27 | 2004-03-11 | 10d | 13d |  |  |  |
| 626 | 1.6.6.3.3.2.1 | FM 2 TOF Boards Functional Test |  | 10d | 2004-05-25 | 2004-06-08 | 620, 621 |  |  | 2004-02-27 | 2004-03-11 | 10d | 13d |  |  |  |
| 627 | 1.6.6.4 | **Energy Board** |  | 159d | 2003-11-10 A | 2004-06-28 |  | 83% | 26.39d | 2003-11-10 | 2004-04-02 | 99d | -1d | 0d |  |  |
| 628 | 1.6.6.4.1 | **Assembly** |  | 114d | 2003-11-10 A | 2004-04-23 A |  | 100% |  | 2003-11-10 | 2004-02-20 | 69d |  |  |  |  |
| 629 | 1.6.6.4.1.1 | **FM 1** |  | 92d | 2003-11-10 A | 2004-03-24 A |  | 100% |  | 2003-11-10 | 2004-02-20 | 69d |  |  |  |  |
| 630 | 1.6.6.4.1.1.1 | Assemble FM 1 Energy Board |  | 92d | 2003-11-10 A | 2004-03-24 A |  | 100% |  | 2003-11-10 | 2004-02-20 | 69d |  |  | start no earlier than 2003-11-10 |  |
| 631 | 1.6.6.4.1.2 | **FM 2** |  | 114d | 2003-11-10 A | 2004-04-23 A |  | 100% |  | 2003-11-10 | 2004-02-20 | 69d |  |  |  |  |
| 632 | 1.6.6.4.1.2.1 | Assemble FM 2 Energy Board |  | 82d | 2003-11-10 A | 2004-04-23 A | 630FF+22d | 100% |  | 2003-11-10 | 2004-02-20 | 69d |  |  |  |  |

Notes:
- 617: SIT Actel design review held 4/30 by Rod Barto. Relayout of the board possible. Reccomend performing a funtional test on FM1 with the Flight ACTEL to analyze possible ground bounce issues. Tech can not burn chip until the new algorithm is released after 5/19.

| ID | WBS | Task | Duration | Start | Finish | Predecessors | Complete | Remaining | Baseline start | Baseline finish | Baseline duration | Total slack | Free slack | Constraint |
| --- | --- | --- | --- | --- | --- | --- | --- | --- | --- | --- | --- | --- | --- | --- |
| 633 | 1.6.6.4.2 | **Test** | 67d | 2004-03-25 A | 2004-06-28 |  | 40% | 40d | 2004-02-23 | 2004-04-02 | 30d | -1d | 0d |  |
| 634 | 1.6.6.4.2.1 | **FM 1** | 52d | 2004-03-25 A | 2004-06-07 |  | 52% | 25d | 2004-02-23 | 2004-03-12 | 15d | -5d | 0d |  |
| 635 | 1.6.6.4.2.1.1 | Bench Test/Calibration | 47d | 2004-03-25 A | 2004-05-28 | 630 | 57% | 20d | 2004-02-23 | 2004-03-05 | 10d | -10d | 0d |  |
| 636 | 1.6.6.4.2.1.2 | Thermal | 3d | 2004-06-01 | 2004-06-03 | 635 |  |  | 2004-03-08 | 2004-03-10 | 3d | -10d | 0d |  |
| 637 | 1.6.6.4.2.1.3 | Voltage Margin | 2d | 2004-06-04 | 2004-06-07 | 636 |  |  | 2004-03-11 | 2004-03-12 | 2d | -10d | 0d |  |
| 638 | 1.6.6.4.2.2 | **FM 2** | 15d | 2004-06-08 | 2004-06-28 |  |  |  | 2004-03-15 | 2004-04-02 | 15d | -1d | 0d |  |
| 639 | 1.6.6.4.2.2.1 | FM 2 Energy Board Functional Test | 15d | 2004-06-08 | 2004-06-28 | 632, 637 |  |  | 2004-03-15 | 2004-04-02 | 15d | -1d | 0d |  |
| 640 | 1.6.6.5 | **Logic Board** | 165d | 2003-11-10 A | 2004-07-07 |  | 77% | 38.08d | 2003-11-10 | 2004-07-09 | 168d | -7d | 0d |  |
| 641 | 1.6.6.5.1 | **Design** | 3d | 2003-11-17 A | 2003-11-19 A |  | 100% |  | 2003-11-17 | 2003-11-19 | 3d |  |  |  |
| 642 | 1.6.6.5.1.1 | Layout new Logic Board Design | 3d | 2003-11-17 A | 2003-11-19 A |  | 100% |  | 2003-11-17 | 2003-11-19 | 3d |  |  | start no earlier than 2003-11-17 |
| 643 | 1.6.6.5.2 | **Fabrication** | 10d | 2004-03-08 A | 2004-03-19 A |  | 100% |  | 2004-02-09 | 2004-02-23 | 10d |  |  |  |
| 644 | 1.6.6.5.2.1 | FM 1 & FM 2 Logic Board Fabrication | 10d | 2004-03-08 A | 2004-03-19 A | 642, 652 | 100% |  | 2004-02-09 | 2004-02-23 | 10d |  |  | start no earlier than 2004-02-02 |
| 645 | 1.6.6.5.3 | **Assembly** | 20d | 2004-05-25 | 2004-06-22 |  |  |  | 2004-03-09 | 2004-07-07 | 86d | -16d | 0d |  |
| 646 | 1.6.6.5.3.1 | **FM 1** | 5d | 2004-05-25 | 2004-06-01 |  |  |  | 2004-03-09 | 2004-05-27 | 58d | -16d | 0d |  |
| 647 | 1.6.6.5.3.1.1 | Assemble FM 1 Logic Board with Flight ACTELs | 5d | 2004-05-25 | 2004-06-01 | 654, 618 |  |  | 2004-03-09 | 2004-03-23 | 11d | -16d | 0d |  |
| 648 | 1.6.6.5.3.2 | **FM 2** | 5d | 2004-06-16 | 2004-06-22 |  |  |  | 2004-03-09 | 2004-07-07 | 86d | -7d | 0d |  |
| 649 | 1.6.6.5.3.2.1 | Assemble FM 2 Logic Board with Flight ACTELS | 5d | 2004-06-16 | 2004-06-22 | 654, 618, 656 |  |  | 2004-03-09 | 2004-03-23 | 11d | -7d | 0d |  |
| 650 | 1.6.6.5.4 | **Test** | 165d | 2003-11-10 A | 2004-07-07 |  | 81% | 30.84d | 2003-11-10 | 2004-07-09 | 168d | -7d | 0d |  |
| 651 | 1.6.6.5.4.1 | **ETU** | 79d | 2003-11-10 A | 2004-03-05 A |  | 100% |  | 2003-11-10 | 2004-02-06 | 60d |  |  |  |
| 652 | 1.6.6.5.4.1.1 | Test New ETU Logic Board | 79d | 2003-11-10 A | 2004-03-05 A |  | 100% |  | 2003-11-10 | 2004-02-06 | 60d |  |  | start no earlier than 2003-11-10 |
| 653 | 1.6.6.5.4.2 | **FM1 & FM 2** | 8d | 2004-03-22 A | 2004-03-31 A |  | 100% |  | 2004-02-24 | 2004-03-08 | 10d |  |  |  |
| 654 | 1.6.6.5.4.2.1 | Coupon Testing | 8d | 2004-03-22 A | 2004-03-31 A | 644 | 100% |  | 2004-02-24 | 2004-03-08 | 10d |  |  |  |
| 655 | 1.6.6.5.4.3 | **FM 1** | 10d | 2004-06-02 | 2004-06-15 |  |  |  | 2004-03-24 | 2004-06-01 | 49d | -16d | 0d |  |
| 656 | 1.6.6.5.4.3.1 | Functional Test of FM 1 Logic Board w/Flight ACTELS | 10d | 2004-06-02 | 2004-06-15 | 647 |  |  | 2004-03-24 | 2004-04-13 | 15d | -16d | 0d |  |

Notes:
- 647: SIT Actel design review held 4/30 by Rod Barto. Relayout of the board possible. SRAM adhesive issue will be resolved soon and will not ad to the relayout delay.

| ID | WBS | Task | Duration | Start | Finish | Predecessors | Complete | Remaining | Baseline start | Baseline finish | Baseline duration | Total slack | Free slack | Constraint |
| --- | --- | --- | --- | --- | --- | --- | --- | --- | --- | --- | --- | --- | --- | --- |
| 657 | 1.6.6.5.4.4 | **FM 2** | 10d | 2004-06-23 | 2004-07-07 |  |  |  | 2004-04-14 | 2004-07-09 | 62d | -7d | 0d |  |
| 658 | 1.6.6.5.4.4.1 | Functional Test of FM 2 Logic Board w/Flight ACTELS | 10d | 2004-06-23 | 2004-07-07 | 649 |  |  | 2004-04-14 | 2004-05-04 | 15d | -7d | 0d |  |
| 659 | 1.6.6.6 | **Mother Board** | 111d | 2003-12-22 A | 2004-05-28 |  | 74% | 28.46d | 2003-12-22 | 2004-03-25 | 65d | 6d |  |  |
| 660 | 1.6.6.6.1 | **Design** | 67d | 2003-12-22 A | 2004-03-29 A |  | 100% |  | 2003-12-22 | 2004-02-04 | 30d |  |  |  |
| 661 | 1.6.6.6.1.1 | **FM 1 & FM 2** | 67d | 2003-12-22 A | 2004-03-29 A |  | 100% |  | 2003-12-22 | 2004-02-04 | 30d |  |  |  |
| 662 | 1.6.6.6.1.1.1 | Finalize Mother Board Layout | 30d | 2003-12-22 A | 2004-02-04 A |  | 100% |  | 2003-12-22 | 2004-02-04 | 30d |  |  | start no earlier than 2003-12-22 |
| 663 | 1.6.6.6.1.1.2 | Redesign Mother Board Layout | 17d | 2004-03-05 A | 2004-03-29 A | 662, 673 | 100% |  | 2004-03-05 | 2004-03-29 | 17d |  |  |  |
| 664 | 1.6.6.6.2 | **Fabrication** | 52d | 2004-02-05 A | 2004-04-19 A |  | 100% |  | 2004-02-05 | 2004-02-26 | 15d |  |  |  |
| 665 | 1.6.6.6.2.1 | **FM 1 & FM 2** | 52d | 2004-02-05 A | 2004-04-19 A |  | 100% |  | 2004-02-05 | 2004-02-26 | 15d |  |  |  |
| 666 | 1.6.6.6.2.1.1 | Fabricate FM 1 & FM 2 Mother Boards | 15d | 2004-02-05 A | 2004-02-26 A |  | 100% |  | 2004-02-05 | 2004-02-26 | 15d |  |  |  |
| 667 | 1.6.6.6.2.1.2 | Refabricate FM1 & FM2 Mother Boards | 15d | 2004-03-30 A | 2004-04-19 A | 673, 663 | 100% |  | 2004-03-30 | 2004-04-19 | 15d |  |  |  |
| 668 | 1.6.6.6.3 | **Assembly** | 10d | 2004-05-03 | 2004-05-14 |  |  |  | 2004-02-27 | 2004-03-11 | 10d | 0d |  |  |
| 669 | 1.6.6.6.3.1 | Assemble FM 1 Mother Board | 10d | 2004-05-03 | 2004-05-14 | 666, 674FS+4d |  |  | 2004-02-27 | 2004-03-11 | 10d | 0d |  | start no earlier than 2004-03-15 |
| 670 | 1.6.6.6.3.2 | Assemble FM 2 Mother Board | 10d | 2004-05-03 | 2004-05-14 | 669SS |  |  | 2004-02-27 | 2004-03-11 | 10d | 11d | 5d |  |
| 671 | 1.6.6.6.4 | **Test** | 66d | 2004-02-27 A | 2004-05-28 |  | 50% | 33d | 2004-02-27 | 2004-03-25 | 20d | 6d |  |  |
| 672 | 1.6.6.6.4.1 | **FM 1 & FM 2** | 42d | 2004-02-27 A | 2004-04-26 A |  | 100% |  | 2004-02-27 | 2004-03-18 | 15d |  |  |  |
| 673 | 1.6.6.6.4.1.1 | Coupon Testing of Mother Boards | 5d | 2004-02-27 A | 2004-03-04 A |  | 100% |  | 2004-02-27 | 2004-03-18 | 15d |  |  |  |
| 674 | 1.6.6.6.4.1.2 | Coupon Testing of 2nd Mother Boards | 5d | 2004-04-20 A | 2004-04-26 A | 667 | 100% |  | 2004-04-20 | 2004-04-26 | 5d |  |  |  |
| 675 | 1.6.6.6.4.2 | **FM 1** | 5d | 2004-05-17 | 2004-05-21 |  |  |  | 2004-03-12 | 2004-03-18 | 5d | 0d |  |  |
| 676 | 1.6.6.6.4.2.1 | Functional Test FM 1 Mother Board | 5d | 2004-05-17 | 2004-05-21 | 669 |  |  | 2004-03-12 | 2004-03-18 | 5d | 0d |  |  |
| 677 | 1.6.6.6.4.3 | **FM 2** | 5d | 2004-05-24 | 2004-05-28 |  |  |  | 2004-03-19 | 2004-03-25 | 5d | 6d |  |  |
| 678 | 1.6.6.6.4.3.1 | Functional Test FM 2 Mother Board | 5d | 2004-05-24 | 2004-05-28 | 670, 676 |  |  | 2004-03-19 | 2004-03-25 | 5d | 6d |  |  |
| 679 | 1.6.6.7 | **HVPS** | 124d | 2004-01-12 A | 2004-07-07 |  | 75% | 31d | 2004-01-12 | 2004-04-27 | 75d | -10d | 0d |  |
| 680 | 1.6.6.7.1 | **Test** | 124d | 2004-01-12 A | 2004-07-07 |  | 75% | 31d | 2004-01-12 | 2004-04-27 | 75d | -10d | 0d |  |
| 681 | 1.6.6.7.1.1 | **FM 1** | 30d | 2004-01-12 A | 2004-02-24 A |  | 100% |  | 2004-01-12 | 2004-02-09 | 20d |  |  |  |
| 682 | 1.6.6.7.1.1.1 | Functional Test SIT FM 1 HVPS | 30d | 2004-01-12 A | 2004-02-24 A | 71 | 100% |  | 2004-01-12 | 2004-02-09 | 20d |  |  | start no earlier than 2004-01-12 |

Notes:
- 673: After Coupon testing a Mechnical Interface error was found in the board. The design was changed and sent out for Fabrication again.

| ID | WBS | Task | Duration | Start | Finish | Predecessors | Complete | Remaining | Baseline start | Baseline finish | Baseline duration | Total slack | Free slack | Constraint | Text1 |
| --- | --- | --- | --- | --- | --- | --- | --- | --- | --- | --- | --- | --- | --- | --- | --- |
| 683 | 1.6.6.7.1.2 | **FM 2** | 10d | 2004-06-23 | 2004-07-07 |  |  |  | 2004-04-14 | 2004-04-27 | 10d | -10d | 0d |  |  |
| 684 | 1.6.6.7.1.2.1 | Functional Test SIT FM 2 HVPS | 10d | 2004-06-23 | 2004-07-07 | 77, 678 |  |  | 2004-04-14 | 2004-04-27 | 10d | -10d | 0d |  |  |
| 685 | 1.6.6.8 | **Flight Software** | 235d | 2003-06-02 A | 2004-05-06 |  | 89% | 26d | 2003-06-02 | 2004-04-01 | 210d | 38d |  |  |  |
| 686 | 1.6.6.8.1 | **Test** | 235d | 2003-06-02 A | 2004-05-06 |  | 89% | 26d | 2003-06-02 | 2004-04-01 | 210d | 38d |  |  |  |
| 687 | 1.6.6.8.1.1 | **FM 1 & FM 2** | 235d | 2003-06-02 A | 2004-05-06 |  | 89% | 26d | 2003-06-02 | 2004-04-01 | 210d | 38d |  |  |  |
| 688 | 1.6.6.8.1.1.1 | Validate SIT On-Board Code | 235d | 2003-06-02 A | 2004-05-06 |  | 89% | 26d | 2003-06-02 | 2004-04-01 | 210d | 38d |  | start no earlier than 2003-06-02 |  |
| 689 | 1.6.6.9 | **Integration & Test (using ETU Telescope for FM 1)** | 149d | 2004-02-25 A | 2004-09-23 |  | 4% | 143.61d | 2004-03-31 | 2004-07-22 | 81d | -25d | 0d |  |  |
| 690 | 1.6.6.9.1 | **FM 1 (Flight Telescope)** | 12d | 2004-07-27 | 2004-08-11 |  |  |  | 2004-06-02 | 2004-06-17 | 12d | -16d | 0d |  |  |
| 691 | 1.6.6.9.1.1 | Disassemble SIT FM 1 | 1d | 2004-07-27 | 2004-07-27 | 709 |  |  | 2004-06-02 | 2004-06-02 | 1d | -16d | 0d |  |  |
| 692 | 1.6.6.9.1.2 | Conformal Coat SIT FM 1 Boards (includes FM 1 LVPS) | 2d | 2004-07-28 | 2004-07-29 | 691 |  |  | 2004-06-03 | 2004-06-04 | 2d | -16d | 0d |  |  |
| 693 | 1.6.6.9.1.3 | Reassemble SIT FM 1 with Flight Telescope | 1d | 2004-07-30 | 2004-07-30 | 692, 399, 365 |  |  | 2004-06-07 | 2004-06-07 | 1d | -16d | 0d |  |  |
| 694 | 1.6.6.9.1.4 | Bench Calibration SIT FM 1 w/Flight Telescope | 3d | 2004-08-02 | 2004-08-04 | 693 |  |  | 2004-06-08 | 2004-06-10 | 3d | -16d | 0d |  |  |
| 695 | 1.6.6.9.1.5 | Vacuum Test SIT FM 1 w/Flight Telescope | 5d | 2004-08-05 | 2004-08-11 | 694 |  |  | 2004-06-11 | 2004-06-17 | 5d | -16d | 0d |  |  |
| 696 | 1.6.6.9.2 | **FM 2** | 9d | 2004-09-13 | 2004-09-23 |  |  |  | 2004-07-12 | 2004-07-22 | 9d | -25d | 0d |  |  |
| 697 | 1.6.6.9.2.1 | Disassemble SIT FM 2 | 1d | 2004-09-13 | 2004-09-13 | 718 |  |  | 2004-07-12 | 2004-07-12 | 1d | -25d | 0d |  |  |
| 698 | 1.6.6.9.2.2 | Conformal Coat SIT FM 2 Boards | 2d | 2004-09-14 | 2004-09-15 | 697 |  |  | 2004-07-13 | 2004-07-14 | 2d | -25d | 0d |  |  |
| 699 | 1.6.6.9.2.3 | Reassemble SIT FM 2 | 1d | 2004-09-16 | 2004-09-16 | 698 |  |  | 2004-07-15 | 2004-07-15 | 1d | -25d | 0d |  |  |
| 700 | 1.6.6.9.2.4 | Post-Coat Retest SIT FM 2 | 5d | 2004-09-17 | 2004-09-23 | 699 |  |  | 2004-07-16 | 2004-07-22 | 5d | -25d | 0d |  |  |
| 701 | 1.6.6.9.3 | **FM 1 (ETU Telescope)** | 107d | 2004-02-25 A | 2004-07-26 |  | 10% | 96.64d | 2004-03-31 | 2004-05-21 | 38d | -16d | 0d |  |  |
| 702 | 1.6.6.9.3.1 | Integrate SIT FM 1 HVPS and SIT ETU Telescope Without Electronics | 3d | 2004-02-25 A | 2004-02-27 A | 682 | 100% |  | 2004-03-31 | 2004-04-02 | 3d |  |  |  | MS-SEP |
| 703 | 1.6.6.9.3.2 | Integrate Electronics to SIT ETU Telescope | 2d | 2004-06-16 | 2004-06-17 | 656, 624, 676, 637, 702 |  |  | 2004-04-14 | 2004-04-15 | 2d | -16d | 0d |  |  |
| 704 | 1.6.6.9.3.3 | SIT FM 1 Debug | 5d | 2004-06-18 | 2004-06-24 | 703 |  |  | 2004-04-16 | 2004-04-22 | 5d | -16d | 0d |  |  |
| 705 | 1.6.6.9.3.4 | SIT FM 1 Bench Test | 5d | 2004-06-25 | 2004-07-01 | 704 |  |  | 2004-04-23 | 2004-04-29 | 5d | -16d | 0d |  |  |
| 706 | 1.6.6.9.3.5 | SIT FM 1 Alpha TEST | 5d | 2004-07-02 | 2004-07-09 | 705 |  |  | 2004-04-30 | 2004-05-06 | 5d | -16d | 0d |  |  |
| 707 | 1.6.6.9.3.6 | SIT FM 1 Noise Removal | 5d | 2004-07-12 | 2004-07-16 | 706 |  |  | 2004-05-07 | 2004-05-13 | 5d | -16d | 0d |  |  |
| 708 | 1.6.6.9.3.7 | SIT FM 1 Thermal Test | 5d | 2004-07-19 | 2004-07-23 | 707 |  |  | 2004-05-14 | 2004-05-20 | 5d | -16d | 0d |  |  |
| 709 | 1.6.6.9.3.8 | SIT FM 1 Functional Test | 1d | 2004-07-26 | 2004-07-26 | 708, 688 |  |  | 2004-05-21 | 2004-05-21 | 1d | -16d | 0d |  |  |

| ID | WBS | Task | Duration | Start | Finish | Predecessors | Baseline start | Baseline finish | Baseline duration | Total slack | Free slack | Constraint | Text1 |
| --- | --- | --- | --- | --- | --- | --- | --- | --- | --- | --- | --- | --- | --- |
| 710 | 1.6.6.9.4 | **FM 2** | 31d | 2004-07-29 | 2004-09-10 |  | 2004-05-19 | 2004-07-01 | 31d | -25d | 0d |  |  |
| 711 | 1.6.6.9.4.1 | Integrate SIT FM 2 HVPS and SIT FM 2 Telescope Without Electronics | 3d | 2004-07-29 | 2004-08-02 | 684, 399, 365 | 2004-05-19 | 2004-05-21 | 3d | -25d | 0d |  | MS-SEP |
| 712 | 1.6.6.9.4.2 | Integrate Electronics to SIT FM 2 Telescope | 2d | 2004-08-03 | 2004-08-04 | 658, 626, 678, 639, 711 | 2004-05-24 | 2004-05-25 | 2d | -25d | 0d |  |  |
| 713 | 1.6.6.9.4.3 | SIT FM 2 Debug | 5d | 2004-08-05 | 2004-08-11 | 712 | 2004-05-26 | 2004-06-02 | 5d | -25d | 0d |  |  |
| 714 | 1.6.6.9.4.4 | SIT FM 2 Bench Test | 5d | 2004-08-12 | 2004-08-18 | 713 | 2004-06-03 | 2004-06-09 | 5d | -25d | 0d |  |  |
| 715 | 1.6.6.9.4.5 | SIT FM 2 Alpha Test | 5d | 2004-08-19 | 2004-08-25 | 714 | 2004-06-10 | 2004-06-16 | 5d | -25d | 0d |  |  |
| 716 | 1.6.6.9.4.6 | SIT FM 2 Noise Removal | 5d | 2004-08-26 | 2004-09-01 | 715, 707 | 2004-06-17 | 2004-06-23 | 5d | -25d | 0d |  |  |
| 717 | 1.6.6.9.4.7 | SIT FM 2 Thermal Test | 5d | 2004-09-02 | 2004-09-09 | 716 | 2004-06-24 | 2004-06-30 | 5d | -25d | 0d |  |  |
| 718 | 1.6.6.9.4.8 | SIT FM 2 Functional Test | 1d | 2004-09-10 | 2004-09-10 | 717 | 2004-07-01 | 2004-07-01 | 1d | -25d | 0d |  |  |
| 719 | 1.6.6.10 | Integrate SIT Door FM 1 | 1d | 2004-09-10 | 2004-09-10 | 611, 412 | 2004-08-20 | 2004-08-20 | 1d | -17d | 0d |  |  |
| 720 | 1.6.6.11 | Integrate SIT Door FM 2 | 1d | 2004-10-12 | 2004-10-12 | 614, 719 | 2004-09-01 | 2004-09-01 | 1d | -24d | 0d |  |  |
| 721 | 1.6.6.12 | **Environmental Testing at GSFC (FM 1)** | 34d | 2004-09-13 | 2004-10-29 |  | 2004-07-15 | 2004-08-31 | 34d | -17d | 0d |  |  |
| 722 | 1.6.6.12.1 | SIT FM 1 Vibration and Acoustics | 10d | 2004-09-13 | 2004-09-24 | 611, 719 | 2004-07-15 | 2004-07-28 | 10d | -17d | 0d | start no earlier than 2004-08-23 |  |
| 723 | 1.6.6.12.2 | Functional Test | 1d | 2004-09-27 | 2004-09-27 | 722 | 2004-07-29 | 2004-07-29 | 1d | -17d | 0d |  |  |
| 724 | 1.6.6.12.3 | SIT FM 1 Thermal Balance | 5d | 2004-09-28 | 2004-10-04 | 723 | 2004-07-30 | 2004-08-05 | 5d | -17d | 0d |  |  |
| 725 | 1.6.6.12.4 | SIT FM 1 Thermal Vac | 10d | 2004-10-05 | 2004-10-19 | 724 | 2004-08-06 | 2004-08-19 | 10d | -17d | 0d |  |  |
| 726 | 1.6.6.12.5 | Disassemble SIT Instruments | 2d | 2004-10-20 | 2004-10-21 | 725 | 2004-08-20 | 2004-08-23 | 2d | -17d | 0d |  |  |
| 727 | 1.6.6.12.6 | Bake Out | 3d | 2004-10-22 | 2004-10-26 | 726 | 2004-08-24 | 2004-08-26 | 3d | -17d | 0d |  |  |
| 728 | 1.6.6.12.7 | Reassemble Instruments | 2d | 2004-10-27 | 2004-10-28 | 727 | 2004-08-27 | 2004-08-30 | 2d | -17d | 0d |  |  |
| 729 | 1.6.6.12.8 | Functional Test | 1d | 2004-10-29 | 2004-10-29 | 728 | 2004-08-31 | 2004-08-31 | 1d | -17d | 0d |  |  |
| 730 | 1.6.6.13 | **Environmental Testing at GSFC (FM 2)** | 34d | 2004-10-13 | 2004-12-01 |  | 2004-08-23 | 2004-10-08 | 34d | -24d | 0d |  |  |
| 731 | 1.6.6.13.1 | SIT FM 2 Vibration and Acoustics | 10d | 2004-10-13 | 2004-10-26 | 614, 720 | 2004-08-23 | 2004-09-03 | 10d | -24d | 0d | start no earlier than 2004-09-02 |  |
| 732 | 1.6.6.13.2 | Functional Test | 1d | 2004-10-27 | 2004-10-27 | 731 | 2004-09-07 | 2004-09-07 | 1d | -24d | 0d |  |  |
| 733 | 1.6.6.13.3 | SIT FM 2 Thermal Balance | 5d | 2004-10-28 | 2004-11-03 | 732 | 2004-09-08 | 2004-09-14 | 5d | -24d | 0d |  |  |
| 734 | 1.6.6.13.4 | SIT FM 2 Thermal Vac | 10d | 2004-11-04 | 2004-11-18 | 733 | 2004-09-15 | 2004-09-28 | 10d | -24d | 0d |  |  |
| 735 | 1.6.6.13.5 | Disassemble SIT Instruments | 2d | 2004-11-19 | 2004-11-22 | 734 | 2004-09-29 | 2004-09-30 | 2d | -24d | 0d |  |  |
| 736 | 1.6.6.13.6 | Bake Out | 3d | 2004-11-23 | 2004-11-26 | 735 | 2004-10-01 | 2004-10-05 | 3d | -24d | 0d |  |  |
| 737 | 1.6.6.13.7 | Reassemble Instruments | 2d | 2004-11-29 | 2004-11-30 | 736 | 2004-10-06 | 2004-10-07 | 2d | -24d | 0d |  |  |
| 738 | 1.6.6.13.8 | Functional Test | 1d | 2004-12-01 | 2004-12-01 | 737 | 2004-10-08 | 2004-10-08 | 1d | -24d | 0d |  |  |

| ID | WBS | Task | Duration | Start | Finish | Predecessors | Complete | Remaining | Baseline start | Baseline finish | Baseline duration | Total slack | Free slack | Constraint | Text1 |
| --- | --- | --- | --- | --- | --- | --- | --- | --- | --- | --- | --- | --- | --- | --- | --- |
| 739 | 1.6.6.14 | **Emulators/Simulators/GSE** | 237d | 2003-12-17 A | 2004-11-24 |  | 76% | 57.34d | 2003-12-17 | 2004-10-20 | 214d | -20d | 0d |  |  |
| 740 | 1.6.6.14.1 | **Simulators** | 104d | 2003-12-17 A | 2004-05-14 |  | 90% | 10d | 2003-12-17 | 2004-04-12 | 80d | 73d |  |  |  |
| 741 | 1.6.6.14.1.1 | Labview CPU Ready | 104d | 2003-12-17 A | 2004-05-14 |  | 90% | 10d | 2003-12-17 | 2004-04-12 | 80d | 0d |  | must start on 2003-12-17 |  |
| 742 | 1.6.6.14.1.2 | Test Simulator | 104d | 2003-12-17 A | 2004-05-14 | 741SS | 90% | 10d | 2003-12-17 | 2004-04-12 | 80d | 73d |  |  |  |
| 743 | 1.6.6.14.2 | **GSE** | 40d | 2004-09-28 | 2004-11-24 |  |  |  | 2004-07-27 | 2004-10-20 | 60d | -20d | 0d |  |  |
| 744 | 1.6.6.14.2.1 | Pulse Generator | 40d | 2004-09-28 | 2004-11-24 | 610, 613, 742 |  |  | 2004-07-27 | 2004-10-20 | 60d | -20d | 0d |  |  |
| 745 | 1.6.7 | **SEP Suite I&T - CIT** | 333d | 2003-08-01 A | 2004-11-29 |  | 46% | 180.34d | 2003-08-01 | 2004-10-21 | 309d | -20d | 0d |  |  |
| 746 | 1.6.7.1 | **ETU** | 5d | 2004-01-26 A | 2004-01-30 A |  | 100% |  | 2004-01-26 | 2004-01-30 | 5d |  |  |  |  |
| 747 | 1.6.7.1.1 | Complete Integration/Test of SEP Central EM with Sensors | 5d | 2004-01-26 A | 2004-01-30 A |  | 100% |  | 2004-01-26 | 2004-01-30 | 5d |  |  | start no earlier than 2004-01-26 |  |
| 748 | 1.6.7.2 | **FM 1 & FM 2** | 43d | 2004-06-17 | 2004-08-17 |  |  |  | 2004-03-05 | 2004-10-21 | 162d | -17d | 0d |  |  |
| 749 | 1.6.7.2.1 | Generate HET integration & test procedure | 5d | 2004-06-17 | 2004-06-23 | 758FS-10d |  |  | 2004-05-20 | 2004-05-26 | 5d | 4d |  |  |  |
| 750 | 1.6.7.2.2 | Generate LET integration & test procedure | 5d | 2004-06-21 | 2004-06-25 | 759FS-10d |  |  | 2004-05-05 | 2004-05-11 | 5d | 3d |  |  |  |
| 751 | 1.6.7.2.3 | Generate SEPT integration & test procedure | 5d | 2004-07-21 | 2004-07-27 | 762FS-10d |  |  | 2004-03-05 | 2004-03-11 | 5d | -6d | 0d |  |  |
| 752 | 1.6.7.2.4 | Generate SEP-IDPU integration procedure | 5d | 2004-07-22 | 2004-07-28 | 763FS-10d |  |  | 2004-05-27 | 2004-06-03 | 5d | -10d | 0d |  |  |
| 753 | 1.6.7.2.5 | Generate SEP-IDPU test procedure | 5d | 2004-07-29 | 2004-08-04 | 752 |  |  | 2004-06-04 | 2004-06-10 | 5d | -10d | 0d |  |  |
| 754 | 1.6.7.2.6 | Generate SIT integration & test procedure | 5d | 2004-08-10 | 2004-08-16 | 766FS-10d |  |  | 2004-06-09 | 2004-06-15 | 5d | -16d | 0d |  |  |
| 755 | 1.6.7.2.7 | Generate SEP system test procedure | 5d | 2004-08-11 | 2004-08-17 | 767FS-10d |  |  | 2004-06-10 | 2004-06-16 | 5d | -21d | 0d |  |  |
| 756 | 1.6.7.3 | **FM 1** | 39d | 2004-06-30 | 2004-08-24 |  |  |  | 2004-03-18 | 2004-06-28 | 72d | -21d | 0d |  | MS-SEP |
| 757 | 1.6.7.3.1 | Integrate/test SEP Central FM 1 | 5d | 2004-07-01 | 2004-07-08 | 420, 422, 375 |  |  | 2004-05-11 | 2004-05-17 | 5d | -2d | 0d |  |  |
| 758 | 1.6.7.3.2 | Receive & inspect HET FM 1 | 1d | 2004-06-30 | 2004-06-30 | 450, 453 |  |  | 2004-06-03 | 2004-06-03 | 1d | 4d | 0d |  |  |
| 759 | 1.6.7.3.3 | Integrate & test HET FM 1 | 1d | 2004-07-02 | 2004-07-02 | 749, 757FS-4d |  |  | 2004-06-10 | 2004-06-10 | 1d | -2d | 0d |  |  |
| 760 | 1.6.7.3.4 | Integrate & test LET FM 1 | 1d | 2004-07-08 | 2004-07-08 | 759, 750, 506 |  |  | 2004-06-09 | 2004-06-09 | 1d | -4d | 0d |  |  |
| 761 | 1.6.7.3.5 | Re-integrate & test HET FM 1 w/ Flight detectors | 1d | 2004-07-22 | 2004-07-22 | 451, 799 |  |  |  |  |  | -4d | 0d |  |  |
| 762 | 1.6.7.3.6 | Receive & inspect SEPT FM 1 | 1d | 2004-08-03 | 2004-08-03 | 761, 529, 530 |  |  | 2004-03-18 | 2004-03-18 | 1d | -11d | 0d |  |  |
| 763 | 1.6.7.3.7 | Integrate & test SEPT FM 1 | 1d | 2004-08-04 | 2004-08-04 | 762, 751 |  |  | 2004-05-18 | 2004-05-18 | 1d | -11d | 0d |  |  |
| 764 | 1.6.7.3.8 | Integrate SEP FM 1 - IDPU FM 1 | 1d | 2004-08-19 | 2004-08-19 | 752, 351, 763 |  |  | 2004-06-11 | 2004-06-11 | 1d | -21d | 0d |  |  |
| 765 | 1.6.7.3.9 | Test SEP FM 1 - IDPU FM 1 | 1d | 2004-08-20 | 2004-08-20 | 764, 753 |  |  | 2004-06-22 | 2004-06-22 | 1d | -21d | 0d |  |  |
| 766 | 1.6.7.3.10 | Receive & inspect SIT FM 1 | 1d | 2004-08-23 | 2004-08-23 | 610, 765 |  |  | 2004-06-22 | 2004-06-22 | 1d | -21d | 0d |  |  |
| 767 | 1.6.7.3.11 | Integrate & test SIT FM 1 | 1d | 2004-08-24 | 2004-08-24 | 766, 754 |  |  | 2004-06-23 | 2004-06-23 | 1d | -21d | 0d |  |  |
| 768 | 1.6.7.3.12 | SEP system test FM 1 | 3d | 2004-08-19 | 2004-08-23 | 417, 755 |  |  | 2004-06-24 | 2004-06-28 | 3d | -22d | 0d |  |  |

| ID | WBS | Task | Duration | Start | Finish | Predecessors | Baseline start | Baseline finish | Baseline duration | Total slack | Free slack | Constraint | Text1 |
| --- | --- | --- | --- | --- | --- | --- | --- | --- | --- | --- | --- | --- | --- |
| 769 | 1.6.7.4 | **FM 2** | 49d | 2004-07-27 | 2004-10-04 |  | 2004-03-29 | 2004-08-11 | 97d | 2d |  |  | MS-SEP |
| 770 | 1.6.7.4.1 | Integrate/testSEP Central FM 2 | 5d | 2004-07-27 | 2004-08-02 | 421, 422, 375 | 2004-05-11 | 2004-05-17 | 5d | 41d | 1d |  |  |
| 771 | 1.6.7.4.2 | Receive & inspect SEPT FM 2 | 1d | 2004-08-03 | 2004-08-03 | 532, 533 | 2004-03-29 | 2004-03-29 | 1d | 40d | 0d |  |  |
| 772 | 1.6.7.4.3 | Integrate & test SEPT FM 2 | 1d | 2004-08-04 | 2004-08-04 | 771, 770, 751 | 2004-05-18 | 2004-05-18 | 1d | 40d | 0d |  |  |
| 773 | 1.6.7.4.4 | Integrate & test LET FM 2 | 1d | 2004-08-05 | 2004-08-05 | 772, 507, 508, 750 | 2004-06-09 | 2004-06-09 | 1d | 40d | 0d |  |  |
| 774 | 1.6.7.4.5 | Receive & inspect HET FM 2 | 1d | 2004-08-05 | 2004-08-05 | 452 | 2004-06-24 | 2004-06-24 | 1d | 40d | 0d |  |  |
| 775 | 1.6.7.4.6 | Integrate & test HET FM 2 | 1d | 2004-08-06 | 2004-08-06 | 749, 773, 774 | 2004-06-25 | 2004-06-25 | 1d | 40d | 4d |  |  |
| 776 | 1.6.7.4.7 | Integrate SEP FM 2 - IDPU FM 2 | 1d | 2004-08-13 | 2004-08-13 | 775, 161, 752 | 2004-06-28 | 2004-06-28 | 1d | 36d | 0d |  |  |
| 777 | 1.6.7.4.8 | Test SEP FM 2 - IDPU FM 2 | 1d | 2004-08-16 | 2004-08-16 | 776, 753 | 2004-06-29 | 2004-06-29 | 1d | 36d | 28d |  |  |
| 778 | 1.6.7.4.9 | Receive & inspect SIT FM 2 | 1d | 2004-09-28 | 2004-09-28 | 613 | 2004-07-27 | 2004-07-27 | 1d | -25d | 0d |  |  |
| 779 | 1.6.7.4.10 | Integrate & test SIT FM 2 | 1d | 2004-09-29 | 2004-09-29 | 778, 754 | 2004-08-06 | 2004-08-06 | 1d | -25d | 0d |  |  |
| 780 | 1.6.7.4.11 | SEP FM 2 system test | 3d | 2004-09-30 | 2004-10-04 | 779, 755 | 2004-08-09 | 2004-08-11 | 3d | -25d | 0d |  |  |
| 781 | 1.6.7.5 | **Environmental Test (at JPL)** | 135d | 2004-05-17 | 2004-11-29 |  | 2004-05-17 | 2004-09-24 | 93d | -20d | 0d |  |  |
| 782 | 1.6.7.5.1 | Generate Environmental Test Procedures | 15d | 2004-05-17 | 2004-06-07 |  | 2004-05-17 | 2004-06-07 | 15d | 45d |  | start no earlier than 2004-05-17 |  |
| 783 | 1.6.7.5.2 | Manufacture test cables (JPL) | 20d | 2004-06-01 | 2004-06-28 |  | 2004-06-01 | 2004-06-28 | 20d | 30d |  | start no earlier than 2004-06-01 |  |
| 784 | 1.6.7.5.3 | **FM 1** | 43d | 2004-09-13 | 2004-11-12 |  | 2004-07-23 | 2004-09-24 | 45d | -24d | 0d |  |  |
| 785 | 1.6.7.5.3.1 | FM 1 LET/HET/SEP Central Vibration/Acoustics Test | 10d | 2004-09-13 | 2004-09-24 | 19FS+3d, 782, 783, 799FS+3d | 2004-07-23 | 2004-08-05 | 10d | -22d | 0d |  |  |
| 786 | 1.6.7.5.3.2 | FM 1 LET/HET/SEP Central Thermal Balance Test | 5d | 2004-09-27 | 2004-10-01 | 785 | 2004-08-06 | 2004-08-12 | 5d | -22d | 0d |  |  |
| 787 | 1.6.7.5.3.3 | FM 1 LET/HET/SEP Central T/V Test | 15d | 2004-10-07 | 2004-10-28 | 786, 792 | 2004-08-19 | 2004-09-09 | 15d | -25d | 0d |  |  |
| 788 | 1.6.7.5.3.4 | Evaluate SEP performance | 10d | 2004-10-29 | 2004-11-12 | 787 | 2004-09-10 | 2004-09-23 | 10d | -25d | 0d |  |  |
| 789 | 1.6.7.5.3.5 | Generate test reports | 11d | 2004-09-23 | 2004-10-07 | 788SS | 2004-09-10 | 2004-09-24 | 11d | -25d | 0d | finish no later than 2004-10-07 |  |
| 790 | 1.6.7.5.3.6 | Bakeout Clean SEP exterior & prepare for delivery | 3d | 2004-10-29 | 2004-11-02 | 787 | 2004-09-10 | 2004-09-14 | 3d | -18d | 0d |  |  |
| 791 | 1.6.7.5.4 | **FM 2** | 37d | 2004-10-05 | 2004-11-29 |  | 2004-07-23 | 2004-09-24 | 45d | -25d | 0d |  |  |
| 792 | 1.6.7.5.4.1 | FM 2 EMI/EMC Test at CalTech | 2d | 2004-10-05 | 2004-10-06 | 780 | 2004-08-12 | 2004-08-18 | 5d | -25d | 0d |  | MS-SEP |
| 793 | 1.6.7.5.4.2 | FM 2 LET/HET/SEP Central Vibration/Acoustics Test | 10d | 2004-10-07 | 2004-10-21 | 792 | 2004-07-23 | 2004-08-05 | 10d | -21d | 0d |  |  |
| 794 | 1.6.7.5.4.3 | FM 2 LET/HET/SEP Central T/V Test | 15d | 2004-10-22 | 2004-11-12 | 792, 793 | 2004-08-19 | 2004-09-09 | 15d | -21d | 0d |  |  |
| 795 | 1.6.7.5.4.4 | Evaluate SEP performance | 10d | 2004-11-15 | 2004-11-29 | 794 | 2004-09-10 | 2004-09-23 | 10d | -21d | 0d |  |  |
| 796 | 1.6.7.5.4.5 | Generate test reports | 11d | 2004-10-14 | 2004-10-28 | 795SS | 2004-09-10 | 2004-09-24 | 11d | -21d | 0d | finish no later than 2004-10-28 |  |
| 797 | 1.6.7.5.4.6 | Bakeout Clean SEP exterior & prepare for delivery | 3d | 2004-11-15 | 2004-11-17 | 794 | 2004-09-10 | 2004-09-14 | 3d | -14d | 0d |  |  |

| ID | WBS | Task | Duration | Start | Finish | Predecessors | Complete | Remaining | Baseline start | Baseline finish | Baseline duration | Total slack | Free slack | Constraint | Calendar |
| --- | --- | --- | --- | --- | --- | --- | --- | --- | --- | --- | --- | --- | --- | --- | --- |
| 798 | 1.6.7.6 | **Accelerator Test (at MSU)** | 4d | 2004-07-10 | 2004-07-15 |  |  |  | 2004-07-13 | 2004-07-19 | 5d | -5d | 0d |  |  |
| 799 | 1.6.7.6.1 | FM 1 LET/SEP Cen end-to-end test at Accelerator | 3d | 2004-07-10 | 2004-07-12 | 806, 406, 760 |  |  | 2004-07-13 | 2004-07-19 | 5d | -6d | 0d | start no earlier than 2004-07-10 | Weekend |
| 800 | 1.6.7.6.2 | Detach HET FM1 from SEP Suite | 1d | 2004-07-13 | 2004-07-13 | 799 |  |  | 2004-07-12 | 2004-07-12 | 1d | -4d | 0d |  |  |
| 801 | 1.6.7.6.3 | Deliver HET FM1 to GSFC for Replacement Detectors | 2d | 2004-07-14 | 2004-07-15 | 800 |  |  | 2004-07-13 | 2004-07-14 | 2d | -4d | 0d |  |  |
| 802 | 1.6.7.7 | **GSE** | 305d | 2003-08-01 A | 2004-10-18 |  | 62% | 115.97d | 2003-08-01 | 2004-10-15 | 305d | 8d |  |  |  |
| 803 | 1.6.7.7.1 | **End-to-End Test Equipment** | 218d | 2003-08-11 A | 2004-06-22 |  | 83% | 36d | 2003-08-11 | 2004-06-22 | 218d | 7d |  |  |  |
| 804 | 1.6.7.7.1.1 | Design | 192d | 2003-08-11 A | 2004-05-14 |  | 95% | 10d | 2003-08-11 | 2004-05-14 | 192d | 7d | 0d | start no earlier than 2003-08-11 |  |
| 805 | 1.6.7.7.1.2 | Assemble | 21d | 2004-05-17 | 2004-06-15 | 804 |  |  | 2004-05-17 | 2004-06-15 | 21d | 7d | 0d |  |  |
| 806 | 1.6.7.7.1.3 | Test | 5d | 2004-06-16 | 2004-06-22 | 805 |  |  | 2004-06-16 | 2004-06-22 | 5d | 7d |  |  |  |
| 807 | 1.6.7.7.2 | **GSE software** | 305d | 2003-08-01 A | 2004-10-18 |  | 50% | 153.71d | 2003-08-01 | 2004-10-15 | 305d | 8d |  |  |  |
| 808 | 1.6.7.7.2.1 | Build GSE software release 2 | 232d | 2003-08-01 A | 2004-07-02 |  | 81% | 44d | 2003-08-01 | 2004-03-18 | 157d | 0d |  | must start on 2003-08-01 |  |
| 809 | 1.6.7.7.2.2 | Write user's guide | 10d | 2004-06-21 | 2004-07-02 | 808FS-10d |  |  | 2004-03-22 | 2004-03-31 | 8d | 9d | 0d | start no earlier than 2004-03-22 |  |
| 810 | 1.6.7.7.2.3 | Build GSE software release 3 | 117d | 2004-05-03 | 2004-10-18 | 809FS-45d |  |  | 2004-05-03 | 2004-10-15 | 117d | 8d | 0d | start no earlier than 2004-05-03 |  |
| 811 | 1.6.7.7.2.4 | Write user's guide supplement | 20d | 2004-09-20 | 2004-10-18 | 810FS-20d |  |  | 2004-09-15 | 2004-10-15 | 22d | 8d |  | finish no later than 2004-10-28 |  |
| 812 | 1.7 | **SWEA and SIT Refurbishment (after S/C Environmental Testing)** | 40d | 2005-09-27 | 2005-11-21 |  |  |  | 2005-09-27 | 2005-11-18 | 39d | 0d |  |  |  |
| 813 | 1.7.1 | Ship SWEA FM 1 to UCB | 3d | 2005-09-27 | 2005-09-29 |  |  |  | 2005-09-27 | 2005-09-29 | 3d | 25d | 0d | start no earlier than 2005-09-27 |  |
| 814 | 1.7.2 | Ship (Hand Carry) SIT FM 1 to UMD | 1d | 2005-09-27 | 2005-09-27 |  |  |  | 2005-09-27 | 2005-09-27 | 1d | 27d | 0d | start no earlier than 2005-09-27 |  |
| 815 | 1.7.3 | Ship SWEA FM 2 to UCB | 3d | 2005-10-04 | 2005-10-06 |  |  |  | 2005-10-04 | 2005-10-06 | 3d | 20d | 0d | start no earlier than 2005-10-04 |  |
| 816 | 1.7.4 | Ship (Hand Carry) SIT FM 2 to UMD | 1d | 2005-10-04 | 2005-10-04 |  |  |  | 2005-10-04 | 2005-10-04 | 1d | 22d | 0d | start no earlier than 2005-10-04 |  |
| 817 | 1.7.5 | Vacuum Testing of SWEA FM 1 @ UCB | 5d | 2005-09-30 | 2005-10-06 | 813 |  |  | 2005-09-30 | 2005-10-06 | 5d | 25d | 5d |  |  |
| 818 | 1.7.6 | Vacuum Testing of SIT FM 1 @ UMD | 5d | 2005-09-28 | 2005-10-04 | 814 |  |  | 2005-09-28 | 2005-10-04 | 5d | 27d | 5d |  |  |
| 819 | 1.7.7 | Vacuum Testing of SWEA FM 2 @ UCB | 5d | 2005-10-07 | 2005-10-13 | 815 |  |  | 2005-10-07 | 2005-10-13 | 5d | 20d | 0d |  |  |
| 820 | 1.7.8 | Vacuum Testing of SIT FM 2 @ UMD | 5d | 2005-10-05 | 2005-10-11 | 816 |  |  | 2005-10-05 | 2005-10-11 | 5d | 22d | 0d |  |  |
| 821 | 1.7.9 | Ship SWEA FM 1 & 2 to Launch Site for Re-integration to S/C | 3d | 2005-10-14 | 2005-10-18 | 817, 819 |  |  | 2005-10-07 | 2005-10-11 | 3d | 20d | 0d |  |  |
| 822 | 1.7.10 | Ship SIT FM 1 & 2 to Launch Site for Re-integration to S/C | 3d | 2005-10-12 | 2005-10-14 | 818, 820 |  |  | 2005-10-05 | 2005-10-07 | 3d | 22d | 2d |  |  |
| 823 | 1.7.11 | Reintegration of SWEA and SIT to S/C (at Launch Site) | 3d | 2005-10-19 | 2005-10-21 | 821, 822 |  |  | 2005-10-12 | 2005-10-14 | 3d | 20d |  |  |  |
| 824 | 1.7.12 | Target Date for Reintegration to S/C | 1d | 2005-11-19 | 2005-11-21 | 823 |  |  | 2005-11-18 | 2005-11-18 | 1d | 0d |  | must start on 2005-11-19 |  |

Notes:
- 798: The Accelerator Test Date is still TBD. The actual testing date will depend on availability of the facility at MSU and the readiness of our flight hardware. The date currently reflected in the schedule is therefore subject to change as required.
