# IMPACT Master Schedule

Schedule from MS Project, 2003-02-26 to 2005-11-21, status date 2004-04-30, A marks actual dates.
IMPACT Instrument Suites
NASA GSFC - STEREO
This is the IMPACT Consolidated Schedule. Creation began in October 2003 and was then put on hold and subsequently completed in January 2004. Completed tasks, redundant milestones, contingency blocks and obsolete tasks were deleted from this schedule. / Schedule was baselined on 2/18/04 with status through January 31, 2004. / Maintenance of this Schedule was transferred from Jim Rodgers to Tabitha Merchant on 03/22/04

## Calendars

- Standard: Mon-Fri 08:00-12:00, 13:00-17:00; Sat-Sun off. Exceptions (off unless hours are given): 2003-05-26, 2003-07-04, 2003-09-01, 2003-10-13, 2003-11-11, 2003-11-27, 2003-12-25, 2004-01-01, 2004-01-19, 2004-02-16, 2004-05-31, 2004-07-05, 2004-09-06, 2004-10-11, 2004-11-11, 2004-11-25.
- Boom Test Calendar: Mon-Fri 08:00-12:00, 13:00-17:00; Sat-Sun off. Exceptions (off unless hours are given): 2003-05-26, 2003-07-04, 2003-09-01, 2003-10-13, 2003-11-11, 2003-11-27, 2003-12-25, 2004-01-01, 2004-01-19, 2004-02-16, 2004-02-28 to 2004-02-29 08:00-12:00, 13:00-17:00, 2004-03-06 to 2004-03-07 08:00-12:00, 13:00-17:00, 2004-05-31, 2004-09-06, 2004-10-11, 2004-11-11, 2004-11-25.
- Weekend: Mon-Fri 08:00-12:00, 13:00-17:00; Sat-Sun off. Exceptions (off unless hours are given): 2004-07-10 to 2004-07-11 08:00-12:00, 13:00-17:00.
- Internation Work Schedule: Mon-Fri 08:00-12:00, 13:00-17:00; Sat-Sun off. Exceptions (off unless hours are given): 2003-05-26, 2003-07-04, 2003-09-01, 2003-10-13, 2003-11-11, 2003-11-27, 2003-12-25, 2004-01-01, 2004-01-19, 2004-02-16, 2004-05-31, 2004-07-05, 2004-09-06, 2004-10-11 08:00-12:00, 13:00-17:00, 2004-11-11, 2004-11-25.

## Schedule

| ID | WBS | Task | Type | Duration | Start | Finish | Predecessors | Complete | Remaining | Baseline start | Baseline finish | Baseline duration | Total slack | Free slack | Constraint | Text1 |
| --- | --- | --- | --- | --- | --- | --- | --- | --- | --- | --- | --- | --- | --- | --- | --- | --- |
| 1 | 1 | **IMPACT - Dave Curtis (UCB) & Lil Reichenthal (GSFC)** |  | 698d | 2003-02-26 A | 2005-11-21 |  | 81% | 130.34d | 2003-02-26 | 2005-11-18 | 698d | 0d |  |  |  |
| 2 | 1.1 | **Suite Deliveries to APL** |  | 50d | 2004-10-07 | 2004-12-20 |  |  |  | 2004-08-13 | 2004-10-28 | 51d | -36d | 0d |  |  |
| 3 | 1.1.1 | FM 1 Target Delivery Date | milestone | 0d | 2004-10-07 | 2004-10-07 | 5, 7 |  |  | 2004-10-07 | 2004-10-07 | 0d | -37d | 0d | must start on 2004-10-07 | MS-BOOM |
| 4 | 1.1.2 | FM 2 Target Delivery Date | milestone | 0d | 2004-10-28 | 2004-10-28 | 8, 6 |  |  | 2004-10-28 | 2004-10-28 | 0d | -36d | 0d | must start on 2004-10-28 | MS-BOOM |
| 5 | 1.1.3 | Boom Suite FM 1 Ready for Delivery to APL | milestone | 0d | 2004-11-09 | 2004-11-09 | 399 |  |  | 2004-08-13 | 2004-08-13 | 0d | -23d | 0d |  | MS-BOOM |
| 6 | 1.1.4 | Boom Suite FM 2 Ready for Delivery to APL | milestone | 0d | 2004-11-30 | 2004-11-30 | 405 |  |  | 2004-09-28 | 2004-09-28 | 0d | -22d | 0d |  | MS-BOOM |
| 7 | 1.1.5 | SEP Suite FM 1 Ready for Delivery to APL | milestone | 0d | 2004-12-01 | 2004-12-01 | 874, 698, 595 |  |  | 2004-09-14 | 2004-09-14 | 0d | -37d | 0d |  | MS-SEP |
| 8 | 1.1.6 | SEP Suite FM 2 Ready for Delivery to APL | milestone | 0d | 2004-12-20 | 2004-12-20 | 884 |  |  | 2004-10-12 | 2004-10-12 | 0d | -36d | 0d |  | MS-SEP |
| 9 | 1.2 | **Environmental Testing - PER, Impact Suite EMC, Snapshots of Boom & SEP Suite Test Flows** |  | 238d | 2004-01-14 A | 2004-12-22 |  | 23% | 182.21d | 2004-01-14 | 2004-10-05 | 186d | 238d |  |  |  |
| 10 | 1.2.1 | **Reviews (PER and TRR's) - TRR Dates are Tentative** |  | 184d | 2004-01-14 A | 2004-10-04 |  | 50% | 92d | 2004-01-14 | 2004-07-08 | 124d | 292d |  |  |  |
| 11 | 1.2.1.1 | Instrument PER at UCB |  | 1d | 2004-01-14 A | 2004-01-14 A |  | 100% |  | 2004-01-14 | 2004-01-14 | 1d |  |  | start no earlier than 2004-01-14 |  |
| 12 | 1.2.1.2 | TRR 1 - Prior to FM 1 SEPT Thermal Vac |  | 1d | 2004-02-13 A | 2004-02-13 A | 39SS-6d | 100% |  | 2004-02-13 | 2004-02-13 | 1d |  |  |  |  |
| 13 | 1.2.1.3 | TRR 2 - Prior to FM 1 STE-U Thermal Vac/Thermal Balance |  | 1d | 2004-04-19 A | 2004-04-19 A | 21SS-6d | 100% |  | 2004-03-25 | 2004-03-25 | 1d |  |  | start no earlier than 2004-04-19 |  |
| 14 | 1.2.1.4 | TRR 3 - Prior to FM 1 Boom Structure Vibration |  | 1d | 2004-04-19 A | 2004-04-19 A | 22SS-19d | 100% |  | 2004-04-20 | 2004-04-20 | 1d |  |  |  |  |
| 15 | 1.2.1.5 | TRR 4 - Prior to FM 1 IDPU Vibration |  | 1d | 2004-09-29 | 2004-09-29 | 23SS-5d |  |  | 2004-04-26 | 2004-04-26 | 1d | 295d |  |  |  |
| 16 | 1.2.1.6 | TRR 5 - Prior to FM 1 SWEA Vibration |  | 1d | 2004-09-29 | 2004-09-29 | 26SS-5d |  |  | 2004-05-28 | 2004-05-28 | 1d | 295d |  |  |  |
| 17 | 1.2.1.7 | TRR 6 - Prior to FM 1 Impact Suite EMC (for Boom and SEP) |  | 1d | 2004-09-15 | 2004-09-15 | 19SS-5d |  |  | 2004-06-22 | 2004-06-22 | 1d | 305d |  |  |  |
| 18 | 1.2.1.8 | TRR 7 - Prior to FM 1 SIT Vibration |  | 1d | 2004-10-04 | 2004-10-04 | 43SS-5d |  |  | 2004-07-08 | 2004-07-08 | 1d | 292d |  |  |  |
| 19 | 1.2.2 | IMPACT Suite FM 1 EMC Testing at UCB |  | 10d | 2004-09-22 | 2004-10-05 | 854, 485, 479 |  |  | 2004-06-29 | 2004-07-12 | 10d | -42d | 0d |  | MS-BOOM |
| 20 | 1.2.3 | **Boom Suite FM 1 Environmental Test Flow Snapshot - UCB** |  | 133d | 2004-04-26 A | 2004-11-02 |  | 48% | 69.46d | 2004-04-01 | 2004-07-30 | 86d | 272d |  |  |  |
| 21 | 1.2.3.1 | STE-U Thermal Vac/Thermal Balance/Bake Out |  | 37d | 2004-04-26 A | 2004-06-16 A | 318SS | 100% |  | 2004-04-01 | 2004-04-20 | 14d |  |  |  |  |
| 22 | 1.2.3.2 | Boom Structure Vibration |  | 4d | 2004-06-23 A | 2004-06-28 A | 260SS | 100% |  | 2004-04-27 | 2004-04-30 | 4d |  |  |  |  |
| 23 | 1.2.3.3 | IDPU Vibration |  | 5d | 2004-10-06 | 2004-10-13 | 223SS |  |  | 2004-05-03 | 2004-05-07 | 5d | 286d | 0d |  |  |
| 24 | 1.2.3.4 | Boom Structure Thermal Vac & Bake Out |  | 15d | 2004-06-29 A | 2004-07-20 | 261SS | 13% | 13d | 2004-05-03 | 2004-05-21 | 15d | 345d |  |  |  |
| 25 | 1.2.3.5 | IDPU Thermal Vac & Bake Out |  | 10d | 2004-10-14 | 2004-10-27 | 224SS |  |  | 2004-05-10 | 2004-05-21 | 10d | 276d |  |  |  |
| 26 | 1.2.3.6 | SWEA/STE Vibration |  | 5d | 2004-10-06 | 2004-10-13 | 384SS |  |  | 2004-06-07 | 2004-06-11 | 5d | 286d | 0d |  |  |
| 27 | 1.2.3.7 | SWEA/STE Thermal Vac/Thermal Balance/Bake Out |  | 14d | 2004-10-14 | 2004-11-02 | 385SS |  |  | 2004-07-13 | 2004-07-30 | 14d | 272d |  |  |  |

Notes:
- 1: This is the new IMPACT Consolidated Schedule. Creation began in October 2003 and was then put on hold and subsequently completed in January 2004. Completed tasks, redundant milestones, contingency blocks and obsolete tasks were deleted from this schedule. / Schedule was baselined on 2/18/04 with status through January 31, 2004.
- 7: The SEPT (FM 1) and SIT (FM 1 & 2) instruments are being delivered directly to APL after their environmental testing at GSFC and seperate from the other SEP Suite instruments (SEP Central, LET and HET).
- 8: The SEPT (FM 1) and SIT (FM 1 & 2) instruments are being delivered directly to APL after their environmental testing at GSFC and seperate from the other SEP Suite instruments (SEP Central, LET and HET).
- 11: This is the initial IMPACT PER. Additional TRR's (Test Readiness Reviews) will be scheduled and held as the suite instruments become ready for their environmental testing.
- 20: This section is a "snapshot" of the environmental test flow for the FM 1 Boom Suite. It reflects the details of the testing activities found within the body of the schedule. It was placed in the schedule to allow someone to get a quick look at the test flow and the associated dates. The tasks contained within this section are not tied to any other activities (and do not drive any other activities) and so therefore you will see large float values associated with them. It is simply a quick look at the test flow so that one does not have to filter through the schedule to locate the environmental test activities.

| ID | WBS | Task | Duration | Start | Finish | Predecessors | Complete | Remaining | Baseline start | Baseline finish | Baseline duration | Total slack | Free slack | Calendar |
| --- | --- | --- | --- | --- | --- | --- | --- | --- | --- | --- | --- | --- | --- | --- |
| 28 | 1.2.4 | **Boom Suite FM 2 Environmental Test Flow Snapshot - UCB** | 78d | 2004-08-02 | 2004-11-22 |  |  |  | 2004-04-27 | 2004-09-14 | 99d | 259d |  |  |
| 29 | 1.2.4.1 | STE-U Thermal Vac/Bake Out | 10d | 2004-08-02 | 2004-08-13 | 326SS |  |  | 2004-04-27 | 2004-05-10 | 10d | 327d |  |  |
| 30 | 1.2.4.2 | IDPU Vibration | 5d | 2004-09-16 | 2004-09-22 | 227SS |  |  | 2004-05-10 | 2004-05-14 | 5d | 300d |  |  |
| 31 | 1.2.4.3 | Boom Structure Vibration | 4d | 2004-08-20 | 2004-08-25 | 281SS |  |  | 2004-05-17 | 2004-05-20 | 4d | 319d |  |  |
| 32 | 1.2.4.4 | IDPU Thermal Vac & Bake Out | 10d | 2004-09-23 | 2004-10-06 | 228SS |  |  | 2004-05-17 | 2004-05-28 | 10d | 290d |  |  |
| 33 | 1.2.4.5 | Boom Structure Thermal Vac & Bake Out | 15d | 2004-08-26 | 2004-09-16 | 282SS |  |  | 2004-05-24 | 2004-06-14 | 15d | 304d |  |  |
| 34 | 1.2.4.6 | SWEA/STE Vibration | 5d | 2004-10-15 | 2004-10-21 | 392SS |  |  | 2004-08-09 | 2004-08-13 | 5d | 280d |  |  |
| 35 | 1.2.4.7 | SWEA/STE Thermal Vac & Bake Out | 10d | 2004-10-22 | 2004-11-04 | 393SS |  |  | 2004-08-16 | 2004-08-27 | 10d | 270d |  |  |
| 36 | 1.2.4.8 | Boom Suite FM 2 EMC | 5d | 2004-11-16 | 2004-11-22 | 404SS |  |  | 2004-09-08 | 2004-09-14 | 5d | 259d |  |  |
| 37 | 1.2.5 | **SEP Suite FM 1 Environmental Test Flow Snapshot** | 197d | 2004-02-19 A | 2004-11-29 |  | 19% | 160.2d | 2004-02-17 | 2004-09-14 | 149d | 255d |  |  |
| 38 | 1.2.5.1 | SEPT (NS & E) Vibration (in Europe) | 4d | 2004-02-19 A | 2004-02-24 A | 632SS | 100% |  | 2004-02-17 | 2004-02-24 | 8d |  |  |  |
| 39 | 1.2.5.2 | SEPT (NS & E) Thermal Vac (in Europe) | 11d | 2004-02-27 A | 2004-03-12 A | 633SS, 649SS | 100% |  | 2004-02-25 | 2004-03-08 | 9d |  |  |  |
| 40 | 1.2.5.3 | SEPT (NS & E) Bake Out (in Europe) | 2d | 2004-03-05 A | 2004-03-08 A | 634SS, 650SS | 100% |  | 2004-03-09 | 2004-03-10 | 2d |  |  |  |
| 41 | 1.2.5.4 | SEPT (NS & E) Thermal Balance (at GSFC) | 10d | 2004-10-13 | 2004-10-26 | 642SS, 658SS |  |  | 2004-07-13 | 2004-07-26 | 10d | 277d |  |  |
| 42 | 1.2.5.5 | LET/HET/SEP Cen Accelerator Test (at MSU) | 3d | 2004-07-10 | 2004-07-12 | 886SS |  |  | 2004-07-13 | 2004-07-27 | 11d | 355d |  | Weekend |
| 43 | 1.2.5.6 | SIT Vibe and Acoustics (at GSFC) | 10d | 2004-10-12 | 2004-10-25 | 808SS |  |  | 2004-07-15 | 2004-07-28 | 10d | 278d | 0d |  |
| 44 | 1.2.5.7 | LET/HET/SEP Cen Vibe and Acoustics (at JPL) | 10d | 2004-10-12 | 2004-10-25 | 869SS |  |  | 2004-07-23 | 2004-08-05 | 10d | 278d |  |  |
| 45 | 1.2.5.8 | SIT Thermal Balance (at GSFC) | 5d | 2004-10-27 | 2004-11-02 | 810SS |  |  | 2004-07-30 | 2004-08-05 | 5d | 272d |  |  |
| 46 | 1.2.5.9 | LET/HET/SEP Cen Thermal Balance (at JPL) | 5d | 2004-10-26 | 2004-11-01 | 870SS |  |  | 2004-08-06 | 2004-08-12 | 5d | 273d |  |  |
| 47 | 1.2.5.10 | SIT Thermal Vac (at GSFC) | 10d | 2004-11-03 | 2004-11-17 | 811SS |  |  | 2004-08-06 | 2004-08-19 | 10d | 262d |  |  |
| 48 | 1.2.5.11 | LET/HET/SEP Cen Thermal Vac (at JPL) | 15d | 2004-11-02 | 2004-11-23 | 871SS |  |  | 2004-08-19 | 2004-09-09 | 15d | 258d |  |  |
| 49 | 1.2.5.12 | SIT Bake Out (at GSFC) | 3d | 2004-11-22 | 2004-11-24 | 813SS |  |  | 2004-08-24 | 2004-08-26 | 3d | 257d |  |  |
| 50 | 1.2.5.13 | LET/HET/SEP Cen Bake Out (at JPL) | 3d | 2004-11-24 | 2004-11-29 | 874SS |  |  | 2004-09-10 | 2004-09-14 | 3d | 255d |  |  |
| 51 | 1.2.6 | **SEP Suite FM 2 Environmental Test Flow Snapshot** | 214d | 2004-02-19 A | 2004-12-22 |  | 20% | 170.62d | 2004-02-17 | 2004-10-05 | 164d | 238d |  |  |
| 52 | 1.2.6.1 | SEPT (NS & E) Vibe and Acoustics (in Europe) | 4d | 2004-02-19 A | 2004-02-24 A | 665SS | 100% |  | 2004-02-17 | 2004-02-24 | 8d |  |  |  |
| 53 | 1.2.6.2 | SEPT (NS & E) Thermal Vac (in Europe) | 9d | 2004-03-05 A | 2004-03-17 A | 666SS, 682SS | 100% |  | 2004-03-09 | 2004-03-17 | 9d |  |  |  |
| 54 | 1.2.6.3 | SEPT (NS & E) Bake Out (in Europe) | 2d | 2004-03-12 A | 2004-03-15 A | 667SS, 683SS | 100% |  | 2004-03-18 | 2004-03-19 | 2d |  |  |  |
| 55 | 1.2.6.4 | LET/HET/SEP Cen Accelerator Test (at MSU) | 3d | 2004-07-10 | 2004-07-12 | 887SS |  |  | 2004-07-13 | 2004-07-27 | 11d | 355d |  | Weekend |
| 56 | 1.2.6.5 | LET/HET/SEP Cen Vibe and Acoustics (at JPL) | 10d | 2004-10-12 | 2004-10-25 | 876SS |  |  | 2004-07-23 | 2004-08-05 | 10d | 278d |  |  |
| 57 | 1.2.6.6 | SEP Suite FM 2 EMC (at Caltech) | 5d | 2004-12-16 | 2004-12-22 | 883SS |  |  | 2004-08-12 | 2004-08-18 | 5d | 238d |  |  |
| 58 | 1.2.6.7 | LET/HET/SEP Cen Thermal Vac (at JPL) | 15d | 2004-10-26 | 2004-11-16 | 877SS |  |  | 2004-08-19 | 2004-09-09 | 15d | 263d |  |  |
| 59 | 1.2.6.8 | SIT Vibe and Acoustics (at GSFC) | 10d | 2004-11-01 | 2004-11-15 | 817SS |  |  | 2004-08-23 | 2004-09-03 | 10d | 264d |  |  |
| 60 | 1.2.6.9 | LET/HET/SEP Cen Bake Out (at JPL) | 3d | 2004-11-17 | 2004-11-19 | 880SS |  |  | 2004-09-10 | 2004-09-14 | 3d | 260d |  |  |
| 61 | 1.2.6.10 | SIT Thermal Vac (at GSFC) | 10d | 2004-11-17 | 2004-12-01 | 819SS |  |  | 2004-09-15 | 2004-09-28 | 10d | 253d |  |  |
| 62 | 1.2.6.11 | SIT Bake Out (at GSFC) | 3d | 2004-12-06 | 2004-12-08 | 821SS |  |  | 2004-10-01 | 2004-10-05 | 3d | 248d |  |  |

Notes:
- 28: This section is a "snapshot" of the environmental test flow for the FM 2 Boom Suite. It reflects the details of the testing activities found within the body of the schedule. It was placed in the schedule to allow someone to get a quick look at the test flow and the associated dates. The tasks contained within this section are not tied to any other activities (and do not drive any other activities) and so therefore you will see large float values associated with them. It is simply a quick look at the test flow so that one does not have to filter through the schedule to locate the environmental test activities.
- 37: This section is a "snapshot" of the environmental test flow for the FM 1 SEP Suite. It reflects the details of the testing activities found within the body of the schedule. It was placed in the schedule to allow someone to get a quick look at the test flow and the associated dates. The tasks contained within this section are not tied to any other activities (and do not drive any other activities) and so therefore you will see large float values associated with them. It is simply a quick look at the test flow so that one does not have to filter through the schedule to locate the environmental test activities.
- 38: There was a failure on the SEPT door during Vibration Test. Vibration Test will be repeated once the fix to the door is implemented. Time and place is TBD.
- 51: This section is a "snapshot" of the environmental test flow for the FM 2 SEP Suite. It reflects the details of the testing activities found within the body of the schedule. It was placed in the schedule to allow someone to get a quick look at the test flow and the associated dates. The tasks contained within this section are not tied to any other activities (and do not drive any other activities) and so therefore you will see large float values associated with them. It is simply a quick look at the test flow so that one does not have to filter through the schedule to locate the environmental test activities.
- 52: There was a failure on the SEPT door during Vibration Test. Vibration Test will be repeated once the fix to the door is implemented. Time and place is TBD.

| ID | WBS | Task | Type | Duration | Start | Finish | Predecessors | Complete | Remaining | Baseline start | Baseline finish | Baseline duration | Total slack | Free slack | Constraint | Text1 |
| --- | --- | --- | --- | --- | --- | --- | --- | --- | --- | --- | --- | --- | --- | --- | --- | --- |
| 63 | 1.3 | **Power Converters - UCB** |  | 389.5d | 2003-02-26 A | 2004-09-10 |  | 82% | 70.17d | 2003-02-26 | 2004-06-23 | 335d | 2.5d |  |  |  |
| 64 | 1.3.1 | **Deliveries** |  | 180d | 2003-12-09 A | 2004-08-24 |  | 60% | 72d | 2003-12-09 | 2004-04-30 | 100d | -1d | 0d |  |  |
| 65 | 1.3.1.1 | **FM 1** |  | 158d | 2003-12-09 A | 2004-07-23 |  | 99% | 0d | 2003-12-09 | 2004-04-23 | 95d | -15d | 0d |  |  |
| 66 | 1.3.1.1.1 | Deliver IDPU FM 1 LVPS (stays at UCB) | milestone | 0d | 2004-07-20 | 2004-07-20 | 120 |  |  | 2004-04-23 | 2004-04-23 | 0d | -12d | 0d |  | MS-BOOM |
| 67 | 1.3.1.1.2 | Deliver SEP FM 1 LVPS (to Caltech) |  | 1d | 2004-06-01 A | 2004-06-01 A | 124 | 100% |  | 2004-04-06 | 2004-04-06 | 1d |  |  |  | MS-SEP |
| 68 | 1.3.1.1.3 | Deliver SWEA/STE FM 1 LVPS (stays at UCB) | milestone | 0d | 2004-07-23 | 2004-07-23 | 128 |  |  | 2004-04-15 | 2004-04-15 | 0d | -42d | 0d |  | MS-BOOM |
| 69 | 1.3.1.1.4 | Deliver PLASTIC FM 1 LVPS (to UNH) |  | 2d | 2004-05-24 A | 2004-05-25 A | 132 | 100% |  | 2004-03-24 | 2004-03-25 | 2d |  |  | finish no later than 2004-06-10 |  |
| 70 | 1.3.1.1.5 | Deliver SIT FM 1 HVPS (to UMD) |  | 2d | 2003-12-09 A | 2003-12-10 A | 134 | 100% |  | 2003-12-09 | 2003-12-10 | 2d |  |  |  |  |
| 71 | 1.3.1.2 | **FM 2** |  | 40d | 2004-06-29 A | 2004-08-24 |  | 20% | 32d | 2004-04-12 | 2004-04-30 | 15d | -1d | 0d |  |  |
| 72 | 1.3.1.2.1 | Deliver IDPU FM 2 LVPS (stays at UCB) | milestone | 0d | 2004-08-24 | 2004-08-24 | 139 |  |  | 2004-04-30 | 2004-04-30 | 0d | -1d | 0d |  | MS-BOOM |
| 73 | 1.3.1.2.2 | Deliver SEP FM 2 LVPS (to Caltech) |  | 1d | 2004-06-29 A | 2004-06-29 A | 141 | 100% |  | 2004-04-19 | 2004-04-19 | 1d |  |  |  | MS-SEP |
| 74 | 1.3.1.2.3 | Deliver SWEA/STE FM 2 LVPS (stays at UCB) | milestone | 0d | 2004-08-24 | 2004-08-24 | 148 |  |  | 2004-04-26 | 2004-04-26 | 0d | -22d | 0d |  | MS-BOOM |
| 75 | 1.3.1.2.4 | Deliver PLASTIC FM 2 LVPS (to UNH) |  | 2d | 2004-07-27 | 2004-07-28 | 152 |  |  | 2004-04-12 | 2004-04-13 | 2d | 16d |  | finish no later than 2004-08-19 |  |
| 76 | 1.3.1.2.5 | Deliver SIT FM 2 HVPS (to UMD) |  | 2d | 2004-08-17 | 2004-08-18 | 156 |  |  | 2004-04-12 | 2004-04-13 | 2d | -36d | 0d |  | MS-SEP |
| 77 | 1.3.2 | **Remaining Flight Procurements** |  | 95d | 2003-10-24 A | 2004-03-12 A |  | 100% |  | 2003-10-24 | 2004-02-19 | 79d |  |  |  |  |
| 78 | 1.3.2.1 | Procure IDPU Flight Printed Wiring Board |  | 10d | 2004-03-01 A | 2004-03-12 A | 84 | 100% |  | 2004-02-05 | 2004-02-19 | 10d |  |  | start no earlier than 2004-03-01 |  |
| 79 | 1.3.2.2 | Procure SEP Flight Printed Wiring Board |  | 10d | 2003-11-24 A | 2003-12-08 A | 85 | 100% |  | 2003-11-24 | 2003-12-08 | 10d |  |  | start no earlier than 2003-11-24 |  |
| 80 | 1.3.2.3 | Procure SWEA Flight Printed Wiring Board |  | 10d | 2003-12-04 A | 2003-12-17 A | 86 | 100% |  | 2003-12-04 | 2003-12-17 | 10d |  |  |  |  |
| 81 | 1.3.2.4 | Procure PLASTIC Flight Printed Wiring Board |  | 10d | 2003-10-24 A | 2003-11-06 A |  | 100% |  | 2003-10-24 | 2003-11-06 | 10d |  |  | start no earlier than 2003-10-24 |  |
| 82 | 1.3.3 | **Fabrication** |  | 239d | 2003-02-26 A | 2004-02-06 A |  | 100% |  | 2003-02-26 | 2004-02-06 | 239d |  |  |  |  |
| 83 | 1.3.3.1 | **FM 1 & FM 2** |  | 195d | 2003-02-26 A | 2003-12-03 A |  | 100% |  | 2003-02-26 | 2003-12-03 | 195d |  |  |  |  |
| 84 | 1.3.3.1.1 | Re-layout IDPU LVPS Flight Printed Wiring Board |  | 186d | 2003-02-26 A | 2003-11-19 A |  | 100% |  | 2003-02-26 | 2003-11-19 | 186d |  |  | start no earlier than 2003-02-26 |  |
| 85 | 1.3.3.1.2 | Re-layout SEP LVPS Flight Printed Wiring Board |  | 32d | 2003-09-24 A | 2003-11-07 A |  | 100% |  | 2003-09-24 | 2003-11-07 | 32d |  |  | start no earlier than 2003-09-24 |  |
| 86 | 1.3.3.1.3 | Re-layout SWEA LVPS Flight Printed Wiring Board |  | 5d | 2003-11-26 A | 2003-12-03 A |  | 100% |  | 2003-11-26 | 2003-12-03 | 5d |  |  | start no earlier than 2003-11-26 |  |

| ID | WBS | Task | Duration | Start | Finish | Predecessors | Complete | Remaining | Baseline start | Baseline finish | Baseline duration | Total slack | Free slack | Constraint |
| --- | --- | --- | --- | --- | --- | --- | --- | --- | --- | --- | --- | --- | --- | --- |
| 87 | 1.3.3.2 | **FM 1** | 45d | 2003-09-29 A | 2003-12-03 A |  | 100% |  | 2003-09-29 | 2003-12-03 | 45d |  |  |  |
| 88 | 1.3.3.2.1 | Wind IDPU LVPS FM 1 Magnets | 10d | 2003-10-17 A | 2003-10-30 A |  | 100% |  | 2003-10-17 | 2003-10-30 | 10d |  |  | start no earlier than 2003-10-17 |
| 89 | 1.3.3.2.2 | Wind SEP LVPS FM 1 Magnets | 15d | 2003-09-29 A | 2003-10-20 A |  | 100% |  | 2003-09-29 | 2003-10-20 | 15d |  |  | start no earlier than 2003-09-29 |
| 90 | 1.3.3.2.3 | Wind SWEA LVPS FM 1 Magnets | 5d | 2003-11-26 A | 2003-12-03 A |  | 100% |  | 2003-11-26 | 2003-12-03 | 5d |  |  | start no earlier than 2003-11-26 |
| 91 | 1.3.3.2.4 | Wind PLASTIC LVPS FM 1 Magnets | 45d | 2003-09-29 A | 2003-12-03 A |  | 100% |  | 2003-09-29 | 2003-12-03 | 45d |  |  | start no earlier than 2003-09-29 |
| 92 | 1.3.3.3 | **FM 2** | 28d | 2003-12-29 A | 2004-02-06 A |  | 100% |  | 2003-12-29 | 2004-02-06 | 28d |  |  |  |
| 93 | 1.3.3.3.1 | Wind HVPS FM 2 Magnets | 28d | 2003-12-29 A | 2004-02-06 A |  | 100% |  | 2003-12-29 | 2004-02-06 | 28d |  |  | start no earlier than 2003-12-29 |
| 94 | 1.3.3.3.2 | Wind IDPU LVPS FM 2 Magnets | 28d | 2003-12-29 A | 2004-02-06 A | 93SS | 100% |  | 2003-12-29 | 2004-02-06 | 28d |  |  |  |
| 95 | 1.3.3.3.3 | Wind SEP LVPS FM 2 Magnets | 28d | 2003-12-29 A | 2004-02-06 A | 93SS | 100% |  | 2003-12-29 | 2004-02-06 | 28d |  |  |  |
| 96 | 1.3.3.3.4 | Wind SWEA LVPS FM 2 Magnets | 28d | 2003-12-29 A | 2004-02-06 A | 93SS | 100% |  | 2003-12-29 | 2004-02-06 | 28d |  |  |  |
| 97 | 1.3.3.3.5 | Wind PLASTIC LVPS FM 2 Magnets | 28d | 2003-12-29 A | 2004-02-06 A | 93SS | 100% |  | 2003-12-29 | 2004-02-06 | 28d |  |  |  |
| 98 | 1.3.4 | **Assembly** | 142d | 2003-12-29 A | 2004-07-20 |  | 88% | 17d | 2003-12-29 | 2004-03-19 | 57d | 39d |  |  |
| 99 | 1.3.4.1 | **FM 1** | 84d | 2003-12-29 A | 2004-04-27 A |  | 100% |  | 2003-12-29 | 2004-03-12 | 52d |  |  |  |
| 100 | 1.3.4.1.1 | Assemble IDPU FM 1 LVPS | 17d | 2004-04-05 A | 2004-04-27 A | 88, 112FS+2d | 100% |  | 2004-02-26 | 2004-03-12 | 12d |  |  |  |
| 101 | 1.3.4.1.2 | Assemble SEP FM 1 LVPS | 40d | 2004-01-12 A | 2004-03-09 A | 113, 89 | 100% |  | 2004-01-12 | 2004-02-23 | 29d |  |  | start no earlier than 2004-01-12 |
| 102 | 1.3.4.1.3 | Assemble SWEA FM 1 LVPS | 30d | 2004-02-13 A | 2004-03-26 A | 90, 114 | 100% |  | 2004-02-13 | 2004-03-04 | 14d |  |  | start no earlier than 2004-02-13 |
| 103 | 1.3.4.1.4 | Assemble PLASTIC FM 1 LVPS | 29d | 2003-12-29 A | 2004-02-09 A | 115, 91 | 100% |  | 2003-12-29 | 2004-02-09 | 29d |  |  | start no earlier than 2003-12-29 |
| 104 | 1.3.4.2 | **FM 2** | 80d | 2004-03-29 A | 2004-07-20 |  | 80% | 16.19d | 2004-02-09 | 2004-03-19 | 29d | 39d |  |  |
| 105 | 1.3.4.2.1 | Assemble IDPU FM 2 LVPS | 10d | 2004-06-28 A | 2004-07-12 | 94, 118FS-25d | 30% | 7d | 2004-03-01 | 2004-03-19 | 15d | 5d |  | start no earlier than 2004-03-01 |
| 106 | 1.3.4.2.2 | Assemble SEP FM 2 LVPS | 20d | 2004-05-24 A | 2004-06-21 A | 95, 122FS+5d | 100% |  | 2004-02-13 | 2004-03-05 | 15d |  |  | start no earlier than 2004-02-13 |
| 107 | 1.3.4.2.3 | Assemble SWEA FM 2 LVPS | 14d | 2004-06-22 A | 2004-07-20 | 96, 126 | 50% | 7d | 2004-02-24 | 2004-03-15 | 15d | -22d | 0d | start no earlier than 2004-02-24 |
| 108 | 1.3.4.2.4 | Assemble PLASTIC FM 2 LVPS | 50d | 2004-05-10 A | 2004-07-20 | 97, 130 | 74% | 13d | 2004-02-09 | 2004-02-27 | 14d | 39d | 0d | start no earlier than 2004-02-09 |
| 109 | 1.3.4.2.5 | Assemble SIT FM 2 HVPS | 74d | 2004-03-29 A | 2004-07-12 | 93, 102 | 91% | 7d | 2004-02-09 | 2004-02-27 | 14d | -36d | 0d |  |
| 110 | 1.3.5 | **Testing** | 205d | 2003-10-31 A | 2004-08-24 |  | 69% | 63.44d | 2003-10-31 | 2004-06-23 | 162d | 4d |  |  |
| 111 | 1.3.5.1 | **FM 1 & FM 2** | 88d | 2003-11-24 A | 2004-03-31 A |  | 100% |  | 2003-11-24 | 2004-02-25 | 63d |  |  |  |
| 112 | 1.3.5.1.1 | Coupon Test IDPU Flight Printed Wiring Board | 4d | 2004-03-26 A | 2004-03-31 A | 78FS+9d | 100% |  | 2004-02-20 | 2004-02-25 | 4d |  |  |  |
| 113 | 1.3.5.1.2 | Coupon Test SEP Flight Printed Wiring Board | 5d | 2003-12-09 A | 2003-12-15 A | 79 | 100% |  | 2003-12-09 | 2003-12-15 | 5d |  |  |  |
| 114 | 1.3.5.1.3 | Coupon Test SWEA Flight Printed Wiring Board | 6d | 2004-01-09 A | 2004-01-16 A | 80 | 100% |  | 2004-01-09 | 2004-01-16 | 6d |  |  | start no earlier than 2004-01-09 |
| 115 | 1.3.5.1.4 | Coupon Test PLASTIC Flight Printed Wiring Board | 5d | 2003-11-24 A | 2003-12-01 A | 81 | 100% |  | 2003-11-24 | 2003-12-01 | 5d |  |  | start no earlier than 2003-11-24 |

Notes:
- 109: Stuck in the technician backlog

| ID | WBS | Task | Type | Duration | Start | Finish | Predecessors | Complete | Remaining | Baseline start | Baseline finish | Baseline duration | Total slack | Free slack | Constraint |
| --- | --- | --- | --- | --- | --- | --- | --- | --- | --- | --- | --- | --- | --- | --- | --- |
| 116 | 1.3.5.2 | **FM 1** |  | 183d | 2003-10-31 A | 2004-07-23 |  | 89% | 19.66d | 2003-10-31 | 2004-06-23 | 162d | -3d | 0d |  |
| 117 | 1.3.5.2.1 | **IDPU** |  | 21d | 2004-06-21 A | 2004-07-20 |  | 38% | 13d | 2004-03-15 | 2004-04-23 | 30d | 0d |  |  |
| 118 | 1.3.5.2.1.1 | Test IDPU FM 1 LVPS |  | 21d | 2004-06-21 A | 2004-07-20 | 100FS+37d | 38% | 13d | 2004-03-15 | 2004-04-02 | 15d | -12d | 0d |  |
| 119 | 1.3.5.2.1.2 | Coat & Stake IDPU LVPS FM 1 Boards | milestone | 0d | 2004-07-20 | 2004-07-20 | 118 |  |  | 2004-04-05 | 2004-04-09 | 5d | -12d | 0d |  |
| 120 | 1.3.5.2.1.3 | Retest IDPU LVPS FM 1 Boards | milestone | 0d | 2004-07-20 | 2004-07-20 | 119 |  |  | 2004-04-12 | 2004-04-23 | 10d | -12d | 0d |  |
| 121 | 1.3.5.2.2 | **SEP** |  | 58d | 2004-03-10 A | 2004-05-28 A |  | 100% |  | 2004-02-24 | 2004-04-05 | 30d |  |  |  |
| 122 | 1.3.5.2.2.1 | Test SEP FM 1 LVPS |  | 48d | 2004-03-10 A | 2004-05-14 A | 101 | 100% |  | 2004-02-24 | 2004-03-15 | 15d |  |  |  |
| 123 | 1.3.5.2.2.2 | Coat & Stake SEP LVPS FM 1 Boards |  | 5d | 2004-05-17 A | 2004-05-21 A | 122 | 100% |  | 2004-03-16 | 2004-03-22 | 5d |  |  |  |
| 124 | 1.3.5.2.2.3 | Retest SEP LVPS FM 1 Boards |  | 5d | 2004-05-24 A | 2004-05-28 A | 123, 417 | 100% |  | 2004-03-23 | 2004-04-05 | 10d |  |  |  |
| 125 | 1.3.5.2.3 | **SWEA** |  | 93d | 2004-03-15 A | 2004-07-23 |  | 83% | 16d | 2004-03-05 | 2004-04-15 | 30d | -10d | 0d |  |
| 126 | 1.3.5.2.3.1 | Test SWEA FM 1 LVPS |  | 83d | 2004-03-15 A | 2004-07-09 | 102 | 93% | 6d | 2004-03-05 | 2004-03-25 | 15d | -42d | 0d |  |
| 127 | 1.3.5.2.3.2 | Coat & Stake SWEA LVPS FM 1 Boards |  | 5d | 2004-07-12 | 2004-07-16 | 126 |  |  | 2004-03-26 | 2004-04-01 | 5d | -42d | 0d |  |
| 128 | 1.3.5.2.3.3 | Retest SWEA LVPS FM 1 Boards |  | 5d | 2004-07-19 | 2004-07-23 | 127 |  |  | 2004-04-02 | 2004-04-15 | 10d | -42d | 0d |  |
| 129 | 1.3.5.2.4 | **PLASTIC** |  | 73d | 2004-02-10 A | 2004-05-21 A |  | 100% |  | 2004-02-10 | 2004-03-23 | 30d |  |  |  |
| 130 | 1.3.5.2.4.1 | Test PLASTIC FM 1 LVPS |  | 63d | 2004-02-10 A | 2004-05-07 A | 103 | 100% |  | 2004-02-10 | 2004-03-02 | 15d |  |  |  |
| 131 | 1.3.5.2.4.2 | Coat & Stake PLASTIC LVPS FM 1 Boards |  | 5d | 2004-05-10 A | 2004-05-14 A | 130 | 100% |  | 2004-03-03 | 2004-03-09 | 5d |  |  |  |
| 132 | 1.3.5.2.4.3 | Retest PLASTIC LVPS FM 1 Boards |  | 5d | 2004-05-17 A | 2004-05-21 A | 131 | 100% |  | 2004-03-10 | 2004-03-23 | 10d |  |  |  |
| 133 | 1.3.5.2.5 | **SIT** |  | 25d | 2003-10-31 A | 2003-12-08 A |  | 100% |  | 2003-10-31 | 2004-06-23 | 162d |  |  |  |
| 134 | 1.3.5.2.5.1 | Test SIT FM 1 HVPS |  | 25d | 2003-10-31 A | 2003-12-08 A |  | 100% |  | 2003-10-31 | 2003-12-08 | 25d |  |  | start no earlier than 2003-10-31 |
| 135 | 1.3.5.3 | **FM 2** |  | 61d | 2004-05-28 A | 2004-08-24 |  | 27% | 44.79d | 2004-03-01 | 2004-04-30 | 45d | 4d |  |  |
| 136 | 1.3.5.3.1 | **IDPU** |  | 25d | 2004-07-21 | 2004-08-24 |  |  |  | 2004-03-22 | 2004-04-30 | 30d | -1d | 0d |  |
| 137 | 1.3.5.3.1.1 | Test IDPU FM 2 LVPS |  | 15d | 2004-07-21 | 2004-08-10 | 105, 118 |  |  | 2004-03-22 | 2004-04-09 | 15d | -1d | 0d |  |
| 138 | 1.3.5.3.1.2 | Coat & Stake IDPU LVPS FM 2 Boards |  | 5d | 2004-08-11 | 2004-08-17 | 137 |  |  | 2004-04-12 | 2004-04-16 | 5d | -1d | 0d |  |
| 139 | 1.3.5.3.1.3 | Retest IDPU LVPS FM 2 Boards |  | 5d | 2004-08-18 | 2004-08-24 | 138 |  |  | 2004-04-19 | 2004-04-30 | 10d | -1d | 0d |  |

| ID | WBS | Task | Type | Duration | Start | Finish | Predecessors | Complete | Remaining | Baseline start | Baseline finish | Baseline duration | Total slack | Free slack | Constraint |
| --- | --- | --- | --- | --- | --- | --- | --- | --- | --- | --- | --- | --- | --- | --- | --- |
| 140 | 1.3.5.3.2 | **SEP** |  | 44d | 2004-06-08 A | 2004-08-09 |  | 54% | 20.43d | 2004-03-08 | 2004-04-16 | 30d | 15d |  |  |
| 141 | 1.3.5.3.2.1 | Test SEP FM 2 LVPS |  | 15d | 2004-06-08 A | 2004-06-28 A | 106FS-10d | 100% |  | 2004-03-08 | 2004-03-26 | 15d |  |  |  |
| 142 | 1.3.5.3.2.2 | Coat & Stake SEP LVPS FM 2 Boards |  | 5d | 2004-07-22 | 2004-07-28 | 141, 893 |  |  | 2004-03-29 | 2004-04-02 | 5d | 15d | 0d |  |
| 143 | 1.3.5.3.2.3 | Retest SEP LVPS FM 2 Boards |  | 5d | 2004-07-29 | 2004-08-04 | 142, 417 |  |  | 2004-04-05 | 2004-04-16 | 10d | 15d | 0d |  |
| 144 | 1.3.5.3.2.4 | Bakeout SEP LVPS FM 2 Boards |  | 3d | 2004-08-05 | 2004-08-09 | 143 |  |  | 2004-06-22 | 2004-06-24 | 3d | 15d | 0d |  |
| 145 | 1.3.5.3.3 | **SWEA** |  | 25d | 2004-07-21 | 2004-08-24 |  |  |  | 2004-03-16 | 2004-04-26 | 30d | -22d | 0d |  |
| 146 | 1.3.5.3.3.1 | Test SWEA FM 2 LVPS |  | 15d | 2004-07-21 | 2004-08-10 | 107 |  |  | 2004-03-16 | 2004-04-05 | 15d | -22d | 0d |  |
| 147 | 1.3.5.3.3.2 | Coat & Stake SWEA LVPS FM 2 Boards |  | 5d | 2004-08-11 | 2004-08-17 | 146 |  |  | 2004-04-06 | 2004-04-12 | 5d | -22d | 0d |  |
| 148 | 1.3.5.3.3.3 | Retest SWEA LVPS FM 2 Boards |  | 5d | 2004-08-18 | 2004-08-24 | 147 |  |  | 2004-04-13 | 2004-04-26 | 10d | -22d | 0d |  |
| 149 | 1.3.5.3.4 | **PLASTIC** |  | 40d | 2004-05-28 A | 2004-07-26 |  | 57% | 17d | 2004-03-01 | 2004-04-09 | 30d | 16d |  |  |
| 150 | 1.3.5.3.4.1 | Test PLASTIC FM 2 LVPS |  | 30d | 2004-05-28 A | 2004-07-12 | 108FS-36d | 77% | 7d | 2004-03-01 | 2004-03-19 | 15d | 16d | 0d |  |
| 151 | 1.3.5.3.4.2 | Coat & Stake PLASTIC LVPS FM 2 Boards |  | 5d | 2004-07-13 | 2004-07-19 | 150 |  |  | 2004-03-22 | 2004-03-26 | 5d | 16d | 0d |  |
| 152 | 1.3.5.3.4.3 | Retest PLASTIC LVPS FM 2 Boards |  | 5d | 2004-07-20 | 2004-07-26 | 151 |  |  | 2004-03-29 | 2004-04-09 | 10d | 16d | 0d |  |
| 153 | 1.3.5.3.5 | **SIT** |  | 35d | 2004-06-28 | 2004-08-16 |  |  |  | 2004-03-01 | 2004-04-09 | 30d | -36d | 0d |  |
| 154 | 1.3.5.3.5.1 | Test SIT FM 2 HVPS |  | 15d | 2004-06-28 | 2004-08-02 | 109FS-10d |  |  | 2004-03-01 | 2004-03-19 | 15d | -36d | 0d |  |
| 155 | 1.3.5.3.5.2 | Coat & Stake SIT FM 2 HVPS Boards |  | 5d | 2004-08-03 | 2004-08-09 | 154 |  |  | 2004-03-22 | 2004-03-26 | 5d | -36d | 0d |  |
| 156 | 1.3.5.3.5.3 | Retest SIT FM 2 HVPS Boards |  | 5d | 2004-08-10 | 2004-08-16 | 155 |  |  | 2004-03-29 | 2004-04-09 | 10d | -36d | 0d |  |
| 157 | 1.3.6 | **Replacement of LTC1877s** |  | 15.5d | 2004-08-18 | 2004-09-10 |  |  |  | 2004-08-18 | 2004-09-10 | 15.5d | -1.5d | 0d |  |
| 158 | 1.3.6.1 | Receive new parts | milestone | 0d | 2004-08-18 | 2004-08-18 |  |  |  | 2004-08-18 | 2004-08-18 | 0d | -1.5d | 0d | finish no earlier than 2004-08-18 |
| 159 | 1.3.6.2 | **FM 1** |  | 12.5d | 2004-08-19 | 2004-09-07 | 158 |  |  |  |  |  | 2.5d | 2d |  |
| 160 | 1.3.6.2.1 | **IDPU w/ replacement part** |  | 6.5d | 2004-08-20 | 2004-08-30 |  |  |  | 2004-03-15 | 2004-04-23 | 30d | 4d |  |  |
| 161 | 1.3.6.2.1.1 | Replace LTC1877 |  | 0.5d | 2004-08-20 | 2004-08-20 | 185 |  |  |  |  |  | 4d | 0d |  |
| 162 | 1.3.6.2.1.2 | Test IDPU FM 1 LVPS |  | 1d | 2004-08-23 | 2004-08-23 | 161 |  |  | 2004-03-15 | 2004-04-02 | 15d | 7d | 0d |  |
| 163 | 1.3.6.2.1.3 | Coat & Stake IDPU LVPS FM 1 Boards |  | 3d | 2004-08-24 | 2004-08-26 | 162 |  |  | 2004-04-05 | 2004-04-09 | 5d | 7d | 0d |  |
| 164 | 1.3.6.2.1.4 | Retest/Reassenble IDPU LVPS FM 1 Boards |  | 2d | 2004-08-27 | 2004-08-30 | 163 |  |  | 2004-03-23 | 2004-04-05 | 10d | 7d |  |  |

| ID | WBS | Task | Duration | Start | Finish | Predecessors | Baseline start | Baseline finish | Baseline duration | Total slack | Free slack | Constraint |
| --- | --- | --- | --- | --- | --- | --- | --- | --- | --- | --- | --- | --- |
| 165 | 1.3.6.2.2 | **SEP w/ replacement part** | 7.5d | 2004-08-19 | 2004-08-30 |  | 2004-02-24 | 2004-04-05 | 30d | 5d |  |  |
| 166 | 1.3.6.2.2.1 | Receive SEP FM 1 LVPS from CIT | 1d | 2004-08-19 | 2004-08-19 |  |  |  |  | 5d | 1d |  |
| 167 | 1.3.6.2.2.2 | Replace LTC1877 | 0.5d | 2004-08-23 | 2004-08-23 | 166, 161 |  |  |  | 4d | 0d |  |
| 168 | 1.3.6.2.2.3 | Test SEP FM 1 LVPS | 1d | 2004-08-23 | 2004-08-24 | 167 | 2004-02-24 | 2004-03-15 | 15d | 7.5d | 0d |  |
| 169 | 1.3.6.2.2.4 | Coat & Stake SEP LVPS FM 1 Boards | 2d | 2004-08-24 | 2004-08-26 | 168 | 2004-03-16 | 2004-03-22 | 5d | 7.5d | 0d |  |
| 170 | 1.3.6.2.2.5 | Retest/ Reassmeble SEP LVPS FM 1 Boards | 2d | 2004-08-26 | 2004-08-30 | 169 | 2004-03-23 | 2004-04-05 | 10d | 7.5d |  |  |
| 171 | 1.3.6.2.3 | **SWEA w/ replacement part** | 6.5d | 2004-08-23 | 2004-08-31 |  | 2004-03-05 | 2004-04-15 | 30d | 4d |  |  |
| 172 | 1.3.6.2.3.1 | Replace LTC1877 | 0.5d | 2004-08-23 | 2004-08-23 | 167 |  |  |  | 4d | 0d |  |
| 173 | 1.3.6.2.3.2 | Test SWEA FM 1 LVPS | 1d | 2004-08-24 | 2004-08-24 | 172 | 2004-03-05 | 2004-03-25 | 15d | 6d | 0d |  |
| 174 | 1.3.6.2.3.3 | Coat & Stake SWEA LVPS FM 1 Boards | 3d | 2004-08-25 | 2004-08-27 | 173 | 2004-03-26 | 2004-04-01 | 5d | 6d | 0d |  |
| 175 | 1.3.6.2.3.4 | Retest/ Reassmeble SWEA LVPS FM 1 Boards | 2d | 2004-08-30 | 2004-08-31 | 174 | 2004-04-02 | 2004-04-15 | 10d | 6d |  |  |
| 176 | 1.3.6.2.4 | **PLASTIC w/ replacement part** | 6.5d | 2004-08-27 | 2004-09-07 |  | 2004-02-10 | 2004-03-23 | 30d | 0.5d |  |  |
| 177 | 1.3.6.2.4.1 | Receive PLASTIC FM 1 LVPS from UNH | 0.5d | 2004-08-27 | 2004-08-27 |  |  |  |  | 0.5d | 0d | start no earlier than 2004-08-27 |
| 178 | 1.3.6.2.4.2 | Replace LTC1877 | 1d | 2004-08-27 | 2004-08-30 | 177, 172 |  |  |  | 0.5d | 0d |  |
| 179 | 1.3.6.2.4.3 | Test PLASTIC FM 1 LVPS | 1d | 2004-08-30 | 2004-08-31 | 178 | 2004-02-10 | 2004-03-02 | 15d | 2.5d | 0d |  |
| 180 | 1.3.6.2.4.4 | Coat & Stake PLASTIC LVPS FM 1 Boards | 2d | 2004-08-31 | 2004-09-02 | 179 | 2004-03-03 | 2004-03-09 | 5d | 2.5d | 0d |  |
| 181 | 1.3.6.2.4.5 | Retest/ Reassmeble PLASTIC LVPS FM 1 Boards | 2d | 2004-09-02 | 2004-09-07 | 180 | 2004-03-10 | 2004-03-23 | 10d | 2.5d |  |  |
| 182 | 1.3.6.3 | **FM 2** | 14.5d | 2004-08-19 | 2004-09-09 | 158 |  |  |  | -1.5d | 0d |  |
| 183 | 1.3.6.3.1 | **PLASTIC w/ replacement part** | 7d | 2004-08-19 | 2004-08-27 |  | 2004-02-10 | 2004-03-23 | 30d | -1.5d | 0d |  |
| 184 | 1.3.6.3.1.1 | Receive PLASTIC FM 2 LVPS from UNH | 1d | 2004-08-19 | 2004-08-19 |  |  |  |  | -1.5d | 0d |  |
| 185 | 1.3.6.3.1.2 | Replace LTC1877 | 0.5d | 2004-08-20 | 2004-08-20 | 184 |  |  |  | -1.5d | 0d |  |
| 186 | 1.3.6.3.1.3 | Test PLASTIC FM 2 LVPS | 1d | 2004-08-20 | 2004-08-23 | 185 | 2004-02-10 | 2004-03-02 | 15d | -1.5d | 0d |  |
| 187 | 1.3.6.3.1.4 | Final Coat & Stake PLASTIC LVPS FM 2 Boards | 2d | 2004-08-23 | 2004-08-25 | 186 | 2004-03-03 | 2004-03-09 | 5d | -1.5d | 0d |  |
| 188 | 1.3.6.3.1.5 | Retest/ Reassmeble PLASTIC LVPS FM 2 Boards | 2d | 2004-08-25 | 2004-08-27 | 187 | 2004-03-10 | 2004-03-23 | 10d | -1.5d | 0d |  |
| 189 | 1.3.6.3.1.6 | Deliver PLASTIC LVPS FM 2 (to UNH) | 2d | 2004-08-26 | 2004-08-27 | 188 |  |  |  | -1.5d | 0d | finish no later than 2004-08-27 |

| ID | WBS | Task | Type | Duration | Start | Finish | Predecessors | Complete | Remaining | Baseline start | Baseline finish | Baseline duration | Total slack | Free slack | Constraint | Text1 |
| --- | --- | --- | --- | --- | --- | --- | --- | --- | --- | --- | --- | --- | --- | --- | --- | --- |
| 190 | 1.3.6.3.2 | **IDPU w/ replacement part** |  | 6.5d | 2004-08-30 | 2004-09-08 |  |  |  | 2004-03-15 | 2004-04-23 | 30d | 0.5d |  |  |  |
| 191 | 1.3.6.3.2.1 | Replace LTC1877 |  | 0.5d | 2004-08-30 | 2004-08-30 | 178 |  |  |  |  |  | 0.5d | 0d |  |  |
| 192 | 1.3.6.3.2.2 | Test IDPU FM 2 LVPS |  | 1d | 2004-08-31 | 2004-08-31 | 191 |  |  | 2004-03-15 | 2004-04-02 | 15d | 1d | 0d |  |  |
| 193 | 1.3.6.3.2.3 | Final Coat & Stake IDPU LVPS FM 2 Boards |  | 3d | 2004-09-01 | 2004-09-03 | 192 |  |  | 2004-04-05 | 2004-04-09 | 5d | 1d | 0d |  |  |
| 194 | 1.3.6.3.2.4 | Retest/Reassenble IDPU LVPS FM 1 Boards |  | 2d | 2004-09-07 | 2004-09-08 | 193 |  |  | 2004-03-23 | 2004-04-05 | 10d | 1d |  |  |  |
| 195 | 1.3.6.3.3 | **SEP w/ replacement part** |  | 13.5d | 2004-08-19 | 2004-09-08 |  |  |  | 2004-02-24 | 2004-04-05 | 30d | 1.5d |  |  |  |
| 196 | 1.3.6.3.3.1 | Receive SEP FM 2 LVPS from CIT |  | 1d | 2004-08-19 | 2004-08-19 |  |  |  |  |  |  | 7.5d | 7d |  |  |
| 197 | 1.3.6.3.3.2 | Replace LTC1877 |  | 0.5d | 2004-08-31 | 2004-08-31 | 191, 196 |  |  |  |  |  | 0.5d | 0d |  |  |
| 198 | 1.3.6.3.3.3 | Test SEP FM 2 LVPS |  | 1d | 2004-08-31 | 2004-09-01 | 197 |  |  | 2004-02-24 | 2004-03-15 | 15d | 1.5d | 0d |  |  |
| 199 | 1.3.6.3.3.4 | Final Coat & Stake SEP LVPS FM 2 Boards |  | 2d | 2004-09-01 | 2004-09-03 | 198 |  |  | 2004-03-16 | 2004-03-22 | 5d | 1.5d | 0d |  |  |
| 200 | 1.3.6.3.3.5 | Retest/ Reassmeble SEP LVPS FM 2 Boards |  | 2d | 2004-09-03 | 2004-09-08 | 199 |  |  | 2004-03-23 | 2004-04-05 | 10d | 1.5d |  |  |  |
| 201 | 1.3.6.3.4 | **SWEA w/ replacement part** |  | 14.5d | 2004-08-19 | 2004-09-09 |  |  |  | 2004-03-05 | 2004-04-15 | 30d | 0.5d |  |  |  |
| 202 | 1.3.6.3.4.1 | Replace LTC1877 |  | 0.5d | 2004-08-19 | 2004-08-19 |  |  |  |  |  |  | 8.5d | 8d |  |  |
| 203 | 1.3.6.3.4.2 | Test SWEA FM 2 LVPS |  | 1d | 2004-08-31 | 2004-09-01 | 202, 197 |  |  | 2004-03-05 | 2004-03-25 | 15d | 0.5d | 0d |  |  |
| 204 | 1.3.6.3.4.3 | Final Coat & Stake SWEA LVPS FM 2 Boards |  | 3d | 2004-09-01 | 2004-09-07 | 203 |  |  | 2004-03-26 | 2004-04-01 | 5d | 0.5d | 0d |  |  |
| 205 | 1.3.6.3.4.4 | Retest/ Reassmeble SWEA LVPS FM 2 Boards |  | 2d | 2004-09-07 | 2004-09-09 | 204 |  |  | 2004-04-02 | 2004-04-15 | 10d | 0.5d |  |  |  |
| 206 | 1.3.6.4 | Deliver all LVPS w/ Replacement Parts ( to CIT for re-integration before EMC) |  | 1d | 2004-09-09 | 2004-09-10 | 159, 182 |  |  |  |  |  | 0.5d |  | finish no later than 2004-09-10 |  |
| 207 | 1.4 | **IDPU - UCB** |  | 374d | 2003-05-05 A | 2004-10-27 |  | 86% | 52.28d | 2003-05-05 | 2004-09-07 | 340d | -14d | 0d |  |  |
| 208 | 1.4.1 | **Deliveries** |  | 25d | 2004-07-27 | 2004-08-31 |  |  |  | 2004-04-13 | 2004-05-28 | 33d | -12d | 0d |  |  |
| 209 | 1.4.1.1 | IDPU FM 1 Complete (to UCB for Boom I&T, then to CIT for SEP I&T, Suite EMC, BO & Final Boom I&T) | milestone | 0d | 2004-07-27 | 2004-07-27 | 222 |  |  | 2004-05-21 | 2004-05-21 | 0d | -12d | 0d |  | MS-BOOM |
| 210 | 1.4.1.2 | IDPU FM 2 Complete (to CIT for SEP I&T, then to UCB for Boom I&T, Boom EMC, BO & Final Boom I&T) | milestone | 0d | 2004-08-31 | 2004-08-31 | 226 |  |  | 2004-05-28 | 2004-05-28 | 0d | -1d | 0d |  | MS-BOOM |
| 211 | 1.4.2 | **Flight Software** |  | 321d | 2003-05-05 A | 2004-08-11 |  | 92% | 24.5d | 2003-05-05 | 2004-04-13 | 237d | 29d |  |  |  |
| 212 | 1.4.2.1 | IDPU S/W Build #2.5 |  | 131d | 2003-05-05 A | 2003-11-07 A |  | 100% |  | 2003-05-05 | 2003-11-07 | 131d |  |  | start no earlier than 2003-05-05 |  |
| 213 | 1.4.2.2 | IDPU S/W Build #3 (also goes to UNH) |  | 249d | 2003-08-15 A | 2004-08-11 |  | 88% | 29d | 2003-08-15 | 2004-04-13 | 165d | 29d |  | start no earlier than 2003-08-15 | MS-BOOM |

| ID | WBS | Task | Type | Duration | Start | Finish | Predecessors | Complete | Remaining | Baseline start | Baseline finish | Baseline duration | Total slack | Free slack | Constraint | Text1 |
| --- | --- | --- | --- | --- | --- | --- | --- | --- | --- | --- | --- | --- | --- | --- | --- | --- |
| 214 | 1.4.3 | **GSE** |  | 301d | 2003-06-30 A | 2004-09-08 |  | 87% | 37.86d | 2003-06-30 | 2004-09-07 | 301d | 0d |  |  |  |
| 215 | 1.4.3.1 | STE Science Display |  | 27d | 2003-10-23 A | 2003-12-02 A |  | 100% |  | 2003-10-23 | 2003-12-02 | 27d |  |  | start no earlier than 2003-10-23 |  |
| 216 | 1.4.3.2 | SWEA Science Display |  | 167d | 2003-06-30 A | 2004-03-01 A |  | 100% |  | 2003-06-30 | 2004-02-23 | 162d |  |  | start no earlier than 2003-06-30 |  |
| 217 | 1.4.3.3 | GSE Continued Development (LOE) |  | 291d | 2003-07-15 A | 2004-09-08 |  | 79% | 61d | 2003-07-15 | 2004-09-07 | 291d | 0d |  | must start on 2003-07-15 |  |
| 218 | 1.4.4 | **Integration & Test** |  | 266d | 2003-10-07 A | 2004-10-27 |  | 38% | 163.69d | 2003-10-07 | 2004-05-28 | 162d | -14d | 0d |  |  |
| 219 | 1.4.4.1 | IDPU DCB FM 2 Board Level Testing |  | 15d | 2003-10-07 A | 2003-10-28 A |  | 100% |  | 2003-10-07 | 2003-10-28 | 15d |  |  | start no earlier than 2003-10-07 |  |
| 220 | 1.4.4.2 | IDPU DCB Clean/Stake/Coat (FM 1 & FM 2) |  | 10d | 2003-12-26 A | 2004-01-09 A | 219 | 100% |  | 2003-12-26 | 2004-01-09 | 10d |  |  | start no earlier than 2003-12-26 |  |
| 221 | 1.4.4.3 | **FM 1** |  | 69d | 2004-07-21 | 2004-10-27 |  |  |  | 2004-04-26 | 2004-05-21 | 20d | -19d | 0d |  |  |
| 222 | 1.4.4.3.1 | IDPU FM 1 I & T |  | 5d | 2004-07-21 | 2004-07-27 | 212, 66, 285, 329, 220 |  |  | 2004-04-26 | 2004-04-30 | 5d | -12d | 0d |  | MS-BOOM |
| 223 | 1.4.4.3.2 | IDPU FM 1 Vibration |  | 5d | 2004-10-06 | 2004-10-13 | 222, 19 |  |  | 2004-05-03 | 2004-05-07 | 5d | -19d | 0d |  |  |
| 224 | 1.4.4.3.3 | IDPU FM 1 Thermal Vacuum & Bake Out |  | 10d | 2004-10-14 | 2004-10-27 | 223 |  |  | 2004-05-10 | 2004-05-21 | 10d | -19d | 0d |  |  |
| 225 | 1.4.4.4 | **FM 2** |  | 30d | 2004-08-25 | 2004-10-06 |  |  |  | 2004-05-03 | 2004-05-28 | 20d | -1d | 0d |  |  |
| 226 | 1.4.4.4.1 | IDPU FM 2 I & T |  | 5d | 2004-08-25 | 2004-08-31 | 72, 286, 330, 219, 220 |  |  | 2004-05-03 | 2004-05-07 | 5d | -1d | 0d |  |  |
| 227 | 1.4.4.4.2 | IDPU FM 2 Vibration |  | 5d | 2004-09-16 | 2004-09-22 | 863FS+2d |  |  | 2004-05-10 | 2004-05-14 | 5d | 0d |  |  |  |
| 228 | 1.4.4.4.3 | IDPU FM 2 Thermal Vacuum & Bake Out |  | 10d | 2004-09-23 | 2004-10-06 | 227, 213 |  |  | 2004-05-17 | 2004-05-28 | 10d | 0d |  |  |  |
| 229 | 1.5 | **BOOM Suite - UCB** |  | 356d | 2003-07-01 A | 2004-11-30 |  | 91% | 32.11d | 2003-07-01 | 2004-09-28 | 315d | -22d | 0d |  |  |
| 230 | 1.5.1 | **BOOM Structure - UCB** |  | 257d | 2003-09-10 A | 2004-09-16 |  | 94% | 15.08d | 2003-09-10 | 2004-06-18 | 195d | 12d |  |  |  |
| 231 | 1.5.1.1 | **Deliveries** |  | 174d | 2004-01-09 A | 2004-09-16 |  |  | 174d | 2004-01-09 | 2004-06-18 | 112d | 12d |  |  |  |
| 232 | 1.5.1.1.1 | Protoflight Boom available for I&T (if needed) | milestone | 0d | 2004-01-09 A | 2004-01-09 A | 237 | 100% |  | 2004-01-09 | 2004-01-09 | 0d |  |  |  |  |
| 233 | 1.5.1.1.2 | Deliver Boom Structure FM 1 (stays at UCB for Boom Suite FM 1 I&T) | milestone | 0d | 2004-07-20 | 2004-07-20 | 261 |  |  | 2004-05-27 | 2004-05-27 | 0d | -9d | 0d |  | MS-BOOM |
| 234 | 1.5.1.1.3 | Deliver Boom Structure FM 2 (stays at UCB for Boom Suite FM 2 I&T) | milestone | 0d | 2004-09-16 | 2004-09-16 | 282 |  |  | 2004-06-18 | 2004-06-18 | 0d | 12d |  |  | MS-BOOM |
| 235 | 1.5.1.2 | **Protoflight** |  | 79d | 2003-09-16 A | 2004-01-09 A |  | 100% |  | 2003-09-16 | 2004-01-09 | 79d |  |  |  |  |
| 236 | 1.5.1.2.1 | Protoflight Boom Post Environmental Deployment Test |  | 35d | 2003-09-16 A | 2003-11-04 A |  | 100% |  | 2003-09-16 | 2003-11-04 | 35d |  |  | start no earlier than 2003-09-16 |  |
| 237 | 1.5.1.2.2 | Document Protoflight Boom Test Results |  | 44d | 2003-11-05 A | 2004-01-09 A | 236 | 100% |  | 2003-11-05 | 2004-01-09 | 44d |  |  |  |  |

| ID | WBS | Task | Duration | Start | Finish | Predecessors | Complete | Remaining | Baseline start | Baseline finish | Baseline duration | Total slack | Free slack | Constraint | Calendar | Text1 |
| --- | --- | --- | --- | --- | --- | --- | --- | --- | --- | --- | --- | --- | --- | --- | --- | --- |
| 238 | 1.5.1.3 | **Flight Procurements** | 40d | 2003-09-10 A | 2003-11-05 A |  | 100% |  | 2003-09-10 | 2003-11-05 | 40d |  |  |  |  |  |
| 239 | 1.5.1.3.1 | Receive and Inspect Flight Boom Structure Tubes (FM 1) | 32d | 2003-09-10 A | 2003-10-24 A |  | 100% |  | 2003-09-10 | 2003-10-24 | 32d |  |  | start no earlier than 2003-09-10 |  |  |
| 240 | 1.5.1.3.2 | Receive and Inspect Flight Boom Structure Tubes (FM 2) | 40d | 2003-09-10 A | 2003-11-05 A |  | 100% |  | 2003-09-10 | 2003-11-05 | 40d |  |  | start no earlier than 2003-09-10 |  |  |
| 241 | 1.5.1.4 | **FM 1** | 203d | 2003-09-29 A | 2004-07-20 |  | 95% | 9.39d | 2003-09-29 | 2004-05-27 | 167d | 0d |  |  |  |  |
| 242 | 1.5.1.4.1 | **Telescoping** | 84d | 2003-10-27 A | 2004-02-29 A |  | 100% |  | 2003-10-27 | 2004-02-29 | 84d |  |  |  |  |  |
| 243 | 1.5.1.4.1.1 | **Fabrication, Assembly & Test** | 84d | 2003-10-27 A | 2004-02-29 A |  | 100% |  | 2003-10-27 | 2004-02-29 | 84d |  |  |  |  |  |
| 244 | 1.5.1.4.1.1.1 | Machine FM 1 Boom Structure Tubes as necessary | 5d | 2003-10-27 A | 2003-10-31 A | 239 | 100% |  | 2003-10-27 | 2003-10-31 | 5d |  |  |  |  |  |
| 245 | 1.5.1.4.1.1.2 | Machine FM 1 Boom Structure Parts (Rings) | 38d | 2003-11-07 A | 2004-01-05 A | 239FF+47d | 100% |  | 2003-11-07 | 2004-01-05 | 38d |  |  |  |  |  |
| 246 | 1.5.1.4.1.1.3 | Assemble FM 1 Boom Structure Telescoping Assembly | 5d | 2004-02-23 A | 2004-02-27 A | 244, 245 | 100% |  | 2004-02-23 | 2004-02-27 | 5d |  |  | start no earlier than 2004-02-23 |  |  |
| 247 | 1.5.1.4.1.1.4 | Test FM 1 Boom Structure Telescoping Assembly | 2d | 2004-02-28 A | 2004-02-29 A | 246 | 100% |  | 2004-02-28 | 2004-02-29 | 2d |  |  |  | Boom Test Calendar |  |
| 248 | 1.5.1.4.2 | **Harness** | 109d | 2003-09-29 A | 2004-03-08 A |  | 100% |  | 2003-09-29 | 2004-03-08 | 109d |  |  |  |  |  |
| 249 | 1.5.1.4.2.1 | **Fabrication** | 103d | 2003-09-29 A | 2004-02-27 A |  | 100% |  | 2003-09-29 | 2004-02-27 | 103d |  |  |  |  |  |
| 250 | 1.5.1.4.2.1.1 | Machine FM 1 Harness Parts | 103d | 2003-09-29 A | 2004-02-27 A |  | 100% |  | 2003-09-29 | 2004-02-27 | 103d |  |  | start no earlier than 2003-09-29 |  |  |
| 251 | 1.5.1.4.2.2 | **Assembly & Test** | 6d | 2004-03-01 A | 2004-03-08 A |  | 100% |  | 2004-03-01 | 2004-03-08 | 6d |  |  |  |  |  |
| 252 | 1.5.1.4.2.2.1 | Assemble FM 1 Harness subassembly | 7d | 2004-03-01 A | 2004-03-07 A | 250 | 100% |  | 2004-03-01 | 2004-03-07 | 7d |  |  | start no earlier than 2004-03-01 | Boom Test Calendar |  |
| 253 | 1.5.1.4.2.2.2 | FM1 Harness Test | 1d | 2004-03-08 A | 2004-03-08 A | 252 | 100% |  | 2004-03-08 | 2004-03-08 | 1d |  |  |  |  |  |
| 254 | 1.5.1.4.3 | **Mounting** | 38d | 2003-09-29 A | 2003-11-21 A |  | 100% |  | 2003-09-29 | 2003-11-21 | 38d |  |  |  |  |  |
| 255 | 1.5.1.4.3.1 | FM 1Boom Structure Mounting Fabrication | 28d | 2003-09-29 A | 2003-11-06 A |  | 100% |  | 2003-09-29 | 2003-11-06 | 28d |  |  | start no earlier than 2003-09-29 |  |  |
| 256 | 1.5.1.4.3.2 | FM 1Boom Structure Mounting Assembly | 10d | 2003-11-07 A | 2003-11-21 A | 255 | 100% |  | 2003-11-07 | 2003-11-21 | 10d |  |  |  |  |  |
| 257 | 1.5.1.4.4 | **Integration & Test** | 89d | 2004-03-16 A | 2004-07-20 |  | 84% | 14.11d | 2004-03-09 | 2004-05-27 | 58d | 0d |  |  |  |  |
| 258 | 1.5.1.4.4.1 | Integrate FM 1 Boom Structure subassemblies & Harness Completion | 60d | 2004-03-16 A | 2004-06-08 A | 247, 253FS+5d | 100% |  | 2004-03-09 | 2004-04-05 | 20d |  |  |  |  | MS-BOOM |
| 259 | 1.5.1.4.4.2 | FM 1 Boom Structure Deployment Test | 3d | 2004-06-09 A | 2004-06-11 A | 258 | 100% |  | 2004-04-06 | 2004-04-19 | 10d |  |  |  |  | MS-BOOM |
| 260 | 1.5.1.4.4.3 | FM 1 Boom Structure Vibration Test | 4d | 2004-06-23 A | 2004-06-28 A | 259, 396 | 100% |  | 2004-04-27 | 2004-04-30 | 4d |  |  |  |  |  |
| 261 | 1.5.1.4.4.4 | FM 1 Boom Structure Themal Vac & Bake Out | 15d | 2004-06-29 A | 2004-07-20 | 260 | 13% | 13d | 2004-05-03 | 2004-05-21 | 15d | -9d | 0d |  |  |  |

| ID | WBS | Task | Duration | Start | Finish | Predecessors | Complete | Remaining | Baseline start | Baseline finish | Baseline duration | Total slack | Free slack | Text1 |
| --- | --- | --- | --- | --- | --- | --- | --- | --- | --- | --- | --- | --- | --- | --- |
| 262 | 1.5.1.5 | **FM 2** | 244d | 2003-09-29 A | 2004-09-16 |  | 90% | 24.32d | 2003-09-29 | 2004-06-18 | 182d | 12d |  |  |
| 263 | 1.5.1.5.1 | **Telescoping** | 78d | 2003-11-06 A | 2004-03-02 A |  | 100% |  | 2003-11-06 | 2004-03-16 | 88d |  |  |  |
| 264 | 1.5.1.5.1.1 | **Fabrication, Assembly & Test** | 78d | 2003-11-06 A | 2004-03-02 A |  | 100% |  | 2003-11-06 | 2004-03-16 | 88d |  |  |  |
| 265 | 1.5.1.5.1.1.1 | Machine FM 2 Boom Structure Tubes as necessary | 11d | 2003-11-06 A | 2003-11-21 A | 240 | 100% |  | 2003-11-06 | 2003-11-21 | 11d |  |  |  |
| 266 | 1.5.1.5.1.1.2 | Machine FM 2 Boom Structure Parts (Rings) | 38d | 2003-11-07 A | 2004-01-05 A | 245SS | 100% |  | 2003-11-07 | 2004-01-05 | 38d |  |  |  |
| 267 | 1.5.1.5.1.1.3 | Assemble FM 2 Boom Structure Telescoping Assembly | 5d | 2004-02-23 A | 2004-02-27 A | 265, 266, 246SS | 100% |  | 2004-02-23 | 2004-02-27 | 5d |  |  |  |
| 268 | 1.5.1.5.1.1.4 | Test FM 2 Boom Structure Telescoping Assembly | 2d | 2004-03-01 A | 2004-03-02 A | 267 | 100% |  | 2004-03-15 | 2004-03-16 | 2d |  |  |  |
| 269 | 1.5.1.5.2 | **Harness** | 110d | 2003-09-29 A | 2004-03-09 A |  | 100% |  | 2003-09-29 | 2004-03-16 | 115d |  |  |  |
| 270 | 1.5.1.5.2.1 | **Fabrication** | 103d | 2003-09-29 A | 2004-02-27 A |  | 100% |  | 2003-09-29 | 2004-02-27 | 103d |  |  |  |
| 271 | 1.5.1.5.2.1.1 | Machine FM 2 Harness Parts | 103d | 2003-09-29 A | 2004-02-27 A | 250SS | 100% |  | 2003-09-29 | 2004-02-27 | 103d |  |  |  |
| 272 | 1.5.1.5.2.2 | **Assembly & Test** | 7d | 2004-03-01 A | 2004-03-09 A |  | 100% |  | 2004-03-01 | 2004-03-16 | 12d |  |  |  |
| 273 | 1.5.1.5.2.2.1 | Assemble FM 2 Harness subassembly | 6d | 2004-03-01 A | 2004-03-08 A | 271 | 100% |  | 2004-03-01 | 2004-03-15 | 11d |  |  |  |
| 274 | 1.5.1.5.2.2.2 | FM 2 Harness Test | 1d | 2004-03-09 A | 2004-03-09 A | 273 | 100% |  | 2004-03-16 | 2004-03-16 | 1d |  |  |  |
| 275 | 1.5.1.5.3 | **Mounting** | 38d | 2003-09-29 A | 2003-11-21 A |  | 100% |  | 2003-09-29 | 2003-11-21 | 38d |  |  |  |
| 276 | 1.5.1.5.3.1 | FM 2 Boom Structure Mountings Fabrication | 28d | 2003-09-29 A | 2003-11-06 A | 255SS | 100% |  | 2003-09-29 | 2003-11-06 | 28d |  |  |  |
| 277 | 1.5.1.5.3.2 | FM 2 Boom Structure Mountings Assembly | 10d | 2003-11-07 A | 2003-11-21 A | 276 | 100% |  | 2003-11-07 | 2003-11-21 | 10d |  |  |  |
| 278 | 1.5.1.5.4 | **Integration & Test** | 121d | 2004-03-29 A | 2004-09-16 |  | 69% | 37.42d | 2004-03-17 | 2004-06-18 | 67d | 12d |  |  |
| 279 | 1.5.1.5.4.1 | Integrate FM 2 Boom Structure subassemblies & Harness Completion | 75d | 2004-03-29 A | 2004-07-13 | 268, 274, 258SS+10d | 89% | 8d | 2004-03-17 | 2004-04-13 | 20d | 32d | 0d |  |
| 280 | 1.5.1.5.4.2 | FM 2 Boom Structure Deployment Test | 3d | 2004-07-14 | 2004-07-16 | 279 |  |  | 2004-04-14 | 2004-04-27 | 10d | 32d | 20d |  |
| 281 | 1.5.1.5.4.3 | FM 2 Boom Structure Vibration Test | 4d | 2004-08-20 | 2004-08-25 | 280, 401 |  |  | 2004-05-17 | 2004-05-20 | 4d | 12d | 0d |  |
| 282 | 1.5.1.5.4.4 | FM 2 Boom Structure Themal Vac & Bake Out | 15d | 2004-08-26 | 2004-09-16 | 281, 261 |  |  | 2004-05-24 | 2004-06-14 | 15d | 12d | 0d |  |
| 283 | 1.5.2 | **MAG - GSFC** | 63d | 2004-02-20 A | 2004-05-18 A |  | 100% |  | 2004-02-20 | 2004-03-29 | 27d |  |  |  |
| 284 | 1.5.2.1 | **Deliveries** | 15d | 2004-04-28 A | 2004-05-18 A |  | 100% |  | 2004-03-26 | 2004-03-29 | 2d |  |  |  |
| 285 | 1.5.2.1.1 | Deliver MAG FM 1 (to UCB for IDPU/BOOM Suite FM 1 I&T) | 2d | 2004-04-28 A | 2004-04-29 A | 289 | 100% |  | 2004-03-26 | 2004-03-29 | 2d |  |  | MS-BOOM |
| 286 | 1.5.2.1.2 | Deliver MAG FM 2 (to UCB for IDPU/BOOM Suite FM 2 I&T) | 2d | 2004-05-17 A | 2004-05-18 A | 292 | 100% |  | 2004-03-26 | 2004-03-29 | 2d |  |  | MS-BOOM |

| ID | WBS | Task | Type | Duration | Start | Finish | Predecessors | Complete | Remaining | Baseline start | Baseline finish | Baseline duration | Total slack | Free slack | Constraint | Text1 |
| --- | --- | --- | --- | --- | --- | --- | --- | --- | --- | --- | --- | --- | --- | --- | --- | --- |
| 287 | 1.5.2.2 | **FM 1** |  | 48d | 2004-02-20 A | 2004-04-27 A |  | 100% |  | 2004-02-20 | 2004-03-25 | 25d |  |  |  |  |
| 288 | 1.5.2.2.1 | FM 1 MAG Testing |  | 20d | 2004-02-20 A | 2004-03-18 A |  | 100% |  | 2004-02-20 | 2004-03-04 | 10d |  |  | start no earlier than 2004-02-20 |  |
| 289 | 1.5.2.2.2 | MAG FM 1 Calibration |  | 22d | 2004-03-26 A | 2004-04-27 A | 288FS+10d | 100% |  | 2004-03-05 | 2004-03-25 | 15d |  |  |  |  |
| 290 | 1.5.2.3 | **FM 2** |  | 51d | 2004-03-05 A | 2004-05-14 A |  | 100% |  | 2004-02-20 | 2004-03-25 | 25d |  |  |  |  |
| 291 | 1.5.2.3.1 | FM 2 MAG Testing |  | 20d | 2004-03-05 A | 2004-04-01 A | 288FF+10d | 100% |  | 2004-02-20 | 2004-03-04 | 10d |  |  |  |  |
| 292 | 1.5.2.3.2 | MAG FM 2 Calibration |  | 21d | 2004-04-16 A | 2004-05-14 A | 291FS+10d | 100% |  | 2004-03-05 | 2004-03-25 | 15d |  |  |  |  |
| 293 | 1.5.3 | **SWEA - CESR** |  | 126d | 2003-12-08 A | 2004-06-07 A |  | 100% |  | 2003-12-08 | 2004-04-20 | 93d |  |  |  |  |
| 294 | 1.5.3.1 | **Deliveries** |  | 126d | 2003-12-08 A | 2004-06-07 A |  | 100% |  | 2003-12-08 | 2004-04-20 | 93d |  |  |  |  |
| 295 | 1.5.3.1.1 | SWEA FM 1 Delivery to UCB |  | 3d | 2003-12-08 A | 2003-12-10 A |  | 100% |  | 2003-12-08 | 2003-12-10 | 3d |  |  | start no earlier than 2003-12-08 |  |
| 296 | 1.5.3.1.2 | SWEA FM 2 Delivery to UCB |  | 3d | 2004-06-03 A | 2004-06-07 A | 299FS+7d | 100% |  | 2004-04-16 | 2004-04-20 | 3d |  |  |  | MS-BOOM |
| 297 | 1.5.3.2 | **FM 2** |  | 50d | 2004-03-15 A | 2004-05-21 A |  | 100% |  | 2004-02-10 | 2004-04-15 | 47d |  |  |  |  |
| 298 | 1.5.3.2.1 | SWEA FM 2 Final Assembly (Block 2) |  | 5d | 2004-03-15 A | 2004-03-19 A |  | 100% |  | 2004-02-10 | 2004-02-12 | 3d |  |  | start no earlier than 2004-03-15 |  |
| 299 | 1.5.3.2.2 | SWEA FM 2 Calibration |  | 45d | 2004-03-22 A | 2004-05-21 A | 298 | 100% |  | 2004-02-13 | 2004-04-15 | 44d |  |  |  | MS-BOOM |
| 300 | 1.5.4 | **STE - UCB** |  | 241d | 2003-08-29 A | 2004-08-13 |  | 92% | 19.8d | 2003-08-29 | 2004-05-10 | 174d | 12d |  |  |  |
| 301 | 1.5.4.1 | **Deliveries** |  | 43d | 2004-06-14 A | 2004-08-13 |  |  | 43d | 2004-04-14 | 2004-05-10 | 18d | 12d |  |  |  |
| 302 | 1.5.4.1.1 | Deliver STE-D FM 1 (stays at UCB for SWEA/STE-D FM 1 I&T) | milestone | 0d | 2004-06-14 A | 2004-06-14 A | 317 | 100% |  | 2004-04-14 | 2004-04-14 | 0d |  |  |  | MS-BOOM |
| 303 | 1.5.4.1.2 | Deliver STE-D FM 2 (stays at UCB for SWEA/STE-D FM 2 I&T) | milestone | 0d | 2004-08-13 | 2004-08-13 | 325 |  |  | 2004-05-10 | 2004-05-10 | 0d | -5d | 0d |  | MS-BOOM |
| 304 | 1.5.4.1.3 | Deliver STE-U FM 1 (stays at UCB for BOOM Suite FM 1 I&T) | milestone | 0d | 2004-06-16 A | 2004-06-16 A | 318 | 100% |  | 2004-04-20 | 2004-04-20 | 0d |  |  |  | MS-BOOM |
| 305 | 1.5.4.1.4 | Deliver STE-U FM 2 (stays at UCB for BOOM Suite FM 2 I&T) | milestone | 0d | 2004-08-13 | 2004-08-13 | 326 |  |  | 2004-05-10 | 2004-05-10 | 0d | 12d | 0d |  | MS-BOOM |
| 306 | 1.5.4.2 | **STE-U/D Housing** |  | 53d | 2003-11-21 A | 2004-02-09 A |  | 100% |  | 2003-11-21 | 2004-02-09 | 53d |  |  |  |  |
| 307 | 1.5.4.2.1 | Fabricate STE FM 1 Box |  | 53d | 2003-11-21 A | 2004-02-09 A |  | 100% |  | 2003-11-21 | 2004-02-09 | 53d |  |  | start no earlier than 2003-11-21 |  |
| 308 | 1.5.4.2.2 | Fabricate STE FM 2 Box |  | 53d | 2003-11-21 A | 2004-02-09 A |  | 100% |  | 2003-11-21 | 2004-02-09 | 53d |  |  | start no earlier than 2003-11-21 |  |
| 309 | 1.5.4.3 | **STE-U/D Detector Boards** |  | 241d | 2003-08-29 A | 2004-08-13 |  | 90% | 24.42d | 2003-08-29 | 2004-05-10 | 174d | 12d |  |  |  |
| 310 | 1.5.4.3.1 | Coupon Test STE FM 1 & FM 2 Detector Printed Wiring Board |  | 17d | 2003-10-10 A | 2003-11-04 A | 312, 320 | 100% |  | 2003-10-10 | 2003-11-04 | 17d |  |  | start no earlier than 2003-10-10 |  |

| ID | WBS | Task | Type | Duration | Start | Finish | Predecessors | Complete | Remaining | Baseline start | Baseline finish | Baseline duration | Total slack | Free slack | Constraint | Text1 |
| --- | --- | --- | --- | --- | --- | --- | --- | --- | --- | --- | --- | --- | --- | --- | --- | --- |
| 311 | 1.5.4.3.2 | **FM 1** |  | 200d | 2003-08-29 A | 2004-06-16 A |  | 100% |  | 2003-08-29 | 2004-04-20 | 160d |  |  |  |  |
| 312 | 1.5.4.3.2.1 | Fabrication STE FM 1 Detector Printed Wiring Board |  | 29d | 2003-08-29 A | 2003-10-09 A |  | 100% |  | 2003-08-29 | 2003-10-09 | 29d |  |  | start no earlier than 2003-08-29 |  |
| 313 | 1.5.4.3.2.2 | Load STE FM 1 Detector Printed Wiring Board |  | 60d | 2003-11-05 A | 2004-02-03 A | 310 | 100% |  | 2003-11-05 | 2004-02-03 | 60d |  |  |  |  |
| 314 | 1.5.4.3.2.3 | Test STE FM 1 Detector Printed Wiring Board |  | 10d | 2004-02-04 A | 2004-02-18 A | 313 | 100% |  | 2004-02-04 | 2004-02-18 | 10d |  |  |  |  |
| 315 | 1.5.4.3.2.4 | **Integration & Test** |  | 84d | 2004-02-19 A | 2004-06-16 A |  | 100% |  | 2004-02-19 | 2004-04-20 | 44d |  |  |  |  |
| 316 | 1.5.4.3.2.4.1 | Integrate & Test STE-U/D FM 1 Detectors W/ FM 1 Housings |  | 47d | 2004-02-19 A | 2004-04-23 A | 307, 314 | 100% |  | 2004-02-19 | 2004-03-17 | 20d |  |  |  |  |
| 317 | 1.5.4.3.2.4.2 | Calibrate STE-U/D FM 1 |  | 45d | 2004-04-12 A | 2004-06-14 A | 316FS-10d | 100% |  | 2004-03-18 | 2004-04-14 | 20d |  |  |  |  |
| 318 | 1.5.4.3.2.4.3 | STE-U FM 1 Thermal Vacuum/Balance/Bake Out |  | 31d | 2004-04-26 A | 2004-06-16 A | 317FS-6d | 100% |  | 2004-04-01 | 2004-04-20 | 14d |  |  |  |  |
| 319 | 1.5.4.3.3 | **FM 2** |  | 241d | 2003-08-29 A | 2004-08-13 |  | 79% | 51.56d | 2003-08-29 | 2004-05-10 | 174d | 12d |  |  |  |
| 320 | 1.5.4.3.3.1 | Fabricate STE FM 2 Detector Printed Wiring Board |  | 29d | 2003-08-29 A | 2003-10-09 A |  | 100% |  | 2003-08-29 | 2003-10-09 | 29d |  |  | start no earlier than 2003-08-29 |  |
| 321 | 1.5.4.3.3.2 | Load STE FM 2 Detector Printed Wiring Board |  | 63d | 2003-11-05 A | 2004-03-12 A | 310, 314FF+17d | 100% |  | 2003-11-05 | 2004-03-17 | 63d |  |  |  |  |
| 322 | 1.5.4.3.3.3 | Test STE FM 2 Detector Printed Wiring Board |  | 65d | 2004-03-15 A | 2004-06-14 A | 321 | 100% |  | 2004-03-18 | 2004-03-31 | 10d |  |  |  |  |
| 323 | 1.5.4.3.3.4 | **Integration & Test** |  | 43d | 2004-06-15 A | 2004-08-13 |  | 21% | 34.1d | 2004-04-01 | 2004-05-10 | 28d | 12d |  |  |  |
| 324 | 1.5.4.3.3.4.1 | Integrate & Test STE-U/D FM 2 Detectors W/ FM 2 Housings |  | 20d | 2004-06-15 A | 2004-07-13 | 308, 322, 316FS-10d, 317 | 60% | 8d | 2004-04-01 | 2004-04-14 | 10d | -5d | 0d |  |  |
| 325 | 1.5.4.3.3.4.2 | Calibrate STE-U/D FM 2 |  | 28d | 2004-07-07 | 2004-08-13 | 324FS-5d |  |  | 2004-04-15 | 2004-05-10 | 18d | -5d | 0d |  |  |
| 326 | 1.5.4.3.3.4.3 | STE-U FM 2 Thermal Vacuum/Bake Out |  | 10d | 2004-08-02 | 2004-08-13 | 325FS-10d |  |  | 2004-04-27 | 2004-05-10 | 10d | 12d | 0d |  |  |
| 327 | 1.5.5 | **STE and SWEA - UCB** |  | 340d | 2003-07-01 A | 2004-11-04 |  | 90% | 35.03d | 2003-07-01 | 2004-08-27 | 294d | -22d | 0d |  |  |
| 328 | 1.5.5.1 | **Deliveries** |  | 120d | 2004-05-14 A | 2004-11-04 |  |  | 120d | 2004-02-27 | 2004-08-27 | 129d | -22d | 0d |  |  |
| 329 | 1.5.5.1.1 | Deliver STE-U FM 1 Interface (stays at UCB for IDPU FM 1 I&T) | milestone | 0d | 2004-05-14 A | 2004-05-14 A | 378 | 100% |  | 2004-02-27 | 2004-02-27 | 0d |  |  |  | MS-BOOM |
| 330 | 1.5.5.1.2 | Deliver STE-U FM 2 Interface (stays at UCB for IDPU FM 2 I&T) | milestone | 0d | 2004-06-09 A | 2004-06-09 A | 387 | 100% |  | 2004-03-01 | 2004-03-01 | 0d |  |  |  | MS-BOOM |
| 331 | 1.5.5.1.3 | Deliver SWEA/STE-D FM 1 (stays at UCB for Boom Suite FM 1 I&T) | milestone | 0d | 2004-09-03 | 2004-09-03 | 383 |  |  | 2004-06-11 | 2004-06-11 | 0d | -42d | 0d |  | MS-BOOM |
| 332 | 1.5.5.1.4 | Deliver SWEA/STE-D FM 2 (stays at UCB for Boom Suite FM 2 I&T) | milestone | 0d | 2004-11-04 | 2004-11-04 | 393 |  |  | 2004-08-27 | 2004-08-27 | 0d | -22d | 0d |  | MS-BOOM |
| 333 | 1.5.5.2 | **SWEA Pedestal** |  | 152d | 2003-07-01 A | 2004-02-09 A |  | 100% |  | 2003-07-01 | 2004-02-09 | 152d |  |  |  |  |
| 334 | 1.5.5.2.1 | Fabricate SWEA FM 1 Baseplate |  | 152d | 2003-07-01 A | 2004-02-09 A |  | 100% |  | 2003-07-01 | 2004-02-09 | 152d |  |  | start no earlier than 2003-07-01 |  |
| 335 | 1.5.5.2.2 | Fabricate SWEA FM 2 Baseplate |  | 152d | 2003-07-01 A | 2004-02-09 A |  | 100% |  | 2003-07-01 | 2004-02-09 | 152d |  |  | start no earlier than 2003-07-01 |  |

| ID | WBS | Task | Duration | Start | Finish | Predecessors | Complete | Baseline start | Baseline finish | Baseline duration | Constraint |
| --- | --- | --- | --- | --- | --- | --- | --- | --- | --- | --- | --- |
| 336 | 1.5.5.3 | **STE-D Pre-Amp Board** | 163d | 2003-09-22 A | 2004-05-14 A |  | 100% | 2003-09-22 | 2004-02-23 | 104d |  |
| 337 | 1.5.5.3.1 | **FM 1** | 163d | 2003-09-22 A | 2004-05-14 A |  | 100% | 2003-09-22 | 2004-02-23 | 104d |  |
| 338 | 1.5.5.3.1.1 | Fabricate STE-D FM 1 Preamp Printed Wiring Board | 34d | 2003-09-22 A | 2003-11-07 A |  | 100% | 2003-09-22 | 2003-11-07 | 34d | start no earlier than 2003-09-22 |
| 339 | 1.5.5.3.1.2 | Load STE-D FM 1 Preamp Printed Wiring Board | 49d | 2004-03-09 A | 2004-05-14 A | 343 | 100% | 2004-02-17 | 2004-02-23 | 5d | start no earlier than 2004-03-09 |
| 340 | 1.5.5.3.2 | **FM 2** | 163d | 2003-09-22 A | 2004-05-14 A |  | 100% | 2003-09-22 | 2004-02-23 | 104d |  |
| 341 | 1.5.5.3.2.1 | Fabricate STE-D FM 2 Preamp Printed Wiring Board | 34d | 2003-09-22 A | 2003-11-07 A |  | 100% | 2003-09-22 | 2003-11-07 | 34d | start no earlier than 2003-09-22 |
| 342 | 1.5.5.3.2.2 | Load STE-D FM 2 Preamp Printed Wiring Board | 49d | 2004-03-09 A | 2004-05-14 A | 339SS | 100% | 2004-02-17 | 2004-02-23 | 5d |  |
| 343 | 1.5.5.3.3 | Coupon Test STE-D FM 1 & FM 2 Pre-Amp Printed Wiring Boards | 15d | 2003-11-10 A | 2003-12-02 A | 338, 341 | 100% | 2003-11-10 | 2003-12-02 | 15d |  |
| 344 | 1.5.5.4 | **STE-D Shaper Board** | 118d | 2003-12-04 A | 2004-05-21 A |  | 100% | 2003-12-04 | 2004-05-13 | 112d |  |
| 345 | 1.5.5.4.1 | **FM 1** | 67d | 2003-12-04 A | 2004-03-11 A |  | 100% | 2003-12-04 | 2004-02-20 | 53d |  |
| 346 | 1.5.5.4.1.1 | Fabricate STE-D FM 1 Shaper Printed Wiring Board | 10d | 2003-12-04 A | 2003-12-17 A |  | 100% | 2003-12-04 | 2003-12-17 | 10d | start no earlier than 2003-12-04 |
| 347 | 1.5.5.4.1.2 | Load STE-D FM 1 Shaper Printed Wiring Board | 5d | 2004-03-05 A | 2004-03-11 A | 351 | 100% | 2004-02-13 | 2004-02-20 | 5d | start no earlier than 2004-03-05 |
| 348 | 1.5.5.4.2 | **FM 2** | 118d | 2003-12-04 A | 2004-05-21 A |  | 100% | 2003-12-04 | 2004-05-13 | 112d |  |
| 349 | 1.5.5.4.2.1 | Fabricate STE-D FM 2 Shaper Printed Wiring Board | 10d | 2003-12-04 A | 2003-12-17 A |  | 100% | 2003-12-04 | 2003-12-17 | 10d | start no earlier than 2003-12-04 |
| 350 | 1.5.5.4.2.2 | Load STE-D FM 2 Shaper Printed Wiring Board | 15d | 2004-05-03 A | 2004-05-21 A | 351FS+78d | 100% | 2004-05-07 | 2004-05-13 | 5d |  |
| 351 | 1.5.5.4.3 | Coupon Test STE-D FM 1 & FM 2 Shaper Printed Wiring Boards | 15d | 2003-12-18 A | 2004-01-09 A | 346, 349 | 100% | 2003-12-18 | 2004-01-09 | 15d |  |
| 352 | 1.5.5.5 | **STE-D Interface Board** | 118d | 2003-12-04 A | 2004-05-21 A |  | 100% | 2003-12-04 | 2004-05-13 | 112d |  |
| 353 | 1.5.5.5.1 | **FM 1** | 67d | 2003-12-04 A | 2004-03-11 A |  | 100% | 2003-12-04 | 2004-02-20 | 53d |  |
| 354 | 1.5.5.5.1.1 | Fabricate SWEA / STE-D FM 1 Digital to Analog Converter Printed Wiring Board | 10d | 2003-12-04 A | 2003-12-17 A |  | 100% | 2003-12-04 | 2003-12-17 | 10d | start no earlier than 2003-12-04 |
| 355 | 1.5.5.5.1.2 | Load SWEA / STE-D FM 1 Digital to Analog Converter Printed Wiring Board | 5d | 2004-03-05 A | 2004-03-11 A | 347SS | 100% | 2004-02-13 | 2004-02-20 | 5d |  |
| 356 | 1.5.5.5.2 | **FM 2** | 118d | 2003-12-04 A | 2004-05-21 A |  | 100% | 2003-12-04 | 2004-05-13 | 112d |  |
| 357 | 1.5.5.5.2.1 | Fabricate SWEA / STE-D FM 2 Digital to Analog Converter Printed Wiring Board | 10d | 2003-12-04 A | 2003-12-17 A |  | 100% | 2003-12-04 | 2003-12-17 | 10d | start no earlier than 2003-12-04 |
| 358 | 1.5.5.5.2.2 | Load SWEA / STE-D FM 2 Digital to Analog Converter Printed Wiring Board | 15d | 2004-05-03 A | 2004-05-21 A | 350SS | 100% | 2004-05-07 | 2004-05-13 | 5d |  |
| 359 | 1.5.5.5.3 | Coupon Test STE-D FM 1 & FM 2 D/A Converter Printed Wiring Boards | 15d | 2003-12-18 A | 2004-01-09 A | 354, 357 | 100% | 2003-12-18 | 2004-01-09 | 15d |  |

| ID | WBS | Task | Duration | Start | Finish | Predecessors | Complete | Remaining | Baseline start | Baseline finish | Baseline duration | Total slack | Free slack | Constraint |
| --- | --- | --- | --- | --- | --- | --- | --- | --- | --- | --- | --- | --- | --- | --- |
| 360 | 1.5.5.6 | **STE-U Pre-Amp Board** | 160d | 2003-09-22 A | 2004-05-11 A |  | 100% |  | 2003-09-22 | 2004-02-23 | 104d |  |  |  |
| 361 | 1.5.5.6.1 | **FM 1** | 79d | 2003-09-22 A | 2004-01-15 A |  | 100% |  | 2003-09-22 | 2004-01-15 | 79d |  |  |  |
| 362 | 1.5.5.6.1.1 | Fabricate STE-U FM 1 Preamp Printed Wiring Board | 34d | 2003-09-22 A | 2003-11-07 A |  | 100% |  | 2003-09-22 | 2003-11-07 | 34d |  |  | start no earlier than 2003-09-22 |
| 363 | 1.5.5.6.1.2 | Load STE-U FM 1 Preamp Printed Wiring Board | 4d | 2004-01-12 A | 2004-01-15 A | 367 | 100% |  | 2004-01-12 | 2004-01-15 | 4d |  |  | start no earlier than 2004-01-12 |
| 364 | 1.5.5.6.2 | **FM 2** | 160d | 2003-09-22 A | 2004-05-11 A |  | 100% |  | 2003-09-22 | 2004-02-23 | 104d |  |  |  |
| 365 | 1.5.5.6.2.1 | Fabricate STE-U FM 2 Preamp Printed Wiring Board | 34d | 2003-09-22 A | 2003-11-07 A |  | 100% |  | 2003-09-22 | 2003-11-07 | 34d |  |  | start no earlier than 2003-09-22 |
| 366 | 1.5.5.6.2.2 | Load STE-U FM 2 Preamp Printed Wiring Board | 46d | 2004-03-09 A | 2004-05-11 A | 367 | 100% |  | 2004-02-17 | 2004-02-23 | 5d |  |  | start no earlier than 2004-03-09 |
| 367 | 1.5.5.6.3 | Coupon Test STE-U FM 1 & FM 2 Pre-Amp Printed Wiring Boards | 15d | 2003-11-10 A | 2003-12-02 A | 362, 365 | 100% |  | 2003-11-10 | 2003-12-02 | 15d |  |  |  |
| 368 | 1.5.5.7 | **STE-U Shaper & Interface Board** | 78d | 2003-12-04 A | 2004-03-26 A |  | 100% |  | 2003-12-04 | 2004-02-20 | 53d |  |  |  |
| 369 | 1.5.5.7.1 | **FM 1** | 73d | 2003-12-04 A | 2004-03-19 A |  | 100% |  | 2003-12-04 | 2004-02-20 | 53d |  |  |  |
| 370 | 1.5.5.7.1.1 | Fabricate STE-U FM 1Shaper & Interface Printed Wiring Board | 10d | 2003-12-04 A | 2003-12-17 A |  | 100% |  | 2003-12-04 | 2003-12-17 | 10d |  |  | start no earlier than 2003-12-04 |
| 371 | 1.5.5.7.1.2 | Load STE-U FM 1 Shaper & Interface Printed Wiring Board | 13d | 2004-03-03 A | 2004-03-19 A | 375 | 100% |  | 2004-02-13 | 2004-02-20 | 5d |  |  | start no earlier than 2004-03-03 |
| 372 | 1.5.5.7.2 | **FM 2** | 78d | 2003-12-04 A | 2004-03-26 A |  | 100% |  | 2003-12-04 | 2004-02-20 | 53d |  |  |  |
| 373 | 1.5.5.7.2.1 | Fabricate STE-U FM 2 Shaper & Interface Printed Wiring Board | 10d | 2003-12-04 A | 2003-12-17 A |  | 100% |  | 2003-12-04 | 2003-12-17 | 10d |  |  | start no earlier than 2003-12-04 |
| 374 | 1.5.5.7.2.2 | Load STE-U FM 2 Shaper & Interface Printed Wiring Board | 5d | 2004-03-22 A | 2004-03-26 A | 371 | 100% |  | 2004-02-13 | 2004-02-20 | 5d |  |  |  |
| 375 | 1.5.5.7.3 | Coupon Test STE-U FM 1 & FM 2 Shaper & Interface Printed Wiring Boards | 15d | 2003-12-18 A | 2004-01-09 A | 370, 373 | 100% |  | 2003-12-18 | 2004-01-09 | 15d |  |  |  |
| 376 | 1.5.5.8 | **Integration & Test** | 160d | 2004-03-22 A | 2004-11-04 |  | 51% | 78.09d | 2004-02-23 | 2004-08-27 | 134d | -22d | 0d |  |
| 377 | 1.5.5.8.1 | **FM 1** | 158d | 2004-03-22 A | 2004-11-02 |  | 56% | 69.04d | 2004-02-23 | 2004-07-30 | 114d | -23d | 0d |  |
| 378 | 1.5.5.8.1.1 | Integrate & Test STE-U FM 1 Interface Boards | 40d | 2004-03-22 A | 2004-05-14 A | 363, 371 | 100% |  | 2004-02-23 | 2004-02-27 | 5d |  |  |  |
| 379 | 1.5.5.8.1.2 | Integrate & Test SWEA/STE-D FM 1 Interface Boards | 20d | 2004-05-24 A | 2004-06-21 A | 334, 339, 347, 355, 350 | 100% |  | 2004-02-24 | 2004-03-22 | 20d |  |  |  |
| 380 | 1.5.5.8.1.3 | Integrate & Test SWEA/STE-D FM 1 Interface with SWEA/STE-D FM 1 LVPS | 10d | 2004-07-26 | 2004-08-06 | 379, 68 |  |  | 2004-04-16 | 2004-04-29 | 10d | -42d | 0d |  |
| 381 | 1.5.5.8.1.4 | Clean/Coat/Stake SWEA/STE-D Interface | 10d | 2004-06-22 A | 2004-07-06 | 379 | 70% | 3d | 2004-03-23 | 2004-04-05 | 10d | -19d | 0d |  |
| 382 | 1.5.5.8.1.5 | Integrate & Test SWEA/STE-D FM 1 Combined | 5d | 2004-08-09 | 2004-08-13 | 380, 381, 295, 302 |  |  | 2004-04-30 | 2004-05-06 | 5d | -42d | 0d |  |
| 383 | 1.5.5.8.1.6 | Calibrate SWEA/STE FM 1 | 15d | 2004-08-16 | 2004-09-03 | 382 |  |  | 2004-05-07 | 2004-06-04 | 20d | -42d | 0d |  |
| 384 | 1.5.5.8.1.7 | SWEA/STE FM 1 Vibration | 5d | 2004-10-06 | 2004-10-13 | 383, 19 |  |  | 2004-06-07 | 2004-06-11 | 5d | -23d | 0d |  |
| 385 | 1.5.5.8.1.8 | SWEA/STE-D FM 1 Thermal Vac/Thermal Balance/Bake Out | 14d | 2004-10-14 | 2004-11-02 | 384 |  |  | 2004-07-13 | 2004-07-30 | 14d | -23d | 0d |  |

Notes:
- 378: STE-U FM1 was completed and started thermal vac. Unfortunately we had a problem in thermal vac and STE-U FM1 is currently disassembled while we fix the problem.

| ID | WBS | Task | Duration | Start | Finish | Predecessors | Complete | Remaining | Baseline start | Baseline finish | Baseline duration | Total slack | Free slack | Constraint | Text1 |
| --- | --- | --- | --- | --- | --- | --- | --- | --- | --- | --- | --- | --- | --- | --- | --- |
| 386 | 1.5.5.8.2 | **FM 2** | 123d | 2004-05-12 A | 2004-11-04 |  | 44% | 68.33d | 2004-02-24 | 2004-08-27 | 133d | -22d | 0d |  |  |
| 387 | 1.5.5.8.2.1 | Integrate & Test STE-U FM 2 Interface Boards | 20d | 2004-05-12 A | 2004-06-09 A | 366, 374 | 100% |  | 2004-02-24 | 2004-03-01 | 5d |  |  |  |  |
| 388 | 1.5.5.8.2.2 | Integrate & Test SWEA/STE-D FM 2 Interface Boards | 20d | 2004-05-24 A | 2004-06-21 A | 335, 342, 350, 358 | 100% |  | 2004-05-14 | 2004-06-11 | 20d |  |  |  |  |
| 389 | 1.5.5.8.2.3 | Integrate & Test SWEA/STE-D FM 2 Interface with SWEA/STE-D FM 2 LVPS | 10d | 2004-08-25 | 2004-09-08 | 388, 74 |  |  | 2004-06-14 | 2004-06-25 | 10d | -22d | 0d |  |  |
| 390 | 1.5.5.8.2.4 | Integrate & Test SWEA/STE-D FM 2 Combined | 10d | 2004-09-09 | 2004-09-22 | 389, 296, 303 |  |  | 2004-06-28 | 2004-07-09 | 10d | -22d | 0d |  |  |
| 391 | 1.5.5.8.2.5 | Calibrate SWEA/STE FM 2 | 15d | 2004-09-23 | 2004-10-14 | 390 |  |  | 2004-07-12 | 2004-08-06 | 20d | -22d | 0d |  |  |
| 392 | 1.5.5.8.2.6 | SWEA/STE FM 2 Vibration | 5d | 2004-10-15 | 2004-10-21 | 391 |  |  | 2004-08-09 | 2004-08-13 | 5d | -22d | 0d |  |  |
| 393 | 1.5.5.8.2.7 | SWEA/STE-D FM 2 Thermal Vac & bake Out | 10d | 2004-10-22 | 2004-11-04 | 392 |  |  | 2004-08-16 | 2004-08-27 | 10d | -22d | 0d |  |  |
| 394 | 1.5.6 | **Boom Suite I&T - UCB** | 114d | 2004-06-17 A | 2004-11-30 |  | 11% | 100.97d | 2004-04-21 | 2004-09-28 | 113d | -22d | 0d |  |  |
| 395 | 1.5.6.1 | **FM 1** | 101d | 2004-06-17 A | 2004-11-09 |  | 27% | 74.07d | 2004-04-21 | 2004-08-13 | 82d | -23d | 0d |  |  |
| 396 | 1.5.6.1.1 | FM 1 Boom/MAG/STE-U I&T | 4d | 2004-06-17 A | 2004-06-22 A | 259, 285, 304 | 100% |  | 2004-04-21 | 2004-04-26 | 4d |  |  |  | MS-BOOM |
| 397 | 1.5.6.1.2 | FM 1 Boom/SWEA/STE/MAG I&T | 2d | 2004-09-07 | 2004-09-08 | 331, 233 |  |  | 2004-06-14 | 2004-06-15 | 2d | -42d | 0d |  |  |
| 398 | 1.5.6.1.3 | FM 1 Integrated Boom/IDPU I&T | 4d | 2004-09-09 | 2004-09-14 | 397, 233, 209 |  |  | 2004-06-16 | 2004-06-21 | 4d | -42d | 0d |  |  |
| 399 | 1.5.6.1.4 | Final BOOM Suite FM 1 I & T | 5d | 2004-11-03 | 2004-11-09 | 398, 385, 224 |  |  | 2004-08-02 | 2004-08-13 | 10d | -23d | 0d |  |  |
| 400 | 1.5.6.2 | **FM 2** | 73d | 2004-08-16 | 2004-11-30 |  |  |  | 2004-05-11 | 2004-09-28 | 99d | -22d | 0d |  |  |
| 401 | 1.5.6.2.1 | FM 2 Boom/MAG/STE-U I&T | 4d | 2004-08-16 | 2004-08-19 | 280, 286, 305 |  |  | 2004-05-11 | 2004-05-14 | 4d | 12d | 0d |  | MS-BOOM |
| 402 | 1.5.6.2.2 | FM 2 Boom/SWEA/STE/MAG I&T | 2d | 2004-11-05 | 2004-11-08 | 332, 234 |  |  | 2004-08-30 | 2004-08-31 | 2d | -22d | 0d |  |  |
| 403 | 1.5.6.2.3 | FM 2 Integrated Boom/IDPU I&T | 4d | 2004-11-09 | 2004-11-15 | 402, 234, 228 |  |  | 2004-09-01 | 2004-09-07 | 4d | -22d | 0d |  |  |
| 404 | 1.5.6.2.4 | Boom Suite FM 2 EMC | 5d | 2004-11-16 | 2004-11-22 | 403 |  |  | 2004-09-08 | 2004-09-14 | 5d | -22d | 0d |  | MS-BOOM |
| 405 | 1.5.6.2.5 | Final BOOM Suite FM 2 I & T | 5d | 2004-11-23 | 2004-11-30 | 404 |  |  | 2004-09-15 | 2004-09-28 | 10d | -22d | 0d |  |  |
| 406 | 1.6 | **SEP Suite - CIT** | 391d | 2003-06-02 A | 2004-12-20 |  | 80% | 77.45d | 2003-06-02 | 2004-10-21 | 352d | -35d | 0d |  |  |
| 407 | 1.6.1 | **SEP Mechanical - Sandy Shuman (GSFC)** | 169d | 2004-01-27 A | 2004-09-23 |  | 72% | 48.03d | 2004-01-27 | 2004-06-02 | 90d | -29d | 0d |  |  |
| 408 | 1.6.1.1 | **SIT Electronics Enclosure (Priority 1)** | 70d | 2004-02-09 A | 2004-05-17 A |  | 100% |  | 2004-02-09 | 2004-03-16 | 26d |  |  |  |  |
| 409 | 1.6.1.1.1 | Complete Design/Drawings for SIT Enclosure | 10d | 2004-02-09 A | 2004-02-23 A |  | 100% |  | 2004-02-09 | 2004-02-23 | 10d |  |  | start no earlier than 2004-02-09 |  |
| 410 | 1.6.1.1.2 | Fabrication of SIT Enclosure | 21d | 2004-04-08 A | 2004-05-06 A | 409FS+32d | 100% |  | 2004-02-24 | 2004-03-08 | 10d |  |  |  |  |
| 411 | 1.6.1.1.3 | Inspection and Final Assembly of SIT Enclosure | 6d | 2004-05-07 A | 2004-05-14 A | 410 | 100% |  | 2004-03-09 | 2004-03-15 | 5d |  |  |  |  |
| 412 | 1.6.1.1.4 | Deliver SIT Enclosure to UMD | 1d | 2004-05-17 A | 2004-05-17 A | 411 | 100% |  | 2004-03-16 | 2004-03-16 | 1d |  |  |  |  |

| ID | WBS | Task | Type | Duration | Start | Finish | Predecessors | Complete | Baseline start | Baseline finish | Baseline duration | Constraint | Text1 |
| --- | --- | --- | --- | --- | --- | --- | --- | --- | --- | --- | --- | --- | --- |
| 413 | 1.6.1.2 | **SEP FM 1 & FM 2 LVPS Boxes (Priority 2)** |  | 53d | 2004-02-09 A | 2004-04-22 A |  | 100% | 2004-02-09 | 2004-03-11 | 23d |  |  |
| 414 | 1.6.1.2.1 | Complete Design/Drawings for SEP LVPS Boxes |  | 5d | 2004-02-09 A | 2004-02-13 A | 409SS | 100% | 2004-02-09 | 2004-02-13 | 5d |  |  |
| 415 | 1.6.1.2.2 | Fabrication of SEP LVPS Boxes |  | 35d | 2004-02-17 A | 2004-04-05 A | 414 | 100% | 2004-02-17 | 2004-03-01 | 10d |  |  |
| 416 | 1.6.1.2.3 | Inspection of SEP LVPS Boxes (Final Assembly at UCB) |  | 10d | 2004-04-06 A | 2004-04-19 A | 415 | 100% | 2004-03-02 | 2004-03-08 | 5d |  |  |
| 417 | 1.6.1.2.4 | Deliver SEP LVPS Boxes to UCB |  | 3d | 2004-04-20 A | 2004-04-22 A | 416 | 100% | 2004-03-09 | 2004-03-11 | 3d | start no earlier than 2004-04-07 |  |
| 418 | 1.6.1.3 | **SEP Electronics Enclosure (Priority 3)** |  | 92d | 2004-02-17 A | 2004-06-24 A |  | 100% | 2004-02-17 | 2004-03-30 | 31d |  |  |
| 419 | 1.6.1.3.1 | Complete Design/Drawings for SEP Enclosure |  | 73d | 2004-02-17 A | 2004-05-27 A | 414 | 100% | 2004-02-17 | 2004-03-04 | 13d |  |  |
| 420 | 1.6.1.3.2 | Fabrication of SEP Enclosure |  | 15d | 2004-05-21 A | 2004-06-11 A | 419FS-5d | 100% | 2004-03-05 | 2004-03-18 | 10d |  |  |
| 421 | 1.6.1.3.3 | Inspection and Final Assembly of SEP Enclosure |  | 6d | 2004-06-14 A | 2004-06-21 A | 420 | 100% | 2004-03-19 | 2004-03-25 | 5d |  |  |
| 422 | 1.6.1.3.4 | Deliver SEP Enclosure to CIT |  | 3d | 2004-06-22 A | 2004-06-24 A | 421 | 100% | 2004-03-26 | 2004-03-30 | 3d |  | MS-SEP |
| 423 | 1.6.1.4 | **SEP Central Bias Supply Shields (Priority 4)** |  | 20d | 2004-05-25 A | 2004-06-22 A |  | 100% | 2004-03-05 | 2004-04-01 | 20d |  |  |
| 424 | 1.6.1.4.1 | Complete Design/Drawings for Bias Supply Shields |  | 5d | 2004-05-25 A | 2004-06-01 A | 419FS-3d | 100% | 2004-03-05 | 2004-03-11 | 5d |  |  |
| 425 | 1.6.1.4.2 | Fabrication of Bias Supply Shields |  | 10d | 2004-06-02 A | 2004-06-15 A | 424 | 100% | 2004-03-12 | 2004-03-25 | 10d |  |  |
| 426 | 1.6.1.4.3 | Inspection and Delivery (to CIT) of Bias Supply Shields |  | 5d | 2004-06-16 A | 2004-06-22 A | 425 | 100% | 2004-03-26 | 2004-04-01 | 5d |  |  |
| 427 | 1.6.1.5 | **LET Telescope (Priority 5)** |  | 24d | 2004-05-25 A | 2004-06-28 A |  | 100% | 2004-03-12 | 2004-04-16 | 26d |  |  |
| 428 | 1.6.1.5.1 | Complete Design/Drawings for LET Telescope |  | 5d | 2004-05-25 A | 2004-06-01 A | 424FS-5d | 100% | 2004-03-12 | 2004-03-23 | 8d |  |  |
| 429 | 1.6.1.5.2 | Fabrication of LET Telescope |  | 10d | 2004-06-02 A | 2004-06-15 A | 428 | 100% | 2004-03-24 | 2004-04-06 | 10d |  |  |
| 430 | 1.6.1.5.3 | Inspection and Final Assembly of LET Telescope (CIT has detectors) |  | 8d | 2004-06-16 A | 2004-06-25 A | 429 | 100% | 2004-04-07 | 2004-04-13 | 5d |  |  |
| 431 | 1.6.1.5.4 | Deliver LET Telescope to CIT |  | 1d | 2004-06-28 A | 2004-06-28 A | 430 | 100% | 2004-04-14 | 2004-04-16 | 3d |  |  |
| 432 | 1.6.1.6 | **HET Electronics Enclosure (Priority 6)** |  | 67d | 2004-03-22 A | 2004-06-23 A |  | 100% | 2004-03-24 | 2004-04-23 | 23d |  |  |
| 433 | 1.6.1.6.1 | Complete Design/Drawings for HET Enclosure |  | 23d | 2004-03-22 A | 2004-06-02 A | 428FS-14d | 100% | 2004-03-24 | 2004-04-02 | 8d |  |  |
| 434 | 1.6.1.6.2 | Fabrication of HET Enclosure |  | 10d | 2004-06-03 A | 2004-06-16 A | 433 | 100% | 2004-04-05 | 2004-04-16 | 10d |  |  |
| 435 | 1.6.1.6.3 | Inspection and Final Assembly of HET Enclosure |  | 5d | 2004-06-17 A | 2004-06-23 A | 434 | 100% | 2004-04-19 | 2004-04-23 | 5d |  |  |
| 436 | 1.6.1.6.4 | Deliver HET Enclosure (stays at GSFC) | milestone | 0d | 2004-06-23 A | 2004-06-23 A | 435 | 100% | 2004-04-23 | 2004-04-23 | 0d |  |  |

| ID | WBS | Task | Type | Duration | Start | Finish | Predecessors | Complete | Baseline start | Baseline finish | Baseline duration | Total slack | Free slack | Constraint | Text1 |
| --- | --- | --- | --- | --- | --- | --- | --- | --- | --- | --- | --- | --- | --- | --- | --- |
| 437 | 1.6.1.7 | **HET Telescope (Priority 7)** |  | 102d | 2004-01-27 A | 2004-06-18 A |  | 100% | 2004-01-27 | 2004-04-30 | 68d |  |  |  |  |
| 438 | 1.6.1.7.1 | On Going work for HET Telescope (Complete Design/Drawings & Prep for Fab) |  | 89d | 2004-01-27 A | 2004-06-02 A | 433FF | 100% | 2004-01-27 | 2004-03-31 | 46d |  |  | finish no earlier than 2004-06-01 |  |
| 439 | 1.6.1.7.2 | Fabrication of HET Telescope |  | 10d | 2004-05-28 A | 2004-06-11 A | 438FS-3d | 100% | 2004-04-01 | 2004-04-14 | 10d |  |  |  |  |
| 440 | 1.6.1.7.3 | Inspection and Final Assembly of HET Telescope |  | 5d | 2004-06-14 A | 2004-06-18 A | 439, 435SS-3d, 436FS-8d | 100% | 2004-04-26 | 2004-04-30 | 5d |  |  |  | MS-SEP |
| 441 | 1.6.1.7.4 | Deliver HET Telescope (stays at GSFC) | milestone | 0d | 2004-06-18 A | 2004-06-18 A | 440 | 100% | 2004-04-30 | 2004-04-30 | 0d |  |  |  | MS-SEP |
| 442 | 1.6.1.8 | **SIT Telescope (Priority 9)** |  | 36d | 2004-07-13 | 2004-08-31 |  |  | 2004-04-01 | 2004-05-18 | 34d | -40d | 0d |  |  |
| 443 | 1.6.1.8.1 | Complete Design/Drawings for SIT Telescope |  | 20d | 2004-07-13 | 2004-08-09 | 886, 887 |  | 2004-04-01 | 2004-04-26 | 18d | -40d | 0d |  |  |
| 444 | 1.6.1.8.2 | Fabrication of SIT Telescope |  | 20d | 2004-07-27 | 2004-08-23 | 443FS-10d |  | 2004-04-27 | 2004-05-10 | 10d | -40d | 0d |  |  |
| 445 | 1.6.1.8.3 | Inspection and Final Assembly of SIT Telescope |  | 5d | 2004-08-24 | 2004-08-30 | 444 |  | 2004-05-11 | 2004-05-17 | 5d | -40d | 0d |  |  |
| 446 | 1.6.1.8.4 | Deliver SIT Telescope to UMD (Includes the Foils and Detectors) |  | 1d | 2004-08-31 | 2004-08-31 | 445 |  | 2004-05-18 | 2004-05-18 | 1d | -40d | 0d |  |  |
| 447 | 1.6.1.9 | **Shipping Containers for HET, SIT & SEP Central (Priority 8)** |  | 33d | 2004-05-10 A | 2004-06-24 A |  | 100% | 2004-04-27 | 2004-05-27 | 23d |  |  |  |  |
| 448 | 1.6.1.9.1 | Design |  | 15d | 2004-05-10 A | 2004-05-28 A |  | 100% | 2004-04-27 | 2004-05-03 | 5d |  |  | start no earlier than 2004-05-10 |  |
| 449 | 1.6.1.9.2 | Fabrication/Machining |  | 10d | 2004-06-01 A | 2004-06-14 A | 448 | 100% | 2004-05-04 | 2004-05-17 | 10d |  |  |  |  |
| 450 | 1.6.1.9.3 | Inspection and Assembly |  | 5d | 2004-06-15 A | 2004-06-21 A | 449 | 100% | 2004-05-18 | 2004-05-24 | 5d |  |  |  |  |
| 451 | 1.6.1.9.4 | HET Container stays at GSFC | milestone | 0d | 2004-06-21 A | 2004-06-21 A | 450 | 100% | 2004-05-24 | 2004-05-24 | 0d |  |  |  |  |
| 452 | 1.6.1.9.5 | SIT Container to UMD |  | 1d | 2004-06-22 A | 2004-06-22 A | 450 | 100% | 2004-05-25 | 2004-05-25 | 1d |  |  |  |  |
| 453 | 1.6.1.9.6 | SEP Central Container to CIT |  | 3d | 2004-06-22 A | 2004-06-24 A | 450 | 100% | 2004-05-25 | 2004-05-27 | 3d |  |  |  |  |
| 454 | 1.6.1.10 | **Remaining LET Brackets (Priority 10)** |  | 19d | 2004-07-26 | 2004-08-19 |  |  | 2004-07-26 | 2004-08-19 | 19d | -40d | 0d |  |  |
| 455 | 1.6.1.10.1 | Complete Drawings for Remaining LET Brackets |  | 3d | 2004-07-26 | 2004-07-28 | 443FS-11d |  | 2004-03-24 | 2004-04-02 | 8d | -40d | 0d |  |  |
| 456 | 1.6.1.10.2 | Fabrication of Remaining LET Brackets |  | 10d | 2004-07-29 | 2004-08-11 | 455 |  | 2004-04-05 | 2004-04-16 | 10d | -24d | 0d |  |  |
| 457 | 1.6.1.10.3 | Inspection and Final Assembly of Remaining LET Brackets |  | 5d | 2004-08-12 | 2004-08-18 | 456 |  | 2004-04-19 | 2004-04-23 | 5d | -24d | 0d |  |  |
| 458 | 1.6.1.10.4 | Deliver Remaining LET Brackets to CIT for SEP I&T |  | 1d | 2004-08-19 | 2004-08-19 | 457 |  | 2004-04-23 | 2004-04-23 | 0d | -24d | 0d |  |  |
| 459 | 1.6.1.11 | **Rework of SEP Central MDM side panel (Priority 11)** |  | 21d | 2004-07-29 | 2004-08-26 |  |  | 2004-07-29 | 2004-08-26 | 21d | -40d | 0d |  |  |
| 460 | 1.6.1.11.1 | Complete Drawings for Reworked SEP Central MDM side panels |  | 5d | 2004-07-29 | 2004-08-04 | 455 |  | 2004-03-24 | 2004-04-02 | 8d | -40d | 0d |  |  |
| 461 | 1.6.1.11.2 | Fabrication of ReworkedSEP Central MDM side panels |  | 10d | 2004-08-05 | 2004-08-18 | 460 |  | 2004-04-05 | 2004-04-16 | 10d | -29d | 0d |  |  |
| 462 | 1.6.1.11.3 | Inspection and Final Assembly of Reworked SEP Central MDM side panels |  | 5d | 2004-08-19 | 2004-08-25 | 461 |  | 2004-04-19 | 2004-04-23 | 5d | -29d | 0d |  |  |
| 463 | 1.6.1.11.4 | Deliver Reworked SEP Central MDM side panels to CIT for SEP I&T |  | 1d | 2004-08-26 | 2004-08-26 | 462 |  | 2004-04-23 | 2004-04-23 | 0d | -29d | 0d |  |  |

| ID | WBS | Task | Type | Duration | Start | Finish | Predecessors | Complete | Remaining | Baseline start | Baseline finish | Baseline duration | Total slack | Free slack | Constraint | Text1 |
| --- | --- | --- | --- | --- | --- | --- | --- | --- | --- | --- | --- | --- | --- | --- | --- | --- |
| 464 | 1.6.1.12 | **Redesign of HET Housings (Priority 12)** |  | 23d | 2004-08-05 | 2004-09-07 |  |  |  | 2004-08-05 | 2004-09-07 | 23d | -40d | 0d |  |  |
| 465 | 1.6.1.12.1 | Complete Design/Drawings for Redesign of HET Housings |  | 8d | 2004-08-05 | 2004-08-16 | 460 |  |  | 2004-03-24 | 2004-04-02 | 8d | -40d | 0d | start no earlier than 2004-07-19 |  |
| 466 | 1.6.1.12.2 | Fabrication of Redesigned HET Housings |  | 10d | 2004-08-17 | 2004-08-30 | 465 |  |  | 2004-04-05 | 2004-04-16 | 10d | -40d | 0d |  |  |
| 467 | 1.6.1.12.3 | Inspection and Final Assembly of Redesigned HET Housings |  | 5d | 2004-08-31 | 2004-09-07 | 466 |  |  | 2004-04-19 | 2004-04-23 | 5d | -40d | 0d |  |  |
| 468 | 1.6.1.12.4 | Deliver Redesigned HET Housings (stays at GSFC) | milestone | 0d | 2004-09-07 | 2004-09-07 | 467 |  |  | 2004-04-23 | 2004-04-23 | 0d | -40d | 0d |  |  |
| 469 | 1.6.1.13 | **SIT Door (Priority 13)** |  | 27d | 2004-08-17 | 2004-09-23 |  |  |  | 2004-05-18 | 2004-06-24 | 27d | -29d | 0d |  |  |
| 470 | 1.6.1.13.1 | Complete Design/Drawings for SIT Door |  | 10d | 2004-08-17 | 2004-08-30 | 465 |  |  | 2004-05-18 | 2004-06-01 | 10d | -29d | 0d |  |  |
| 471 | 1.6.1.13.2 | Fabrication |  | 10d | 2004-08-31 | 2004-09-14 | 470 |  |  | 2004-06-02 | 2004-06-15 | 10d | -29d | 0d |  |  |
| 472 | 1.6.1.13.3 | Inspection |  | 5d | 2004-09-15 | 2004-09-21 | 471 |  |  | 2004-06-16 | 2004-06-22 | 5d | -29d | 0d |  |  |
| 473 | 1.6.1.13.4 | Final Assembly |  | 1d | 2004-09-22 | 2004-09-22 | 472 |  |  | 2004-06-23 | 2004-06-23 | 1d | -29d | 0d |  |  |
| 474 | 1.6.1.13.5 | Deliver SIT Door (stay at GSFC for Environmental Testing) |  | 1d | 2004-09-23 | 2004-09-23 | 473 |  |  | 2004-06-24 | 2004-06-24 | 1d | -29d | 0d |  |  |
| 475 | 1.6.1.14 | **LET Radiation Test Fixture (Priority 14)** |  | 26d | 2004-08-10 | 2004-09-15 |  |  |  | 2004-05-04 | 2004-06-02 | 21d | -38d | 0d |  |  |
| 476 | 1.6.1.14.1 | Design |  | 5d | 2004-08-10 | 2004-08-16 | 443 |  |  | 2004-05-04 | 2004-05-10 | 5d | -38d | 0d |  |  |
| 477 | 1.6.1.14.2 | Fabrication |  | 10d | 2004-08-17 | 2004-08-30 | 476 |  |  | 2004-05-11 | 2004-05-24 | 10d | -38d | 0d |  |  |
| 478 | 1.6.1.14.3 | Inspection and Assembly |  | 10d | 2004-08-31 | 2004-09-14 | 477 |  |  | 2004-05-25 | 2004-06-01 | 5d | -38d | 0d |  |  |
| 479 | 1.6.1.14.4 | Deliver to CIT for SEP I&T |  | 1d | 2004-09-15 | 2004-09-15 | 478 |  |  | 2004-06-02 | 2004-06-02 | 1d | -38d | 0d |  |  |
| 480 | 1.6.2 | **SEP Central - CIT** |  | 285d | 2003-08-01 A | 2004-09-17 |  | 86% | 38.74d | 2003-08-01 | 2004-06-03 | 211d | -18d | 0d |  |  |
| 481 | 1.6.2.1 | **Deliveries** |  | 57d | 2004-06-28 A | 2004-09-17 |  |  | 57d | 2004-04-14 | 2004-06-03 | 35d | -18d | 0d |  |  |
| 482 | 1.6.2.1.1 | Deliver all SEP Cen FM 1 Boards to SEP I&T (stays at CIT) | milestone | 0d | 2004-06-28 A | 2004-06-28 A | 491, 494, 501, 67FS+19d | 100% |  | 2004-05-10 | 2004-05-10 | 0d |  |  |  | MS-SEP |
| 483 | 1.6.2.1.2 | Deliver all SEP Cen FM 2 Boards & FM 2 LVPS to SEP I&T (stays at CIT) | milestone | 0d | 2004-06-29 A | 2004-06-29 A | 73, 426, 492, 495, 502 | 100% |  | 2004-05-10 | 2004-05-10 | 0d |  |  |  | MS-SEP |
| 484 | 1.6.2.1.3 | SEP Central Build 3 Software Complete | milestone | 0d | 2004-07-29 | 2004-07-29 | 508 |  |  | 2004-04-14 | 2004-04-14 | 0d | 17d | 0d |  |  |
| 485 | 1.6.2.1.4 | Final SEP Central Flight Software Complete | milestone | 0d | 2004-09-17 | 2004-09-17 | 509 |  |  | 2004-06-03 | 2004-06-03 | 0d | -40d | 0d |  |  |
| 486 | 1.6.2.2 | **Logic Board** |  | 75d | 2004-02-13 A | 2004-05-28 A |  | 100% |  | 2004-02-13 | 2004-03-26 | 30d |  |  |  |  |
| 487 | 1.6.2.2.1 | **Assembly** |  | 10d | 2004-02-13 A | 2004-02-27 A |  | 100% |  | 2004-02-13 | 2004-02-27 | 10d |  |  |  |  |
| 488 | 1.6.2.2.1.1 | Assemble FM 1 SEP Central Logic board |  | 10d | 2004-02-13 A | 2004-02-27 A |  | 100% |  | 2004-02-13 | 2004-02-27 | 10d |  |  | start no earlier than 2004-02-13 | MS-SEP |
| 489 | 1.6.2.2.1.2 | Assemble FM 2 SEP Central Logic board |  | 10d | 2004-02-13 A | 2004-02-27 A | 488SS | 100% |  | 2004-02-13 | 2004-02-27 | 10d |  |  |  | MS-SEP |

Notes:
- 465: Pieces must finish Accelerator testing 7/12 and conformal coating for completion

| ID | WBS | Task | Type | Duration | Start | Finish | Predecessors | Complete | Remaining | Baseline start | Baseline finish | Baseline duration | Total slack | Free slack | Constraint | Text1 |
| --- | --- | --- | --- | --- | --- | --- | --- | --- | --- | --- | --- | --- | --- | --- | --- | --- |
| 490 | 1.6.2.2.2 | **Test** |  | 65d | 2004-03-01 A | 2004-05-28 A |  | 100% |  | 2004-03-01 | 2004-03-26 | 20d |  |  |  |  |
| 491 | 1.6.2.2.2.1 | Test FM 1 SEP Central Logic board (initial) |  | 20d | 2004-03-01 A | 2004-03-26 A | 488 | 100% |  | 2004-03-01 | 2004-03-26 | 20d |  |  |  |  |
| 492 | 1.6.2.2.2.2 | Test FM 2 SEP Central Logic board (initial) |  | 65d | 2004-03-01 A | 2004-05-28 A | 489 | 100% |  | 2004-03-01 | 2004-03-26 | 20d |  |  |  |  |
| 493 | 1.6.2.3 | **Analog/Post-Reg Board** |  | 0d | 2004-01-27 A | 2004-01-27 A |  | 100% |  | 2004-01-27 | 2004-01-27 | 0d |  |  |  |  |
| 494 | 1.6.2.3.1 | FM 1 Analog/Post-Reg Board Complete Test and awaiting Conformal Coat with other SEP Central Boards | milestone | 0d | 2004-01-27 A | 2004-01-27 A |  | 100% |  | 2004-01-27 | 2004-01-27 | 0d |  |  | start no earlier than 2004-01-27 |  |
| 495 | 1.6.2.3.2 | FM 2 Analog/Post-Reg Board Complete Test and awaiting Conformal Coat with other SEP Central Boards | milestone | 0d | 2004-01-27 A | 2004-01-27 A |  | 100% |  | 2004-01-27 | 2004-01-27 | 0d |  |  | start no earlier than 2004-01-27 |  |
| 496 | 1.6.2.4 | **SEP Solid State Detector Bias Supply Board** |  | 55d | 2004-01-20 A | 2004-04-06 A |  | 100% |  | 2004-01-20 | 2004-04-15 | 62d |  |  |  |  |
| 497 | 1.6.2.4.1 | **Assembly & Initial Test** |  | 40d | 2004-01-20 A | 2004-03-16 A |  | 100% |  | 2004-01-20 | 2004-03-16 | 40d |  |  |  |  |
| 498 | 1.6.2.4.1.1 | Assemble and Initial Test FM 1 SSD Bias Supply Board |  | 40d | 2004-01-20 A | 2004-03-16 A |  | 100% |  | 2004-01-20 | 2004-03-16 | 40d |  |  | start no earlier than 2004-01-20 |  |
| 499 | 1.6.2.4.1.2 | Assemble and Initial Test FM 2 SSD Bias Supply Board |  | 40d | 2004-01-20 A | 2004-03-16 A | 498SS | 100% |  | 2004-01-20 | 2004-03-16 | 40d |  |  |  |  |
| 500 | 1.6.2.4.2 | **Final Test** |  | 15d | 2004-03-17 A | 2004-04-06 A |  | 100% |  | 2004-04-02 | 2004-04-15 | 10d |  |  |  |  |
| 501 | 1.6.2.4.2.1 | Final Test FM 1 SSD Bias Supply Board |  | 15d | 2004-03-17 A | 2004-04-06 A | 498 | 100% |  | 2004-04-02 | 2004-04-15 | 10d |  |  |  |  |
| 502 | 1.6.2.4.2.2 | Final Test FM 2 SSD Bias Supply Board |  | 15d | 2004-03-17 A | 2004-04-06 A | 499 | 100% |  | 2004-04-02 | 2004-04-15 | 10d |  |  |  |  |
| 503 | 1.6.2.5 | **Conformal Coat, Mass Properties and Bake Out (SEP Central, LET, SEP LVPS)** |  | 15d | 2004-07-21 | 2004-08-10 |  |  |  | 2004-04-16 | 2004-05-10 | 17d | -17d | 0d |  |  |
| 504 | 1.6.2.5.1 | Stake/Conformal Coat All SEP Central and LET Boards |  | 8d | 2004-07-21 | 2004-07-30 | 891 |  |  | 2004-04-16 | 2004-04-29 | 10d | -17d | 0d |  |  |
| 505 | 1.6.2.5.2 | Mass Properties/Photo All SEP Central and LET Boards |  | 4d | 2004-08-02 | 2004-08-05 | 504 |  |  | 2004-04-30 | 2004-05-05 | 4d | -17d | 0d |  |  |
| 506 | 1.6.2.5.3 | Bake Out All SEP Central/LET Boards and SEP LVPS FM 1 |  | 3d | 2004-08-06 | 2004-08-10 | 505, 67 |  |  | 2004-05-06 | 2004-05-10 | 3d | -17d | 0d |  |  |
| 507 | 1.6.2.6 | **Flight Software** |  | 285d | 2003-08-01 A | 2004-09-17 |  | 81% | 55d | 2003-08-01 | 2004-06-03 | 211d | -35d | 0d |  |  |
| 508 | 1.6.2.6.1 | SEP Central Build 3 |  | 250d | 2003-08-01 A | 2004-07-29 |  | 92% | 20d | 2003-08-01 | 2004-04-14 | 176d | -40d | 0d | start no earlier than 2003-08-01 |  |
| 509 | 1.6.2.6.2 | Final Flight S/W Build |  | 35d | 2004-07-30 | 2004-09-17 | 508 |  |  | 2004-04-15 | 2004-06-03 | 35d | -40d | 0d |  |  |
| 510 | 1.6.3 | **HET - Tycho (GSFC)** |  | 173d | 2004-01-06 A | 2004-09-09 |  | 89% | 18.73d | 2004-01-06 | 2004-06-23 | 119d | -6d | 0d |  |  |
| 511 | 1.6.3.1 | **Deliveries** |  | 52d | 2004-06-28 A | 2004-09-09 |  | 60% | 20.8d | 2004-04-30 | 2004-06-23 | 38d | -6d | 0d |  |  |
| 512 | 1.6.3.1.1 | Deliver HET FM 1w/o replacement detectors (to CIT for SEP Suite I&T) |  | 2d | 2004-06-28 A | 2004-06-29 A | 451, 558 | 100% |  | 2004-06-01 | 2004-06-02 | 2d |  |  |  | MS-SEP |
| 513 | 1.6.3.1.2 | Deliver HET FM 1 w/ replacement detectors & FM 2 after coating (to CIT for SEP Suite I&T) |  | 2d | 2004-09-08 | 2004-09-09 | 468, 561 |  |  | 2004-07-19 | 2004-07-20 | 2d | -40d | 0d |  |  |
| 514 | 1.6.3.1.3 | Deliver HET FM 2 w/o replacement detectors (to CIT for SEP Suite I&T) |  | 2d | 2004-06-28 A | 2004-06-29 A | 564, 451 | 100% |  | 2004-06-01 | 2004-06-02 | 2d |  |  |  | MS-SEP |
| 515 | 1.6.3.1.4 | Deliver HET FM 2 w/ replacement detectors (to CIT for SEP Suite I&T) |  | 2d | 2004-09-08 | 2004-09-09 | 468, 567 |  |  | 2004-06-22 | 2004-06-23 | 2d | -6d | 0d |  | MS-SEP |
| 516 | 1.6.3.1.5 | Deliver Final HET Flight Software to SEP I&T |  | 2d | 2004-06-28 A | 2004-06-29 A | 554 | 100% |  | 2004-04-30 | 2004-05-03 | 2d |  |  |  |  |

Notes:
- 506: SEP FM 2 LVPS Bakeout will occur at Berkley prior to delivery 6/18. This allows LET to proceed, which has more to do before I&T than SEP Central.

| ID | WBS | Task | Type | Duration | Start | Finish | Predecessors | Complete | Remaining | Baseline start | Baseline finish | Baseline duration | Total slack | Free slack | Constraint | Text1 |
| --- | --- | --- | --- | --- | --- | --- | --- | --- | --- | --- | --- | --- | --- | --- | --- | --- |
| 517 | 1.6.3.2 | **Detectors (Batch 1)** |  | 40d | 2004-01-06 A | 2004-03-03 A |  | 100% |  | 2004-01-06 | 2004-03-31 | 60d |  |  |  |  |
| 518 | 1.6.3.2.1 | Receive & Inspect HET Flight Detectors |  | 40d | 2004-01-06 A | 2004-03-03 A |  | 100% |  | 2004-01-06 | 2004-03-03 | 40d |  |  | start no earlier than 2004-01-06 |  |
| 519 | 1.6.3.2.2 | **Detector Testing** |  | 40d | 2004-01-06 A | 2004-03-03 A |  | 100% |  | 2004-01-06 | 2004-03-31 | 60d |  |  |  |  |
| 520 | 1.6.3.2.2.1 | Capacitance, Current, Depletion, Alpha Resolution Testing |  | 40d | 2004-01-06 A | 2004-03-03 A | 518SS | 100% |  | 2004-01-06 | 2004-03-31 | 60d |  |  |  | MS-SEP |
| 521 | 1.6.3.2.2.2 | Life Test HET Detectors |  | 40d | 2004-01-06 A | 2004-03-03 A | 520SS | 100% |  | 2004-01-06 | 2004-03-31 | 60d |  |  |  | MS-SEP |
| 522 | 1.6.3.3 | **Replacement HET Detectors (Batch 2)** |  | 109d | 2004-03-12 A | 2004-08-13 |  | 73% | 29.38d | 2004-03-12 | 2004-06-14 | 66d | 0d |  |  |  |
| 523 | 1.6.3.3.1 | Receive H1 Detector Mounts | milestone | 0d | 2004-03-12 A | 2004-03-12 A |  | 100% |  | 2004-03-12 | 2004-03-12 | 0d |  |  | start no earlier than 2004-03-12 |  |
| 524 | 1.6.3.3.2 | Receive H3 Detector Mounts | milestone | 0d | 2004-03-26 A | 2004-03-26 A |  | 100% |  | 2004-03-26 | 2004-03-26 | 0d |  |  | start no earlier than 2004-03-26 |  |
| 525 | 1.6.3.3.3 | Detector Mounting at Micron |  | 20d | 2004-04-15 A | 2004-05-12 A | 523, 524 | 100% |  | 2004-04-15 | 2004-05-12 | 20d |  |  | start no earlier than 2004-04-15 |  |
| 526 | 1.6.3.3.4 | Detector Delivery to GSFC |  | 32d | 2004-05-13 A | 2004-06-28 A | 525 | 100% |  | 2004-05-13 | 2004-05-14 | 2d |  |  |  |  |
| 527 | 1.6.3.3.5 | Detector Testing at GSFC |  | 63d | 2004-05-17 A | 2004-08-13 | 526FS-20d | 51% | 31d | 2004-05-17 | 2004-06-14 | 20d | -26d | 0d |  |  |
| 528 | 1.6.3.4 | **Electronics Board** |  | 138d | 2004-01-22 A | 2004-08-05 |  | 76% | 33.25d | 2004-01-22 | 2004-05-13 | 80d | 14d |  |  | MS-SEP |
| 529 | 1.6.3.4.1 | **Assembly** |  | 38d | 2004-01-22 A | 2004-03-16 A |  | 100% |  | 2004-01-22 | 2004-03-12 | 36d |  |  |  |  |
| 530 | 1.6.3.4.1.1 | Install Socket on HET Electronics FM 1 Board for ETU ACTEL |  | 1d | 2004-01-22 A | 2004-01-22 A |  | 100% |  | 2004-01-22 | 2004-01-22 | 1d |  |  | start no earlier than 2004-01-22 |  |
| 531 | 1.6.3.4.1.2 | Complete Population of HET Electronics FM 1 Board (ETU ACTEL) |  | 1d | 2004-01-23 A | 2004-01-23 A | 530 | 100% |  | 2004-01-23 | 2004-01-23 | 1d |  |  |  |  |
| 532 | 1.6.3.4.1.3 | Complete Population of HET Electronics FM 2 Board (Flight ACTEL) |  | 2d | 2004-03-15 A | 2004-03-16 A | 531, 538, 576 | 100% |  | 2004-03-11 | 2004-03-12 | 2d |  |  |  |  |
| 533 | 1.6.3.4.2 | **Test** |  | 136d | 2004-01-26 A | 2004-08-05 |  | 75% | 34.43d | 2004-01-26 | 2004-05-13 | 78d | 14d |  |  |  |
| 534 | 1.6.3.4.2.1 | **FM 1** |  | 136d | 2004-01-26 A | 2004-08-05 |  | 77% | 30.91d | 2004-01-26 | 2004-03-22 | 40d | -20d | 0d |  |  |
| 535 | 1.6.3.4.2.1.1 | Test HET FM 1 Electronics Board w/ETU ACTEL |  | 23d | 2004-01-26 A | 2004-02-26 A | 531 | 100% |  | 2004-01-26 | 2004-02-23 | 20d |  |  |  |  |
| 536 | 1.6.3.4.2.1.2 | Remove ETU ACTEL and socket from HET FM 1 Electronics Board |  | 0.5d | 2004-02-27 A | 2004-02-27 A | 535 | 100% |  | 2004-02-24 | 2004-02-24 | 1d |  |  |  |  |
| 537 | 1.6.3.4.2.1.3 | Install Flight ACTEL on HET FM 1 Electronics Board |  | 0.5d | 2004-02-27 A | 2004-02-27 A | 536 | 100% |  | 2004-02-25 | 2004-02-25 | 1d |  |  |  |  |
| 538 | 1.6.3.4.2.1.4 | Retest HET FM 1 Electronics Board w/Flight ACTEL |  | 10d | 2004-03-01 A | 2004-03-12 A | 537 | 100% |  | 2004-02-26 | 2004-03-10 | 10d |  |  |  |  |
| 539 | 1.6.3.4.2.1.5 | Clean, Bake, Conformal Coat HET FM 1 Electronics Board |  | 5d | 2004-07-23 | 2004-07-29 | 538FS+61d, 559 |  |  | 2004-03-11 | 2004-03-12 | 2d | -20d | 0d |  |  |
| 540 | 1.6.3.4.2.1.6 | Retest Conformal Coated HET FM 1 Electronics Board |  | 5d | 2004-07-30 | 2004-08-05 | 539 |  |  | 2004-03-15 | 2004-03-16 | 2d | -20d | 0d |  |  |

Notes:
- 539: Questioning when to begin the process of Conformally Coating these boards due to part issues. Expect Answer by 4/30/04. / Engineer is out on Leave until June 9th. Cleaning will begin after this date.

| ID | WBS | Task | Type | Duration | Start | Finish | Predecessors | Complete | Remaining | Baseline start | Baseline finish | Baseline duration | Total slack | Free slack | Constraint |
| --- | --- | --- | --- | --- | --- | --- | --- | --- | --- | --- | --- | --- | --- | --- | --- |
| 541 | 1.6.3.4.2.2 | **FM 2** |  | 100d | 2004-03-17 A | 2004-08-05 |  | 71% | 28.57d | 2004-03-23 | 2004-05-13 | 38d | 14d |  |  |
| 542 | 1.6.3.4.2.2.1 | Test HET FM 2 Electronics Board |  | 25d | 2004-03-17 A | 2004-04-20 A | 532, 535 | 100% |  | 2004-03-23 | 2004-05-03 | 30d |  |  |  |
| 543 | 1.6.3.4.2.2.2 | Clean, Bake, Conformal Coat HET FM 2 Electronics Board |  | 5d | 2004-07-23 | 2004-07-29 | 565 |  |  | 2004-05-04 | 2004-05-05 | 2d | 14d | 0d |  |
| 544 | 1.6.3.4.2.2.3 | Retest Conformal Coated HET FM 2 Electronics Board |  | 5d | 2004-07-30 | 2004-08-05 | 543 |  |  | 2004-05-06 | 2004-05-07 | 2d | 14d | 6d |  |
| 545 | 1.6.3.5 | **Flight Software** |  | 110d | 2004-01-22 A | 2004-06-25 A |  | 100% |  | 2004-01-22 | 2004-04-29 | 70d |  |  |  |
| 546 | 1.6.3.5.1 | **Design** |  | 71d | 2004-01-22 A | 2004-04-30 A |  | 100% |  | 2004-01-22 | 2004-02-04 | 10d |  |  |  |
| 547 | 1.6.3.5.1.1 | Complete Definition of HET PH Event Processing |  | 22d | 2004-01-22 A | 2004-02-23 A |  | 100% |  | 2004-01-22 | 2004-02-04 | 10d |  |  | start no earlier than 2004-01-22 |
| 548 | 1.6.3.5.1.2 | Design Change of HET PH Event Processing |  | 20d | 2004-04-05 A | 2004-04-30 A |  | 100% |  | 2004-04-05 | 2004-04-23 | 15d |  |  | start no earlier than 2004-04-05 |
| 549 | 1.6.3.5.2 | **Coding** |  | 64d | 2004-02-24 A | 2004-05-21 A |  | 100% |  | 2004-02-05 | 2004-03-04 | 20d |  |  |  |
| 550 | 1.6.3.5.2.1 | Code HET PH Event Processing Update for Flight |  | 59d | 2004-02-24 A | 2004-05-14 A | 547 | 100% |  | 2004-02-05 | 2004-02-19 | 10d |  |  |  |
| 551 | 1.6.3.5.2.2 | Code HET Telemetry Formatting Update for Flight |  | 34d | 2004-03-12 A | 2004-05-21 A | 550FS-15d | 100% |  | 2004-02-20 | 2004-03-04 | 10d |  |  |  |
| 552 | 1.6.3.5.3 | **Test** |  | 68d | 2004-03-23 A | 2004-06-25 A |  | 100% |  | 2004-03-05 | 2004-04-29 | 40d |  |  |  |
| 553 | 1.6.3.5.3.1 | Test Integrated HET S/W with Simulated Data |  | 63d | 2004-03-23 A | 2004-06-18 A |  | 100% |  | 2004-03-05 | 2004-03-25 | 15d |  |  | start no later than 2004-03-23 |
| 554 | 1.6.3.5.3.2 | Verify HET On-Board Software |  | 5d | 2004-06-21 A | 2004-06-25 A | 548, 553 | 100% |  | 2004-03-26 | 2004-04-29 | 25d |  |  |  |
| 555 | 1.6.3.6 | **Integration & Test** |  | 41d | 2004-06-21 A | 2004-08-17 |  | 71% | 11.71d | 2004-05-03 | 2004-06-21 | 35d | 8d |  |  |
| 556 | 1.6.3.6.1 | **FM 1** |  | 41d | 2004-06-21 A | 2004-08-17 |  | 71% | 11.71d | 2004-05-03 | 2004-05-28 | 20d | -26d | 0d |  |
| 557 | 1.6.3.6.1.1 | Integrate HET FM 1 Electronics Telescope (Ahead) |  | 3d | 2004-06-21 A | 2004-06-23 A | 521, 554FS-10d, 441 | 100% |  | 2004-05-03 | 2004-05-07 | 5d |  |  |  |
| 558 | 1.6.3.6.1.2 | Test HET FM 1 Telescope (Ahead) |  | 2d | 2004-06-24 A | 2004-06-25 A | 557 | 100% |  | 2004-05-10 | 2004-05-28 | 15d |  |  |  |
| 559 | 1.6.3.6.1.3 | Receive HET FM1 from CIT | milestone | 0d | 2004-07-22 | 2004-07-22 | 890 |  |  | 2004-07-14 | 2004-07-14 | 0d | -20d | 0d |  |
| 560 | 1.6.3.6.1.4 | Install new HET Flight Detectors in FM 1 |  | 1d | 2004-08-16 | 2004-08-16 | 527, 559, 540 |  |  | 2004-06-16 | 2004-06-16 | 1d | -26d | 0d |  |
| 561 | 1.6.3.6.1.5 | Performance Test FM 1 with New Flight Detectors |  | 1d | 2004-08-17 | 2004-08-17 | 560, 551 |  |  | 2004-06-17 | 2004-06-17 | 1d | -26d | 0d |  |
| 562 | 1.6.3.6.2 | **FM 2** |  | 41d | 2004-06-21 A | 2004-08-17 |  | 71% | 11.71d | 2004-05-14 | 2004-06-21 | 26d | 8d |  |  |
| 563 | 1.6.3.6.2.1 | Integrate HET FM 2 Electronics Telescope (Behind) |  | 3d | 2004-06-21 A | 2004-06-23 A | 521, 554FS-10d, 441, 542 | 100% |  | 2004-05-14 | 2004-05-20 | 5d |  |  |  |
| 564 | 1.6.3.6.2.2 | Test HET FM 2 Telescope (Behind) |  | 2d | 2004-06-24 A | 2004-06-25 A | 563 | 100% |  | 2004-06-01 | 2004-06-21 | 15d |  |  |  |
| 565 | 1.6.3.6.2.3 | Receive HET FM2 from CIT | milestone | 0d | 2004-07-22 | 2004-07-22 | 892 |  |  | 2004-07-14 | 2004-07-14 | 0d | 14d | 0d |  |
| 566 | 1.6.3.6.2.4 | Install new HET Flight Detectors in FM 2 |  | 1d | 2004-08-16 | 2004-08-16 | 527, 565, 544 |  |  | 2004-06-17 | 2004-06-17 | 1d | 8d | 0d |  |
| 567 | 1.6.3.6.2.5 | Performance Test FM 2 with New Flight Detectors |  | 1d | 2004-08-17 | 2004-08-17 | 566 |  |  | 2004-07-16 | 2004-07-16 | 1d | 8d |  |  |

Notes:
- 542: During removal of a temporary commercial ACTEL (U200) several pads(29) were lifted. We will build a new board, and repair the other board. One will become a Flight Spare. Continue with testing and switch out boards later on. 5d hit to the schedule.
- 548: The scientist needed to make changes to the HET PH Event Processing design due to issues found after the developer completed the majority of the software. Coding and testing can not finish until the design chagne is complete.

| ID | WBS | Task | Type | Duration | Start | Finish | Predecessors | Complete | Remaining | Baseline start | Baseline finish | Baseline duration | Total slack | Free slack | Constraint | Text1 |
| --- | --- | --- | --- | --- | --- | --- | --- | --- | --- | --- | --- | --- | --- | --- | --- | --- |
| 568 | 1.6.4 | **LET - CIT** |  | 245d | 2003-07-14 A | 2004-07-01 A |  | 100% |  | 2003-07-14 | 2004-06-08 | 228d |  |  |  |  |
| 569 | 1.6.4.1 | **Deliveries** |  | 4d | 2004-06-25 A | 2004-07-01 A |  | 100% |  | 2004-05-04 | 2004-06-08 | 24d |  |  |  |  |
| 570 | 1.6.4.1.1 | Deliver LET FM 1 (stays at CIT for SEP I&T) | milestone | 0d | 2004-07-01 A | 2004-07-01 A | 588 | 100% |  | 2004-06-08 | 2004-06-08 | 0d |  |  |  | MS-SEP |
| 571 | 1.6.4.1.2 | Deliver LET FM 2 (stays at CIT for SEP I&T) | milestone | 0d | 2004-07-01 A | 2004-07-01 A | 590 | 100% |  | 2004-06-08 | 2004-06-08 | 0d |  |  |  | MS-SEP |
| 572 | 1.6.4.1.3 | Deliver LET Flight Software Build 3 | milestone | 0d | 2004-06-25 A | 2004-06-25 A | 585 | 100% |  | 2004-05-04 | 2004-05-04 | 0d |  |  |  |  |
| 573 | 1.6.4.2 | **Detectors** |  | 167d | 2003-07-14 A | 2004-03-12 A |  | 100% |  | 2003-07-14 | 2004-03-12 | 167d |  |  |  |  |
| 574 | 1.6.4.2.1 | Complete LET Flight Detector Testing |  | 167d | 2003-07-14 A | 2004-03-12 A |  | 100% |  | 2003-07-14 | 2004-03-12 | 167d |  |  | start no earlier than 2003-07-14 | MS-SEP |
| 575 | 1.6.4.3 | **Hybrids** |  | 144d | 2003-08-01 A | 2004-03-01 A |  | 100% |  | 2003-08-01 | 2004-03-01 | 144d |  |  |  |  |
| 576 | 1.6.4.3.1 | Complete Test of Flight Hybrids (LET and to GSFC for HET FM 2) |  | 144d | 2003-08-01 A | 2004-03-01 A |  | 100% |  | 2003-08-01 | 2004-03-01 | 144d |  |  | start no earlier than 2003-08-01 |  |
| 577 | 1.6.4.4 | **Detector/Misc Board** |  | 82d | 2004-03-02 A | 2004-06-24 A |  | 100% |  | 2004-03-02 | 2004-03-30 | 21d |  |  |  |  |
| 578 | 1.6.4.4.1 | **Assembly** |  | 10d | 2004-03-02 A | 2004-03-15 A |  | 100% |  | 2004-03-02 | 2004-03-15 | 10d |  |  |  |  |
| 579 | 1.6.4.4.1.1 | Assemble LET FM 1 Detector Board |  | 10d | 2004-03-02 A | 2004-03-15 A | 576 | 100% |  | 2004-03-02 | 2004-03-15 | 10d |  |  |  |  |
| 580 | 1.6.4.4.1.2 | Assemble LET FM 2 Detector Board |  | 10d | 2004-03-02 A | 2004-03-15 A | 576 | 100% |  | 2004-03-02 | 2004-03-15 | 10d |  |  |  |  |
| 581 | 1.6.4.4.2 | **Test** |  | 72d | 2004-03-16 A | 2004-06-24 A |  | 100% |  | 2004-03-16 | 2004-03-30 | 11d |  |  |  |  |
| 582 | 1.6.4.4.2.1 | Test LET FM 1 Detector Board |  | 72d | 2004-03-16 A | 2004-06-24 A | 579 | 100% |  | 2004-03-16 | 2004-03-30 | 11d |  |  |  |  |
| 583 | 1.6.4.4.2.2 | Test LET FM 2 Detector Board |  | 72d | 2004-03-16 A | 2004-06-24 A | 580 | 100% |  | 2004-03-16 | 2004-03-30 | 11d |  |  |  |  |
| 584 | 1.6.4.5 | **Flight Software** |  | 227d | 2003-08-01 A | 2004-06-25 A |  | 100% |  | 2003-08-01 | 2004-05-04 | 190d |  |  |  |  |
| 585 | 1.6.4.5.1 | Let Flight Software Build 3 |  | 227d | 2003-08-01 A | 2004-06-25 A |  | 100% |  | 2003-08-01 | 2004-05-04 | 190d |  |  | start no earlier than 2003-08-01 |  |
| 586 | 1.6.4.6 | **Integration & Test** |  | 3d | 2004-06-29 A | 2004-07-01 A |  | 100% |  | 2004-05-11 | 2004-06-08 | 20d |  |  |  |  |
| 587 | 1.6.4.6.1 | **FM 1** |  | 3d | 2004-06-29 A | 2004-07-01 A |  | 100% |  | 2004-05-11 | 2004-06-08 | 20d |  |  |  |  |
| 588 | 1.6.4.6.1.1 | Integrate LET FM 1 Housing With Detectors |  | 3d | 2004-06-29 A | 2004-07-01 A | 574, 431, 582 | 100% |  | 2004-05-11 | 2004-06-08 | 20d |  |  |  | MS-SEP |
| 589 | 1.6.4.6.2 | **FM 2** |  | 3d | 2004-06-29 A | 2004-07-01 A |  | 100% |  | 2004-05-11 | 2004-06-08 | 20d |  |  |  |  |
| 590 | 1.6.4.6.2.1 | Integrate LET FM 2 Housing With Detectors |  | 3d | 2004-06-29 A | 2004-07-01 A | 574, 431, 583 | 100% |  | 2004-05-11 | 2004-06-08 | 20d |  |  |  | MS-SEP |
| 591 | 1.6.5 | **SEPT - Kiel/ESTEC** |  | 328d | 2003-08-08 A | 2004-11-29 |  | 76% | 77.25d | 2003-08-08 | 2004-07-28 | 245d | -26d | 0d |  |  |
| 592 | 1.6.5.1 | **Deliveries** |  | 67d | 2004-08-23 | 2004-11-29 |  |  |  | 2004-03-11 | 2004-07-28 | 99d | -31d | 0d |  |  |
| 593 | 1.6.5.1.1 | Deliver SEPT-NS FM 1 to CIT for SEP I&T and Suite EMC |  | 5d | 2004-08-23 | 2004-08-27 | 640 |  |  | 2004-03-11 | 2004-03-17 | 5d | -31d | 0d |  | MS-SEP |
| 594 | 1.6.5.1.2 | Deliver SEPT-E FM 1 to CIT for SEP I&T and Suite EMC |  | 5d | 2004-08-23 | 2004-08-27 | 656 |  |  | 2004-03-11 | 2004-03-17 | 5d | -31d | 0d |  | MS-SEP |
| 595 | 1.6.5.1.3 | Final Delivery of SEPT FM 1 to APL |  | 2d | 2004-11-12 | 2004-11-15 | 626, 644, 660 |  |  | 2004-07-27 | 2004-07-28 | 2d | -26d | 0d |  |  |
| 596 | 1.6.5.1.4 | Deliver SEPT-NS FM 2 to CIT for Suite EMC and final delivery to APL |  | 5d | 2004-11-22 | 2004-11-29 | 677 |  |  | 2004-03-22 | 2004-03-26 | 5d | -26d | 0d |  | MS-SEP |
| 597 | 1.6.5.1.5 | Deliver SEPT-E FM 2 to CIT for Suite EMC and final delivery to APL |  | 5d | 2004-11-22 | 2004-11-29 | 693 |  |  | 2004-03-22 | 2004-03-26 | 5d | -26d | 0d |  | MS-SEP |

| ID | WBS | Task | Duration | Start | Finish | Predecessors | Complete | Remaining | Baseline start | Baseline finish | Baseline duration | Total slack | Free slack | Constraint |
| --- | --- | --- | --- | --- | --- | --- | --- | --- | --- | --- | --- | --- | --- | --- |
| 598 | 1.6.5.2 | **Mechanical Assembly** | 46d | 2003-12-22 A | 2004-02-27 A |  | 100% |  | 2003-12-22 | 2004-02-27 | 46d |  |  |  |
| 599 | 1.6.5.2.1 | **FM 1** | 13d | 2003-12-22 A | 2004-01-09 A |  | 100% |  | 2003-12-22 | 2004-01-09 | 13d |  |  |  |
| 600 | 1.6.5.2.1.1 | Assemble SEPT-NS FM 1 Sensor and E-Box Housing | 13d | 2003-12-22 A | 2004-01-09 A |  | 100% |  | 2003-12-22 | 2004-01-09 | 13d |  |  | start no earlier than 2003-12-22 |
| 601 | 1.6.5.2.1.2 | Assemble SEPT-E FM 1 Sensor and E-Box Housing | 13d | 2003-12-22 A | 2004-01-09 A |  | 100% |  | 2003-12-22 | 2004-01-09 | 13d |  |  | start no earlier than 2003-12-22 |
| 602 | 1.6.5.2.2 | **FM 2** | 14d | 2003-12-29 A | 2004-01-16 A |  | 100% |  | 2003-12-29 | 2004-01-16 | 14d |  |  |  |
| 603 | 1.6.5.2.2.1 | Assemble SEPT-NS FM 2 Sensor and E-Box Housing | 14d | 2003-12-29 A | 2004-01-16 A | 600SS+4d | 100% |  | 2003-12-29 | 2004-01-16 | 14d |  |  |  |
| 604 | 1.6.5.2.2.2 | Assemble SEPT-E FM 2 Sensor and E-Box Housing | 14d | 2003-12-29 A | 2004-01-16 A | 601SS+4d | 100% |  | 2003-12-29 | 2004-01-16 | 14d |  |  |  |
| 605 | 1.6.5.2.3 | **Spare** | 28d | 2004-01-20 A | 2004-02-27 A |  | 100% |  | 2004-01-20 | 2004-02-27 | 28d |  |  |  |
| 606 | 1.6.5.2.3.1 | Assemble SEPT Spare Sensor and E-Box Housing | 28d | 2004-01-20 A | 2004-02-27 A | 603, 604 | 100% |  | 2004-01-20 | 2004-02-27 | 28d |  |  |  |
| 607 | 1.6.5.3 | **Electronics** | 272d | 2003-08-08 A | 2004-09-07 |  | 91% | 23.37d | 2003-08-08 | 2004-05-21 | 198d | 19d |  |  |
| 608 | 1.6.5.3.1 | **Assembly** | 172d | 2003-08-08 A | 2004-04-15 A |  | 100% |  | 2003-08-08 | 2004-04-15 | 172d |  |  |  |
| 609 | 1.6.5.3.1.1 | **FM 2** | 106d | 2003-08-08 A | 2004-01-12 A |  | 100% |  | 2003-08-08 | 2004-01-12 | 106d |  |  |  |
| 610 | 1.6.5.3.1.1.1 | Assemble SEPT-NS FM 2 Electronics | 106d | 2003-08-08 A | 2004-01-12 A |  | 100% |  | 2003-08-08 | 2004-01-12 | 106d |  |  | start no earlier than 2003-08-08 |
| 611 | 1.6.5.3.1.1.2 | Assemble SEPT-E FM 2 Electronics | 92d | 2003-08-08 A | 2003-12-19 A |  | 100% |  | 2003-08-08 | 2003-12-19 | 92d |  |  | start no earlier than 2003-08-08 |
| 612 | 1.6.5.3.1.2 | **Spare** | 172d | 2003-08-08 A | 2004-04-15 A |  | 100% |  | 2003-08-08 | 2004-04-15 | 172d |  |  |  |
| 613 | 1.6.5.3.1.2.1 | Assemble SEPT FS Electronics | 172d | 2003-08-08 A | 2004-04-15 A | 610SS | 100% |  | 2003-08-08 | 2004-04-15 | 172d |  |  |  |
| 614 | 1.6.5.3.2 | **Test** | 187d | 2003-12-11 A | 2004-09-07 |  | 73% | 49.66d | 2003-12-11 | 2004-05-21 | 113d | 19d |  |  |
| 615 | 1.6.5.3.2.1 | **FM 2** | 183d | 2003-12-11 A | 2004-08-31 |  | 69% | 56.61d | 2003-12-11 | 2004-01-30 | 34d | 19d |  |  |
| 616 | 1.6.5.3.2.1.1 | SEPT-NS FM 2 Electronics Test | 4d | 2004-01-13 A | 2004-01-16 A | 610 | 100% |  | 2004-01-13 | 2004-01-16 | 4d |  |  |  |
| 617 | 1.6.5.3.2.1.2 | SEPT-E FM 2 Electronics Test | 4d | 2003-12-11 A | 2003-12-16 A | 611FS-7d | 100% |  | 2003-12-11 | 2003-12-16 | 4d |  |  |  |
| 618 | 1.6.5.3.2.1.3 | Coat SEPT-NS FM 2 Electronics Board | 4d | 2004-01-20 A | 2004-01-23 A | 616 | 100% |  | 2004-01-20 | 2004-01-23 | 4d |  |  |  |
| 619 | 1.6.5.3.2.1.4 | Coat SEPT-E FM 2 Electronics Board | 5d | 2003-12-17 A | 2003-12-23 A | 617 | 100% |  | 2003-12-17 | 2003-12-23 | 5d |  |  |  |
| 620 | 1.6.5.3.2.1.5 | SEPT-NS FM 2 Mechanical Integration | 5d | 2004-01-26 A | 2004-01-30 A | 618 | 100% |  | 2004-01-26 | 2004-01-30 | 5d |  |  |  |
| 621 | 1.6.5.3.2.1.6 | SEPT-E FM 2 Mechanical Integration | 13d | 2003-12-24 A | 2004-01-13 A | 619 | 100% |  | 2003-12-24 | 2004-01-13 | 13d |  |  |  |
| 622 | 1.6.5.3.2.1.7 | Repair SEPT-NS FM 2 Electronic Board for use as Spare | 104d | 2004-04-06 A | 2004-08-31 | 668SS | 59% | 43d | 2004-04-06 | 2004-06-14 | 49d | 19d | 0d |  |

Notes:
- 622: The repair task duration is not determined yet and is waiting for the new Actel Programming software to get to Europe. (after May 19th)

| ID | WBS | Task | Duration | Start | Finish | Predecessors | Complete | Remaining | Baseline start | Baseline finish | Baseline duration | Total slack | Free slack | Constraint | Calendar | Text1 |
| --- | --- | --- | --- | --- | --- | --- | --- | --- | --- | --- | --- | --- | --- | --- | --- | --- |
| 623 | 1.6.5.3.2.2 | **Spare** | 94d | 2004-04-26 A | 2004-09-07 |  | 89% | 9.89d | 2004-04-26 | 2004-05-21 | 20d | 19d |  |  |  |  |
| 624 | 1.6.5.3.2.2.1 | SEPT Flight Spare Electronics Test | 5d | 2004-04-26 A | 2004-04-30 A | 613 | 100% |  | 2004-04-26 | 2004-04-30 | 5d |  |  | start no earlier than 2004-04-26 |  |  |
| 625 | 1.6.5.3.2.2.2 | Coat SEPT FS Electronics Board | 29d | 2004-05-10 A | 2004-06-18 A | 624 | 100% |  | 2004-05-10 | 2004-05-14 | 5d |  |  | start no earlier than 2004-05-10 |  |  |
| 626 | 1.6.5.3.2.2.3 | SEPT FS Mechanical Integration | 4d | 2004-09-01 | 2004-09-07 | 625, 622 |  |  | 2004-05-17 | 2004-05-21 | 5d | 19d |  |  |  |  |
| 627 | 1.6.5.4 | **Integration & Test** | 218d | 2004-01-12 A | 2004-11-19 |  | 62% | 83.26d | 2004-01-12 | 2004-07-26 | 138d | -26d | 0d |  |  |  |
| 628 | 1.6.5.4.1 | **FM 1** | 212d | 2004-01-12 A | 2004-11-10 |  | 62% | 80.97d | 2004-01-12 | 2004-07-26 | 138d | -26d | 0d |  |  |  |
| 629 | 1.6.5.4.1.1 | **SEPT-NS** | 203d | 2004-01-26 A | 2004-11-10 |  | 62% | 77.53d | 2004-01-26 | 2004-07-26 | 129d | -26d | 0d |  |  |  |
| 630 | 1.6.5.4.1.1.1 | SEPT-NS FM 1 Integration & Test | 5d | 2004-01-26 A | 2004-01-30 A | 600 | 100% |  | 2004-01-26 | 2004-01-30 | 5d |  |  | start no earlier than 2004-01-26 |  |  |
| 631 | 1.6.5.4.1.1.2 | Muon and Radioactive Source Test | 5d | 2004-02-02 A | 2004-02-06 A | 630 | 100% |  | 2004-02-02 | 2004-02-06 | 5d |  |  |  |  |  |
| 632 | 1.6.5.4.1.1.3 | SEPT-NS FM 1 Vibration | 4d | 2004-02-19 A | 2004-02-24 A | 631 | 100% |  | 2004-02-17 | 2004-02-20 | 4d |  |  | start no earlier than 2004-02-19 |  | MS-SEP |
| 633 | 1.6.5.4.1.1.4 | SEPT-NS FM 1 Thermal Vac | 11d | 2004-02-27 A | 2004-03-12 A | 632FS+2d | 100% |  | 2004-02-25 | 2004-03-08 | 9d |  |  |  |  |  |
| 634 | 1.6.5.4.1.1.5 | SEPT-NS FM 1 Bake Out | 2d | 2004-03-05 A | 2004-03-08 A | 633FS-6d | 100% |  | 2004-03-09 | 2004-03-10 | 2d |  |  |  |  |  |
| 635 | 1.6.5.4.1.1.6 | **SEPT-NS FM 1 Repair** | 82d | 2004-04-06 A | 2004-07-30 | 634FS+20d | 76% | 20d | 2004-04-06 | 2004-07-30 | 82d | -20d | 0d |  |  |  |
| 636 | 1.6.5.4.1.1.6.1 | SEPT-NS FM 1 Initial Repair | 45d | 2004-04-06 A | 2004-06-08 A |  | 100% |  | 2004-04-06 | 2004-06-08 | 45d |  |  |  |  |  |
| 637 | 1.6.5.4.1.1.6.2 | SEPT-NS FM 1 Titanium Parts Repair (GSFC) | 17d | 2004-06-09 A | 2004-07-01 A | 636 | 100% |  | 2004-06-09 | 2004-07-01 | 17d |  |  |  |  |  |
| 638 | 1.6.5.4.1.1.6.3 | SEPT-NS FM 1 Final Repair | 20d | 2004-07-02 | 2004-07-30 | 637 |  |  | 2004-07-02 | 2004-07-30 | 20d | -31d | 0d |  |  |  |
| 639 | 1.6.5.4.1.1.7 | SEPT-NS FM 1 Post Repair Integration & Test | 5d | 2004-08-02 | 2004-08-06 | 635 |  |  | 2004-08-02 | 2004-08-06 | 5d | -31d | 0d |  |  |  |
| 640 | 1.6.5.4.1.1.8 | Cleaning, Packing, Customs, Transport | 5d | 2004-08-16 | 2004-08-20 | 639, 673SS |  |  | 2004-08-16 | 2004-08-20 | 5d | -31d | 0d |  |  |  |
| 641 | 1.6.5.4.1.1.9 | SEPT-NS FM 1 Install Thermal H/W (GSFC) | 4d | 2004-10-06 | 2004-10-12 | 19 |  |  | 2004-09-21 | 2004-09-24 | 4d | -26d | 0d |  |  |  |
| 642 | 1.6.5.4.1.1.10 | SEPT-NS FM 1 Thermal Balance (at GSFC after Suite EMC) | 10d | 2004-10-13 | 2004-10-26 | 641 |  |  | 2004-07-13 | 2004-07-26 | 10d | -26d | 0d |  |  |  |
| 643 | 1.6.5.4.1.1.11 | SEPT-NS FM 1 Post Repair Vibration (ESTEC) | 5d | 2004-10-27 | 2004-11-02 | 642 |  |  | 2004-11-09 | 2004-11-16 | 5d | -26d | 0d |  |  |  |
| 644 | 1.6.5.4.1.1.12 | SEPT-NSFM 1 Post Repair Thermal Vac (ESTEC) | 6d | 2004-11-03 | 2004-11-10 | 643 |  |  | 2004-11-17 | 2004-11-24 | 6d | -27d | 0d |  | Internation Work Schedule |  |
| 645 | 1.6.5.4.1.2 | **SEPT-E** | 212d | 2004-01-12 A | 2004-11-10 |  | 62% | 80.97d | 2004-01-12 | 2004-07-26 | 138d | -26d | 0d |  |  |  |
| 646 | 1.6.5.4.1.2.1 | SEPT-E FM 1 Integration & Test | 5d | 2004-01-12 A | 2004-01-16 A | 601 | 100% |  | 2004-01-12 | 2004-01-16 | 5d |  |  |  |  |  |
| 647 | 1.6.5.4.1.2.2 | Muon and Radioactive Source Test | 5d | 2004-01-29 A | 2004-02-04 A | 646 | 100% |  | 2004-01-29 | 2004-02-04 | 5d |  |  | start no earlier than 2004-01-29 |  |  |
| 648 | 1.6.5.4.1.2.3 | SEPT-E FM 1 Vibration | 4d | 2004-02-19 A | 2004-02-24 A | 647, 632SS | 100% |  | 2004-02-21 | 2004-02-24 | 4d |  |  |  |  |  |
| 649 | 1.6.5.4.1.2.4 | SEPT-E FM 1 Thermal Vac | 11d | 2004-02-27 A | 2004-03-12 A | 648, 633SS | 100% |  | 2004-02-25 | 2004-03-08 | 9d |  |  |  |  |  |
| 650 | 1.6.5.4.1.2.5 | SEPT-E FM 1 Bake Out | 2d | 2004-03-05 A | 2004-03-08 A | 649FS-6d | 100% |  | 2004-03-09 | 2004-03-10 | 2d |  |  |  |  |  |

Notes:
- 632: There was a failure on the SEPT door during Vibration Test. Vibration Test will be repeated once the fix to the door is implemented. Time and place is TBD.
- 648: There was a failure on the SEPT door during Vibration Test. Vibration Test will be repeated once the fix to the door is implemented. Time and place is TBD.

| ID | WBS | Task | Duration | Start | Finish | Predecessors | Complete | Remaining | Baseline start | Baseline finish | Baseline duration | Total slack | Free slack | Constraint | Calendar |
| --- | --- | --- | --- | --- | --- | --- | --- | --- | --- | --- | --- | --- | --- | --- | --- |
| 651 | 1.6.5.4.1.2.6 | **SEPT-E FM 1 Repair** | 82d | 2004-04-06 A | 2004-07-30 | 650FS+20d | 76% | 20d | 2004-04-06 | 2004-07-30 | 82d | -20d | 0d |  |  |
| 652 | 1.6.5.4.1.2.6.1 | SEPT-E FM 1 Initial Repair | 45d | 2004-04-06 A | 2004-06-08 A |  | 100% |  | 2004-04-06 | 2004-06-08 | 45d |  |  |  |  |
| 653 | 1.6.5.4.1.2.6.2 | SEPT-E FM 1 Titanium Parts Repair (at GSFC then shipped back to Kiel) | 17d | 2004-06-09 A | 2004-07-01 A | 652 | 100% |  | 2004-06-09 | 2004-07-01 | 17d |  |  |  |  |
| 654 | 1.6.5.4.1.2.6.3 | SEPT-E FM 1 Final Repair | 20d | 2004-07-02 | 2004-07-30 | 653 |  |  | 2004-07-02 | 2004-07-30 | 20d | -31d | 0d |  |  |
| 655 | 1.6.5.4.1.2.7 | SEPT-E FM 1 Post Repair Integration & Test | 5d | 2004-08-02 | 2004-08-06 | 651 |  |  | 2004-08-02 | 2004-08-06 | 5d | -31d | 0d |  |  |
| 656 | 1.6.5.4.1.2.8 | Cleaning, Packing, Customs, Transport | 5d | 2004-08-16 | 2004-08-20 | 655, 689SS |  |  | 2004-08-16 | 2004-08-20 | 5d | -31d | 0d |  |  |
| 657 | 1.6.5.4.1.2.9 | SEPT-E FM 1 Install Thermal H/W (GSFC) | 4d | 2004-10-06 | 2004-10-12 | 19 |  |  | 2004-09-21 | 2004-09-24 | 4d | -26d | 0d |  |  |
| 658 | 1.6.5.4.1.2.10 | SEPT-E FM 1Thermal Balance (at GSFC after Suite EMC) | 10d | 2004-10-13 | 2004-10-26 | 657, 691SS |  |  | 2004-07-13 | 2004-07-26 | 10d | -26d | 0d |  |  |
| 659 | 1.6.5.4.1.2.11 | SEPT-E FM1 Post Repair Vibration (ESTEC) | 5d | 2004-10-27 | 2004-11-02 | 658 |  |  | 2004-11-09 | 2004-11-16 | 5d | -26d | 0d |  |  |
| 660 | 1.6.5.4.1.2.12 | SEPT-E FM1 Post Repair Thermal Vac (ESTEC) | 6d | 2004-11-03 | 2004-11-10 | 659 |  |  | 2004-11-17 | 2004-11-24 | 6d | -27d | 0d |  | Internation Work Schedule |
| 661 | 1.6.5.4.2 | **FM 2** | 218d | 2004-01-12 A | 2004-11-19 |  | 62% | 83.26d | 2004-01-12 | 2004-03-19 | 48d | -26d | 0d |  |  |
| 662 | 1.6.5.4.2.1 | **SEPT-NS** | 213d | 2004-01-20 A | 2004-11-19 |  | 62% | 80.24d | 2004-01-20 | 2004-03-19 | 43d | -26d | 0d |  |  |
| 663 | 1.6.5.4.2.1.1 | SEPT-NS FM 2 Integration & Test | 8d | 2004-01-20 A | 2004-01-29 A | 603 | 100% |  | 2004-01-20 | 2004-01-29 | 8d |  |  |  |  |
| 664 | 1.6.5.4.2.1.2 | Muon and Radioactive Source Test | 6d | 2004-01-30 A | 2004-02-06 A | 663 | 100% |  | 2004-01-30 | 2004-02-06 | 6d |  |  |  |  |
| 665 | 1.6.5.4.2.1.3 | SEPT-NS FM 2 Vibration | 4d | 2004-02-19 A | 2004-02-24 A | 664, 632SS | 100% |  | 2004-02-17 | 2004-02-20 | 4d |  |  |  |  |
| 666 | 1.6.5.4.2.1.4 | SEPT-NS FM 2 Thermal Vac | 9d | 2004-03-05 A | 2004-03-17 A | 665 | 100% |  | 2004-03-09 | 2004-03-17 | 9d |  |  | start no earlier than 2004-03-05 |  |
| 667 | 1.6.5.4.2.1.5 | SEPT-NS FM 2 Bake Out | 2d | 2004-03-12 A | 2004-03-15 A | 666FS-4d | 100% |  | 2004-03-18 | 2004-03-19 | 2d |  |  |  |  |
| 668 | 1.6.5.4.2.1.6 | **SEPT-NS FM 2 Repair** | 82d | 2004-04-06 A | 2004-07-30 | 667FS+15d | 76% | 20d | 2004-04-06 | 2004-07-30 | 82d | -20d | 0d |  |  |
| 669 | 1.6.5.4.2.1.6.1 | SEPT-NS FM 2 Initial Repair | 45d | 2004-04-06 A | 2004-06-08 A |  | 100% |  | 2004-04-06 | 2004-06-08 | 45d |  |  |  |  |
| 670 | 1.6.5.4.2.1.6.2 | SEPT-NS FM 2 Titanium Parts Repair (at GSFC then shipped back to Kiel) | 17d | 2004-06-09 A | 2004-07-01 A | 669 | 100% |  | 2004-06-09 | 2004-07-01 | 17d |  |  |  |  |
| 671 | 1.6.5.4.2.1.6.3 | SEPT-NS FM 2 Final Repair | 20d | 2004-07-02 | 2004-07-30 | 670 |  |  | 2004-07-02 | 2004-07-30 | 20d | -26d | 0d |  |  |
| 672 | 1.6.5.4.2.1.7 | SEPT-NS FM 2 Post Repair Integration & Test | 5d | 2004-08-09 | 2004-08-13 | 625, 668, 639 |  |  | 2004-08-09 | 2004-08-13 | 5d | -31d | 0d |  |  |
| 673 | 1.6.5.4.2.1.8 | Cleaning, Packing, Customs, Transport | 5d | 2004-08-16 | 2004-08-20 | 672 |  |  | 2004-08-16 | 2004-08-20 | 5d | -31d | 0d |  |  |
| 674 | 1.6.5.4.2.1.9 | SEPT-NS FM 2 Install Thermal H/W (GSFC) | 4d | 2004-10-06 | 2004-10-12 | 673, 641SS |  |  | 2004-10-20 | 2004-10-25 | 4d | -20d | 0d |  |  |
| 675 | 1.6.5.4.2.1.10 | SEPT-NS FM 2 Thermal Balance (GSFC) | 10d | 2004-10-13 | 2004-10-26 | 674 |  |  | 2004-07-13 | 2004-07-26 | 10d | -20d | 0d |  |  |
| 676 | 1.6.5.4.2.1.11 | SEPT-NS FM 2 Post Repair Vibration (ESTEC) | 5d | 2004-10-27 | 2004-11-02 | 675 |  |  | 2004-11-09 | 2004-11-16 | 5d | -20d | 0d |  |  |
| 677 | 1.6.5.4.2.1.12 | SEPT-NS FM 2 Post Repair Thermal Vac (ESTEC) | 6d | 2004-11-12 | 2004-11-19 | 676, 644 |  |  | 2004-11-17 | 2004-11-24 | 6d | -26d | 0d |  |  |

Notes:
- 665: There was a failure on the SEPT door during Vibration Test. Vibration Test will be repeated once the fix to the door is implemented. Time and place is TBD.

| ID | WBS | Task | Type | Duration | Start | Finish | Predecessors | Complete | Remaining | Baseline start | Baseline finish | Baseline duration | Total slack | Free slack | Constraint | Text1 |
| --- | --- | --- | --- | --- | --- | --- | --- | --- | --- | --- | --- | --- | --- | --- | --- | --- |
| 678 | 1.6.5.4.2.2 | **SEPT-E** |  | 218d | 2004-01-12 A | 2004-11-19 |  | 61% | 84.44d | 2004-01-12 | 2004-03-19 | 48d | -26d | 0d |  |  |
| 679 | 1.6.5.4.2.2.1 | SEPT-E FM 2 Integration & Test |  | 5d | 2004-01-12 A | 2004-01-16 A | 646SS | 100% |  | 2004-01-12 | 2004-01-16 | 5d |  |  |  |  |
| 680 | 1.6.5.4.2.2.2 | Muon and Radioactive Source Test |  | 5d | 2004-01-29 A | 2004-02-04 A | 679, 647SS | 100% |  | 2004-01-29 | 2004-02-04 | 5d |  |  |  |  |
| 681 | 1.6.5.4.2.2.3 | SEPT-E FM 2 Vibration |  | 4d | 2004-02-19 A | 2004-02-24 A | 680, 632SS | 100% |  | 2004-02-21 | 2004-02-24 | 4d |  |  |  |  |
| 682 | 1.6.5.4.2.2.4 | SEPT-E FM 2 Thermal Vac |  | 9d | 2004-03-05 A | 2004-03-17 A | 681, 666SS | 100% |  | 2004-03-09 | 2004-03-17 | 9d |  |  |  |  |
| 683 | 1.6.5.4.2.2.5 | SEPT-E FM 2 Bake Out |  | 2d | 2004-03-12 A | 2004-03-15 A | 682FS-4d | 100% |  | 2004-03-18 | 2004-03-19 | 2d |  |  |  |  |
| 684 | 1.6.5.4.2.2.6 | **SEPT-E FM 2 Repair** |  | 82d | 2004-04-06 A | 2004-07-30 | 683FS+15d | 76% | 20d | 2004-04-06 | 2004-07-30 | 82d | -20d | 0d |  |  |
| 685 | 1.6.5.4.2.2.6.1 | SEPT-E FM 2 Initial Repair |  | 45d | 2004-04-06 A | 2004-06-08 A |  | 100% |  | 2004-04-06 | 2004-06-08 | 45d |  |  |  |  |
| 686 | 1.6.5.4.2.2.6.2 | SEPT-E FM 2 Titanium Parts Repair (at GSFC then shipped back to Kiel) |  | 17d | 2004-06-09 A | 2004-07-01 A | 685 | 100% |  | 2004-06-09 | 2004-07-01 | 17d |  |  |  |  |
| 687 | 1.6.5.4.2.2.6.3 | SEPT-E FM 2 Final Repair |  | 20d | 2004-07-02 | 2004-07-30 | 686 |  |  | 2004-07-02 | 2004-07-30 | 20d | -26d | 0d |  |  |
| 688 | 1.6.5.4.2.2.7 | SEPT-E FM 2 Post Repair Integration & Test |  | 5d | 2004-08-09 | 2004-08-13 | 686, 684, 655 |  |  | 2004-08-09 | 2004-08-13 | 5d | -31d | 0d |  |  |
| 689 | 1.6.5.4.2.2.8 | Cleaning, Packing, Customs, Transport |  | 5d | 2004-08-16 | 2004-08-20 | 688 |  |  | 2004-08-16 | 2004-08-20 | 5d | -31d | 0d |  |  |
| 690 | 1.6.5.4.2.2.9 | SEPT-E FM 2 Install Thermal H/W (GSFC) |  | 4d | 2004-10-06 | 2004-10-12 | 657SS |  |  | 2004-10-20 | 2004-10-25 | 4d | -26d | 0d |  |  |
| 691 | 1.6.5.4.2.2.10 | SEPT-E FM 2 Thermal Balance (GSFC) |  | 10d | 2004-10-13 | 2004-10-26 | 690 |  |  | 2004-07-13 | 2004-07-26 | 10d | -26d | 0d |  |  |
| 692 | 1.6.5.4.2.2.11 | SEPT-E FM 2 Post Repair Vibration (ESTEC) |  | 5d | 2004-10-27 | 2004-11-02 | 691 |  |  | 2004-11-09 | 2004-11-16 | 5d | -20d | 0d |  |  |
| 693 | 1.6.5.4.2.2.12 | SEPT-E FM 2 Post Repair Thermal Vac (ESTEC) |  | 6d | 2004-11-12 | 2004-11-19 | 692, 660 |  |  | 2004-11-17 | 2004-11-24 | 6d | -26d | 0d |  |  |
| 694 | 1.6.6 | **SIT - UMD** |  | 387d | 2003-06-02 A | 2004-12-14 |  | 82% | 70.97d | 2003-06-02 | 2004-10-20 | 351d | -36d | 0d |  |  |
| 695 | 1.6.6.1 | **Deliveries** |  | 61d | 2004-09-16 | 2004-12-14 |  |  |  | 2004-06-18 | 2004-10-12 | 81d | -40d | 0d |  |  |
| 696 | 1.6.6.1.1 | Deliver SIT FM 1 to CIT for SEP I&T and Suite EMC |  | 2d | 2004-09-16 | 2004-09-17 | 452, 781 |  |  | 2004-06-18 | 2004-06-21 | 2d | -40d | 0d |  | MS-SEP |
| 697 | 1.6.6.1.2 | Deliver SIT FM 1 back to GSFC for Environmental Testing (after EMC Test) |  | 2d | 2004-10-06 | 2004-10-07 | 19, 474 |  |  | 2004-07-13 | 2004-07-14 | 2d | -37d | 0d |  | MS-SEP |
| 698 | 1.6.6.1.3 | Final Delivery of SIT FM 1 to APL |  | 1d | 2004-12-01 | 2004-12-01 | 815 |  |  | 2004-09-01 | 2004-09-01 | 1d | -37d | 0d |  | MS-SEP |
| 699 | 1.6.6.1.4 | Final Delivery of SIT FM 2 to CIT for Suie EMC |  | 1d | 2004-12-14 | 2004-12-14 | 823, 829 |  |  | 2004-10-12 | 2004-10-12 | 1d | -36d | 0d |  | MS-SEP |
| 700 | 1.6.6.2 | **ACTEL - for SIT Logic Board** |  | 1d | 2004-05-24 A | 2004-05-24 A |  | 100% |  | 2004-02-27 | 2004-03-12 | 11d |  |  |  |  |
| 701 | 1.6.6.2.1 | Burn Final SIT ACTEL Chip w/latest algorithm (at GSFC) |  | 1d | 2004-05-24 A | 2004-05-24 A |  | 100% |  | 2004-02-27 | 2004-02-27 | 1d |  |  | start no earlier than 2004-05-24 |  |
| 702 | 1.6.6.2.2 | Evaluate (Test) SIT Final ACTEL Chip | milestone | 0d | 2004-05-24 A | 2004-05-24 A | 701 | 100% |  | 2004-03-01 | 2004-03-12 | 10d |  |  |  |  |

Notes:
- 681: There was a failure on the SEPT door during Vibration Test. Vibration Test will be repeated once the fix to the door is implemented. Time and place is TBD.
- 701: SIT Actel design review held 4/30 by Rod Barto. Relayout of the board possible. Reccomend performing a funtional test on FM1 with the Flight ACTEL to analyze possible ground bounce issues. Tech can not burn chip until the new algorithm is released after 5/19.

| ID | WBS | Task | Type | Duration | Start | Finish | Predecessors | Complete | Remaining | Baseline start | Baseline finish | Baseline duration | Total slack | Free slack | Constraint |
| --- | --- | --- | --- | --- | --- | --- | --- | --- | --- | --- | --- | --- | --- | --- | --- |
| 703 | 1.6.6.3 | **TOF Boards** |  | 119d | 2004-02-12 A | 2004-07-30 |  | 88% | 13.84d | 2004-02-12 | 2004-03-11 | 20d | -10d | 0d |  |
| 704 | 1.6.6.3.1 | Receive Analog and Digital TOF Boards (FM 1) | milestone | 0d | 2004-02-12 A | 2004-02-12 A |  | 100% |  | 2004-02-12 | 2004-02-12 | 0d |  |  | start no earlier than 2004-02-12 |
| 705 | 1.6.6.3.2 | Receive Analog and Digital TOF Boards (FM 2) |  | 20d | 2004-03-25 A | 2004-05-28 A | 708FS+32d | 100% |  | 2004-03-15 | 2004-04-09 | 20d |  |  |  |
| 706 | 1.6.6.3.3 | **Test** |  | 108d | 2004-03-01 A | 2004-07-30 |  | 78% | 23.48d | 2004-02-12 | 2004-03-11 | 20d | -10d | 0d |  |
| 707 | 1.6.6.3.3.1 | **FM 1** |  | 18d | 2004-03-01 A | 2004-03-24 A |  | 100% |  | 2004-02-12 | 2004-02-26 | 10d |  |  |  |
| 708 | 1.6.6.3.3.1.1 | FM 1 TOF Boards Functional Test |  | 18d | 2004-03-01 A | 2004-03-24 A | 704 | 100% |  | 2004-02-12 | 2004-02-26 | 10d |  |  | start no earlier than 2004-03-01 |
| 709 | 1.6.6.3.3.2 | **FM 2** |  | 5d | 2004-07-26 | 2004-07-30 |  |  |  | 2004-02-27 | 2004-03-11 | 10d | -10d | 0d |  |
| 710 | 1.6.6.3.3.2.1 | FM 2 TOF Boards Functional Test |  | 5d | 2004-07-26 | 2004-07-30 | 704, 705FS+38d |  |  | 2004-02-27 | 2004-03-11 | 10d | -10d | 0d |  |
| 711 | 1.6.6.4 | **Energy Board** |  | 143d | 2003-11-10 A | 2004-06-04 A |  | 100% |  | 2003-11-10 | 2004-04-02 | 99d |  |  |  |
| 712 | 1.6.6.4.1 | **Assembly** |  | 114d | 2003-11-10 A | 2004-04-23 A |  | 100% |  | 2003-11-10 | 2004-02-20 | 69d |  |  |  |
| 713 | 1.6.6.4.1.1 | **FM 1** |  | 92d | 2003-11-10 A | 2004-03-24 A |  | 100% |  | 2003-11-10 | 2004-02-20 | 69d |  |  |  |
| 714 | 1.6.6.4.1.1.1 | Assemble FM 1 Energy Board |  | 92d | 2003-11-10 A | 2004-03-24 A |  | 100% |  | 2003-11-10 | 2004-02-20 | 69d |  |  | start no earlier than 2003-11-10 |
| 715 | 1.6.6.4.1.2 | **FM 2** |  | 114d | 2003-11-10 A | 2004-04-23 A |  | 100% |  | 2003-11-10 | 2004-02-20 | 69d |  |  |  |
| 716 | 1.6.6.4.1.2.1 | Assemble FM 2 Energy Board |  | 82d | 2003-11-10 A | 2004-04-23 A | 714FF+22d | 100% |  | 2003-11-10 | 2004-02-20 | 69d |  |  |  |
| 717 | 1.6.6.4.2 | **Test** |  | 51d | 2004-03-25 A | 2004-06-04 A |  | 100% |  | 2004-02-23 | 2004-04-02 | 30d |  |  |  |
| 718 | 1.6.6.4.2.1 | **FM 1** |  | 50d | 2004-03-25 A | 2004-06-03 A |  | 100% |  | 2004-02-23 | 2004-03-12 | 15d |  |  |  |
| 719 | 1.6.6.4.2.1.1 | Bench Test/Calibration |  | 47d | 2004-03-25 A | 2004-05-28 A | 714 | 100% |  | 2004-02-23 | 2004-03-05 | 10d |  |  |  |
| 720 | 1.6.6.4.2.1.2 | Thermal |  | 3d | 2004-06-01 A | 2004-06-03 A | 719 | 100% |  | 2004-03-08 | 2004-03-10 | 3d |  |  |  |
| 721 | 1.6.6.4.2.1.3 | Voltage Margin |  | 2d | 2004-06-01 A | 2004-06-02 A | 720SS | 100% |  | 2004-03-11 | 2004-03-12 | 2d |  |  |  |
| 722 | 1.6.6.4.2.2 | **FM 2** |  | 7d | 2004-05-26 A | 2004-06-04 A |  | 100% |  | 2004-03-15 | 2004-04-02 | 15d |  |  |  |
| 723 | 1.6.6.4.2.2.1 | FM 2 Energy Board Functional Test |  | 7d | 2004-05-26 A | 2004-06-04 A | 716, 721FS-5d | 100% |  | 2004-03-15 | 2004-04-02 | 15d |  |  |  |
| 724 | 1.6.6.5 | **Logic Board** |  | 175d | 2003-11-10 A | 2004-07-21 |  | 94% | 11.02d | 2003-11-10 | 2004-07-09 | 168d | -3d | 0d |  |
| 725 | 1.6.6.5.1 | **Design** |  | 3d | 2003-11-17 A | 2003-11-19 A |  | 100% |  | 2003-11-17 | 2003-11-19 | 3d |  |  |  |
| 726 | 1.6.6.5.1.1 | Layout new Logic Board Design |  | 3d | 2003-11-17 A | 2003-11-19 A |  | 100% |  | 2003-11-17 | 2003-11-19 | 3d |  |  | start no earlier than 2003-11-17 |

| ID | WBS | Task | Duration | Start | Finish | Predecessors | Complete | Remaining | Baseline start | Baseline finish | Baseline duration | Total slack | Free slack | Constraint |
| --- | --- | --- | --- | --- | --- | --- | --- | --- | --- | --- | --- | --- | --- | --- |
| 727 | 1.6.6.5.2 | **Fabrication** | 10d | 2004-03-08 A | 2004-03-19 A |  | 100% |  | 2004-02-09 | 2004-02-23 | 10d |  |  |  |
| 728 | 1.6.6.5.2.1 | FM 1 & FM 2 Logic Board Fabrication | 10d | 2004-03-08 A | 2004-03-19 A | 726, 736 | 100% |  | 2004-02-09 | 2004-02-23 | 10d |  |  | start no earlier than 2004-02-02 |
| 729 | 1.6.6.5.3 | **Assembly** | 35d | 2004-05-25 A | 2004-07-14 |  | 73% | 9.55d | 2004-03-09 | 2004-07-07 | 86d | -3d | 0d |  |
| 730 | 1.6.6.5.3.1 | **FM 1** | 8d | 2004-05-25 A | 2004-06-04 A |  | 100% |  | 2004-03-09 | 2004-05-27 | 58d |  |  |  |
| 731 | 1.6.6.5.3.1.1 | Assemble FM 1 Logic Board with Flight ACTELs | 8d | 2004-05-25 A | 2004-06-04 A | 738, 702 | 100% |  | 2004-03-09 | 2004-03-23 | 11d |  |  |  |
| 732 | 1.6.6.5.3.2 | **FM 2** | 3d | 2004-07-12 | 2004-07-14 |  |  |  | 2004-03-09 | 2004-07-07 | 86d | -3d | 0d |  |
| 733 | 1.6.6.5.3.2.1 | Assemble FM 2 Logic Board with Flight ACTELS | 3d | 2004-07-12 | 2004-07-14 | 738, 702, 740FS+13d |  |  | 2004-03-09 | 2004-03-23 | 11d | -3d | 0d |  |
| 734 | 1.6.6.5.4 | **Test** | 175d | 2003-11-10 A | 2004-07-21 |  | 95% | 8.49d | 2003-11-10 | 2004-07-09 | 168d | -3d | 0d |  |
| 735 | 1.6.6.5.4.1 | **ETU** | 79d | 2003-11-10 A | 2004-03-05 A |  | 100% |  | 2003-11-10 | 2004-02-06 | 60d |  |  |  |
| 736 | 1.6.6.5.4.1.1 | Test New ETU Logic Board | 79d | 2003-11-10 A | 2004-03-05 A |  | 100% |  | 2003-11-10 | 2004-02-06 | 60d |  |  | start no earlier than 2003-11-10 |
| 737 | 1.6.6.5.4.2 | **FM1 & FM 2** | 8d | 2004-03-22 A | 2004-03-31 A |  | 100% |  | 2004-02-24 | 2004-03-08 | 10d |  |  |  |
| 738 | 1.6.6.5.4.2.1 | Coupon Testing | 8d | 2004-03-22 A | 2004-03-31 A | 728 | 100% |  | 2004-02-24 | 2004-03-08 | 10d |  |  |  |
| 739 | 1.6.6.5.4.3 | **FM 1** | 11d | 2004-06-07 A | 2004-06-21 A |  | 100% |  | 2004-03-24 | 2004-06-01 | 49d |  |  |  |
| 740 | 1.6.6.5.4.3.1 | Functional Test of FM 1 Logic Board w/Flight ACTELS | 11d | 2004-06-07 A | 2004-06-21 A | 731 | 100% |  | 2004-03-24 | 2004-04-13 | 15d |  |  |  |
| 741 | 1.6.6.5.4.4 | **FM 2** | 5d | 2004-07-15 | 2004-07-21 |  |  |  | 2004-04-14 | 2004-07-09 | 62d | -3d | 0d |  |
| 742 | 1.6.6.5.4.4.1 | Functional Test of FM 2 Logic Board w/Flight ACTELS | 5d | 2004-07-15 | 2004-07-21 | 733 |  |  | 2004-04-14 | 2004-05-04 | 15d | -3d | 0d |  |
| 743 | 1.6.6.6 | **Mother Board** | 127d | 2003-12-22 A | 2004-06-22 A |  | 100% |  | 2003-12-22 | 2004-03-25 | 65d |  |  |  |
| 744 | 1.6.6.6.1 | **Design** | 67d | 2003-12-22 A | 2004-03-29 A |  | 100% |  | 2003-12-22 | 2004-02-04 | 30d |  |  |  |
| 745 | 1.6.6.6.1.1 | **FM 1 & FM 2** | 67d | 2003-12-22 A | 2004-03-29 A |  | 100% |  | 2003-12-22 | 2004-02-04 | 30d |  |  |  |
| 746 | 1.6.6.6.1.1.1 | Finalize Mother Board Layout | 30d | 2003-12-22 A | 2004-02-04 A |  | 100% |  | 2003-12-22 | 2004-02-04 | 30d |  |  | start no earlier than 2003-12-22 |
| 747 | 1.6.6.6.1.1.2 | Redesign Mother Board Layout | 17d | 2004-03-05 A | 2004-03-29 A | 746, 757 | 100% |  | 2004-03-05 | 2004-03-29 | 17d |  |  |  |
| 748 | 1.6.6.6.2 | **Fabrication** | 52d | 2004-02-05 A | 2004-04-19 A |  | 100% |  | 2004-02-05 | 2004-02-26 | 15d |  |  |  |
| 749 | 1.6.6.6.2.1 | **FM 1 & FM 2** | 52d | 2004-02-05 A | 2004-04-19 A |  | 100% |  | 2004-02-05 | 2004-02-26 | 15d |  |  |  |
| 750 | 1.6.6.6.2.1.1 | Fabricate FM 1 & FM 2 Mother Boards | 15d | 2004-02-05 A | 2004-02-26 A |  | 100% |  | 2004-02-05 | 2004-02-26 | 15d |  |  |  |
| 751 | 1.6.6.6.2.1.2 | Refabricate FM1 & FM2 Mother Boards | 15d | 2004-03-30 A | 2004-04-19 A | 757, 747 | 100% |  | 2004-03-30 | 2004-04-19 | 15d |  |  |  |

Notes:
- 731: SIT Actel design review held 4/30 by Rod Barto. Relayout of the board possible. SRAM adhesive issue will be resolved soon and will not ad to the relayout delay.

| ID | WBS | Task | Duration | Start | Finish | Predecessors | Complete | Remaining | Baseline start | Baseline finish | Baseline duration | Total slack | Free slack | Constraint |
| --- | --- | --- | --- | --- | --- | --- | --- | --- | --- | --- | --- | --- | --- | --- |
| 752 | 1.6.6.6.3 | **Assembly** | 10d | 2004-05-10 A | 2004-05-21 A |  | 100% |  | 2004-02-27 | 2004-03-11 | 10d |  |  |  |
| 753 | 1.6.6.6.3.1 | Assemble FM 1 Mother Board | 10d | 2004-05-10 A | 2004-05-21 A | 750, 758FS+9d | 100% |  | 2004-02-27 | 2004-03-11 | 10d |  |  | start no earlier than 2004-03-15 |
| 754 | 1.6.6.6.3.2 | Assemble FM 2 Mother Board | 10d | 2004-05-10 A | 2004-05-21 A | 753SS | 100% |  | 2004-02-27 | 2004-03-11 | 10d |  |  |  |
| 755 | 1.6.6.6.4 | **Test** | 82d | 2004-02-27 A | 2004-06-22 A |  | 100% |  | 2004-02-27 | 2004-03-25 | 20d |  |  |  |
| 756 | 1.6.6.6.4.1 | **FM 1 & FM 2** | 42d | 2004-02-27 A | 2004-04-26 A |  | 100% |  | 2004-02-27 | 2004-03-18 | 15d |  |  |  |
| 757 | 1.6.6.6.4.1.1 | Coupon Testing of Mother Boards | 5d | 2004-02-27 A | 2004-03-04 A |  | 100% |  | 2004-02-27 | 2004-03-18 | 15d |  |  |  |
| 758 | 1.6.6.6.4.1.2 | Coupon Testing of 2nd Mother Boards | 5d | 2004-04-20 A | 2004-04-26 A | 751 | 100% |  | 2004-04-20 | 2004-04-26 | 5d |  |  |  |
| 759 | 1.6.6.6.4.2 | **FM 1** | 7d | 2004-06-14 A | 2004-06-22 A |  | 100% |  | 2004-03-12 | 2004-03-18 | 5d |  |  |  |
| 760 | 1.6.6.6.4.2.1 | Functional Test FM 1 Mother Board | 7d | 2004-06-14 A | 2004-06-22 A | 753FS+14d | 100% |  | 2004-03-12 | 2004-03-18 | 5d |  |  |  |
| 761 | 1.6.6.6.4.3 | **FM 2** | 6d | 2004-06-15 A | 2004-06-22 A |  | 100% |  | 2004-03-19 | 2004-03-25 | 5d |  |  |  |
| 762 | 1.6.6.6.4.3.1 | Functional Test FM 2 Mother Board | 6d | 2004-06-15 A | 2004-06-22 A | 754, 760SS+1d | 100% |  | 2004-03-19 | 2004-03-25 | 5d |  |  |  |
| 763 | 1.6.6.7 | **HVPS** | 164d | 2004-01-12 A | 2004-09-01 |  | 75% | 41d | 2004-01-12 | 2004-04-27 | 75d | -36d | 0d |  |
| 764 | 1.6.6.7.1 | **Test** | 164d | 2004-01-12 A | 2004-09-01 |  | 75% | 41d | 2004-01-12 | 2004-04-27 | 75d | -36d | 0d |  |
| 765 | 1.6.6.7.1.1 | **FM 1** | 30d | 2004-01-12 A | 2004-02-24 A |  | 100% |  | 2004-01-12 | 2004-02-09 | 20d |  |  |  |
| 766 | 1.6.6.7.1.1.1 | Functional Test SIT FM 1 HVPS | 30d | 2004-01-12 A | 2004-02-24 A | 70 | 100% |  | 2004-01-12 | 2004-02-09 | 20d |  |  | start no earlier than 2004-01-12 |
| 767 | 1.6.6.7.1.2 | **FM 2** | 10d | 2004-08-19 | 2004-09-01 |  |  |  | 2004-04-14 | 2004-04-27 | 10d | -36d | 0d |  |
| 768 | 1.6.6.7.1.2.1 | Functional Test SIT FM 2 HVPS | 10d | 2004-08-19 | 2004-09-01 | 76, 762 |  |  | 2004-04-14 | 2004-04-27 | 10d | -36d | 0d |  |
| 769 | 1.6.6.8 | **Flight Software** | 235d | 2003-06-02 A | 2004-05-06 A |  | 100% |  | 2003-06-02 | 2004-04-01 | 210d |  |  |  |
| 770 | 1.6.6.8.1 | **Test** | 235d | 2003-06-02 A | 2004-05-06 A |  | 100% |  | 2003-06-02 | 2004-04-01 | 210d |  |  |  |
| 771 | 1.6.6.8.1.1 | **FM 1 & FM 2** | 235d | 2003-06-02 A | 2004-05-06 A |  | 100% |  | 2003-06-02 | 2004-04-01 | 210d |  |  |  |
| 772 | 1.6.6.8.1.1.1 | Validate SIT On-Board Code | 235d | 2003-06-02 A | 2004-05-06 A |  | 100% |  | 2003-06-02 | 2004-04-01 | 210d |  |  | start no earlier than 2003-06-02 |
| 773 | 1.6.6.9 | **Integration & Test (using ETU Telescope for FM 1)** | 174d | 2004-02-25 A | 2004-10-29 |  | 9% | 158.02d | 2004-03-31 | 2004-07-22 | 81d | -36d | 0d |  |
| 774 | 1.6.6.9.1 | **FM 1 (Flight Telescope)** | 25d | 2004-08-11 | 2004-09-15 |  |  |  | 2004-06-02 | 2004-06-17 | 12d | -25d | 0d |  |
| 775 | 1.6.6.9.1.1 | Disassemble SIT FM 1 | 1d | 2004-08-17 | 2004-08-17 | 795 |  |  | 2004-06-02 | 2004-06-02 | 1d | -8d | 0d |  |
| 776 | 1.6.6.9.1.2 | Conformal Coat SIT FM 1 Boards (includes FM 1 LVPS) | 2d | 2004-08-18 | 2004-08-19 | 775 |  |  | 2004-06-03 | 2004-06-04 | 2d | -8d | 0d |  |
| 777 | 1.6.6.9.1.3 | Reassemble SIT FM 1 | 1d | 2004-08-20 | 2004-08-20 | 776 |  |  |  |  |  | -8d | 0d |  |
| 778 | 1.6.6.9.1.4 | SIT FM 1 end-to-end test at Accelerator w/ ETU Telescope (at Brookhaven) | 3d | 2004-08-11 | 2004-08-13 | 777 |  |  | 2004-08-11 | 2004-08-13 | 3d | -8d | 0d | must start on 2004-08-11 |
| 779 | 1.6.6.9.1.5 | Reassemble SIT FM 1 with Flight Telescope | 2d | 2004-09-01 | 2004-09-02 | 412, 446, 778 |  |  | 2004-06-07 | 2004-06-07 | 1d | -40d | 0d |  |
| 780 | 1.6.6.9.1.6 | Bench Calibration SIT FM 1 w/Flight Telescope | 3d | 2004-09-03 | 2004-09-08 | 779 |  |  | 2004-06-08 | 2004-06-10 | 3d | -40d | 0d |  |
| 781 | 1.6.6.9.1.7 | Vacuum Test SIT FM 1 w/Flight Telescope | 5d | 2004-09-09 | 2004-09-15 | 780 |  |  | 2004-06-11 | 2004-06-17 | 5d | -40d | 0d |  |

Notes:
- 757: After Coupon testing a Mechnical Interface error was found in the board. The design was changed and sent out for Fabrication again.

| ID | WBS | Task | Duration | Start | Finish | Predecessors | Complete | Remaining | Baseline start | Baseline finish | Baseline duration | Total slack | Free slack | Text1 |
| --- | --- | --- | --- | --- | --- | --- | --- | --- | --- | --- | --- | --- | --- | --- |
| 782 | 1.6.6.9.2 | **FM 2** | 9d | 2004-10-19 | 2004-10-29 |  |  |  | 2004-07-12 | 2004-07-22 | 9d | -36d | 0d |  |
| 783 | 1.6.6.9.2.1 | Disassemble SIT FM 2 | 1d | 2004-10-19 | 2004-10-19 | 804 |  |  | 2004-07-12 | 2004-07-12 | 1d | -36d | 0d |  |
| 784 | 1.6.6.9.2.2 | Conformal Coat SIT FM 2 Boards | 2d | 2004-10-20 | 2004-10-21 | 783 |  |  | 2004-07-13 | 2004-07-14 | 2d | -36d | 0d |  |
| 785 | 1.6.6.9.2.3 | Reassemble SIT FM 2 | 1d | 2004-10-22 | 2004-10-22 | 784 |  |  | 2004-07-15 | 2004-07-15 | 1d | -36d | 0d |  |
| 786 | 1.6.6.9.2.4 | Post-Coat Retest SIT FM 2 | 5d | 2004-10-25 | 2004-10-29 | 785 |  |  | 2004-07-16 | 2004-07-22 | 5d | -36d | 0d |  |
| 787 | 1.6.6.9.3 | **FM 1 (ETU Telescope)** | 122d | 2004-02-25 A | 2004-08-16 |  | 22% | 95.22d | 2004-03-31 | 2004-05-21 | 38d | -8d | 0d |  |
| 788 | 1.6.6.9.3.1 | Integrate SIT FM 1 HVPS and SIT ETU Telescope Without Electronics | 3d | 2004-02-25 A | 2004-02-27 A | 766 | 100% |  | 2004-03-31 | 2004-04-02 | 3d |  |  | MS-SEP |
| 789 | 1.6.6.9.3.2 | Integrate Electronics to SIT ETU Telescope | 12d | 2004-06-23 A | 2004-07-09 | 740, 708, 760, 721, 788 | 50% | 6d | 2004-04-14 | 2004-04-15 | 2d | -8d | 0d |  |
| 790 | 1.6.6.9.3.3 | SIT FM 1 Debug | 5d | 2004-07-12 | 2004-07-16 | 789 |  |  | 2004-04-16 | 2004-04-22 | 5d | -8d | 0d |  |
| 791 | 1.6.6.9.3.4 | SIT FM 1 Bench Test | 5d | 2004-07-19 | 2004-07-23 | 790 |  |  | 2004-04-23 | 2004-04-29 | 5d | -8d | 0d |  |
| 792 | 1.6.6.9.3.5 | SIT FM 1 Alpha TEST | 5d | 2004-07-26 | 2004-07-30 | 791 |  |  | 2004-04-30 | 2004-05-06 | 5d | -8d | 0d |  |
| 793 | 1.6.6.9.3.6 | SIT FM 1 Noise Removal | 5d | 2004-08-02 | 2004-08-06 | 792 |  |  | 2004-05-07 | 2004-05-13 | 5d | -8d | 0d |  |
| 794 | 1.6.6.9.3.7 | SIT FM 1 Thermal Test | 5d | 2004-08-09 | 2004-08-13 | 793 |  |  | 2004-05-14 | 2004-05-20 | 5d | -8d | 0d |  |
| 795 | 1.6.6.9.3.8 | SIT FM 1 Functional Test | 1d | 2004-08-16 | 2004-08-16 | 794, 772 |  |  | 2004-05-21 | 2004-05-21 | 1d | -8d | 0d |  |
| 796 | 1.6.6.9.4 | **FM 2** | 31d | 2004-09-02 | 2004-10-18 |  |  |  | 2004-05-19 | 2004-07-01 | 31d | -36d | 0d |  |
| 797 | 1.6.6.9.4.1 | Integrate SIT FM 2 HVPS and SIT FM 2 Telescope Without Electronics | 3d | 2004-09-02 | 2004-09-07 | 768, 412, 446 |  |  | 2004-05-19 | 2004-05-21 | 3d | -36d | 0d | MS-SEP |
| 798 | 1.6.6.9.4.2 | Integrate Electronics to SIT FM 2 Telescope | 2d | 2004-09-08 | 2004-09-09 | 742, 710, 762, 723, 797 |  |  | 2004-05-24 | 2004-05-25 | 2d | -36d | 0d |  |
| 799 | 1.6.6.9.4.3 | SIT FM 2 Debug | 5d | 2004-09-10 | 2004-09-16 | 798 |  |  | 2004-05-26 | 2004-06-02 | 5d | -36d | 0d |  |
| 800 | 1.6.6.9.4.4 | SIT FM 2 Bench Test | 5d | 2004-09-17 | 2004-09-23 | 799 |  |  | 2004-06-03 | 2004-06-09 | 5d | -36d | 0d |  |
| 801 | 1.6.6.9.4.5 | SIT FM 2 Alpha Test | 5d | 2004-09-24 | 2004-09-30 | 800 |  |  | 2004-06-10 | 2004-06-16 | 5d | -36d | 0d |  |
| 802 | 1.6.6.9.4.6 | SIT FM 2 Noise Removal | 5d | 2004-10-01 | 2004-10-07 | 801, 793 |  |  | 2004-06-17 | 2004-06-23 | 5d | -36d | 0d |  |
| 803 | 1.6.6.9.4.7 | SIT FM 2 Thermal Test | 5d | 2004-10-08 | 2004-10-15 | 802 |  |  | 2004-06-24 | 2004-06-30 | 5d | -36d | 0d |  |
| 804 | 1.6.6.9.4.8 | SIT FM 2 Functional Test | 1d | 2004-10-18 | 2004-10-18 | 803 |  |  | 2004-07-01 | 2004-07-01 | 1d | -36d | 0d |  |
| 805 | 1.6.6.10 | Integrate SIT Door FM 1 | 1d | 2004-10-08 | 2004-10-08 | 697, 474 |  |  | 2004-08-20 | 2004-08-20 | 1d | -37d | 0d |  |
| 806 | 1.6.6.11 | Integrate SIT Door FM 2 | 1d | 2004-10-12 | 2004-10-12 | 805 |  |  | 2004-09-01 | 2004-09-01 | 1d | -23d | 0d |  |

| ID | WBS | Task | Duration | Start | Finish | Predecessors | Complete | Remaining | Baseline start | Baseline finish | Baseline duration | Total slack | Free slack | Constraint |
| --- | --- | --- | --- | --- | --- | --- | --- | --- | --- | --- | --- | --- | --- | --- |
| 807 | 1.6.6.12 | **Environmental Testing at GSFC (FM 1)** | 34d | 2004-10-12 | 2004-11-30 |  |  |  | 2004-07-15 | 2004-08-31 | 34d | -37d | 0d |  |
| 808 | 1.6.6.12.1 | SIT FM 1 Vibration and Acoustics | 10d | 2004-10-12 | 2004-10-25 | 697, 805 |  |  | 2004-07-15 | 2004-07-28 | 10d | -37d | 0d | start no earlier than 2004-08-23 |
| 809 | 1.6.6.12.2 | Functional Test | 1d | 2004-10-26 | 2004-10-26 | 808 |  |  | 2004-07-29 | 2004-07-29 | 1d | -37d | 0d |  |
| 810 | 1.6.6.12.3 | SIT FM 1 Thermal Balance | 5d | 2004-10-27 | 2004-11-02 | 809 |  |  | 2004-07-30 | 2004-08-05 | 5d | -37d | 0d |  |
| 811 | 1.6.6.12.4 | SIT FM 1 Thermal Vac | 10d | 2004-11-03 | 2004-11-17 | 810 |  |  | 2004-08-06 | 2004-08-19 | 10d | -37d | 0d |  |
| 812 | 1.6.6.12.5 | Disassemble SIT Instruments | 2d | 2004-11-18 | 2004-11-19 | 811 |  |  | 2004-08-20 | 2004-08-23 | 2d | -37d | 0d |  |
| 813 | 1.6.6.12.6 | Bake Out | 3d | 2004-11-22 | 2004-11-24 | 812 |  |  | 2004-08-24 | 2004-08-26 | 3d | -37d | 0d |  |
| 814 | 1.6.6.12.7 | Reassemble Instruments | 2d | 2004-11-26 | 2004-11-29 | 813 |  |  | 2004-08-27 | 2004-08-30 | 2d | -37d | 0d |  |
| 815 | 1.6.6.12.8 | Functional Test | 1d | 2004-11-30 | 2004-11-30 | 814 |  |  | 2004-08-31 | 2004-08-31 | 1d | -37d | 0d |  |
| 816 | 1.6.6.13 | **Environmental Testing at GSFC (FM 2)** | 29d | 2004-11-01 | 2004-12-13 |  |  |  | 2004-08-23 | 2004-10-08 | 34d | -36d | 0d |  |
| 817 | 1.6.6.13.1 | SIT FM 2 Vibration and Acoustics | 10d | 2004-11-01 | 2004-11-15 | 806, 786 |  |  | 2004-08-23 | 2004-09-03 | 10d | -36d | 0d | start no earlier than 2004-09-02 |
| 818 | 1.6.6.13.2 | Functional Test | 1d | 2004-11-16 | 2004-11-16 | 817 |  |  | 2004-09-07 | 2004-09-07 | 1d | -36d | 0d |  |
| 819 | 1.6.6.13.3 | SIT FM 2 Thermal Vac | 10d | 2004-11-17 | 2004-12-01 | 818 |  |  | 2004-09-15 | 2004-09-28 | 10d | -36d | 0d |  |
| 820 | 1.6.6.13.4 | Disassemble SIT Instruments | 2d | 2004-12-02 | 2004-12-03 | 819 |  |  | 2004-09-29 | 2004-09-30 | 2d | -36d | 0d |  |
| 821 | 1.6.6.13.5 | Bake Out | 3d | 2004-12-06 | 2004-12-08 | 820 |  |  | 2004-10-01 | 2004-10-05 | 3d | -36d | 0d |  |
| 822 | 1.6.6.13.6 | Reassemble Instruments | 2d | 2004-12-09 | 2004-12-10 | 821 |  |  | 2004-10-06 | 2004-10-07 | 2d | -36d | 0d |  |
| 823 | 1.6.6.13.7 | Functional Test | 1d | 2004-12-13 | 2004-12-13 | 822 |  |  | 2004-10-08 | 2004-10-08 | 1d | -36d | 0d |  |
| 824 | 1.6.6.14 | **Emulators/Simulators/GSE** | 231d | 2003-12-17 A | 2004-11-16 |  | 84% | 37.26d | 2003-12-17 | 2004-10-20 | 214d | -18d | 0d |  |
| 825 | 1.6.6.14.1 | **Simulators** | 104d | 2003-12-17 A | 2004-05-14 A |  | 100% |  | 2003-12-17 | 2004-04-12 | 80d |  |  |  |
| 826 | 1.6.6.14.1.1 | Labview CPU Ready | 104d | 2003-12-17 A | 2004-05-14 A |  | 100% |  | 2003-12-17 | 2004-04-12 | 80d |  |  | must start on 2003-12-17 |
| 827 | 1.6.6.14.1.2 | Test Simulator | 104d | 2003-12-17 A | 2004-05-14 A | 826SS | 100% |  | 2003-12-17 | 2004-04-12 | 80d |  |  |  |
| 828 | 1.6.6.14.2 | **GSE** | 40d | 2004-09-20 | 2004-11-16 |  |  |  | 2004-07-27 | 2004-10-20 | 60d | -18d | 0d |  |
| 829 | 1.6.6.14.2.1 | Pulse Generator | 40d | 2004-09-20 | 2004-11-16 | 696, 827 |  |  | 2004-07-27 | 2004-10-20 | 60d | -18d | 0d |  |
| 830 | 1.6.7 | **SEP Suite I&T - CIT** | 348d | 2003-08-01 A | 2004-12-20 |  | 63% | 129.81d | 2003-08-01 | 2004-10-21 | 309d | -35d | 0d |  |
| 831 | 1.6.7.1 | **ETU** | 5d | 2004-01-26 A | 2004-01-30 A |  | 100% |  | 2004-01-26 | 2004-01-30 | 5d |  |  |  |
| 832 | 1.6.7.1.1 | Complete Integration/Test of SEP Central EM with Sensors | 5d | 2004-01-26 A | 2004-01-30 A |  | 100% |  | 2004-01-26 | 2004-01-30 | 5d |  |  | start no earlier than 2004-01-26 |

| ID | WBS | Task | Duration | Start | Finish | Predecessors | Complete | Remaining | Baseline start | Baseline finish | Baseline duration | Total slack | Free slack | Text1 |
| --- | --- | --- | --- | --- | --- | --- | --- | --- | --- | --- | --- | --- | --- | --- |
| 833 | 1.6.7.2 | **FM 1 & FM 2** | 63d | 2004-06-16 A | 2004-09-14 |  | 29% | 45d | 2004-03-05 | 2004-10-21 | 162d | -36d | 0d |  |
| 834 | 1.6.7.2.1 | Generate HET integration & test procedure | 5d | 2004-06-17 A | 2004-06-23 A | 843FS-10d | 100% |  | 2004-05-20 | 2004-05-26 | 5d |  |  |  |
| 835 | 1.6.7.2.2 | Generate LET integration & test procedure | 5d | 2004-06-16 A | 2004-06-22 A | 844FS-10d | 100% |  | 2004-05-05 | 2004-05-11 | 5d |  |  |  |
| 836 | 1.6.7.2.3 | Generate SEPT integration & test procedure | 5d | 2004-08-30 | 2004-09-03 | 852FS-10d |  |  | 2004-03-05 | 2004-03-11 | 5d | -35d | 0d |  |
| 837 | 1.6.7.2.4 | Generate SEP-IDPU integration procedure | 5d | 2004-08-27 | 2004-09-02 | 846FS-10d |  |  | 2004-05-27 | 2004-06-03 | 5d | -39d | 0d |  |
| 838 | 1.6.7.2.5 | Generate SEP-IDPU test procedure | 5d | 2004-09-03 | 2004-09-10 | 837 |  |  | 2004-06-04 | 2004-06-10 | 5d | -39d | 0d |  |
| 839 | 1.6.7.2.6 | Generate SIT integration & test procedure | 5d | 2004-09-07 | 2004-09-13 | 850FS-10d |  |  | 2004-06-09 | 2004-06-15 | 5d | -35d | 0d |  |
| 840 | 1.6.7.2.7 | Generate SEP system test procedure | 5d | 2004-09-08 | 2004-09-14 | 851FS-10d |  |  | 2004-06-10 | 2004-06-16 | 5d | -40d | 0d |  |
| 841 | 1.6.7.3 | **FM 1** | 59d | 2004-06-29 A | 2004-09-21 |  | 25% | 44.25d | 2004-03-18 | 2004-06-28 | 72d | -40d | 0d | MS-SEP |
| 842 | 1.6.7.3.1 | Integrate/test SEP Central FM 1 | 2d | 2004-07-01 A | 2004-07-02 A | 482, 484, 422 | 100% |  | 2004-05-11 | 2004-05-17 | 5d |  |  |  |
| 843 | 1.6.7.3.2 | Receive & inspect HET FM 1 | 1d | 2004-06-30 A | 2004-06-30 A | 512, 516 | 100% |  | 2004-06-03 | 2004-06-03 | 1d |  |  |  |
| 844 | 1.6.7.3.3 | Integrate & test HET FM 1 | 1d | 2004-06-29 A | 2004-06-29 A | 834, 842FS-4d | 100% |  | 2004-06-10 | 2004-06-10 | 1d |  |  |  |
| 845 | 1.6.7.3.4 | Integrate & test LET FM 1 | 1d | 2004-07-02 | 2004-07-02 | 844, 835, 570 |  |  | 2004-06-09 | 2004-06-09 | 1d | -38d | 0d |  |
| 846 | 1.6.7.3.5 | Re-integrate & test HET FM 1 w/ Flight detectors | 1d | 2004-09-10 | 2004-09-10 | 513, 886 |  |  | 2004-08-05 | 2004-08-05 | 1d | -40d | 0d |  |
| 847 | 1.6.7.3.6 | Re-integrate & Test LET/SEP Central FM 1 | 1d | 2004-08-27 | 2004-08-27 | 506, 458, 463 |  |  | 2004-08-05 | 2004-08-05 | 1d | -29d | 0d |  |
| 848 | 1.6.7.3.7 | Integrate SEP FM 1 - IDPU FM 1 | 1d | 2004-09-15 | 2004-09-15 | 837, 398 |  |  | 2004-06-11 | 2004-06-11 | 1d | -42d | 0d |  |
| 849 | 1.6.7.3.8 | Test SEP FM 1 - IDPU FM 1 | 1d | 2004-09-16 | 2004-09-16 | 848, 838 |  |  | 2004-06-22 | 2004-06-22 | 1d | -42d | 0d |  |
| 850 | 1.6.7.3.9 | Receive & inspect SIT FM 1 | 1d | 2004-09-20 | 2004-09-20 | 696 |  |  | 2004-06-22 | 2004-06-22 | 1d | -40d | 0d |  |
| 851 | 1.6.7.3.10 | Integrate & test SIT FM 1 | 1d | 2004-09-21 | 2004-09-21 | 850, 839 |  |  | 2004-06-23 | 2004-06-23 | 1d | -40d | 0d |  |
| 852 | 1.6.7.3.11 | Receive & inspect SEPT FM 1 | 1d | 2004-09-13 | 2004-09-13 | 593, 594, 846 |  |  | 2004-03-18 | 2004-03-18 | 1d | -40d | 0d |  |
| 853 | 1.6.7.3.12 | Integrate & test SEPT FM 1 | 1d | 2004-09-14 | 2004-09-14 | 852, 836 |  |  | 2004-05-18 | 2004-05-18 | 1d | -40d | 0d |  |
| 854 | 1.6.7.3.13 | SEP system test FM 1 | 3d | 2004-09-17 | 2004-09-21 | 840, 853, 849, 847 |  |  | 2004-06-24 | 2004-06-28 | 3d | -42d | 0d |  |
| 855 | 1.6.7.4 | **FM 2** | 56d | 2004-06-30 A | 2004-09-17 |  | 7% | 52.27d | 2004-03-29 | 2004-08-11 | 97d | -8d | 0d | MS-SEP |
| 856 | 1.6.7.4.1 | Receive & inspect HET FM 2 | 1d | 2004-06-30 A | 2004-06-30 A | 514 | 100% |  | 2004-06-24 | 2004-06-24 | 1d |  |  |  |
| 857 | 1.6.7.4.2 | Integrate & test HET FM 2 | 1d | 2004-07-01 | 2004-07-01 | 856, 834 |  |  | 2004-06-25 | 2004-06-25 | 1d | 36d | 19d |  |
| 858 | 1.6.7.4.3 | Integrate & test LET FM 2 | 1d | 2004-07-02 | 2004-07-02 | 571, 572, 835 |  |  | 2004-06-09 | 2004-06-09 | 1d | -38d | 0d |  |
| 859 | 1.6.7.4.4 | Integrate/testSEP Central FM 2 | 5d | 2004-07-30 | 2004-08-05 | 483, 484, 422, 858, 857 |  |  | 2004-05-11 | 2004-05-17 | 5d | 17d | 2d |  |
| 860 | 1.6.7.4.5 | Re-integrate SEP FM 2 LVPS after Coat and Stake | 1d | 2004-08-10 | 2004-08-10 | 859, 144 |  |  | 2004-08-10 | 2004-08-10 | 1d | 15d |  |  |
| 861 | 1.6.7.4.6 | Re-integrate HET FM 2 after Confromal Coating | 1d | 2004-09-10 | 2004-09-10 | 860, 515 |  |  | 2004-08-05 | 2004-08-05 | 1d | -6d | 0d |  |
| 862 | 1.6.7.4.7 | Integrate SEP FM 2 - IDPU FM 2 | 1d | 2004-09-03 | 2004-09-03 | 210, 837 |  |  | 2004-06-28 | 2004-06-28 | 1d | -3d | 0d |  |
| 863 | 1.6.7.4.8 | Test SEP FM 2 - IDPU FM 2 | 1d | 2004-09-13 | 2004-09-13 | 862, 838 |  |  | 2004-06-29 | 2004-06-29 | 1d | -7d | 0d |  |
| 864 | 1.6.7.4.9 | SEP FM 2 system test | 3d | 2004-09-15 | 2004-09-17 | 840, 863, 861 |  |  | 2004-08-09 | 2004-08-11 | 3d | -8d | 0d |  |

| ID | WBS | Task | Type | Duration | Start | Finish | Predecessors | Complete | Remaining | Baseline start | Baseline finish | Baseline duration | Total slack | Free slack | Constraint | Calendar | Text1 |
| --- | --- | --- | --- | --- | --- | --- | --- | --- | --- | --- | --- | --- | --- | --- | --- | --- | --- |
| 865 | 1.6.7.5 | **Environmental Test (at JPL)** |  | 121d | 2004-06-28 A | 2004-12-20 |  | 4% | 115.92d | 2004-05-17 | 2004-09-24 | 93d | -35d | 0d |  |  |  |
| 866 | 1.6.7.5.1 | Generate Environmental Test Procedures |  | 15d | 2004-06-28 A | 2004-07-19 |  | 20% | 12d | 2004-05-17 | 2004-06-07 | 15d | 16d |  | start no earlier than 2004-06-28 |  |  |
| 867 | 1.6.7.5.2 | Manufacture test cables (JPL) |  | 20d | 2004-06-28 A | 2004-07-26 |  | 15% | 17d | 2004-06-01 | 2004-06-28 | 20d | 11d |  | start no earlier than 2004-06-28 |  |  |
| 868 | 1.6.7.5.3 | **FM 1** |  | 52d | 2004-09-23 | 2004-12-08 |  |  |  | 2004-07-23 | 2004-09-24 | 45d | -41d | 0d |  |  |  |
| 869 | 1.6.7.5.3.1 | FM 1 LET/HET/SEP Central Vibration/Acoustics Test |  | 10d | 2004-10-12 | 2004-10-25 | 19FS+3d, 866, 867, 886 |  |  | 2004-07-23 | 2004-08-05 | 10d | -42d | 0d |  |  |  |
| 870 | 1.6.7.5.3.2 | FM 1 LET/HET/SEP Central Thermal Balance Test |  | 5d | 2004-10-26 | 2004-11-01 | 869 |  |  | 2004-08-06 | 2004-08-12 | 5d | -42d | 0d |  |  |  |
| 871 | 1.6.7.5.3.3 | FM 1 LET/HET/SEP Central T/V Test |  | 15d | 2004-11-02 | 2004-11-23 | 870 |  |  | 2004-08-19 | 2004-09-09 | 15d | -42d | 0d |  |  |  |
| 872 | 1.6.7.5.3.4 | Evaluate SEP performance |  | 10d | 2004-11-24 | 2004-12-08 | 871 |  |  | 2004-09-10 | 2004-09-23 | 10d | -42d | 0d |  |  |  |
| 873 | 1.6.7.5.3.5 | Generate test reports |  | 11d | 2004-09-23 | 2004-10-07 | 872SS |  |  | 2004-09-10 | 2004-09-24 | 11d | -42d | 0d | finish no later than 2004-10-07 |  |  |
| 874 | 1.6.7.5.3.6 | Bakeout Clean SEP exterior & prepare for delivery |  | 3d | 2004-11-24 | 2004-11-29 | 871 |  |  | 2004-09-10 | 2004-09-14 | 3d | -35d | 0d |  |  |  |
| 875 | 1.6.7.5.4 | **FM 2** |  | 48d | 2004-10-12 | 2004-12-20 |  |  |  | 2004-07-23 | 2004-09-24 | 45d | -35d | 0d |  |  |  |
| 876 | 1.6.7.5.4.1 | FM 2 LET/HET/SEP Central Vibration/Acoustics Test |  | 10d | 2004-10-12 | 2004-10-25 | 864, 869SS |  |  | 2004-07-23 | 2004-08-05 | 10d | -23d | 0d |  |  |  |
| 877 | 1.6.7.5.4.2 | FM 2 LET/HET/SEP Central T/V Test |  | 15d | 2004-10-26 | 2004-11-16 | 876 |  |  | 2004-08-19 | 2004-09-09 | 15d | -23d | 0d |  |  |  |
| 878 | 1.6.7.5.4.3 | Evaluate SEP performance |  | 10d | 2004-11-17 | 2004-12-01 | 877 |  |  | 2004-09-10 | 2004-09-23 | 10d | -23d | 0d |  |  |  |
| 879 | 1.6.7.5.4.4 | Generate test reports |  | 11d | 2004-10-14 | 2004-10-28 | 878SS |  |  | 2004-09-10 | 2004-09-24 | 11d | -23d | 0d | finish no later than 2004-10-28 |  |  |
| 880 | 1.6.7.5.4.5 | Bakeout Clean SEP exterior & prepare for delivery |  | 3d | 2004-11-17 | 2004-11-19 | 877 |  |  | 2004-09-10 | 2004-09-14 | 3d | -21d | 0d |  |  |  |
| 881 | 1.6.7.5.4.6 | Integrate & test SEPT FM 2 |  | 1d | 2004-11-30 | 2004-11-30 | 880, 596, 597 |  |  | 2004-11-30 | 2004-11-30 | 1d | -26d | 0d |  |  |  |
| 882 | 1.6.7.5.4.7 | Integrate & test SIT FM 2 |  | 1d | 2004-12-15 | 2004-12-15 | 881, 699 |  |  | 2004-12-15 | 2004-12-15 | 1d | -36d | 0d |  |  |  |
| 883 | 1.6.7.5.4.8 | FM 2 EMI/EMC Test at CalTech |  | 2d | 2004-12-16 | 2004-12-17 | 874, 882 |  |  | 2004-08-12 | 2004-08-18 | 5d | -36d | 0d |  |  | MS-SEP |
| 884 | 1.6.7.5.4.9 | Deliver SEP/SIT FM 2 to APL |  | 1d | 2004-12-20 | 2004-12-20 | 883 |  |  | 2004-12-20 | 2004-12-20 | 1d | -36d | 0d |  |  |  |
| 885 | 1.6.7.6 | **Accelerator Test (at MSU)** |  | 9d | 2004-07-10 | 2004-07-22 |  |  |  | 2004-07-13 | 2004-07-19 | 5d | -42d | 0d |  |  |  |
| 886 | 1.6.7.6.1 | FM 1 LET-HET/SEP Cen end-to-end test at Accelerator |  | 3d | 2004-07-10 | 2004-07-12 | 898, 453, 845 |  |  | 2004-07-13 | 2004-07-19 | 5d | -44d | 0d | start no earlier than 2004-07-10 | Weekend |  |
| 887 | 1.6.7.6.2 | FM 2 LET/SEP Cen end-to-end test at Accelerator |  | 3d | 2004-07-10 | 2004-07-12 | 898, 858 |  |  | 2004-07-13 | 2004-07-19 | 5d | -44d | 0d | start no earlier than 2004-07-10 | Weekend |  |
| 888 | 1.6.7.6.3 | **Continue I&T for HET, LET and SEP Cen** |  | 3d | 2004-07-20 | 2004-07-22 | 887 |  |  | 2004-07-12 | 2004-07-12 | 1d | -20d | 0d |  |  |  |
| 889 | 1.6.7.6.3.1 | Detach HET LET and SEP Cen from SEP Suite |  | 1d | 2004-07-20 | 2004-07-20 | 886, 887FS+5d |  |  | 2004-07-12 | 2004-07-12 | 1d | -20d | 0d |  |  |  |
| 890 | 1.6.7.6.3.2 | Deliver HET FM 1 (Rplcmnt Detectors and Conformal Coating @ GSFC) |  | 2d | 2004-07-21 | 2004-07-22 | 889 |  |  | 2004-07-13 | 2004-07-14 | 2d | -20d | 0d |  |  |  |
| 891 | 1.6.7.6.3.3 | Deliver LET and SEP Central (Conformal Coating @ CIT) | milestone | 0d | 2004-07-20 | 2004-07-20 | 889 |  |  | 2004-07-13 | 2004-07-13 | 0d | -17d | 0d |  |  |  |
| 892 | 1.6.7.6.3.4 | Deliver HET FM 2 (Conformal Coating @ GSFC) |  | 2d | 2004-07-21 | 2004-07-22 | 889, 887 |  |  | 2004-07-13 | 2004-07-14 | 2d | 14d | 0d |  |  |  |
| 893 | 1.6.7.6.3.5 | Deliver SEP LVPS FM2 (Coat & Stake @UCB) |  | 1d | 2004-07-21 | 2004-07-21 | 889 |  |  | 2004-07-21 | 2004-07-21 | 1d | 15d | 0d |  |  |  |

| ID | WBS | Task | Duration | Start | Finish | Predecessors | Complete | Remaining | Baseline start | Baseline finish | Baseline duration | Total slack | Free slack | Constraint |
| --- | --- | --- | --- | --- | --- | --- | --- | --- | --- | --- | --- | --- | --- | --- |
| 894 | 1.6.7.7 | **GSE** | 305d | 2003-08-01 A | 2004-10-18 |  | 82% | 54.66d | 2003-08-01 | 2004-10-15 | 305d | 8d |  |  |
| 895 | 1.6.7.7.1 | **End-to-End Test Equipment** | 218d | 2003-08-11 A | 2004-06-22 A |  | 100% |  | 2003-08-11 | 2004-06-22 | 218d |  |  |  |
| 896 | 1.6.7.7.1.1 | Design | 192d | 2003-08-11 A | 2004-05-14 A |  | 100% |  | 2003-08-11 | 2004-05-14 | 192d |  |  | start no earlier than 2003-08-11 |
| 897 | 1.6.7.7.1.2 | Assemble | 21d | 2004-05-17 A | 2004-06-15 A | 896 | 100% |  | 2004-05-17 | 2004-06-15 | 21d |  |  |  |
| 898 | 1.6.7.7.1.3 | Test | 5d | 2004-06-16 A | 2004-06-22 A | 897 | 100% |  | 2004-06-16 | 2004-06-22 | 5d |  |  |  |
| 899 | 1.6.7.7.2 | **GSE software** | 305d | 2003-08-01 A | 2004-10-18 |  | 72% | 86.11d | 2003-08-01 | 2004-10-15 | 305d | 8d |  |  |
| 900 | 1.6.7.7.2.1 | Build GSE software release 2 | 232d | 2003-08-01 A | 2004-07-02 |  | 99% | 2d | 2003-08-01 | 2004-03-18 | 157d | 0d |  | must start on 2003-08-01 |
| 901 | 1.6.7.7.2.2 | Write user's guide | 10d | 2004-07-27 | 2004-08-09 | 900FS+15d |  |  | 2004-03-22 | 2004-03-31 | 8d | 26d | 0d | start no earlier than 2004-03-22 |
| 902 | 1.6.7.7.2.3 | Build GSE software release 3 | 117d | 2004-05-03 A | 2004-10-18 | 901FS-45d | 36% | 75d | 2004-05-03 | 2004-10-15 | 117d | 8d | 0d | start no earlier than 2004-05-03 |
| 903 | 1.6.7.7.2.4 | Write user's guide supplement | 20d | 2004-09-20 | 2004-10-18 | 902FS-20d |  |  | 2004-09-15 | 2004-10-15 | 22d | 8d |  | finish no later than 2004-10-28 |
| 904 | 1.7 | **SWEA and SIT Retest (after S/C Environmental Testing)** | 40d | 2005-09-27 | 2005-11-21 |  |  |  | 2005-09-27 | 2005-11-18 | 39d | 0d |  |  |
| 905 | 1.7.1 | Ship SWEA FM 1 to UCB | 3d | 2005-09-27 | 2005-09-29 |  |  |  | 2005-09-27 | 2005-09-29 | 3d | 25d | 0d | start no earlier than 2005-09-27 |
| 906 | 1.7.2 | Ship (Hand Carry) SIT FM 1 to UMD | 1d | 2005-09-27 | 2005-09-27 |  |  |  | 2005-09-27 | 2005-09-27 | 1d | 27d | 0d | start no earlier than 2005-09-27 |
| 907 | 1.7.3 | Ship SWEA FM 2 to UCB | 3d | 2005-10-04 | 2005-10-06 |  |  |  | 2005-10-04 | 2005-10-06 | 3d | 20d | 0d | start no earlier than 2005-10-04 |
| 908 | 1.7.4 | Ship (Hand Carry) SIT FM 2 to UMD | 1d | 2005-10-04 | 2005-10-04 |  |  |  | 2005-10-04 | 2005-10-04 | 1d | 22d | 0d | start no earlier than 2005-10-04 |
| 909 | 1.7.5 | Vacuum Testing of SWEA FM 1 @ UCB | 5d | 2005-09-30 | 2005-10-06 | 905 |  |  | 2005-09-30 | 2005-10-06 | 5d | 25d | 5d |  |
| 910 | 1.7.6 | Vacuum Testing of SIT FM 1 @ UMD | 5d | 2005-09-28 | 2005-10-04 | 906 |  |  | 2005-09-28 | 2005-10-04 | 5d | 27d | 5d |  |
| 911 | 1.7.7 | Vacuum Testing of SWEA FM 2 @ UCB | 5d | 2005-10-07 | 2005-10-13 | 907 |  |  | 2005-10-07 | 2005-10-13 | 5d | 20d | 0d |  |
| 912 | 1.7.8 | Vacuum Testing of SIT FM 2 @ UMD | 5d | 2005-10-05 | 2005-10-11 | 908 |  |  | 2005-10-05 | 2005-10-11 | 5d | 22d | 0d |  |
| 913 | 1.7.9 | Ship SWEA FM 1 & 2 to Launch Site for Re-integration to S/C | 3d | 2005-10-14 | 2005-10-18 | 909, 911 |  |  | 2005-10-07 | 2005-10-11 | 3d | 20d | 0d |  |
| 914 | 1.7.10 | Ship SIT FM 1 & 2 to Launch Site for Re-integration to S/C | 3d | 2005-10-12 | 2005-10-14 | 910, 912 |  |  | 2005-10-05 | 2005-10-07 | 3d | 22d | 2d |  |
| 915 | 1.7.11 | Reintegration of SWEA and SIT to S/C (at Launch Site) | 3d | 2005-10-19 | 2005-10-21 | 913, 914 |  |  | 2005-10-12 | 2005-10-14 | 3d | 20d |  |  |
| 916 | 1.7.12 | Target Date for Reintegration to S/C | 1d | 2005-11-19 | 2005-11-21 | 915 |  |  | 2005-11-18 | 2005-11-18 | 1d | 0d |  | must start on 2005-11-19 |
