# IMPACT Master Schedule

Schedule from MS Project, 2003-02-26 to 2005-11-21, status date 2004-02-29, A marks actual dates.
IMPACT Instrument Suites
NASA GSFC - STEREO
This is the IMPACT Consolidated Schedule. Creation began in October 2003 and was then put on hold and subsequently completed in January 2004. Completed tasks, redundant milestones, contingency blocks and obsolete tasks were deleted from this schedule. / Schedule was baselined on 2/18/04 with status through January 31, 2004. / Maintenance of this Schedule was transferred from Jim Rodgers to Tabitha Merchant on 03/22/04

## Calendars

- Standard: Mon-Fri 08:00-12:00, 13:00-17:00; Sat-Sun off. Exceptions (off unless hours are given): 2003-05-26, 2003-07-04, 2003-09-01, 2003-10-13, 2003-11-11, 2003-11-27, 2003-12-25, 2004-01-01, 2004-01-19, 2004-02-16, 2004-05-31, 2004-09-06, 2004-10-11, 2004-11-11, 2004-11-25.
- Boom Test Calendar: Mon-Fri 08:00-12:00, 13:00-17:00; Sat-Sun off. Exceptions (off unless hours are given): 2003-05-26, 2003-07-04, 2003-09-01, 2003-10-13, 2003-11-11, 2003-11-27, 2003-12-25, 2004-01-01, 2004-01-19, 2004-02-16, 2004-02-28 to 2004-02-29 08:00-12:00, 13:00-17:00, 2004-03-06 to 2004-03-07 08:00-12:00, 13:00-17:00, 2004-05-31, 2004-09-06, 2004-10-11, 2004-11-11, 2004-11-25.
- Weekend: Mon-Fri 08:00-12:00, 13:00-17:00; Sat-Sun off. Exceptions (off unless hours are given): 2004-07-10 to 2004-07-11 08:00-12:00, 13:00-17:00.

## Schedule

| ID | WBS | Task | Type | Duration | Start | Finish | Predecessors | Complete | Remaining | Baseline start | Baseline finish | Baseline duration | Total slack | Free slack | Constraint | Text1 |
| --- | --- | --- | --- | --- | --- | --- | --- | --- | --- | --- | --- | --- | --- | --- | --- | --- |
| 1 | 1 | **IMPACT - Dave Curtis (UCB) & Lil Reichenthal (GSFC)** |  | 699d | 2003-02-26 A | 2005-11-21 |  | 63% | 261.88d | 2003-02-26 | 2005-11-18 | 698d | 0d |  |  |  |
| 2 | 1.1 | **Suite Deliveries to APL** |  | 25d | 2004-09-21 | 2004-10-28 |  |  |  | 2004-08-13 | 2004-10-28 | 51d | 0d |  |  |  |
| 3 | 1.1.1 | FM 1 Target Delivery Date | milestone | 0d | 2004-10-07 | 2004-10-07 | 5, 7 |  |  | 2004-10-07 | 2004-10-07 | 0d | -3d | 0d | must start on 2004-10-07 | MS-BOOM |
| 4 | 1.1.2 | FM 2 Target Delivery Date | milestone | 0d | 2004-10-28 | 2004-10-28 | 8, 6 |  |  | 2004-10-28 | 2004-10-28 | 0d | 0d |  | must start on 2004-10-28 | MS-BOOM |
| 5 | 1.1.3 | Boom Suite FM 1 Ready for Delivery to APL | milestone | 0d | 2004-09-21 | 2004-09-21 | 352 |  |  | 2004-08-13 | 2004-08-13 | 0d | 11d |  |  | MS-BOOM |
| 6 | 1.1.4 | Boom Suite FM 2 Ready for Delivery to APL | milestone | 0d | 2004-10-06 | 2004-10-06 | 358 |  |  | 2004-09-28 | 2004-09-28 | 0d | 14d |  |  | MS-BOOM |
| 7 | 1.1.5 | SEP Suite FM 1 Ready for Delivery to APL | milestone | 0d | 2004-10-12 | 2004-10-12 | 781, 596, 532 |  |  | 2004-09-14 | 2004-09-14 | 0d | -3d | 0d |  | MS-SEP |
| 8 | 1.1.6 | SEP Suite FM 2 Ready for Delivery to APL | milestone | 0d | 2004-10-25 | 2004-10-25 | 788, 599 |  |  | 2004-10-12 | 2004-10-12 | 0d | 2d |  |  | MS-SEP |
| 9 | 1.2 | **Environmental Testing - PER, Impact Suite EMC, Snapshots of Boom & SEP Suite Test Flows** |  | 195d | 2004-01-14 A | 2004-10-19 |  | 11% | 173.53d | 2004-01-14 | 2004-10-05 | 186d | 282d |  |  |  |
| 10 | 1.2.1 | **Reviews (PER and TRR's) - TRR Dates are Tentative** |  | 151d | 2004-01-14 A | 2004-08-16 |  | 50% | 75.5d | 2004-01-14 | 2004-07-08 | 124d | 326d |  |  |  |
| 11 | 1.2.1.1 | Instrument PER at UCB |  | 1d | 2004-01-14 A | 2004-01-14 A |  | 100% |  | 2004-01-14 | 2004-01-14 | 1d |  |  | start no earlier than 2004-01-14 |  |
| 12 | 1.2.1.2 | TRR 1 - Prior to FM 1 SEPT Thermal Vac |  | 1d | 2004-02-13 A | 2004-02-13 A | 39SS-6d | 100% |  | 2004-02-13 | 2004-02-13 | 1d |  |  |  |  |
| 13 | 1.2.1.3 | TRR 2 - Prior to FM 1 STE-U Thermal Vac/Thermal Balance |  | 1d | 2004-04-19 A | 2004-04-19 A | 21SS-6d | 100% |  | 2004-03-25 | 2004-03-25 | 1d |  |  | start no earlier than 2004-04-19 |  |
| 14 | 1.2.1.4 | TRR 3 - Prior to FM 1 Boom Structure Vibration |  | 1d | 2004-04-19 A | 2004-04-19 A | 22SS-19d | 100% |  | 2004-04-20 | 2004-04-20 | 1d |  |  |  |  |
| 15 | 1.2.1.5 | TRR 4 - Prior to FM 1 IDPU Vibration |  | 1d | 2004-05-26 | 2004-05-26 | 23SS-5d |  |  | 2004-04-26 | 2004-04-26 | 1d | 383d |  |  |  |
| 16 | 1.2.1.6 | TRR 5 - Prior to FM 1 SWEA Vibration |  | 1d | 2004-06-29 | 2004-06-29 | 26SS-5d |  |  | 2004-05-28 | 2004-05-28 | 1d | 360d |  |  |  |
| 17 | 1.2.1.7 | TRR 6 - Prior to FM 1 Impact Suite EMC (for Boom and SEP) |  | 1d | 2004-07-28 | 2004-07-28 | 19SS-5d |  |  | 2004-06-22 | 2004-06-22 | 1d | 339d |  |  |  |
| 18 | 1.2.1.8 | TRR 7 - Prior to FM 1 SIT Vibration |  | 1d | 2004-08-16 | 2004-08-16 | 43SS-5d |  |  | 2004-07-08 | 2004-07-08 | 1d | 326d |  |  |  |
| 19 | 1.2.2 | IMPACT Suite FM 1 EMC Testing at UCB |  | 10d | 2004-08-04 | 2004-08-17 | 351, 759, 423 |  |  | 2004-06-29 | 2004-07-12 | 10d | -8d | 0d |  | MS-BOOM |
| 20 | 1.2.3 | **Boom Suite FM 1 Environmental Test Flow Snapshot - UCB** |  | 95d | 2004-04-26 | 2004-09-07 |  |  |  | 2004-04-01 | 2004-07-30 | 86d | 311d |  |  |  |
| 21 | 1.2.3.1 | STE-U Thermal Vac/Thermal Balance/Bake Out |  | 14d | 2004-04-26 | 2004-05-13 | 271SS |  |  | 2004-04-01 | 2004-04-20 | 14d | 392d | 0d |  |  |
| 22 | 1.2.3.2 | Boom Structure Vibration |  | 4d | 2004-05-14 | 2004-05-19 | 211SS |  |  | 2004-04-27 | 2004-04-30 | 4d | 388d | 0d |  |  |
| 23 | 1.2.3.3 | IDPU Vibration |  | 5d | 2004-06-03 | 2004-06-09 | 174SS |  |  | 2004-05-03 | 2004-05-07 | 5d | 374d | 0d |  |  |
| 24 | 1.2.3.4 | Boom Structure Thermal Vac & Bake Out |  | 15d | 2004-05-20 | 2004-06-10 | 212SS |  |  | 2004-05-03 | 2004-05-21 | 15d | 373d |  |  |  |
| 25 | 1.2.3.5 | IDPU Thermal Vac & Bake Out |  | 10d | 2004-06-10 | 2004-06-23 | 175SS |  |  | 2004-05-10 | 2004-05-21 | 10d | 364d |  |  |  |
| 26 | 1.2.3.6 | SWEA/STE Vibration |  | 5d | 2004-07-06 | 2004-07-12 | 337SS |  |  | 2004-06-07 | 2004-06-11 | 5d | 351d | 0d |  |  |
| 27 | 1.2.3.7 | SWEA/STE Thermal Vac/Thermal Balance/Bake Out |  | 14d | 2004-08-18 | 2004-09-07 | 338SS |  |  | 2004-07-13 | 2004-07-30 | 14d | 311d |  |  |  |

Notes:
- 1: This is the new IMPACT Consolidated Schedule. Creation began in October 2003 and was then put on hold and subsequently completed in January 2004. Completed tasks, redundant milestones, contingency blocks and obsolete tasks were deleted from this schedule. / Schedule was baselined on 2/18/04 with status through January 31, 2004.
- 7: The SEPT (FM 1) and SIT (FM 1 & 2) instruments are being delivered directly to APL after their environmental testing at GSFC and seperate from the other SEP Suite instruments (SEP Central, LET and HET).
- 8: The SEPT (FM 1) and SIT (FM 1 & 2) instruments are being delivered directly to APL after their environmental testing at GSFC and seperate from the other SEP Suite instruments (SEP Central, LET and HET).
- 11: This is the initial IMPACT PER. Additional TRR's (Test Readiness Reviews) will be scheduled and held as the suite instruments become ready for their environmental testing.
- 20: This section is a "snapshot" of the environmental test flow for the FM 1 Boom Suite. It reflects the details of the testing activities found within the body of the schedule. It was placed in the schedule to allow someone to get a quick look at the test flow and the associated dates. The tasks contained within this section are not tied to any other activities (and do not drive any other activities) and so therefore you will see large float values associated with them. It is simply a quick look at the test flow so that one does not have to filter through the schedule to locate the environmental test activities.

| ID | WBS | Task | Duration | Start | Finish | Predecessors | Complete | Remaining | Baseline start | Baseline finish | Baseline duration | Total slack | Free slack | Calendar |
| --- | --- | --- | --- | --- | --- | --- | --- | --- | --- | --- | --- | --- | --- | --- |
| 28 | 1.2.4 | **Boom Suite FM 2 Environmental Test Flow Snapshot - UCB** | 70d | 2004-06-16 | 2004-09-22 |  |  |  | 2004-04-27 | 2004-09-14 | 99d | 300d |  |  |
| 29 | 1.2.4.1 | STE-U Thermal Vac/Bake Out | 10d | 2004-06-16 | 2004-06-29 | 279SS |  |  | 2004-04-27 | 2004-05-10 | 10d | 360d |  |  |
| 30 | 1.2.4.2 | IDPU Vibration | 5d | 2004-07-15 | 2004-07-21 | 178SS |  |  | 2004-05-10 | 2004-05-14 | 5d | 344d |  |  |
| 31 | 1.2.4.3 | Boom Structure Vibration | 4d | 2004-07-06 | 2004-07-09 | 233SS |  |  | 2004-05-17 | 2004-05-20 | 4d | 352d |  |  |
| 32 | 1.2.4.4 | IDPU Thermal Vac & Bake Out | 10d | 2004-07-22 | 2004-08-04 | 179SS |  |  | 2004-05-17 | 2004-05-28 | 10d | 334d |  |  |
| 33 | 1.2.4.5 | Boom Structure Thermal Vac & Bake Out | 15d | 2004-07-12 | 2004-07-30 | 234SS |  |  | 2004-05-24 | 2004-06-14 | 15d | 337d |  |  |
| 34 | 1.2.4.6 | SWEA/STE Vibration | 5d | 2004-08-17 | 2004-08-23 | 345SS |  |  | 2004-08-09 | 2004-08-13 | 5d | 321d |  |  |
| 35 | 1.2.4.7 | SWEA/STE Thermal Vac & Bake Out | 10d | 2004-08-24 | 2004-09-07 | 346SS |  |  | 2004-08-16 | 2004-08-27 | 10d | 311d |  |  |
| 36 | 1.2.4.8 | Boom Suite FM 2 EMC | 5d | 2004-09-16 | 2004-09-22 | 357SS |  |  | 2004-09-08 | 2004-09-14 | 5d | 300d |  |  |
| 37 | 1.2.5 | **SEP Suite FM 1 Environmental Test Flow Snapshot** | 164d | 2004-02-19 A | 2004-10-07 |  | 19% | 133.36d | 2004-02-17 | 2004-09-14 | 149d | 289d |  |  |
| 38 | 1.2.5.1 | SEPT (NS & E) Vibration (in Europe) | 4d | 2004-02-19 A | 2004-02-24 A | 568SS | 100% |  | 2004-02-17 | 2004-02-24 | 8d |  |  |  |
| 39 | 1.2.5.2 | SEPT (NS & E) Thermal Vac (in Europe) | 11d | 2004-02-27 A | 2004-03-12 A | 569SS, 576SS | 100% |  | 2004-02-25 | 2004-03-08 | 9d |  |  |  |
| 40 | 1.2.5.3 | SEPT (NS & E) Bake Out (in Europe) | 2d | 2004-03-05 A | 2004-03-08 A | 570SS, 577SS | 100% |  | 2004-03-09 | 2004-03-10 | 2d |  |  |  |
| 41 | 1.2.5.4 | SEPT (NS & E) Thermal Balance (at GSFC) | 10d | 2004-08-18 | 2004-08-31 | 571SS, 578SS |  |  | 2004-07-13 | 2004-07-26 | 10d | 315d |  |  |
| 42 | 1.2.5.5 | LET/HET/SEP Cen Accelerator Test (at MSU) | 3d | 2004-07-10 | 2004-07-12 | 790SS |  |  | 2004-07-13 | 2004-07-27 | 11d | 355d |  | Weekend |
| 43 | 1.2.5.6 | SIT Vibe and Acoustics (at GSFC) | 10d | 2004-08-23 | 2004-09-03 | 714SS |  |  | 2004-07-15 | 2004-07-28 | 10d | 312d | 0d |  |
| 44 | 1.2.5.7 | LET/HET/SEP Cen Vibe and Acoustics (at JPL) | 10d | 2004-08-23 | 2004-09-03 | 776SS |  |  | 2004-07-23 | 2004-08-05 | 10d | 312d |  |  |
| 45 | 1.2.5.8 | SIT Thermal Balance (at GSFC) | 5d | 2004-09-08 | 2004-09-14 | 716SS |  |  | 2004-07-30 | 2004-08-05 | 5d | 306d |  |  |
| 46 | 1.2.5.9 | LET/HET/SEP Cen Thermal Balance (at JPL) | 5d | 2004-09-07 | 2004-09-13 | 777SS |  |  | 2004-08-06 | 2004-08-12 | 5d | 307d |  |  |
| 47 | 1.2.5.10 | SIT Thermal Vac (at GSFC) | 10d | 2004-09-15 | 2004-09-28 | 717SS |  |  | 2004-08-06 | 2004-08-19 | 10d | 296d |  |  |
| 48 | 1.2.5.11 | LET/HET/SEP Cen Thermal Vac (at JPL) | 15d | 2004-09-14 | 2004-10-04 | 778SS |  |  | 2004-08-19 | 2004-09-09 | 15d | 292d |  |  |
| 49 | 1.2.5.12 | SIT Bake Out (at GSFC) | 3d | 2004-10-01 | 2004-10-05 | 719SS |  |  | 2004-08-24 | 2004-08-26 | 3d | 291d |  |  |
| 50 | 1.2.5.13 | LET/HET/SEP Cen Bake Out (at JPL) | 3d | 2004-10-05 | 2004-10-07 | 781SS |  |  | 2004-09-10 | 2004-09-14 | 3d | 289d |  |  |
| 51 | 1.2.6 | **SEP Suite FM 2 Environmental Test Flow Snapshot** | 171d | 2004-02-19 A | 2004-10-19 |  | 17% | 141.52d | 2004-02-17 | 2004-10-05 | 164d | 282d |  |  |
| 52 | 1.2.6.1 | SEPT (NS & E) Vibe and Acoustics (in Europe) | 4d | 2004-02-19 A | 2004-02-24 A | 583SS | 100% |  | 2004-02-17 | 2004-02-24 | 8d |  |  |  |
| 53 | 1.2.6.2 | SEPT (NS & E) Thermal Vac (in Europe) | 9d | 2004-03-05 A | 2004-03-17 A | 584SS, 590SS | 100% |  | 2004-03-09 | 2004-03-17 | 9d |  |  |  |
| 54 | 1.2.6.3 | SEPT (NS & E) Bake Out (in Europe) | 2d | 2004-03-12 A | 2004-03-15 A | 585SS, 591SS | 100% |  | 2004-03-18 | 2004-03-19 | 2d |  |  |  |
| 55 | 1.2.6.4 | LET/HET/SEP Cen Accelerator Test (at MSU) | 11d | 2004-07-13 | 2004-07-27 | 793SS |  |  | 2004-07-13 | 2004-07-27 | 11d | 340d |  |  |
| 56 | 1.2.6.5 | LET/HET/SEP Cen Vibe and Acoustics (at JPL) | 10d | 2004-08-31 | 2004-09-14 | 784SS |  |  | 2004-07-23 | 2004-08-05 | 10d | 306d |  |  |
| 57 | 1.2.6.6 | SEP Suite FM 2 EMC (at Caltech) | 5d | 2004-08-24 | 2004-08-30 | 783SS |  |  | 2004-08-12 | 2004-08-18 | 5d | 316d |  |  |
| 58 | 1.2.6.7 | LET/HET/SEP Cen Thermal Vac (at JPL) | 15d | 2004-09-15 | 2004-10-05 | 785SS |  |  | 2004-08-19 | 2004-09-09 | 15d | 291d |  |  |
| 59 | 1.2.6.8 | SIT Vibe and Acoustics (at GSFC) | 10d | 2004-09-03 | 2004-09-17 | 723SS |  |  | 2004-08-23 | 2004-09-03 | 10d | 303d |  |  |
| 60 | 1.2.6.9 | SIT Thermal Balance (at GSFC) | 5d | 2004-09-21 | 2004-09-27 | 725SS |  |  | 2004-09-08 | 2004-09-14 | 5d | 297d |  |  |
| 61 | 1.2.6.10 | LET/HET/SEP Cen Bake Out (at JPL) | 3d | 2004-10-06 | 2004-10-08 | 788SS |  |  | 2004-09-10 | 2004-09-14 | 3d | 288d |  |  |
| 62 | 1.2.6.11 | SIT Thermal Vac (at GSFC) | 10d | 2004-09-28 | 2004-10-12 | 726SS |  |  | 2004-09-15 | 2004-09-28 | 10d | 287d |  |  |
| 63 | 1.2.6.12 | SIT Bake Out (at GSFC) | 3d | 2004-10-15 | 2004-10-19 | 728SS |  |  | 2004-10-01 | 2004-10-05 | 3d | 282d |  |  |

Notes:
- 28: This section is a "snapshot" of the environmental test flow for the FM 2 Boom Suite. It reflects the details of the testing activities found within the body of the schedule. It was placed in the schedule to allow someone to get a quick look at the test flow and the associated dates. The tasks contained within this section are not tied to any other activities (and do not drive any other activities) and so therefore you will see large float values associated with them. It is simply a quick look at the test flow so that one does not have to filter through the schedule to locate the environmental test activities.
- 37: This section is a "snapshot" of the environmental test flow for the FM 1 SEP Suite. It reflects the details of the testing activities found within the body of the schedule. It was placed in the schedule to allow someone to get a quick look at the test flow and the associated dates. The tasks contained within this section are not tied to any other activities (and do not drive any other activities) and so therefore you will see large float values associated with them. It is simply a quick look at the test flow so that one does not have to filter through the schedule to locate the environmental test activities.
- 38: There was a failure on the SEPT door during Vibration Test. Vibration Test will be repeated once the fix to the door is implemented. Time and place is TBD.
- 51: This section is a "snapshot" of the environmental test flow for the FM 2 SEP Suite. It reflects the details of the testing activities found within the body of the schedule. It was placed in the schedule to allow someone to get a quick look at the test flow and the associated dates. The tasks contained within this section are not tied to any other activities (and do not drive any other activities) and so therefore you will see large float values associated with them. It is simply a quick look at the test flow so that one does not have to filter through the schedule to locate the environmental test activities.
- 52: There was a failure on the SEPT door during Vibration Test. Vibration Test will be repeated once the fix to the door is implemented. Time and place is TBD.

| ID | WBS | Task | Type | Duration | Start | Finish | Predecessors | Complete | Remaining | Baseline start | Baseline finish | Baseline duration | Total slack | Free slack | Constraint | Text1 |
| --- | --- | --- | --- | --- | --- | --- | --- | --- | --- | --- | --- | --- | --- | --- | --- | --- |
| 64 | 1.3 | **Power Converters - UCB** |  | 345d | 2003-02-26 A | 2004-07-07 |  | 67% | 114.43d | 2003-02-26 | 2004-06-23 | 335d | 37d |  |  |  |
| 65 | 1.3.1 | **Deliveries** |  | 147d | 2003-12-09 A | 2004-07-07 |  | 20% | 117.6d | 2003-12-09 | 2004-04-30 | 100d | 37d |  |  |  |
| 66 | 1.3.1.1 | **FM 1** |  | 117d | 2003-12-09 A | 2004-05-25 |  | 40% | 70.2d | 2003-12-09 | 2004-04-23 | 95d | 15d |  |  |  |
| 67 | 1.3.1.1.1 | Deliver IDPU FM 1 LVPS (stays at UCB) | milestone | 0d | 2004-05-25 | 2004-05-25 | 121 |  |  | 2004-04-23 | 2004-04-23 | 0d | 15d | 0d |  | MS-BOOM |
| 68 | 1.3.1.1.2 | Deliver SEP FM 1 LVPS (to Caltech) |  | 1d | 2004-05-03 | 2004-05-03 | 125 |  |  | 2004-04-06 | 2004-04-06 | 1d | 16d |  |  | MS-SEP |
| 69 | 1.3.1.1.3 | Deliver SWEA/STE FM 1 LVPS (stays at UCB) | milestone | 0d | 2004-04-16 | 2004-04-16 | 129 |  |  | 2004-04-15 | 2004-04-15 | 0d | 22d | 20d |  | MS-BOOM |
| 70 | 1.3.1.1.4 | Deliver PLASTIC FM 1 LVPS (to UNH) |  | 2d | 2004-05-17 | 2004-05-18 | 133 |  |  | 2004-03-24 | 2004-03-25 | 2d | 16d |  | finish no later than 2004-06-10 |  |
| 71 | 1.3.1.1.5 | Deliver SIT FM 1 HVPS (to UMD) |  | 2d | 2003-12-09 A | 2003-12-10 A | 135 | 100% |  | 2003-12-09 | 2003-12-10 | 2d |  |  |  |  |
| 72 | 1.3.1.2 | **FM 2** |  | 33d | 2004-05-21 | 2004-07-07 |  |  |  | 2004-04-12 | 2004-04-30 | 15d | 2d |  |  |  |
| 73 | 1.3.1.2.1 | Deliver IDPU FM 2 LVPS (stays at UCB) | milestone | 0d | 2004-07-07 | 2004-07-07 | 140 |  |  | 2004-04-30 | 2004-04-30 | 0d | 37d | 0d |  | MS-BOOM |
| 74 | 1.3.1.2.2 | Deliver SEP FM 2 LVPS (to Caltech) |  | 1d | 2004-06-25 | 2004-06-25 | 145 |  |  | 2004-04-19 | 2004-04-19 | 1d | 37d | 0d |  | MS-SEP |
| 75 | 1.3.1.2.3 | Deliver SWEA/STE FM 2 LVPS (stays at UCB) | milestone | 0d | 2004-05-28 | 2004-05-28 | 149 |  |  | 2004-04-26 | 2004-04-26 | 0d | 29d | 15d |  | MS-BOOM |
| 76 | 1.3.1.2.4 | Deliver PLASTIC FM 2 LVPS (to UNH) |  | 2d | 2004-06-28 | 2004-06-29 | 153 |  |  | 2004-04-12 | 2004-04-13 | 2d | 16d |  | finish no later than 2004-07-21 |  |
| 77 | 1.3.1.2.5 | Deliver SIT FM 2 HVPS (to UMD) |  | 2d | 2004-05-21 | 2004-05-24 | 157 |  |  | 2004-04-12 | 2004-04-13 | 2d | 2d | 0d |  | MS-SEP |
| 78 | 1.3.2 | **Remaining Flight Procurements** |  | 95d | 2003-10-24 A | 2004-03-12 A |  | 100% |  | 2003-10-24 | 2004-02-19 | 79d |  |  |  |  |
| 79 | 1.3.2.1 | Procure IDPU Flight Printed Wiring Board |  | 10d | 2004-03-01 A | 2004-03-12 A | 85 | 100% |  | 2004-02-05 | 2004-02-19 | 10d |  |  | start no earlier than 2004-03-01 |  |
| 80 | 1.3.2.2 | Procure SEP Flight Printed Wiring Board |  | 10d | 2003-11-24 A | 2003-12-08 A | 86 | 100% |  | 2003-11-24 | 2003-12-08 | 10d |  |  | start no earlier than 2003-11-24 |  |
| 81 | 1.3.2.3 | Procure SWEA Flight Printed Wiring Board |  | 10d | 2003-12-04 A | 2003-12-17 A | 87 | 100% |  | 2003-12-04 | 2003-12-17 | 10d |  |  |  |  |
| 82 | 1.3.2.4 | Procure PLASTIC Flight Printed Wiring Board |  | 10d | 2003-10-24 A | 2003-11-06 A |  | 100% |  | 2003-10-24 | 2003-11-06 | 10d |  |  | start no earlier than 2003-10-24 |  |
| 83 | 1.3.3 | **Fabrication** |  | 239d | 2003-02-26 A | 2004-02-06 A |  | 100% |  | 2003-02-26 | 2004-02-06 | 239d |  |  |  |  |
| 84 | 1.3.3.1 | **FM 1 & FM 2** |  | 195d | 2003-02-26 A | 2003-12-03 A |  | 100% |  | 2003-02-26 | 2003-12-03 | 195d |  |  |  |  |
| 85 | 1.3.3.1.1 | Re-layout IDPU LVPS Flight Printed Wiring Board |  | 186d | 2003-02-26 A | 2003-11-19 A |  | 100% |  | 2003-02-26 | 2003-11-19 | 186d |  |  | start no earlier than 2003-02-26 |  |
| 86 | 1.3.3.1.2 | Re-layout SEP LVPS Flight Printed Wiring Board |  | 32d | 2003-09-24 A | 2003-11-07 A |  | 100% |  | 2003-09-24 | 2003-11-07 | 32d |  |  | start no earlier than 2003-09-24 |  |
| 87 | 1.3.3.1.3 | Re-layout SWEA LVPS Flight Printed Wiring Board |  | 5d | 2003-11-26 A | 2003-12-03 A |  | 100% |  | 2003-11-26 | 2003-12-03 | 5d |  |  | start no earlier than 2003-11-26 |  |

| ID | WBS | Task | Duration | Start | Finish | Predecessors | Complete | Remaining | Baseline start | Baseline finish | Baseline duration | Total slack | Free slack | Constraint |
| --- | --- | --- | --- | --- | --- | --- | --- | --- | --- | --- | --- | --- | --- | --- |
| 88 | 1.3.3.2 | **FM 1** | 45d | 2003-09-29 A | 2003-12-03 A |  | 100% |  | 2003-09-29 | 2003-12-03 | 45d |  |  |  |
| 89 | 1.3.3.2.1 | Wind IDPU LVPS FM 1 Magnets | 10d | 2003-10-17 A | 2003-10-30 A |  | 100% |  | 2003-10-17 | 2003-10-30 | 10d |  |  | start no earlier than 2003-10-17 |
| 90 | 1.3.3.2.2 | Wind SEP LVPS FM 1 Magnets | 15d | 2003-09-29 A | 2003-10-20 A |  | 100% |  | 2003-09-29 | 2003-10-20 | 15d |  |  | start no earlier than 2003-09-29 |
| 91 | 1.3.3.2.3 | Wind SWEA LVPS FM 1 Magnets | 5d | 2003-11-26 A | 2003-12-03 A |  | 100% |  | 2003-11-26 | 2003-12-03 | 5d |  |  | start no earlier than 2003-11-26 |
| 92 | 1.3.3.2.4 | Wind PLASTIC LVPS FM 1 Magnets | 45d | 2003-09-29 A | 2003-12-03 A |  | 100% |  | 2003-09-29 | 2003-12-03 | 45d |  |  | start no earlier than 2003-09-29 |
| 93 | 1.3.3.3 | **FM 2** | 28d | 2003-12-29 A | 2004-02-06 A |  | 100% |  | 2003-12-29 | 2004-02-06 | 28d |  |  |  |
| 94 | 1.3.3.3.1 | Wind HVPS FM 2 Magnets | 28d | 2003-12-29 A | 2004-02-06 A |  | 100% |  | 2003-12-29 | 2004-02-06 | 28d |  |  | start no earlier than 2003-12-29 |
| 95 | 1.3.3.3.2 | Wind IDPU LVPS FM 2 Magnets | 28d | 2003-12-29 A | 2004-02-06 A | 94SS | 100% |  | 2003-12-29 | 2004-02-06 | 28d |  |  |  |
| 96 | 1.3.3.3.3 | Wind SEP LVPS FM 2 Magnets | 28d | 2003-12-29 A | 2004-02-06 A | 94SS | 100% |  | 2003-12-29 | 2004-02-06 | 28d |  |  |  |
| 97 | 1.3.3.3.4 | Wind SWEA LVPS FM 2 Magnets | 28d | 2003-12-29 A | 2004-02-06 A | 94SS | 100% |  | 2003-12-29 | 2004-02-06 | 28d |  |  |  |
| 98 | 1.3.3.3.5 | Wind PLASTIC LVPS FM 2 Magnets | 28d | 2003-12-29 A | 2004-02-06 A | 94SS | 100% |  | 2003-12-29 | 2004-02-06 | 28d |  |  |  |
| 99 | 1.3.4 | **Assembly** | 109d | 2003-12-29 A | 2004-06-02 |  | 55% | 48.58d | 2003-12-29 | 2004-03-19 | 57d | 37d |  |  |
| 100 | 1.3.4.1 | **FM 1** | 79d | 2003-12-29 A | 2004-04-20 |  | 89% | 8.54d | 2003-12-29 | 2004-03-12 | 52d | 15d |  |  |
| 101 | 1.3.4.1.1 | Assemble IDPU FM 1 LVPS | 12d | 2004-04-05 | 2004-04-20 | 89, 113FS+2d |  |  | 2004-02-26 | 2004-03-12 | 12d | 15d | 0d |  |
| 102 | 1.3.4.1.2 | Assemble SEP FM 1 LVPS | 40d | 2004-01-12 A | 2004-03-09 A | 114, 90 | 100% |  | 2004-01-12 | 2004-02-23 | 29d |  |  | start no earlier than 2004-01-12 |
| 103 | 1.3.4.1.3 | Assemble SWEA FM 1 LVPS | 30d | 2004-02-13 A | 2004-03-26 A | 91, 115 | 100% |  | 2004-02-13 | 2004-03-04 | 14d |  |  | start no earlier than 2004-02-13 |
| 104 | 1.3.4.1.4 | Assemble PLASTIC FM 1 LVPS | 29d | 2003-12-29 A | 2004-02-09 A | 116, 92 | 100% |  | 2003-12-29 | 2004-02-09 | 29d |  |  | start no earlier than 2003-12-29 |
| 105 | 1.3.4.2 | **FM 2** | 47d | 2004-03-29 A | 2004-06-02 |  | 4% | 45.07d | 2004-02-09 | 2004-03-19 | 29d | 37d |  |  |
| 106 | 1.3.4.2.1 | Assemble IDPU FM 2 LVPS | 15d | 2004-05-12 | 2004-06-02 | 95, 119 |  |  | 2004-03-01 | 2004-03-19 | 15d | 37d | 0d | start no earlier than 2004-03-01 |
| 107 | 1.3.4.2.2 | Assemble SEP FM 2 LVPS | 15d | 2004-04-26 | 2004-05-14 | 96, 123FS+5d |  |  | 2004-02-13 | 2004-03-05 | 15d | 37d | 0d | start no earlier than 2004-02-13 |
| 108 | 1.3.4.2.3 | Assemble SWEA FM 2 LVPS | 15d | 2004-04-05 | 2004-04-23 | 97, 127 |  |  | 2004-02-24 | 2004-03-15 | 15d | 29d | 0d | start no earlier than 2004-02-24 |
| 109 | 1.3.4.2.4 | Assemble PLASTIC FM 2 LVPS | 14d | 2004-05-03 | 2004-05-20 | 98, 131 |  |  | 2004-02-09 | 2004-02-27 | 14d | 16d | 0d | start no earlier than 2004-02-09 |
| 110 | 1.3.4.2.5 | Assemble SIT FM 2 HVPS | 14d | 2004-03-29 A | 2004-04-15 | 94, 103 | 21% | 11d | 2004-02-09 | 2004-02-27 | 14d | 2d | 0d |  |
| 111 | 1.3.5 | **Testing** | 172d | 2003-10-31 A | 2004-07-07 |  | 26% | 126.52d | 2003-10-31 | 2004-06-23 | 162d | 37d |  |  |
| 112 | 1.3.5.1 | **FM 1 & FM 2** | 88d | 2003-11-24 A | 2004-03-31 A |  | 100% |  | 2003-11-24 | 2004-02-25 | 63d |  |  |  |
| 113 | 1.3.5.1.1 | Coupon Test IDPU Flight Printed Wiring Board | 4d | 2004-03-26 A | 2004-03-31 A | 79FS+9d | 100% |  | 2004-02-20 | 2004-02-25 | 4d |  |  |  |
| 114 | 1.3.5.1.2 | Coupon Test SEP Flight Printed Wiring Board | 5d | 2003-12-09 A | 2003-12-15 A | 80 | 100% |  | 2003-12-09 | 2003-12-15 | 5d |  |  |  |
| 115 | 1.3.5.1.3 | Coupon Test SWEA Flight Printed Wiring Board | 6d | 2004-01-09 A | 2004-01-16 A | 81 | 100% |  | 2004-01-09 | 2004-01-16 | 6d |  |  | start no earlier than 2004-01-09 |
| 116 | 1.3.5.1.4 | Coupon Test PLASTIC Flight Printed Wiring Board | 5d | 2003-11-24 A | 2003-12-01 A | 82 | 100% |  | 2003-11-24 | 2003-12-01 | 5d |  |  | start no earlier than 2003-11-24 |

| ID | WBS | Task | Duration | Start | Finish | Predecessors | Complete | Remaining | Baseline start | Baseline finish | Baseline duration | Total slack | Free slack | Constraint |
| --- | --- | --- | --- | --- | --- | --- | --- | --- | --- | --- | --- | --- | --- | --- |
| 117 | 1.3.5.2 | **FM 1** | 142d | 2003-10-31 A | 2004-05-25 |  | 37% | 89.44d | 2003-10-31 | 2004-06-23 | 162d | 15d |  |  |
| 118 | 1.3.5.2.1 | **IDPU** | 25d | 2004-04-21 | 2004-05-25 |  |  |  | 2004-03-15 | 2004-04-23 | 30d | 15d |  |  |
| 119 | 1.3.5.2.1.1 | Test IDPU FM 1 LVPS | 15d | 2004-04-21 | 2004-05-11 | 101 |  |  | 2004-03-15 | 2004-04-02 | 15d | 15d | 0d |  |
| 120 | 1.3.5.2.1.2 | Coat & Stake IDPU LVPS FM 1 Boards | 5d | 2004-05-12 | 2004-05-18 | 119 |  |  | 2004-04-05 | 2004-04-09 | 5d | 15d | 0d |  |
| 121 | 1.3.5.2.1.3 | Retest IDPU LVPS FM 1 Boards | 5d | 2004-05-19 | 2004-05-25 | 120 |  |  | 2004-04-12 | 2004-04-23 | 10d | 15d | 0d |  |
| 122 | 1.3.5.2.2 | **SEP** | 38d | 2004-03-10 A | 2004-04-30 |  | 42% | 22d | 2004-02-24 | 2004-04-05 | 30d | 16d |  |  |
| 123 | 1.3.5.2.2.1 | Test SEP FM 1 LVPS | 28d | 2004-03-10 A | 2004-04-16 | 102 | 57% | 12d | 2004-02-24 | 2004-03-15 | 15d | 16d | 0d |  |
| 124 | 1.3.5.2.2.2 | Coat & Stake SEP LVPS FM 1 Boards | 5d | 2004-04-19 | 2004-04-23 | 123 |  |  | 2004-03-16 | 2004-03-22 | 5d | 16d | 0d |  |
| 125 | 1.3.5.2.2.3 | Retest SEP LVPS FM 1 Boards | 5d | 2004-04-26 | 2004-04-30 | 124, 370 |  |  | 2004-03-23 | 2004-04-05 | 10d | 16d | 0d |  |
| 126 | 1.3.5.2.3 | **SWEA** | 25d | 2004-03-15 A | 2004-04-16 |  | 52% | 12d | 2004-03-05 | 2004-04-15 | 30d | 22d |  |  |
| 127 | 1.3.5.2.3.1 | Test SWEA FM 1 LVPS | 15d | 2004-03-15 A | 2004-04-02 | 103 | 87% | 2d | 2004-03-05 | 2004-03-25 | 15d | 22d | 0d |  |
| 128 | 1.3.5.2.3.2 | Coat & Stake SWEA LVPS FM 1 Boards | 5d | 2004-04-05 | 2004-04-09 | 127 |  |  | 2004-03-26 | 2004-04-01 | 5d | 22d | 0d |  |
| 129 | 1.3.5.2.3.3 | Retest SWEA LVPS FM 1 Boards | 5d | 2004-04-12 | 2004-04-16 | 128 |  |  | 2004-04-02 | 2004-04-15 | 10d | 22d | 0d |  |
| 130 | 1.3.5.2.4 | **PLASTIC** | 68d | 2004-02-10 A | 2004-05-14 |  | 19% | 55d | 2004-02-10 | 2004-03-23 | 30d | 16d |  |  |
| 131 | 1.3.5.2.4.1 | Test PLASTIC FM 1 LVPS | 58d | 2004-02-10 A | 2004-04-30 | 104 | 22% | 45d | 2004-02-10 | 2004-03-02 | 15d | 16d | 0d |  |
| 132 | 1.3.5.2.4.2 | Coat & Stake PLASTIC LVPS FM 1 Boards | 5d | 2004-05-03 | 2004-05-07 | 131 |  |  | 2004-03-03 | 2004-03-09 | 5d | 16d | 0d |  |
| 133 | 1.3.5.2.4.3 | Retest PLASTIC LVPS FM 1 Boards | 5d | 2004-05-10 | 2004-05-14 | 132 |  |  | 2004-03-10 | 2004-03-23 | 10d | 16d | 0d |  |
| 134 | 1.3.5.2.5 | **SIT** | 25d | 2003-10-31 A | 2003-12-08 A |  | 100% |  | 2003-10-31 | 2004-06-23 | 162d |  |  |  |
| 135 | 1.3.5.2.5.1 | Test SIT FM 1 HVPS | 25d | 2003-10-31 A | 2003-12-08 A |  | 100% |  | 2003-10-31 | 2003-12-08 | 25d |  |  | start no earlier than 2003-10-31 |
| 136 | 1.3.5.3 | **FM 2** | 58d | 2004-04-16 | 2004-07-07 |  |  |  | 2004-03-01 | 2004-04-30 | 45d | 2d |  |  |
| 137 | 1.3.5.3.1 | **IDPU** | 25d | 2004-06-03 | 2004-07-07 |  |  |  | 2004-03-22 | 2004-04-30 | 30d | 37d |  |  |
| 138 | 1.3.5.3.1.1 | Test IDPU FM 2 LVPS | 15d | 2004-06-03 | 2004-06-23 | 106 |  |  | 2004-03-22 | 2004-04-09 | 15d | 37d | 0d |  |
| 139 | 1.3.5.3.1.2 | Coat & Stake IDPU LVPS FM 2 Boards | 5d | 2004-06-24 | 2004-06-30 | 138 |  |  | 2004-04-12 | 2004-04-16 | 5d | 37d | 0d |  |
| 140 | 1.3.5.3.1.3 | Retest IDPU LVPS FM 2 Boards | 5d | 2004-07-01 | 2004-07-07 | 139 |  |  | 2004-04-19 | 2004-04-30 | 10d | 37d | 0d |  |

| ID | WBS | Task | Type | Duration | Start | Finish | Predecessors | Complete | Remaining | Baseline start | Baseline finish | Baseline duration | Total slack | Free slack | Constraint | Text1 |
| --- | --- | --- | --- | --- | --- | --- | --- | --- | --- | --- | --- | --- | --- | --- | --- | --- |
| 141 | 1.3.5.3.2 | **SEP** |  | 28d | 2004-05-17 | 2004-06-24 |  |  |  | 2004-03-08 | 2004-04-16 | 30d | 37d |  |  |  |
| 142 | 1.3.5.3.2.1 | Test SEP FM 2 LVPS |  | 15d | 2004-05-17 | 2004-06-07 | 107 |  |  | 2004-03-08 | 2004-03-26 | 15d | 37d | 0d |  |  |
| 143 | 1.3.5.3.2.2 | Coat & Stake SEP LVPS FM 2 Boards |  | 5d | 2004-06-08 | 2004-06-14 | 142 |  |  | 2004-03-29 | 2004-04-02 | 5d | 37d | 0d |  |  |
| 144 | 1.3.5.3.2.3 | Retest SEP LVPS FM 2 Boards |  | 5d | 2004-06-15 | 2004-06-21 | 143, 370 |  |  | 2004-04-05 | 2004-04-16 | 10d | 37d | 0d |  |  |
| 145 | 1.3.5.3.2.4 | Bakeout SEP LVPS FM 2 Boards |  | 3d | 2004-06-22 | 2004-06-24 | 144 |  |  | 2004-06-22 | 2004-06-24 | 3d | 37d | 0d |  |  |
| 146 | 1.3.5.3.3 | **SWEA** |  | 25d | 2004-04-26 | 2004-05-28 |  |  |  | 2004-03-16 | 2004-04-26 | 30d | 29d |  |  |  |
| 147 | 1.3.5.3.3.1 | Test SWEA FM 2 LVPS |  | 15d | 2004-04-26 | 2004-05-14 | 108 |  |  | 2004-03-16 | 2004-04-05 | 15d | 29d | 0d |  |  |
| 148 | 1.3.5.3.3.2 | Coat & Stake SWEA LVPS FM 2 Boards |  | 5d | 2004-05-17 | 2004-05-21 | 147 |  |  | 2004-04-06 | 2004-04-12 | 5d | 29d | 0d |  |  |
| 149 | 1.3.5.3.3.3 | Retest SWEA LVPS FM 2 Boards |  | 5d | 2004-05-24 | 2004-05-28 | 148 |  |  | 2004-04-13 | 2004-04-26 | 10d | 29d | 0d |  |  |
| 150 | 1.3.5.3.4 | **PLASTIC** |  | 25d | 2004-05-21 | 2004-06-25 |  |  |  | 2004-03-01 | 2004-04-09 | 30d | 16d |  |  |  |
| 151 | 1.3.5.3.4.1 | Test PLASTIC FM 2 LVPS |  | 15d | 2004-05-21 | 2004-06-11 | 109 |  |  | 2004-03-01 | 2004-03-19 | 15d | 16d | 0d |  |  |
| 152 | 1.3.5.3.4.2 | Coat & Stake PLASTIC LVPS FM 2 Boards |  | 5d | 2004-06-14 | 2004-06-18 | 151 |  |  | 2004-03-22 | 2004-03-26 | 5d | 16d | 0d |  |  |
| 153 | 1.3.5.3.4.3 | Retest PLASTIC LVPS FM 2 Boards |  | 5d | 2004-06-21 | 2004-06-25 | 152 |  |  | 2004-03-29 | 2004-04-09 | 10d | 16d | 0d |  |  |
| 154 | 1.3.5.3.5 | **SIT** |  | 25d | 2004-04-16 | 2004-05-20 |  |  |  | 2004-03-01 | 2004-04-09 | 30d | 2d |  |  |  |
| 155 | 1.3.5.3.5.1 | Test SIT FM 2 HVPS |  | 15d | 2004-04-16 | 2004-05-06 | 110 |  |  | 2004-03-01 | 2004-03-19 | 15d | 2d | 0d |  |  |
| 156 | 1.3.5.3.5.2 | Coat & Stake SIT FM 2 HVPS Boards |  | 5d | 2004-05-07 | 2004-05-13 | 155 |  |  | 2004-03-22 | 2004-03-26 | 5d | 2d | 0d |  |  |
| 157 | 1.3.5.3.5.3 | Retest SIT FM 2 HVPS Boards |  | 5d | 2004-05-14 | 2004-05-20 | 156 |  |  | 2004-03-29 | 2004-04-09 | 10d | 2d | 0d |  |  |
| 158 | 1.4 | **IDPU - UCB** |  | 340d | 2003-05-05 A | 2004-09-07 |  | 76% | 80.69d | 2003-05-05 | 2004-09-07 | 340d | 14d |  |  |  |
| 159 | 1.4.1 | **Deliveries** |  | 30d | 2004-06-23 | 2004-08-04 |  |  |  | 2004-04-13 | 2004-05-28 | 33d | 15d |  |  |  |
| 160 | 1.4.1.1 | IDPU FM 1 Complete (to UCB for Boom I&T, then to CIT for SEP I&T, Suite EMC, BO & Final Boom I&T) | milestone | 0d | 2004-06-23 | 2004-06-23 | 175 |  |  | 2004-05-21 | 2004-05-21 | 0d | 15d |  |  | MS-BOOM |
| 161 | 1.4.1.2 | IDPU FM 2 Complete (to CIT for SEP I&T, then to UCB for Boom I&T, Boom EMC, BO & Final Boom I&T) | milestone | 0d | 2004-08-04 | 2004-08-04 | 179 |  |  | 2004-05-28 | 2004-05-28 | 0d | 37d | 0d |  | MS-BOOM |
| 162 | 1.4.2 | **Flight Software** |  | 259d | 2003-05-05 A | 2004-05-13 |  | 90% | 25.25d | 2003-05-05 | 2004-04-13 | 237d | 85d |  |  |  |
| 163 | 1.4.2.1 | IDPU S/W Build #2.5 |  | 131d | 2003-05-05 A | 2003-11-07 A |  | 100% |  | 2003-05-05 | 2003-11-07 | 131d |  |  | start no earlier than 2003-05-05 |  |
| 164 | 1.4.2.2 | IDPU S/W Build #3 (also goes to UNH) |  | 187d | 2003-08-15 A | 2004-05-13 |  | 83% | 31d | 2003-08-15 | 2004-04-13 | 165d | 85d | 48d | start no earlier than 2003-08-15 | MS-BOOM |

| ID | WBS | Task | Type | Duration | Start | Finish | Predecessors | Complete | Remaining | Baseline start | Baseline finish | Baseline duration | Total slack | Free slack | Constraint | Text1 |
| --- | --- | --- | --- | --- | --- | --- | --- | --- | --- | --- | --- | --- | --- | --- | --- | --- |
| 165 | 1.4.3 | **GSE** |  | 301d | 2003-06-30 A | 2004-09-07 |  | 72% | 83.78d | 2003-06-30 | 2004-09-07 | 301d | 0d |  |  |  |
| 166 | 1.4.3.1 | STE Science Display |  | 27d | 2003-10-23 A | 2003-12-02 A |  | 100% |  | 2003-10-23 | 2003-12-02 | 27d |  |  | start no earlier than 2003-10-23 |  |
| 167 | 1.4.3.2 | SWEA Science Display |  | 167d | 2003-06-30 A | 2004-03-01 A |  | 100% |  | 2003-06-30 | 2004-02-23 | 162d |  |  | start no earlier than 2003-06-30 |  |
| 168 | 1.4.3.3 | GSE Continued Development (LOE) |  | 291d | 2003-07-15 A | 2004-09-07 |  | 54% | 135d | 2003-07-15 | 2004-09-07 | 291d | 0d |  | must start on 2003-07-15 |  |
| 169 | 1.4.4 | **Integration & Test** |  | 209d | 2003-10-07 A | 2004-08-04 |  | 38% | 128.62d | 2003-10-07 | 2004-05-28 | 162d | 37d |  |  |  |
| 170 | 1.4.4.1 | IDPU DCB FM 2 Board Level Testing |  | 15d | 2003-10-07 A | 2003-10-28 A |  | 100% |  | 2003-10-07 | 2003-10-28 | 15d |  |  | start no earlier than 2003-10-07 |  |
| 171 | 1.4.4.2 | IDPU DCB Clean/Stake/Coat (FM 1 & FM 2) |  | 10d | 2003-12-26 A | 2004-01-09 A | 170 | 100% |  | 2003-12-26 | 2004-01-09 | 10d |  |  | start no earlier than 2003-12-26 |  |
| 172 | 1.4.4.3 | **FM 1** |  | 20d | 2004-05-26 | 2004-06-23 |  |  |  | 2004-04-26 | 2004-05-21 | 20d | 15d |  |  |  |
| 173 | 1.4.4.3.1 | IDPU FM 1 I & T |  | 5d | 2004-05-26 | 2004-06-02 | 163, 67, 238, 282, 171 |  |  | 2004-04-26 | 2004-04-30 | 5d | 15d | 0d |  | MS-BOOM |
| 174 | 1.4.4.3.2 | IDPU FM 1 Vibration |  | 5d | 2004-06-03 | 2004-06-09 | 173 |  |  | 2004-05-03 | 2004-05-07 | 5d | 15d | 0d |  |  |
| 175 | 1.4.4.3.3 | IDPU FM 1 Thermal Vacuum & Bake Out |  | 10d | 2004-06-10 | 2004-06-23 | 174 |  |  | 2004-05-10 | 2004-05-21 | 10d | 15d | 0d |  |  |
| 176 | 1.4.4.4 | **FM 2** |  | 20d | 2004-07-08 | 2004-08-04 |  |  |  | 2004-05-03 | 2004-05-28 | 20d | 37d |  |  |  |
| 177 | 1.4.4.4.1 | IDPU FM 2 I & T |  | 5d | 2004-07-08 | 2004-07-14 | 73, 239, 283, 170, 171 |  |  | 2004-05-03 | 2004-05-07 | 5d | 37d | 0d |  |  |
| 178 | 1.4.4.4.2 | IDPU FM 2 Vibration |  | 5d | 2004-07-15 | 2004-07-21 | 177 |  |  | 2004-05-10 | 2004-05-14 | 5d | 37d | 0d |  |  |
| 179 | 1.4.4.4.3 | IDPU FM 2 Thermal Vacuum & Bake Out |  | 10d | 2004-07-22 | 2004-08-04 | 164, 178 |  |  | 2004-05-17 | 2004-05-28 | 10d | 37d | 0d |  |  |
| 180 | 1.5 | **BOOM Suite - UCB** |  | 321d | 2003-07-01 A | 2004-10-06 |  | 76% | 78.08d | 2003-07-01 | 2004-09-28 | 315d | 14d |  |  |  |
| 181 | 1.5.1 | **BOOM Structure - UCB** |  | 229d | 2003-09-10 A | 2004-08-05 |  | 86% | 31.23d | 2003-09-10 | 2004-06-18 | 195d | 36d |  |  |  |
| 182 | 1.5.1.1 | **Deliveries** |  | 146d | 2004-01-09 A | 2004-08-05 |  |  | 146d | 2004-01-09 | 2004-06-18 | 112d | 36d |  |  |  |
| 183 | 1.5.1.1.1 | Protoflight Boom available for I&T (if needed) | milestone | 0d | 2004-01-09 A | 2004-01-09 A | 188 | 100% |  | 2004-01-09 | 2004-01-09 | 0d |  |  |  |  |
| 184 | 1.5.1.1.2 | Deliver Boom Structure FM 1 (stays at UCB for Boom Suite FM 1 I&T) | milestone | 0d | 2004-06-16 | 2004-06-16 | 213 |  |  | 2004-05-27 | 2004-05-27 | 0d | 20d | 18d |  | MS-BOOM |
| 185 | 1.5.1.1.3 | Deliver Boom Structure FM 2 (stays at UCB for Boom Suite FM 2 I&T) | milestone | 0d | 2004-08-05 | 2004-08-05 | 235 |  |  | 2004-06-18 | 2004-06-18 | 0d | 36d | 22d |  | MS-BOOM |
| 186 | 1.5.1.2 | **Protoflight** |  | 79d | 2003-09-16 A | 2004-01-09 A |  | 100% |  | 2003-09-16 | 2004-01-09 | 79d |  |  |  |  |
| 187 | 1.5.1.2.1 | Protoflight Boom Post Environmental Deployment Test |  | 35d | 2003-09-16 A | 2003-11-04 A |  | 100% |  | 2003-09-16 | 2003-11-04 | 35d |  |  | start no earlier than 2003-09-16 |  |
| 188 | 1.5.1.2.2 | Document Protoflight Boom Test Results |  | 44d | 2003-11-05 A | 2004-01-09 A | 187 | 100% |  | 2003-11-05 | 2004-01-09 | 44d |  |  |  |  |

| ID | WBS | Task | Duration | Start | Finish | Predecessors | Complete | Remaining | Baseline start | Baseline finish | Baseline duration | Total slack | Free slack | Constraint | Calendar | Text1 |
| --- | --- | --- | --- | --- | --- | --- | --- | --- | --- | --- | --- | --- | --- | --- | --- | --- |
| 189 | 1.5.1.3 | **Flight Procurements** | 40d | 2003-09-10 A | 2003-11-05 A |  | 100% |  | 2003-09-10 | 2003-11-05 | 40d |  |  |  |  |  |
| 190 | 1.5.1.3.1 | Receive and Inspect Flight Boom Structure Tubes (FM 1) | 32d | 2003-09-10 A | 2003-10-24 A |  | 100% |  | 2003-09-10 | 2003-10-24 | 32d |  |  | start no earlier than 2003-09-10 |  |  |
| 191 | 1.5.1.3.2 | Receive and Inspect Flight Boom Structure Tubes (FM 2) | 40d | 2003-09-10 A | 2003-11-05 A |  | 100% |  | 2003-09-10 | 2003-11-05 | 40d |  |  | start no earlier than 2003-09-10 |  |  |
| 192 | 1.5.1.4 | **FM 1** | 180d | 2003-09-29 A | 2004-06-16 |  | 82% | 31.52d | 2003-09-29 | 2004-05-27 | 167d | 20d |  |  |  |  |
| 193 | 1.5.1.4.1 | **Telescoping** | 84d | 2003-10-27 A | 2004-02-29 A |  | 100% |  | 2003-10-27 | 2004-02-29 | 84d |  |  |  |  |  |
| 194 | 1.5.1.4.1.1 | **Fabrication, Assembly & Test** | 84d | 2003-10-27 A | 2004-02-29 A |  | 100% |  | 2003-10-27 | 2004-02-29 | 84d |  |  |  |  |  |
| 195 | 1.5.1.4.1.1.1 | Machine FM 1 Boom Structure Tubes as necessary | 5d | 2003-10-27 A | 2003-10-31 A | 190 | 100% |  | 2003-10-27 | 2003-10-31 | 5d |  |  |  |  |  |
| 196 | 1.5.1.4.1.1.2 | Machine FM 1 Boom Structure Parts (Rings) | 38d | 2003-11-07 A | 2004-01-05 A | 190FF+47d | 100% |  | 2003-11-07 | 2004-01-05 | 38d |  |  |  |  |  |
| 197 | 1.5.1.4.1.1.3 | Assemble FM 1 Boom Structure Telescoping Assembly | 5d | 2004-02-23 A | 2004-02-27 A | 195, 196 | 100% |  | 2004-02-23 | 2004-02-27 | 5d |  |  | start no earlier than 2004-02-23 |  |  |
| 198 | 1.5.1.4.1.1.4 | Test FM 1 Boom Structure Telescoping Assembly | 2d | 2004-02-28 A | 2004-02-29 A | 197 | 100% |  | 2004-02-28 | 2004-02-29 | 2d |  |  |  | Boom Test Calendar |  |
| 199 | 1.5.1.4.2 | **Harness** | 109d | 2003-09-29 A | 2004-03-08 A |  | 100% |  | 2003-09-29 | 2004-03-08 | 109d |  |  |  |  |  |
| 200 | 1.5.1.4.2.1 | **Fabrication** | 103d | 2003-09-29 A | 2004-02-27 A |  | 100% |  | 2003-09-29 | 2004-02-27 | 103d |  |  |  |  |  |
| 201 | 1.5.1.4.2.1.1 | Machine FM 1 Harness Parts | 103d | 2003-09-29 A | 2004-02-27 A |  | 100% |  | 2003-09-29 | 2004-02-27 | 103d |  |  | start no earlier than 2003-09-29 |  |  |
| 202 | 1.5.1.4.2.2 | **Assembly & Test** | 6d | 2004-03-01 A | 2004-03-08 A |  | 100% |  | 2004-03-01 | 2004-03-08 | 6d |  |  |  |  |  |
| 203 | 1.5.1.4.2.2.1 | Assemble FM 1 Harness subassembly | 7d | 2004-03-01 A | 2004-03-07 A | 201 | 100% |  | 2004-03-01 | 2004-03-07 | 7d |  |  | start no earlier than 2004-03-01 | Boom Test Calendar |  |
| 204 | 1.5.1.4.2.2.2 | FM1 Harness Test | 1d | 2004-03-08 A | 2004-03-08 A | 203 | 100% |  | 2004-03-08 | 2004-03-08 | 1d |  |  |  |  |  |
| 205 | 1.5.1.4.3 | **Mounting** | 38d | 2003-09-29 A | 2003-11-21 A |  | 100% |  | 2003-09-29 | 2003-11-21 | 38d |  |  |  |  |  |
| 206 | 1.5.1.4.3.1 | FM 1Boom Structure Mounting Fabrication | 28d | 2003-09-29 A | 2003-11-06 A |  | 100% |  | 2003-09-29 | 2003-11-06 | 28d |  |  | start no earlier than 2003-09-29 |  |  |
| 207 | 1.5.1.4.3.2 | FM 1Boom Structure Mounting Assembly | 10d | 2003-11-07 A | 2003-11-21 A | 206 | 100% |  | 2003-11-07 | 2003-11-21 | 10d |  |  |  |  |  |
| 208 | 1.5.1.4.4 | **Integration & Test** | 67d | 2004-03-15 A | 2004-06-16 |  | 22% | 51.98d | 2004-03-09 | 2004-05-27 | 58d | 20d |  |  |  |  |
| 209 | 1.5.1.4.4.1 | Integrate FM 1 Boom Structure subassemblies & Harness Completion | 25d | 2004-03-15 A | 2004-04-16 | 198, 204FS+5d | 52% | 12d | 2004-03-09 | 2004-04-05 | 20d | 25d | 0d |  |  | MS-BOOM |
| 210 | 1.5.1.4.4.2 | FM 1 Boom Structure Deployment Test | 10d | 2004-04-19 | 2004-04-30 | 209 |  |  | 2004-04-06 | 2004-04-19 | 10d | 25d | 5d |  |  | MS-BOOM |
| 211 | 1.5.1.4.4.3 | FM 1 Boom Structure Vibration Test | 4d | 2004-05-14 | 2004-05-19 | 210, 349 |  |  | 2004-04-27 | 2004-04-30 | 4d | 20d | 0d |  |  |  |
| 212 | 1.5.1.4.4.4 | FM 1 Boom Structure Themal Vac & Bake Out | 15d | 2004-05-20 | 2004-06-10 | 211 |  |  | 2004-05-03 | 2004-05-21 | 15d | 20d | 0d |  |  |  |
| 213 | 1.5.1.4.4.5 | FM 1 Boom Structure Post Environmental Deployment Test | 4d | 2004-06-11 | 2004-06-16 | 212 |  |  | 2004-05-24 | 2004-05-27 | 4d | 20d | 0d |  |  |  |

| ID | WBS | Task | Duration | Start | Finish | Predecessors | Complete | Remaining | Baseline start | Baseline finish | Baseline duration | Total slack | Free slack | Text1 |
| --- | --- | --- | --- | --- | --- | --- | --- | --- | --- | --- | --- | --- | --- | --- |
| 214 | 1.5.1.5 | **FM 2** | 216d | 2003-09-29 A | 2004-08-05 |  | 82% | 38.57d | 2003-09-29 | 2004-06-18 | 182d | 36d |  |  |
| 215 | 1.5.1.5.1 | **Telescoping** | 78d | 2003-11-06 A | 2004-03-02 A |  | 100% |  | 2003-11-06 | 2004-03-16 | 88d |  |  |  |
| 216 | 1.5.1.5.1.1 | **Fabrication, Assembly & Test** | 78d | 2003-11-06 A | 2004-03-02 A |  | 100% |  | 2003-11-06 | 2004-03-16 | 88d |  |  |  |
| 217 | 1.5.1.5.1.1.1 | Machine FM 2 Boom Structure Tubes as necessary | 11d | 2003-11-06 A | 2003-11-21 A | 191 | 100% |  | 2003-11-06 | 2003-11-21 | 11d |  |  |  |
| 218 | 1.5.1.5.1.1.2 | Machine FM 2 Boom Structure Parts (Rings) | 38d | 2003-11-07 A | 2004-01-05 A | 196SS | 100% |  | 2003-11-07 | 2004-01-05 | 38d |  |  |  |
| 219 | 1.5.1.5.1.1.3 | Assemble FM 2 Boom Structure Telescoping Assembly | 5d | 2004-02-23 A | 2004-02-27 A | 217, 218, 197SS | 100% |  | 2004-02-23 | 2004-02-27 | 5d |  |  |  |
| 220 | 1.5.1.5.1.1.4 | Test FM 2 Boom Structure Telescoping Assembly | 2d | 2004-03-01 A | 2004-03-02 A | 219 | 100% |  | 2004-03-15 | 2004-03-16 | 2d |  |  |  |
| 221 | 1.5.1.5.2 | **Harness** | 110d | 2003-09-29 A | 2004-03-09 A |  | 100% |  | 2003-09-29 | 2004-03-16 | 115d |  |  |  |
| 222 | 1.5.1.5.2.1 | **Fabrication** | 103d | 2003-09-29 A | 2004-02-27 A |  | 100% |  | 2003-09-29 | 2004-02-27 | 103d |  |  |  |
| 223 | 1.5.1.5.2.1.1 | Machine FM 2 Harness Parts | 103d | 2003-09-29 A | 2004-02-27 A | 201SS | 100% |  | 2003-09-29 | 2004-02-27 | 103d |  |  |  |
| 224 | 1.5.1.5.2.2 | **Assembly & Test** | 7d | 2004-03-01 A | 2004-03-09 A |  | 100% |  | 2004-03-01 | 2004-03-16 | 12d |  |  |  |
| 225 | 1.5.1.5.2.2.1 | Assemble FM 2 Harness subassembly | 6d | 2004-03-01 A | 2004-03-08 A | 223 | 100% |  | 2004-03-01 | 2004-03-15 | 11d |  |  |  |
| 226 | 1.5.1.5.2.2.2 | FM 2 Harness Test | 1d | 2004-03-09 A | 2004-03-09 A | 225 | 100% |  | 2004-03-16 | 2004-03-16 | 1d |  |  |  |
| 227 | 1.5.1.5.3 | **Mounting** | 38d | 2003-09-29 A | 2003-11-21 A |  | 100% |  | 2003-09-29 | 2003-11-21 | 38d |  |  |  |
| 228 | 1.5.1.5.3.1 | FM 2 Boom Structure Mountings Fabrication | 28d | 2003-09-29 A | 2003-11-06 A | 206SS | 100% |  | 2003-09-29 | 2003-11-06 | 28d |  |  |  |
| 229 | 1.5.1.5.3.2 | FM 2 Boom Structure Mountings Assembly | 10d | 2003-11-07 A | 2003-11-21 A | 228 | 100% |  | 2003-11-07 | 2003-11-21 | 10d |  |  |  |
| 230 | 1.5.1.5.4 | **Integration & Test** | 93d | 2004-03-29 A | 2004-08-05 |  | 6% | 87.19d | 2004-03-17 | 2004-06-18 | 67d | 36d |  |  |
| 231 | 1.5.1.5.4.1 | Integrate FM 2 Boom Structure subassemblies & Harness Completion | 15d | 2004-03-29 A | 2004-04-16 | 220, 226, 209SS+10d | 20% | 12d | 2004-03-17 | 2004-04-13 | 20d | 77d | 0d |  |
| 232 | 1.5.1.5.4.2 | FM 2 Boom Structure Deployment Test | 10d | 2004-04-19 | 2004-04-30 | 231 |  |  | 2004-04-14 | 2004-04-27 | 10d | 77d | 41d |  |
| 233 | 1.5.1.5.4.3 | FM 2 Boom Structure Vibration Test | 4d | 2004-07-06 | 2004-07-09 | 232, 354 |  |  | 2004-05-17 | 2004-05-20 | 4d | 36d | 0d |  |
| 234 | 1.5.1.5.4.4 | FM 2 Boom Structure Themal Vac & Bake Out | 15d | 2004-07-12 | 2004-07-30 | 233, 212 |  |  | 2004-05-24 | 2004-06-14 | 15d | 36d | 0d |  |
| 235 | 1.5.1.5.4.5 | FM 2 Boom Structure Post Environmental Deployment Test | 4d | 2004-08-02 | 2004-08-05 | 234 |  |  | 2004-06-15 | 2004-06-18 | 4d | 36d | 0d |  |
| 236 | 1.5.2 | **MAG - GSFC** | 57d | 2004-02-20 A | 2004-05-10 |  | 55% | 25.58d | 2004-02-20 | 2004-03-29 | 27d | 71d |  |  |
| 237 | 1.5.2.1 | **Deliveries** | 12d | 2004-04-23 | 2004-05-10 |  |  |  | 2004-03-26 | 2004-03-29 | 2d | 29d |  |  |
| 238 | 1.5.2.1.1 | Deliver MAG FM 1 (to UCB for IDPU/BOOM Suite FM 1 I&T) | 2d | 2004-04-23 | 2004-04-26 | 242 |  |  | 2004-03-26 | 2004-03-29 | 2d | 29d | 9d | MS-BOOM |
| 239 | 1.5.2.1.2 | Deliver MAG FM 2 (to UCB for IDPU/BOOM Suite FM 2 I&T) | 2d | 2004-05-07 | 2004-05-10 | 245 |  |  | 2004-03-26 | 2004-03-29 | 2d | 71d | 35d | MS-BOOM |

| ID | WBS | Task | Type | Duration | Start | Finish | Predecessors | Complete | Remaining | Baseline start | Baseline finish | Baseline duration | Total slack | Free slack | Constraint | Text1 |
| --- | --- | --- | --- | --- | --- | --- | --- | --- | --- | --- | --- | --- | --- | --- | --- | --- |
| 240 | 1.5.2.2 | **FM 1** |  | 45d | 2004-02-20 A | 2004-04-22 |  | 62% | 17.31d | 2004-02-20 | 2004-03-25 | 25d | 29d |  |  |  |
| 241 | 1.5.2.2.1 | FM 1 MAG Testing |  | 20d | 2004-02-20 A | 2004-03-18 A |  | 100% |  | 2004-02-20 | 2004-03-04 | 10d |  |  | start no earlier than 2004-02-20 |  |
| 242 | 1.5.2.2.2 | MAG FM 1 Calibration |  | 19d | 2004-03-26 A | 2004-04-22 | 241FS+10d | 21% | 15d | 2004-03-05 | 2004-03-25 | 15d | 29d | 0d |  |  |
| 243 | 1.5.2.3 | **FM 2** |  | 45d | 2004-03-05 A | 2004-05-06 |  | 54% | 20.57d | 2004-02-20 | 2004-03-25 | 25d | 71d |  |  |  |
| 244 | 1.5.2.3.1 | FM 2 MAG Testing |  | 20d | 2004-03-05 A | 2004-04-01 | 241FF+10d | 95% | 1d | 2004-02-20 | 2004-03-04 | 10d | 71d | 0d |  |  |
| 245 | 1.5.2.3.2 | MAG FM 2 Calibration |  | 15d | 2004-04-16 | 2004-05-06 | 244FS+10d |  |  | 2004-03-05 | 2004-03-25 | 15d | 71d | 0d |  |  |
| 246 | 1.5.3 | **SWEA - CESR** |  | 93d | 2003-12-08 A | 2004-04-20 |  | 53% | 43.4d | 2003-12-08 | 2004-04-20 | 93d | 67d |  |  |  |
| 247 | 1.5.3.1 | **Deliveries** |  | 93d | 2003-12-08 A | 2004-04-20 |  | 50% | 46.5d | 2003-12-08 | 2004-04-20 | 93d | 67d |  |  |  |
| 248 | 1.5.3.1.1 | SWEA FM 1 Delivery to UCB |  | 3d | 2003-12-08 A | 2003-12-10 A |  | 100% |  | 2003-12-08 | 2003-12-10 | 3d |  |  | start no earlier than 2003-12-08 |  |
| 249 | 1.5.3.1.2 | SWEA FM 2 Delivery to UCB |  | 3d | 2004-04-16 | 2004-04-20 | 252 |  |  | 2004-04-16 | 2004-04-20 | 3d | 67d | 53d |  | MS-BOOM |
| 250 | 1.5.3.2 | **FM 2** |  | 24d | 2004-03-15 A | 2004-04-15 |  | 54% | 11d | 2004-02-10 | 2004-04-15 | 47d | 67d |  |  |  |
| 251 | 1.5.3.2.1 | SWEA FM 2 Final Assembly (Block 2) |  | 5d | 2004-03-15 A | 2004-03-19 A |  | 100% |  | 2004-02-10 | 2004-02-12 | 3d |  |  | start no earlier than 2004-03-15 |  |
| 252 | 1.5.3.2.2 | SWEA FM 2 Calibration |  | 19d | 2004-03-22 A | 2004-04-15 | 251 | 42% | 11d | 2004-02-13 | 2004-04-15 | 44d | 67d | 0d |  | MS-BOOM |
| 253 | 1.5.4 | **STE - UCB** |  | 209d | 2003-08-29 A | 2004-06-29 |  | 74% | 54.2d | 2003-08-29 | 2004-05-10 | 174d | 36d |  |  |  |
| 254 | 1.5.4.1 | **Deliveries** |  | 38d | 2004-05-05 | 2004-06-29 |  |  |  | 2004-04-14 | 2004-05-10 | 18d | 19d |  |  |  |
| 255 | 1.5.4.1.1 | Deliver STE-D FM 1 (stays at UCB for SWEA/STE-D FM 1 I&T) | milestone | 0d | 2004-05-05 | 2004-05-05 | 270 |  |  | 2004-04-14 | 2004-04-14 | 0d | 19d | 17d |  | MS-BOOM |
| 256 | 1.5.4.1.2 | Deliver STE-D FM 2 (stays at UCB for SWEA/STE-D FM 2 I&T) | milestone | 0d | 2004-06-29 | 2004-06-29 | 278 |  |  | 2004-05-10 | 2004-05-10 | 0d | 18d | 4d |  | MS-BOOM |
| 257 | 1.5.4.1.3 | Deliver STE-U FM 1 (stays at UCB for BOOM Suite FM 1 I&T) | milestone | 0d | 2004-05-07 | 2004-05-07 | 271 |  |  | 2004-04-20 | 2004-04-20 | 0d | 20d | 0d |  | MS-BOOM |
| 258 | 1.5.4.1.4 | Deliver STE-U FM 2 (stays at UCB for BOOM Suite FM 2 I&T) | milestone | 0d | 2004-06-29 | 2004-06-29 | 279 |  |  | 2004-05-10 | 2004-05-10 | 0d | 36d | 0d |  | MS-BOOM |
| 259 | 1.5.4.2 | **STE-U/D Housing** |  | 53d | 2003-11-21 A | 2004-02-09 A |  | 100% |  | 2003-11-21 | 2004-02-09 | 53d |  |  |  |  |
| 260 | 1.5.4.2.1 | Fabricate STE FM 1 Box |  | 53d | 2003-11-21 A | 2004-02-09 A |  | 100% |  | 2003-11-21 | 2004-02-09 | 53d |  |  | start no earlier than 2003-11-21 |  |
| 261 | 1.5.4.2.2 | Fabricate STE FM 2 Box |  | 53d | 2003-11-21 A | 2004-02-09 A |  | 100% |  | 2003-11-21 | 2004-02-09 | 53d |  |  | start no earlier than 2003-11-21 |  |
| 262 | 1.5.4.3 | **STE-U/D Detector Boards** |  | 209d | 2003-08-29 A | 2004-06-29 |  | 67% | 69.48d | 2003-08-29 | 2004-05-10 | 174d | 36d |  |  |  |
| 263 | 1.5.4.3.1 | Coupon Test STE FM 1 & FM 2 Detector Printed Wiring Board |  | 17d | 2003-10-10 A | 2003-11-04 A | 265, 273 | 100% |  | 2003-10-10 | 2003-11-04 | 17d |  |  | start no earlier than 2003-10-10 |  |

| ID | WBS | Task | Type | Duration | Start | Finish | Predecessors | Complete | Remaining | Baseline start | Baseline finish | Baseline duration | Total slack | Free slack | Constraint | Text1 |
| --- | --- | --- | --- | --- | --- | --- | --- | --- | --- | --- | --- | --- | --- | --- | --- | --- |
| 264 | 1.5.4.3.2 | **FM 1** |  | 173d | 2003-08-29 A | 2004-05-07 |  | 74% | 44.74d | 2003-08-29 | 2004-04-20 | 160d | 20d |  |  |  |
| 265 | 1.5.4.3.2.1 | Fabrication STE FM 1 Detector Printed Wiring Board |  | 29d | 2003-08-29 A | 2003-10-09 A |  | 100% |  | 2003-08-29 | 2003-10-09 | 29d |  |  | start no earlier than 2003-08-29 |  |
| 266 | 1.5.4.3.2.2 | Load STE FM 1 Detector Printed Wiring Board |  | 60d | 2003-11-05 A | 2004-02-03 A | 263 | 100% |  | 2003-11-05 | 2004-02-03 | 60d |  |  |  |  |
| 267 | 1.5.4.3.2.3 | Test STE FM 1 Detector Printed Wiring Board |  | 10d | 2004-02-04 A | 2004-02-18 A | 266 | 100% |  | 2004-02-04 | 2004-02-18 | 10d |  |  |  |  |
| 268 | 1.5.4.3.2.4 | **Integration & Test** |  | 57d | 2004-02-19 A | 2004-05-07 |  | 40% | 34.2d | 2004-02-19 | 2004-04-20 | 44d | 20d |  |  |  |
| 269 | 1.5.4.3.2.4.1 | Integrate & Test STE-U/D FM 1 Detectors W/ FM 1 Housings |  | 47d | 2004-02-19 A | 2004-04-23 | 260, 267 | 64% | 17d | 2004-02-19 | 2004-03-17 | 20d | 18d | 0d |  |  |
| 270 | 1.5.4.3.2.4.2 | Calibrate STE-U/D FM 1 |  | 18d | 2004-04-12 | 2004-05-05 | 269FS-10d |  |  | 2004-03-18 | 2004-04-14 | 20d | 18d | 0d |  |  |
| 271 | 1.5.4.3.2.4.3 | STE-U FM 1 Thermal Vacuum/Balance/Bake Out |  | 10d | 2004-04-26 | 2004-05-07 | 270FS-8d |  |  | 2004-04-01 | 2004-04-20 | 14d | 20d | 0d |  |  |
| 272 | 1.5.4.3.3 | **FM 2** |  | 209d | 2003-08-29 A | 2004-06-29 |  | 57% | 90.38d | 2003-08-29 | 2004-05-10 | 174d | 36d |  |  |  |
| 273 | 1.5.4.3.3.1 | Fabricate STE FM 2 Detector Printed Wiring Board |  | 29d | 2003-08-29 A | 2003-10-09 A |  | 100% |  | 2003-08-29 | 2003-10-09 | 29d |  |  | start no earlier than 2003-08-29 |  |
| 274 | 1.5.4.3.3.2 | Load STE FM 2 Detector Printed Wiring Board |  | 63d | 2003-11-05 A | 2004-03-12 A | 263, 267FF+17d | 100% |  | 2003-11-05 | 2004-03-17 | 63d |  |  |  |  |
| 275 | 1.5.4.3.3.3 | Test STE FM 2 Detector Printed Wiring Board |  | 35d | 2004-03-15 A | 2004-04-30 | 274 | 37% | 22d | 2004-03-18 | 2004-03-31 | 10d | 21d | 3d |  |  |
| 276 | 1.5.4.3.3.4 | **Integration & Test** |  | 38d | 2004-05-06 | 2004-06-29 |  |  |  | 2004-04-01 | 2004-05-10 | 28d | 18d |  |  |  |
| 277 | 1.5.4.3.3.4.1 | Integrate & Test STE-U/D FM 2 Detectors W/ FM 2 Housings |  | 20d | 2004-05-06 | 2004-06-03 | 261, 275, 269FS-10d, 270 |  |  | 2004-04-01 | 2004-04-14 | 10d | 18d | 0d |  |  |
| 278 | 1.5.4.3.3.4.2 | Calibrate STE-U/D FM 2 |  | 28d | 2004-05-20 | 2004-06-29 | 277FS-10d |  |  | 2004-04-15 | 2004-05-10 | 18d | 18d | 0d |  |  |
| 279 | 1.5.4.3.3.4.3 | STE-U FM 2 Thermal Vacuum/Bake Out |  | 10d | 2004-06-16 | 2004-06-29 | 278FS-10d |  |  | 2004-04-27 | 2004-05-10 | 10d | 36d | 0d |  |  |
| 280 | 1.5.5 | **STE and SWEA - UCB** |  | 300d | 2003-07-01 A | 2004-09-07 |  | 75% | 75d | 2003-07-01 | 2004-08-27 | 294d | 14d |  |  |  |
| 281 | 1.5.5.1 | **Deliveries** |  | 100d | 2004-04-16 | 2004-09-07 |  |  |  | 2004-02-27 | 2004-08-27 | 129d | 14d |  |  |  |
| 282 | 1.5.5.1.1 | Deliver STE-U FM 1 Interface (stays at UCB for IDPU FM 1 I&T) | milestone | 0d | 2004-04-16 | 2004-04-16 | 331 |  |  | 2004-02-27 | 2004-02-27 | 0d | 42d | 27d |  | MS-BOOM |
| 283 | 1.5.5.1.2 | Deliver STE-U FM 2 Interface (stays at UCB for IDPU FM 2 I&T) | milestone | 0d | 2004-04-23 | 2004-04-23 | 340 |  |  | 2004-03-01 | 2004-03-01 | 0d | 89d | 52d |  | MS-BOOM |
| 284 | 1.5.5.1.3 | Deliver SWEA/STE-D FM 1 (stays at UCB for Boom Suite FM 1 I&T) | milestone | 0d | 2004-07-12 | 2004-07-12 | 337 |  |  | 2004-06-11 | 2004-06-11 | 0d | 2d | 0d |  | MS-BOOM |
| 285 | 1.5.5.1.4 | Deliver SWEA/STE-D FM 2 (stays at UCB for Boom Suite FM 2 I&T) | milestone | 0d | 2004-09-07 | 2004-09-07 | 346 |  |  | 2004-08-27 | 2004-08-27 | 0d | 14d | 0d |  | MS-BOOM |
| 286 | 1.5.5.2 | **SWEA Pedestal** |  | 152d | 2003-07-01 A | 2004-02-09 A |  | 100% |  | 2003-07-01 | 2004-02-09 | 152d |  |  |  |  |
| 287 | 1.5.5.2.1 | Fabricate SWEA FM 1 Baseplate |  | 152d | 2003-07-01 A | 2004-02-09 A |  | 100% |  | 2003-07-01 | 2004-02-09 | 152d |  |  | start no earlier than 2003-07-01 |  |
| 288 | 1.5.5.2.2 | Fabricate SWEA FM 2 Baseplate |  | 152d | 2003-07-01 A | 2004-02-09 A |  | 100% |  | 2003-07-01 | 2004-02-09 | 152d |  |  | start no earlier than 2003-07-01 |  |

| ID | WBS | Task | Duration | Start | Finish | Predecessors | Complete | Remaining | Baseline start | Baseline finish | Baseline duration | Total slack | Free slack | Constraint |
| --- | --- | --- | --- | --- | --- | --- | --- | --- | --- | --- | --- | --- | --- | --- |
| 289 | 1.5.5.3 | **STE-D Pre-Amp Board** | 143d | 2003-09-22 A | 2004-04-16 |  | 83% | 24.34d | 2003-09-22 | 2004-02-23 | 104d | 39d |  |  |
| 290 | 1.5.5.3.1 | **FM 1** | 143d | 2003-09-22 A | 2004-04-16 |  | 81% | 27.24d | 2003-09-22 | 2004-02-23 | 104d | 2d |  |  |
| 291 | 1.5.5.3.1.1 | Fabricate STE-D FM 1 Preamp Printed Wiring Board | 34d | 2003-09-22 A | 2003-11-07 A |  | 100% |  | 2003-09-22 | 2003-11-07 | 34d |  |  | start no earlier than 2003-09-22 |
| 292 | 1.5.5.3.1.2 | Load STE-D FM 1 Preamp Printed Wiring Board | 29d | 2004-03-09 A | 2004-04-16 | 296 | 59% | 12d | 2004-02-17 | 2004-02-23 | 5d | 2d | 0d | start no earlier than 2004-03-09 |
| 293 | 1.5.5.3.2 | **FM 2** | 143d | 2003-09-22 A | 2004-04-16 |  | 81% | 27.24d | 2003-09-22 | 2004-02-23 | 104d | 39d |  |  |
| 294 | 1.5.5.3.2.1 | Fabricate STE-D FM 2 Preamp Printed Wiring Board | 34d | 2003-09-22 A | 2003-11-07 A |  | 100% |  | 2003-09-22 | 2003-11-07 | 34d |  |  | start no earlier than 2003-09-22 |
| 295 | 1.5.5.3.2.2 | Load STE-D FM 2 Preamp Printed Wiring Board | 29d | 2004-03-09 A | 2004-04-16 | 292SS | 59% | 12d | 2004-02-17 | 2004-02-23 | 5d | 39d | 25d |  |
| 296 | 1.5.5.3.3 | Coupon Test STE-D FM 1 & FM 2 Pre-Amp Printed Wiring Boards | 15d | 2003-11-10 A | 2003-12-02 A | 291, 294 | 100% |  | 2003-11-10 | 2003-12-02 | 15d |  |  |  |
| 297 | 1.5.5.4 | **STE-D Shaper Board** | 118d | 2003-12-04 A | 2004-05-21 |  | 89% | 13.11d | 2003-12-04 | 2004-05-13 | 112d | 14d |  |  |
| 298 | 1.5.5.4.1 | **FM 1** | 67d | 2003-12-04 A | 2004-03-11 A |  | 100% |  | 2003-12-04 | 2004-02-20 | 53d |  |  |  |
| 299 | 1.5.5.4.1.1 | Fabricate STE-D FM 1 Shaper Printed Wiring Board | 10d | 2003-12-04 A | 2003-12-17 A |  | 100% |  | 2003-12-04 | 2003-12-17 | 10d |  |  | start no earlier than 2003-12-04 |
| 300 | 1.5.5.4.1.2 | Load STE-D FM 1 Shaper Printed Wiring Board | 5d | 2004-03-05 A | 2004-03-11 A | 304 | 100% |  | 2004-02-13 | 2004-02-20 | 5d |  |  | start no earlier than 2004-03-05 |
| 301 | 1.5.5.4.2 | **FM 2** | 118d | 2003-12-04 A | 2004-05-21 |  | 67% | 39.33d | 2003-12-04 | 2004-05-13 | 112d | 14d |  |  |
| 302 | 1.5.5.4.2.1 | Fabricate STE-D FM 2 Shaper Printed Wiring Board | 10d | 2003-12-04 A | 2003-12-17 A |  | 100% |  | 2003-12-04 | 2003-12-17 | 10d |  |  | start no earlier than 2003-12-04 |
| 303 | 1.5.5.4.2.2 | Load STE-D FM 2 Shaper Printed Wiring Board | 5d | 2004-05-17 | 2004-05-21 | 304, 332 |  |  | 2004-05-07 | 2004-05-13 | 5d | 14d | 0d |  |
| 304 | 1.5.5.4.3 | Coupon Test STE-D FM 1 & FM 2 Shaper Printed Wiring Boards | 15d | 2003-12-18 A | 2004-01-09 A | 299, 302 | 100% |  | 2003-12-18 | 2004-01-09 | 15d |  |  |  |
| 305 | 1.5.5.5 | **STE-D Interface Board** | 118d | 2003-12-04 A | 2004-05-21 |  | 89% | 13.11d | 2003-12-04 | 2004-05-13 | 112d | 14d |  |  |
| 306 | 1.5.5.5.1 | **FM 1** | 67d | 2003-12-04 A | 2004-03-11 A |  | 100% |  | 2003-12-04 | 2004-02-20 | 53d |  |  |  |
| 307 | 1.5.5.5.1.1 | Fabricate SWEA / STE-D FM 1 Digital to Analog Converter Printed Wiring Board | 10d | 2003-12-04 A | 2003-12-17 A |  | 100% |  | 2003-12-04 | 2003-12-17 | 10d |  |  | start no earlier than 2003-12-04 |
| 308 | 1.5.5.5.1.2 | Load SWEA / STE-D FM 1 Digital to Analog Converter Printed Wiring Board | 5d | 2004-03-05 A | 2004-03-11 A | 300SS | 100% |  | 2004-02-13 | 2004-02-20 | 5d |  |  |  |
| 309 | 1.5.5.5.2 | **FM 2** | 118d | 2003-12-04 A | 2004-05-21 |  | 67% | 39.33d | 2003-12-04 | 2004-05-13 | 112d | 14d |  |  |
| 310 | 1.5.5.5.2.1 | Fabricate SWEA / STE-D FM 2 Digital to Analog Converter Printed Wiring Board | 10d | 2003-12-04 A | 2003-12-17 A |  | 100% |  | 2003-12-04 | 2003-12-17 | 10d |  |  | start no earlier than 2003-12-04 |
| 311 | 1.5.5.5.2.2 | Load SWEA / STE-D FM 2 Digital to Analog Converter Printed Wiring Board | 5d | 2004-05-17 | 2004-05-21 | 303SS |  |  | 2004-05-07 | 2004-05-13 | 5d | 14d | 0d |  |
| 312 | 1.5.5.5.3 | Coupon Test STE-D FM 1 & FM 2 D/A Converter Printed Wiring Boards | 15d | 2003-12-18 A | 2004-01-09 A | 307, 310 | 100% |  | 2003-12-18 | 2004-01-09 | 15d |  |  |  |

| ID | WBS | Task | Duration | Start | Finish | Predecessors | Complete | Remaining | Baseline start | Baseline finish | Baseline duration | Total slack | Free slack | Constraint |
| --- | --- | --- | --- | --- | --- | --- | --- | --- | --- | --- | --- | --- | --- | --- |
| 313 | 1.5.5.6 | **STE-U Pre-Amp Board** | 143d | 2003-09-22 A | 2004-04-16 |  | 90% | 14.79d | 2003-09-22 | 2004-02-23 | 104d | 89d |  |  |
| 314 | 1.5.5.6.1 | **FM 1** | 79d | 2003-09-22 A | 2004-01-15 A |  | 100% |  | 2003-09-22 | 2004-01-15 | 79d |  |  |  |
| 315 | 1.5.5.6.1.1 | Fabricate STE-U FM 1 Preamp Printed Wiring Board | 34d | 2003-09-22 A | 2003-11-07 A |  | 100% |  | 2003-09-22 | 2003-11-07 | 34d |  |  | start no earlier than 2003-09-22 |
| 316 | 1.5.5.6.1.2 | Load STE-U FM 1 Preamp Printed Wiring Board | 4d | 2004-01-12 A | 2004-01-15 A | 320 | 100% |  | 2004-01-12 | 2004-01-15 | 4d |  |  | start no earlier than 2004-01-12 |
| 317 | 1.5.5.6.2 | **FM 2** | 143d | 2003-09-22 A | 2004-04-16 |  | 81% | 27.24d | 2003-09-22 | 2004-02-23 | 104d | 89d |  |  |
| 318 | 1.5.5.6.2.1 | Fabricate STE-U FM 2 Preamp Printed Wiring Board | 34d | 2003-09-22 A | 2003-11-07 A |  | 100% |  | 2003-09-22 | 2003-11-07 | 34d |  |  | start no earlier than 2003-09-22 |
| 319 | 1.5.5.6.2.2 | Load STE-U FM 2 Preamp Printed Wiring Board | 29d | 2004-03-09 A | 2004-04-16 | 320 | 59% | 12d | 2004-02-17 | 2004-02-23 | 5d | 89d | 0d | start no earlier than 2004-03-09 |
| 320 | 1.5.5.6.3 | Coupon Test STE-U FM 1 & FM 2 Pre-Amp Printed Wiring Boards | 15d | 2003-11-10 A | 2003-12-02 A | 315, 318 | 100% |  | 2003-11-10 | 2003-12-02 | 15d |  |  |  |
| 321 | 1.5.5.7 | **STE-U Shaper & Interface Board** | 78d | 2003-12-04 A | 2004-03-26 A |  | 100% |  | 2003-12-04 | 2004-02-20 | 53d |  |  |  |
| 322 | 1.5.5.7.1 | **FM 1** | 73d | 2003-12-04 A | 2004-03-19 A |  | 100% |  | 2003-12-04 | 2004-02-20 | 53d |  |  |  |
| 323 | 1.5.5.7.1.1 | Fabricate STE-U FM 1Shaper & Interface Printed Wiring Board | 10d | 2003-12-04 A | 2003-12-17 A |  | 100% |  | 2003-12-04 | 2003-12-17 | 10d |  |  | start no earlier than 2003-12-04 |
| 324 | 1.5.5.7.1.2 | Load STE-U FM 1 Shaper & Interface Printed Wiring Board | 13d | 2004-03-03 A | 2004-03-19 A | 328 | 100% |  | 2004-02-13 | 2004-02-20 | 5d |  |  | start no earlier than 2004-03-03 |
| 325 | 1.5.5.7.2 | **FM 2** | 78d | 2003-12-04 A | 2004-03-26 A |  | 100% |  | 2003-12-04 | 2004-02-20 | 53d |  |  |  |
| 326 | 1.5.5.7.2.1 | Fabricate STE-U FM 2 Shaper & Interface Printed Wiring Board | 10d | 2003-12-04 A | 2003-12-17 A |  | 100% |  | 2003-12-04 | 2003-12-17 | 10d |  |  | start no earlier than 2003-12-04 |
| 327 | 1.5.5.7.2.2 | Load STE-U FM 2 Shaper & Interface Printed Wiring Board | 5d | 2004-03-22 A | 2004-03-26 A | 324 | 100% |  | 2004-02-13 | 2004-02-20 | 5d |  |  |  |
| 328 | 1.5.5.7.3 | Coupon Test STE-U FM 1 & FM 2 Shaper & Interface Printed Wiring Boards | 15d | 2003-12-18 A | 2004-01-09 A | 323, 326 | 100% |  | 2003-12-18 | 2004-01-09 | 15d |  |  |  |
| 329 | 1.5.5.8 | **Integration & Test** | 120d | 2004-03-22 A | 2004-09-07 |  | 4% | 114.78d | 2004-02-23 | 2004-08-27 | 134d | 14d |  |  |
| 330 | 1.5.5.8.1 | **FM 1** | 120d | 2004-03-22 A | 2004-09-07 |  | 8% | 110.77d | 2004-02-23 | 2004-07-30 | 114d | 11d |  |  |
| 331 | 1.5.5.8.1.1 | Integrate & Test STE-U FM 1 Interface Boards | 20d | 2004-03-22 A | 2004-04-16 | 316, 324 | 40% | 12d | 2004-02-23 | 2004-02-27 | 5d | 42d | 0d |  |
| 332 | 1.5.5.8.1.2 | Integrate & Test SWEA/STE-D FM 1 Interface Boards | 20d | 2004-04-19 | 2004-05-14 | 287, 292, 300, 308 |  |  | 2004-02-24 | 2004-03-22 | 20d | 2d | 0d |  |
| 333 | 1.5.5.8.1.3 | Integrate & Test SWEA/STE-D FM 1 Interface with SWEA/STE-D FM 1 LVPS | 10d | 2004-05-17 | 2004-05-28 | 332, 69 |  |  | 2004-04-16 | 2004-04-29 | 10d | 2d | 0d |  |
| 334 | 1.5.5.8.1.4 | Clean/Coat/Stake SWEA/STE-D Interface | 10d | 2004-05-17 | 2004-05-28 | 332 |  |  | 2004-03-23 | 2004-04-05 | 10d | 2d | 0d |  |
| 335 | 1.5.5.8.1.5 | Integrate & Test SWEA/STE-D FM 1 Combined | 5d | 2004-06-01 | 2004-06-07 | 333, 334, 248, 255 |  |  | 2004-04-30 | 2004-05-06 | 5d | 2d | 0d |  |
| 336 | 1.5.5.8.1.6 | Calibrate SWEA/STE FM 1 | 20d | 2004-06-08 | 2004-07-05 | 335 |  |  | 2004-05-07 | 2004-06-04 | 20d | 2d | 0d |  |
| 337 | 1.5.5.8.1.7 | SWEA/STE FM 1 Vibration | 5d | 2004-07-06 | 2004-07-12 | 336 |  |  | 2004-06-07 | 2004-06-11 | 5d | 2d | 0d |  |
| 338 | 1.5.5.8.1.8 | SWEA/STE-D FM 1 Thermal Vac/Thermal Balance/Bake Out | 14d | 2004-08-18 | 2004-09-07 | 19 |  |  | 2004-07-13 | 2004-07-30 | 14d | 11d | 0d |  |

| ID | WBS | Task | Duration | Start | Finish | Predecessors | Complete | Remaining | Baseline start | Baseline finish | Baseline duration | Total slack | Free slack | Constraint | Text1 |
| --- | --- | --- | --- | --- | --- | --- | --- | --- | --- | --- | --- | --- | --- | --- | --- |
| 339 | 1.5.5.8.2 | **FM 2** | 100d | 2004-04-19 | 2004-09-07 |  |  |  | 2004-02-24 | 2004-08-27 | 133d | 14d |  |  |  |
| 340 | 1.5.5.8.2.1 | Integrate & Test STE-U FM 2 Interface Boards | 5d | 2004-04-19 | 2004-04-23 | 319, 327 |  |  | 2004-02-24 | 2004-03-01 | 5d | 89d | 0d |  |  |
| 341 | 1.5.5.8.2.2 | Integrate & Test SWEA/STE-D FM 2 Interface Boards | 20d | 2004-05-24 | 2004-06-21 | 288, 295, 303, 311 |  |  | 2004-05-14 | 2004-06-11 | 20d | 14d | 0d |  |  |
| 342 | 1.5.5.8.2.3 | Integrate & Test SWEA/STE-D FM 2 Interface with SWEA/STE-D FM 2 LVPS | 10d | 2004-06-22 | 2004-07-05 | 341, 75 |  |  | 2004-06-14 | 2004-06-25 | 10d | 14d | 0d |  |  |
| 343 | 1.5.5.8.2.4 | Integrate & Test SWEA/STE-D FM 2 Combined | 10d | 2004-07-06 | 2004-07-19 | 342, 249, 256 |  |  | 2004-06-28 | 2004-07-09 | 10d | 14d | 0d |  |  |
| 344 | 1.5.5.8.2.5 | Calibrate SWEA/STE FM 2 | 20d | 2004-07-20 | 2004-08-16 | 343 |  |  | 2004-07-12 | 2004-08-06 | 20d | 14d | 0d |  |  |
| 345 | 1.5.5.8.2.6 | SWEA/STE FM 2 Vibration | 5d | 2004-08-17 | 2004-08-23 | 344 |  |  | 2004-08-09 | 2004-08-13 | 5d | 14d | 0d |  |  |
| 346 | 1.5.5.8.2.7 | SWEA/STE-D FM 2 Thermal Vac & bake Out | 10d | 2004-08-24 | 2004-09-07 | 345 |  |  | 2004-08-16 | 2004-08-27 | 10d | 14d | 0d |  |  |
| 347 | 1.5.6 | **Boom Suite I&T - UCB** | 106d | 2004-05-10 | 2004-10-06 |  |  |  | 2004-04-21 | 2004-09-28 | 113d | 14d |  |  |  |
| 348 | 1.5.6.1 | **FM 1** | 95d | 2004-05-10 | 2004-09-21 |  |  |  | 2004-04-21 | 2004-08-13 | 82d | 11d |  |  |  |
| 349 | 1.5.6.1.1 | FM 1 Boom/MAG/STE-U I&T | 4d | 2004-05-10 | 2004-05-13 | 210, 238, 257 |  |  | 2004-04-21 | 2004-04-26 | 4d | 20d | 0d |  | MS-BOOM |
| 350 | 1.5.6.1.2 | FM 1 Boom/SWEA/STE/MAG I&T | 2d | 2004-07-13 | 2004-07-14 | 284, 184 |  |  | 2004-06-14 | 2004-06-15 | 2d | 2d |  |  |  |
| 351 | 1.5.6.1.3 | FM 1 Integrated Boom/IDPU I&T | 4d | 2004-07-26 | 2004-07-29 | 350, 184, 756 |  |  | 2004-06-16 | 2004-06-21 | 4d | -5d | 0d |  |  |
| 352 | 1.5.6.1.4 | Final BOOM Suite FM 1 I & T | 10d | 2004-09-08 | 2004-09-21 | 351, 338 |  |  | 2004-08-02 | 2004-08-13 | 10d | 11d | 0d |  |  |
| 353 | 1.5.6.2 | **FM 2** | 70d | 2004-06-30 | 2004-10-06 |  |  |  | 2004-05-11 | 2004-09-28 | 99d | 14d |  |  |  |
| 354 | 1.5.6.2.1 | FM 2 Boom/MAG/STE-U I&T | 4d | 2004-06-30 | 2004-07-05 | 232, 239, 258 |  |  | 2004-05-11 | 2004-05-14 | 4d | 36d | 0d |  | MS-BOOM |
| 355 | 1.5.6.2.2 | FM 2 Boom/SWEA/STE/MAG I&T | 2d | 2004-09-08 | 2004-09-09 | 285, 185 |  |  | 2004-08-30 | 2004-08-31 | 2d | 14d | 0d |  |  |
| 356 | 1.5.6.2.3 | FM 2 Integrated Boom/IDPU I&T | 4d | 2004-09-10 | 2004-09-15 | 355, 185, 768 |  |  | 2004-09-01 | 2004-09-07 | 4d | 14d | 0d |  |  |
| 357 | 1.5.6.2.4 | Boom Suite FM 2 EMC | 5d | 2004-09-16 | 2004-09-22 | 356 |  |  | 2004-09-08 | 2004-09-14 | 5d | 14d | 0d |  | MS-BOOM |
| 358 | 1.5.6.2.5 | Final BOOM Suite FM 2 I & T | 10d | 2004-09-23 | 2004-10-06 | 357 |  |  | 2004-09-15 | 2004-09-28 | 10d | 14d | 0d |  |  |
| 359 | 1.6 | **SEP Suite - CIT** | 354d | 2003-06-02 A | 2004-10-25 |  | 57% | 152.3d | 2003-06-02 | 2004-10-21 | 352d | 3d |  |  |  |
| 360 | 1.6.1 | **SEP Mechanical - Sandy Shuman (GSFC)** | 115d | 2004-01-27 A | 2004-07-07 |  | 26% | 85.17d | 2004-01-27 | 2004-06-02 | 90d | 29d |  |  |  |
| 361 | 1.6.1.1 | **SIT Electronics Enclosure (Priority 1)** | 61d | 2004-02-09 A | 2004-05-04 |  | 34% | 39.97d | 2004-02-09 | 2004-03-16 | 26d | 26d |  |  |  |
| 362 | 1.6.1.1.1 | Complete Design/Drawings for SIT Enclosure | 10d | 2004-02-09 A | 2004-02-23 A |  | 100% |  | 2004-02-09 | 2004-02-23 | 10d |  |  | start no earlier than 2004-02-09 |  |
| 363 | 1.6.1.1.2 | Fabrication of SIT Enclosure | 12d | 2004-04-08 | 2004-04-23 | 362FS+32d |  |  | 2004-02-24 | 2004-03-08 | 10d | 26d | 0d |  |  |
| 364 | 1.6.1.1.3 | Inspection and Final Assembly of SIT Enclosure | 6d | 2004-04-26 | 2004-05-03 | 363 |  |  | 2004-03-09 | 2004-03-15 | 5d | 26d | 0d |  |  |
| 365 | 1.6.1.1.4 | Deliver SIT Enclosure to UMD | 1d | 2004-05-04 | 2004-05-04 | 364 |  |  | 2004-03-16 | 2004-03-16 | 1d | 26d | 25d |  |  |

| ID | WBS | Task | Type | Duration | Start | Finish | Predecessors | Complete | Remaining | Baseline start | Baseline finish | Baseline duration | Total slack | Free slack | Constraint | Text1 |
| --- | --- | --- | --- | --- | --- | --- | --- | --- | --- | --- | --- | --- | --- | --- | --- | --- |
| 366 | 1.6.1.2 | **SEP FM 1 & FM 2 LVPS Boxes (Priority 2)** |  | 53d | 2004-02-09 A | 2004-04-22 |  | 70% | 16d | 2004-02-09 | 2004-03-11 | 23d | 17d |  |  |  |
| 367 | 1.6.1.2.1 | Complete Design/Drawings for SEP LVPS Boxes |  | 5d | 2004-02-09 A | 2004-02-13 A | 362SS | 100% |  | 2004-02-09 | 2004-02-13 | 5d |  |  |  |  |
| 368 | 1.6.1.2.2 | Fabrication of SEP LVPS Boxes |  | 35d | 2004-02-17 A | 2004-04-05 | 367 | 91% | 3d | 2004-02-17 | 2004-03-01 | 10d | 17d | 0d |  |  |
| 369 | 1.6.1.2.3 | Inspection of SEP LVPS Boxes (Final Assembly at UCB) |  | 10d | 2004-04-06 | 2004-04-19 | 368 |  |  | 2004-03-02 | 2004-03-08 | 5d | 17d | 0d |  |  |
| 370 | 1.6.1.2.4 | Deliver SEP LVPS Boxes to UCB |  | 3d | 2004-04-20 | 2004-04-22 | 369 |  |  | 2004-03-09 | 2004-03-11 | 3d | 17d | 1d | start no earlier than 2004-04-07 |  |
| 371 | 1.6.1.3 | **SEP Electronics Enclosure (Priority 3)** |  | 69d | 2004-02-17 A | 2004-05-21 |  | 46% | 37d | 2004-02-17 | 2004-03-30 | 31d | 19d |  |  |  |
| 372 | 1.6.1.3.1 | Complete Design/Drawings for SEP Enclosure |  | 45d | 2004-02-17 A | 2004-04-19 | 367 | 71% | 13d | 2004-02-17 | 2004-03-04 | 13d | 2d | 0d |  |  |
| 373 | 1.6.1.3.2 | Fabrication of SEP Enclosure |  | 15d | 2004-04-20 | 2004-05-10 | 372 |  |  | 2004-03-05 | 2004-03-18 | 10d | 19d | 0d |  |  |
| 374 | 1.6.1.3.3 | Inspection and Final Assembly of SEP Enclosure |  | 6d | 2004-05-11 | 2004-05-18 | 373 |  |  | 2004-03-19 | 2004-03-25 | 5d | 19d | 0d |  |  |
| 375 | 1.6.1.3.4 | Deliver SEP Enclosure to CIT |  | 3d | 2004-05-19 | 2004-05-21 | 374 |  |  | 2004-03-26 | 2004-03-30 | 3d | 19d | 6d |  | MS-SEP |
| 376 | 1.6.1.4 | **SEP Central Bias Supply Shields (Priority 4)** |  | 20d | 2004-04-15 | 2004-05-12 |  |  |  | 2004-03-05 | 2004-04-01 | 20d | 2d |  |  |  |
| 377 | 1.6.1.4.1 | Complete Design/Drawings for Bias Supply Shields |  | 5d | 2004-04-15 | 2004-04-21 | 372FS-3d |  |  | 2004-03-05 | 2004-03-11 | 5d | 2d | 0d |  |  |
| 378 | 1.6.1.4.2 | Fabrication of Bias Supply Shields |  | 10d | 2004-04-22 | 2004-05-05 | 377 |  |  | 2004-03-12 | 2004-03-25 | 10d | 68d | 0d |  |  |
| 379 | 1.6.1.4.3 | Inspection and Delivery (to CIT) of Bias Supply Shields |  | 5d | 2004-05-06 | 2004-05-12 | 378 |  |  | 2004-03-26 | 2004-04-01 | 5d | 68d | 31d |  |  |
| 380 | 1.6.1.5 | **LET Telescope (Priority 5)** |  | 26d | 2004-04-15 | 2004-05-20 |  |  |  | 2004-03-12 | 2004-04-16 | 26d | 2d |  |  |  |
| 381 | 1.6.1.5.1 | Complete Design/Drawings for LET Telescope |  | 5d | 2004-04-15 | 2004-04-21 | 377FS-5d |  |  | 2004-03-12 | 2004-03-23 | 8d | 2d | 0d |  |  |
| 382 | 1.6.1.5.2 | Fabrication of LET Telescope |  | 10d | 2004-04-22 | 2004-05-05 | 381 |  |  | 2004-03-24 | 2004-04-06 | 10d | 6d | 0d |  |  |
| 383 | 1.6.1.5.3 | Inspection and Final Assembly of LET Telescope (CIT has detectors) |  | 8d | 2004-05-06 | 2004-05-17 | 382 |  |  | 2004-04-07 | 2004-04-13 | 5d | 6d | 0d |  |  |
| 384 | 1.6.1.5.4 | Deliver LET Telescope to CIT |  | 3d | 2004-05-18 | 2004-05-20 | 383 |  |  | 2004-04-14 | 2004-04-16 | 3d | 6d |  |  |  |
| 385 | 1.6.1.6 | **HET Electronics Enclosure (Priority 6)** |  | 39d | 2004-03-22 A | 2004-05-13 |  | 21% | 30.79d | 2004-03-24 | 2004-04-23 | 23d | 2d |  |  |  |
| 386 | 1.6.1.6.1 | Complete Design/Drawings for HET Enclosure |  | 23d | 2004-03-22 A | 2004-04-22 | 381FS-14d | 35% | 15d | 2004-03-24 | 2004-04-02 | 8d | 2d | 0d |  |  |
| 387 | 1.6.1.6.2 | Fabrication of HET Enclosure |  | 10d | 2004-04-23 | 2004-05-06 | 386 |  |  | 2004-04-05 | 2004-04-16 | 10d | 2d | 0d |  |  |
| 388 | 1.6.1.6.3 | Inspection and Final Assembly of HET Enclosure |  | 5d | 2004-05-07 | 2004-05-13 | 387 |  |  | 2004-04-19 | 2004-04-23 | 5d | 2d | 0d |  |  |
| 389 | 1.6.1.6.4 | Deliver HET Enclosure (stays at GSFC) | milestone | 0d | 2004-05-13 | 2004-05-13 | 388 |  |  | 2004-04-23 | 2004-04-23 | 0d | 2d | 0d |  |  |

| ID | WBS | Task | Type | Duration | Start | Finish | Predecessors | Complete | Remaining | Baseline start | Baseline finish | Baseline duration | Total slack | Free slack | Constraint | Text1 |
| --- | --- | --- | --- | --- | --- | --- | --- | --- | --- | --- | --- | --- | --- | --- | --- | --- |
| 390 | 1.6.1.7 | **HET Telescope (Priority 7)** |  | 84d | 2004-01-27 A | 2004-05-24 |  | 32% | 57.53d | 2004-01-27 | 2004-04-30 | 68d | 2d |  |  |  |
| 391 | 1.6.1.7.1 | On Going work for HET Telescope (Complete Design/Drawings & Prep for Fab) |  | 56d | 2004-01-27 A | 2004-04-14 |  | 41% | 33d | 2004-01-27 | 2004-03-31 | 46d | 1d | 0d | start no earlier than 2004-01-27 |  |
| 392 | 1.6.1.7.2 | Fabrication of HET Telescope |  | 10d | 2004-04-15 | 2004-04-28 | 391 |  |  | 2004-04-01 | 2004-04-14 | 10d | 13d | 11d |  |  |
| 393 | 1.6.1.7.3 | Inspection and Final Assembly of HET Telescope |  | 7d | 2004-05-14 | 2004-05-24 | 392, 389 |  |  | 2004-04-26 | 2004-04-30 | 5d | 2d | 0d |  | MS-SEP |
| 394 | 1.6.1.7.4 | Deliver HET Telescope (stays at GSFC) | milestone | 0d | 2004-05-24 | 2004-05-24 | 393 |  |  | 2004-04-30 | 2004-04-30 | 0d | 2d |  |  | MS-SEP |
| 395 | 1.6.1.8 | **SIT Telescope (Priority 8)** |  | 39d | 2004-04-15 | 2004-06-09 |  |  |  | 2004-04-01 | 2004-05-18 | 34d | 1d |  |  |  |
| 396 | 1.6.1.8.1 | Complete Design/Drawings for SIT Telescope |  | 18d | 2004-04-15 | 2004-05-10 | 391 |  |  | 2004-04-01 | 2004-04-26 | 18d | 1d | 0d |  |  |
| 397 | 1.6.1.8.2 | Fabrication of SIT Telescope |  | 10d | 2004-05-11 | 2004-05-24 | 396 |  |  | 2004-04-27 | 2004-05-10 | 10d | 1d | 0d |  |  |
| 398 | 1.6.1.8.3 | Inspection and Final Assembly of SIT Telescope |  | 10d | 2004-05-25 | 2004-06-08 | 397 |  |  | 2004-05-11 | 2004-05-17 | 5d | 1d | 0d |  |  |
| 399 | 1.6.1.8.4 | Deliver SIT Telescope to UMD (Includes the Foils and Detectors) |  | 1d | 2004-06-09 | 2004-06-09 | 398 |  |  | 2004-05-18 | 2004-05-18 | 1d | 1d | 0d |  |  |
| 400 | 1.6.1.9 | **Shipping Containers for HET, SIT & SEP Central (Priority 9)** |  | 23d | 2004-05-11 | 2004-06-11 |  |  |  | 2004-04-27 | 2004-05-27 | 23d | 8d |  |  |  |
| 401 | 1.6.1.9.1 | Design |  | 5d | 2004-05-11 | 2004-05-17 | 396 |  |  | 2004-04-27 | 2004-05-03 | 5d | 8d | 0d |  |  |
| 402 | 1.6.1.9.2 | Fabrication/Machining |  | 10d | 2004-05-18 | 2004-06-01 | 401 |  |  | 2004-05-04 | 2004-05-17 | 10d | 12d | 0d |  |  |
| 403 | 1.6.1.9.3 | Inspection and Assembly |  | 5d | 2004-06-02 | 2004-06-08 | 402 |  |  | 2004-05-18 | 2004-05-24 | 5d | 12d | 0d |  |  |
| 404 | 1.6.1.9.4 | HET Container stays at GSFC | milestone | 0d | 2004-06-08 | 2004-06-08 | 403 |  |  | 2004-05-24 | 2004-05-24 | 0d | 12d |  |  |  |
| 405 | 1.6.1.9.5 | SIT Container to UMD |  | 1d | 2004-06-09 | 2004-06-09 | 403 |  |  | 2004-05-25 | 2004-05-25 | 1d | 24d |  |  |  |
| 406 | 1.6.1.9.6 | SEP Central Container to CIT |  | 3d | 2004-06-09 | 2004-06-11 | 403 |  |  | 2004-05-25 | 2004-05-27 | 3d | 13d |  |  |  |
| 407 | 1.6.1.10 | **SIT Door (Priority 10)** |  | 27d | 2004-05-18 | 2004-06-24 |  |  |  | 2004-05-18 | 2004-06-24 | 27d | 8d |  |  |  |
| 408 | 1.6.1.10.1 | Complete Design/Drawings for SIT Door |  | 10d | 2004-05-18 | 2004-06-01 | 401 |  |  | 2004-05-18 | 2004-06-01 | 10d | 8d | 0d |  |  |
| 409 | 1.6.1.10.2 | Fabrication |  | 10d | 2004-06-02 | 2004-06-15 | 408 |  |  | 2004-06-02 | 2004-06-15 | 10d | 35d | 0d |  |  |
| 410 | 1.6.1.10.3 | Inspection |  | 5d | 2004-06-16 | 2004-06-22 | 409 |  |  | 2004-06-16 | 2004-06-22 | 5d | 35d | 0d |  |  |
| 411 | 1.6.1.10.4 | Final Assembly |  | 1d | 2004-06-23 | 2004-06-23 | 410 |  |  | 2004-06-23 | 2004-06-23 | 1d | 35d | 0d |  |  |
| 412 | 1.6.1.10.5 | Deliver SIT Door (stay at GSFC for Environmental Testing) |  | 1d | 2004-06-24 | 2004-06-24 | 411 |  |  | 2004-06-24 | 2004-06-24 | 1d | 35d |  |  |  |
| 413 | 1.6.1.11 | **LET Radiation Test Fixture (Priority 11)** |  | 26d | 2004-06-02 | 2004-07-07 |  |  |  | 2004-05-04 | 2004-06-02 | 21d | 8d |  |  |  |
| 414 | 1.6.1.11.1 | Design |  | 5d | 2004-06-02 | 2004-06-08 | 408 |  |  | 2004-05-04 | 2004-05-10 | 5d | 8d | 0d |  |  |
| 415 | 1.6.1.11.2 | Fabrication |  | 10d | 2004-06-09 | 2004-06-22 | 414 |  |  | 2004-05-11 | 2004-05-24 | 10d | 8d | 0d |  |  |
| 416 | 1.6.1.11.3 | Inspection and Assembly |  | 10d | 2004-06-23 | 2004-07-06 | 415 |  |  | 2004-05-25 | 2004-06-01 | 5d | 8d | 0d |  |  |
| 417 | 1.6.1.11.4 | Deliver to CIT for SEP I&T |  | 1d | 2004-07-07 | 2004-07-07 | 416 |  |  | 2004-06-02 | 2004-06-02 | 1d | 8d |  |  |  |

| ID | WBS | Task | Type | Duration | Start | Finish | Predecessors | Complete | Remaining | Baseline start | Baseline finish | Baseline duration | Total slack | Free slack | Constraint | Text1 |
| --- | --- | --- | --- | --- | --- | --- | --- | --- | --- | --- | --- | --- | --- | --- | --- | --- |
| 418 | 1.6.2 | **SEP Central - CIT** |  | 227d | 2003-08-01 A | 2004-06-25 |  | 72% | 63.26d | 2003-08-01 | 2004-06-03 | 211d | 37d |  |  |  |
| 419 | 1.6.2.1 | **Deliveries** |  | 51d | 2004-04-14 | 2004-06-25 |  |  |  | 2004-04-14 | 2004-06-03 | 35d | 37d |  |  |  |
| 420 | 1.6.2.1.1 | Deliver all SEP Cen FM 1 Boards to SEP I&T (stays at CIT) | milestone | 0d | 2004-06-01 | 2004-06-01 | 444 |  |  | 2004-05-10 | 2004-05-10 | 0d | 13d | 0d |  | MS-SEP |
| 421 | 1.6.2.1.2 | Deliver all SEP Cen FM 2 Boards & FM 2 LVPS to SEP I&T (stays at CIT) | milestone | 0d | 2004-06-25 | 2004-06-25 | 444, 74, 379 |  |  | 2004-05-10 | 2004-05-10 | 0d | 37d | 0d |  | MS-SEP |
| 422 | 1.6.2.1.3 | SEP Central Build 3 Software Complete | milestone | 0d | 2004-04-14 | 2004-04-14 | 446 |  |  | 2004-04-14 | 2004-04-14 | 0d | 46d | 33d |  |  |
| 423 | 1.6.2.1.4 | Final SEP Central Flight Software Complete | milestone | 0d | 2004-06-03 | 2004-06-03 | 447 |  |  | 2004-06-03 | 2004-06-03 | 0d | 35d |  |  |  |
| 424 | 1.6.2.2 | **Logic Board** |  | 59d | 2004-02-13 A | 2004-05-06 |  | 71% | 17.24d | 2004-02-13 | 2004-03-26 | 30d | 0d |  |  |  |
| 425 | 1.6.2.2.1 | **Assembly** |  | 10d | 2004-02-13 A | 2004-02-27 A |  | 100% |  | 2004-02-13 | 2004-02-27 | 10d |  |  |  |  |
| 426 | 1.6.2.2.1.1 | Assemble FM 1 SEP Central Logic board |  | 10d | 2004-02-13 A | 2004-02-27 A |  | 100% |  | 2004-02-13 | 2004-02-27 | 10d |  |  | start no earlier than 2004-02-13 | MS-SEP |
| 427 | 1.6.2.2.1.2 | Assemble FM 2 SEP Central Logic board |  | 10d | 2004-02-13 A | 2004-02-27 A | 426SS | 100% |  | 2004-02-13 | 2004-02-27 | 10d |  |  |  | MS-SEP |
| 428 | 1.6.2.2.2 | **Test** |  | 49d | 2004-03-01 A | 2004-05-06 |  | 62% | 18.46d | 2004-03-01 | 2004-03-26 | 20d | 0d |  |  |  |
| 429 | 1.6.2.2.2.1 | Test FM 1 SEP Central Logic board (initial) |  | 20d | 2004-03-01 A | 2004-03-26 A | 426 | 100% |  | 2004-03-01 | 2004-03-26 | 20d |  |  |  |  |
| 430 | 1.6.2.2.2.2 | Test FM 2 SEP Central Logic board (initial) |  | 49d | 2004-03-01 A | 2004-05-06 | 427 | 47% | 26d | 2004-03-01 | 2004-03-26 | 20d | -1d | 0d |  |  |
| 431 | 1.6.2.3 | **Analog/Post-Reg Board** |  | 0d | 2004-01-27 A | 2004-01-27 A |  | 100% |  | 2004-01-27 | 2004-01-27 | 0d |  |  |  |  |
| 432 | 1.6.2.3.1 | FM 1 Analog/Post-Reg Board Complete Test and awaiting Conformal Coat with other SEP Central Boards | milestone | 0d | 2004-01-27 A | 2004-01-27 A |  | 100% |  | 2004-01-27 | 2004-01-27 | 0d |  |  | start no earlier than 2004-01-27 |  |
| 433 | 1.6.2.3.2 | FM 2 Analog/Post-Reg Board Complete Test and awaiting Conformal Coat with other SEP Central Boards | milestone | 0d | 2004-01-27 A | 2004-01-27 A |  | 100% |  | 2004-01-27 | 2004-01-27 | 0d |  |  | start no earlier than 2004-01-27 |  |
| 434 | 1.6.2.4 | **SEP Solid State Detector Bias Supply Board** |  | 55d | 2004-01-20 A | 2004-04-06 |  | 93% | 4d | 2004-01-20 | 2004-04-15 | 62d | 21d |  |  |  |
| 435 | 1.6.2.4.1 | **Assembly & Initial Test** |  | 40d | 2004-01-20 A | 2004-03-16 A |  | 100% |  | 2004-01-20 | 2004-03-16 | 40d |  |  |  |  |
| 436 | 1.6.2.4.1.1 | Assemble and Initial Test FM 1 SSD Bias Supply Board |  | 40d | 2004-01-20 A | 2004-03-16 A |  | 100% |  | 2004-01-20 | 2004-03-16 | 40d |  |  | start no earlier than 2004-01-20 |  |
| 437 | 1.6.2.4.1.2 | Assemble and Initial Test FM 2 SSD Bias Supply Board |  | 40d | 2004-01-20 A | 2004-03-16 A | 436SS | 100% |  | 2004-01-20 | 2004-03-16 | 40d |  |  |  |  |
| 438 | 1.6.2.4.2 | **Final Test** |  | 15d | 2004-03-17 A | 2004-04-06 |  | 73% | 4d | 2004-04-02 | 2004-04-15 | 10d | 21d |  |  |  |
| 439 | 1.6.2.4.2.1 | Final Test FM 1 SSD Bias Supply Board |  | 15d | 2004-03-17 A | 2004-04-06 | 436 | 73% | 4d | 2004-04-02 | 2004-04-15 | 10d | 21d |  |  |  |
| 440 | 1.6.2.4.2.2 | Final Test FM 2 SSD Bias Supply Board |  | 15d | 2004-03-17 A | 2004-04-06 | 437 | 73% | 4d | 2004-04-02 | 2004-04-15 | 10d | 21d |  |  |  |
| 441 | 1.6.2.5 | **Conformal Coat, Mass Properties and Bake Out (SEP Central, LET, SEP LVPS)** |  | 17d | 2004-05-07 | 2004-06-01 |  |  |  | 2004-04-16 | 2004-05-10 | 17d | -1d | 0d |  |  |
| 442 | 1.6.2.5.1 | Stake/Conformal Coat All SEP Central and LET Boards |  | 10d | 2004-05-07 | 2004-05-20 | 429, 430, 432, 433, 439, 440, 519, 520 |  |  | 2004-04-16 | 2004-04-29 | 10d | -1d | 0d |  |  |
| 443 | 1.6.2.5.2 | Mass Properties/Photo All SEP Central and LET Boards |  | 4d | 2004-05-21 | 2004-05-26 | 442 |  |  | 2004-04-30 | 2004-05-05 | 4d | -1d | 0d |  |  |
| 444 | 1.6.2.5.3 | Bake Out All SEP Central/LET Boards and SEP LVPS FM 1 |  | 3d | 2004-05-27 | 2004-06-01 | 443, 68 |  |  | 2004-05-06 | 2004-05-10 | 3d | -1d | 0d |  |  |

Notes:
- 444: SEP FM 2 LVPS Bakeout will occur at Berkley prior to delivery 6/18. This allows LET to proceed, which has more to do before I&T than SEP Central.

| ID | WBS | Task | Type | Duration | Start | Finish | Predecessors | Complete | Remaining | Baseline start | Baseline finish | Baseline duration | Total slack | Free slack | Constraint | Text1 |
| --- | --- | --- | --- | --- | --- | --- | --- | --- | --- | --- | --- | --- | --- | --- | --- | --- |
| 445 | 1.6.2.6 | **Flight Software** |  | 211d | 2003-08-01 A | 2004-06-03 |  | 68% | 68d | 2003-08-01 | 2004-06-03 | 211d | 35d |  |  |  |
| 446 | 1.6.2.6.1 | SEP Central Build 3 |  | 176d | 2003-08-01 A | 2004-04-14 |  | 81% | 33d | 2003-08-01 | 2004-04-14 | 176d | 35d | 0d | start no earlier than 2003-08-01 |  |
| 447 | 1.6.2.6.2 | Final Flight S/W Build |  | 35d | 2004-04-15 | 2004-06-03 | 446 |  |  | 2004-04-15 | 2004-06-03 | 35d | 35d | 0d |  |  |
| 448 | 1.6.3 | **HET - Tycho (GSFC)** |  | 139d | 2004-01-06 A | 2004-07-21 |  | 55% | 62.1d | 2004-01-06 | 2004-06-23 | 119d | 48d |  |  |  |
| 449 | 1.6.3.1 | **Deliveries** |  | 36d | 2004-06-02 | 2004-07-21 |  |  |  | 2004-04-30 | 2004-06-23 | 38d | 17d |  |  |  |
| 450 | 1.6.3.1.1 | Deliver HET FM 1w/o replacement detectors (to CIT for SEP Suite I&T) |  | 2d | 2004-06-30 | 2004-07-01 | 404, 496 |  |  | 2004-06-01 | 2004-06-02 | 2d | -3d | 0d |  | MS-SEP |
| 451 | 1.6.3.1.2 | Deliver HET FM 1 w/ replacement detectors (to CIT for SEP Suite I&T) |  | 2d | 2004-07-20 | 2004-07-21 | 499 |  |  | 2004-07-19 | 2004-07-20 | 2d | -5d | 0d |  |  |
| 452 | 1.6.3.1.3 | Deliver HET FM 2 w/o replacement detectors (to CIT for SEP Suite I&T) |  | 2d | 2004-07-07 | 2004-07-08 | 404, 502 |  |  | 2004-06-22 | 2004-06-23 | 2d | 34d | 0d |  | MS-SEP |
| 453 | 1.6.3.1.4 | Deliver HET FM 2 w/ replacement detectors (to CIT for SEP Suite I&T) |  | 2d | 2004-07-20 | 2004-07-21 | 504, 794 |  |  | 2004-07-19 | 2004-07-20 | 2d | 48d | 11d |  |  |
| 454 | 1.6.3.1.5 | Deliver Final HET Flight Software to SEP I&T |  | 2d | 2004-06-02 | 2004-06-03 | 492 |  |  | 2004-04-30 | 2004-05-03 | 2d | 17d |  |  |  |
| 455 | 1.6.3.2 | **Detectors (Batch 1)** |  | 40d | 2004-01-06 A | 2004-03-03 A |  | 100% |  | 2004-01-06 | 2004-03-31 | 60d |  |  |  |  |
| 456 | 1.6.3.2.1 | Receive & Inspect HET Flight Detectors |  | 40d | 2004-01-06 A | 2004-03-03 A |  | 100% |  | 2004-01-06 | 2004-03-03 | 40d |  |  | start no earlier than 2004-01-06 |  |
| 457 | 1.6.3.2.2 | **Detector Testing** |  | 40d | 2004-01-06 A | 2004-03-03 A |  | 100% |  | 2004-01-06 | 2004-03-31 | 60d |  |  |  |  |
| 458 | 1.6.3.2.2.1 | Capacitance, Current, Depletion, Alpha Resolution Testing |  | 40d | 2004-01-06 A | 2004-03-03 A | 456SS | 100% |  | 2004-01-06 | 2004-03-31 | 60d |  |  |  | MS-SEP |
| 459 | 1.6.3.2.2.2 | Life Test HET Detectors |  | 40d | 2004-01-06 A | 2004-03-03 A | 458SS | 100% |  | 2004-01-06 | 2004-03-31 | 60d |  |  |  | MS-SEP |
| 460 | 1.6.3.3 | **Replacement HET Detectors (Batch 2)** |  | 66d | 2004-03-12 A | 2004-06-14 |  |  | 66d | 2004-03-12 | 2004-06-14 | 66d | 18d |  |  |  |
| 461 | 1.6.3.3.1 | Receive H1 Detector Mounts | milestone | 0d | 2004-03-12 A | 2004-03-12 A |  | 100% |  | 2004-03-12 | 2004-03-12 | 0d |  |  | start no earlier than 2004-03-12 |  |
| 462 | 1.6.3.3.2 | Receive H3 Detector Mounts | milestone | 0d | 2004-03-26 A | 2004-03-26 A |  | 100% |  | 2004-03-26 | 2004-03-26 | 0d |  |  | start no earlier than 2004-03-26 |  |
| 463 | 1.6.3.3.3 | Detector Mounting at Micron |  | 20d | 2004-04-15 | 2004-05-12 | 461, 462 |  |  | 2004-04-15 | 2004-05-12 | 20d | 18d | 0d | start no earlier than 2004-04-15 |  |
| 464 | 1.6.3.3.4 | Detector Delivery to GSFC |  | 2d | 2004-05-13 | 2004-05-14 | 463 |  |  | 2004-05-13 | 2004-05-14 | 2d | 18d | 0d |  |  |
| 465 | 1.6.3.3.5 | Detector Testing at GSFC |  | 20d | 2004-05-17 | 2004-06-14 | 464 |  |  | 2004-05-17 | 2004-06-14 | 20d | 18d |  |  |  |
| 466 | 1.6.3.4 | **Electronics Board** |  | 86d | 2004-01-22 A | 2004-05-21 |  | 56% | 38.11d | 2004-01-22 | 2004-05-13 | 80d | 45d |  |  | MS-SEP |
| 467 | 1.6.3.4.1 | **Assembly** |  | 38d | 2004-01-22 A | 2004-03-16 A |  | 100% |  | 2004-01-22 | 2004-03-12 | 36d |  |  |  |  |
| 468 | 1.6.3.4.1.1 | Install Socket on HET Electronics FM 1 Board for ETU ACTEL |  | 1d | 2004-01-22 A | 2004-01-22 A |  | 100% |  | 2004-01-22 | 2004-01-22 | 1d |  |  | start no earlier than 2004-01-22 |  |
| 469 | 1.6.3.4.1.2 | Complete Population of HET Electronics FM 1 Board (ETU ACTEL) |  | 1d | 2004-01-23 A | 2004-01-23 A | 468 | 100% |  | 2004-01-23 | 2004-01-23 | 1d |  |  |  |  |
| 470 | 1.6.3.4.1.3 | Complete Population of HET Electronics FM 2 Board (Flight ACTEL) |  | 2d | 2004-03-15 A | 2004-03-16 A | 469, 476, 513 | 100% |  | 2004-03-11 | 2004-03-12 | 2d |  |  |  |  |

| ID | WBS | Task | Type | Duration | Start | Finish | Predecessors | Complete | Remaining | Baseline start | Baseline finish | Baseline duration | Total slack | Free slack | Constraint |
| --- | --- | --- | --- | --- | --- | --- | --- | --- | --- | --- | --- | --- | --- | --- | --- |
| 471 | 1.6.3.4.2 | **Test** |  | 84d | 2004-01-26 A | 2004-05-21 |  | 54% | 39d | 2004-01-26 | 2004-05-13 | 78d | 45d |  |  |
| 472 | 1.6.3.4.2.1 | **FM 1** |  | 79d | 2004-01-26 A | 2004-05-14 |  | 77% | 17.95d | 2004-01-26 | 2004-03-22 | 40d | 8d |  |  |
| 473 | 1.6.3.4.2.1.1 | Test HET FM 1 Electronics Board w/ETU ACTEL |  | 23d | 2004-01-26 A | 2004-02-26 A | 469 | 100% |  | 2004-01-26 | 2004-02-23 | 20d |  |  |  |
| 474 | 1.6.3.4.2.1.2 | Remove ETU ACTEL and socket from HET FM 1 Electronics Board |  | 0.5d | 2004-02-27 A | 2004-02-27 A | 473 | 100% |  | 2004-02-24 | 2004-02-24 | 1d |  |  |  |
| 475 | 1.6.3.4.2.1.3 | Install Flight ACTEL on HET FM 1 Electronics Board |  | 0.5d | 2004-02-27 A | 2004-02-27 A | 474 | 100% |  | 2004-02-25 | 2004-02-25 | 1d |  |  |  |
| 476 | 1.6.3.4.2.1.4 | Retest HET FM 1 Electronics Board w/Flight ACTEL |  | 10d | 2004-03-01 A | 2004-03-12 A | 475 | 100% |  | 2004-02-26 | 2004-03-10 | 10d |  |  |  |
| 477 | 1.6.3.4.2.1.5 | Clean, Bake, Conformal Coat HET FM 1 Electronics Board |  | 5d | 2004-05-03 | 2004-05-07 | 476FS+35d |  |  | 2004-03-11 | 2004-03-12 | 2d | 8d | 0d |  |
| 478 | 1.6.3.4.2.1.6 | Retest Conformal Coated HET FM 1 Electronics Board |  | 5d | 2004-05-10 | 2004-05-14 | 477 |  |  | 2004-03-15 | 2004-03-16 | 2d | 8d | 0d |  |
| 479 | 1.6.3.4.2.2 | **FM 2** |  | 48d | 2004-03-17 A | 2004-05-21 |  | 28% | 34.8d | 2004-03-23 | 2004-05-13 | 38d | 45d |  |  |
| 480 | 1.6.3.4.2.2.1 | Test HET FM 2 Electronics Board |  | 30d | 2004-03-17 A | 2004-04-27 | 470, 473 | 37% | 19d | 2004-03-23 | 2004-05-03 | 30d | 53d | 0d |  |
| 481 | 1.6.3.4.2.2.2 | Clean, Bake, Conformal Coat HET FM 2 Electronics Board |  | 5d | 2004-04-28 | 2004-05-04 | 480 |  |  | 2004-05-04 | 2004-05-05 | 2d | 53d | 8d |  |
| 482 | 1.6.3.4.2.2.3 | Retest Conformal Coated HET FM 2 Electronics Board |  | 5d | 2004-05-17 | 2004-05-21 | 481, 478 |  |  | 2004-05-06 | 2004-05-07 | 2d | 45d | 11d |  |
| 483 | 1.6.3.5 | **Flight Software** |  | 92d | 2004-01-22 A | 2004-06-01 |  | 54% | 42.08d | 2004-01-22 | 2004-04-29 | 70d | -3d | 0d |  |
| 484 | 1.6.3.5.1 | **Design** |  | 66d | 2004-01-22 A | 2004-04-23 |  | 59% | 26.76d | 2004-01-22 | 2004-02-04 | 10d | -2d | 0d |  |
| 485 | 1.6.3.5.1.1 | Complete Definition of HET PH Event Processing |  | 22d | 2004-01-22 A | 2004-02-23 A |  | 100% |  | 2004-01-22 | 2004-02-04 | 10d |  |  | start no earlier than 2004-01-22 |
| 486 | 1.6.3.5.1.2 | Design Change of HET PH Event Processing |  | 15d | 2004-04-05 | 2004-04-23 |  |  |  | 2004-04-05 | 2004-04-23 | 15d | -2d | 0d | start no earlier than 2004-04-05 |
| 487 | 1.6.3.5.2 | **Coding** |  | 37d | 2004-02-24 A | 2004-04-14 |  | 79% | 7.83d | 2004-02-05 | 2004-03-04 | 20d | 5d |  |  |
| 488 | 1.6.3.5.2.1 | Code HET PH Event Processing Update for Flight |  | 28d | 2004-02-24 A | 2004-04-01 | 485 | 96% | 1d | 2004-02-05 | 2004-02-19 | 10d | 14d | 0d |  |
| 489 | 1.6.3.5.2.2 | Code HET Telemetry Formatting Update for Flight |  | 24d | 2004-03-12 A | 2004-04-14 | 488FS-15d | 58% | 10d | 2004-02-20 | 2004-03-04 | 10d | 0d |  |  |
| 490 | 1.6.3.5.3 | **Test** |  | 50d | 2004-03-23 A | 2004-06-01 |  | 18% | 41.25d | 2004-03-05 | 2004-04-29 | 40d | -3d | 0d |  |
| 491 | 1.6.3.5.3.1 | Test Integrated HET S/W with Simulated Data |  | 15d | 2004-03-23 A | 2004-04-26 | 489 | 47% | 8d | 2004-03-05 | 2004-03-25 | 15d | 0d |  |  |
| 492 | 1.6.3.5.3.2 | Verify HET On-Board Software |  | 25d | 2004-04-27 | 2004-06-01 | 486, 491 |  |  | 2004-03-26 | 2004-04-29 | 25d | -3d | 0d |  |
| 493 | 1.6.3.6 | **Integration & Test** |  | 34d | 2004-06-02 | 2004-07-19 |  |  |  | 2004-05-03 | 2004-06-21 | 35d | -3d | 0d |  |
| 494 | 1.6.3.6.1 | **FM 1** |  | 34d | 2004-06-02 | 2004-07-19 |  |  |  | 2004-05-03 | 2004-05-28 | 20d | -5d | 0d |  |
| 495 | 1.6.3.6.1.1 | Integrate HET FM 1 Electronics Telescope (Ahead) |  | 5d | 2004-06-02 | 2004-06-08 | 459, 492, 394, 478 |  |  | 2004-05-03 | 2004-05-07 | 5d | -3d | 0d |  |
| 496 | 1.6.3.6.1.2 | Test HET FM 1 Telescope (Ahead) |  | 15d | 2004-06-09 | 2004-06-29 | 495 |  |  | 2004-05-10 | 2004-05-28 | 15d | -3d | 0d |  |
| 497 | 1.6.3.6.1.3 | Receive HET FM1 from CIT | milestone | 0d | 2004-07-15 | 2004-07-15 | 792 |  |  | 2004-07-14 | 2004-07-14 | 0d | -5d | 0d |  |
| 498 | 1.6.3.6.1.4 | Install new HET Flight Detectors in FM 1 |  | 1d | 2004-07-16 | 2004-07-16 | 465, 497 |  |  | 2004-06-16 | 2004-06-16 | 1d | -5d | 0d |  |
| 499 | 1.6.3.6.1.5 | Performance Test FM 1 with New Flight Detectors |  | 1d | 2004-07-19 | 2004-07-19 | 498 |  |  | 2004-06-17 | 2004-06-17 | 1d | -5d | 0d |  |

Notes:
- 477: Questioning when to begin the process of Conformally Coating these boards due to part issues. Expect Answer by 4/30/04.
- 480: During removal of a temporary commercial ACTEL (U200) several pads(29) were lifted. We will build a new board, and repair the other board. One will become a Flight Spare. Continue with testing and switch out boards later on. 5d hit to the schedule.
- 486: The scientist needed to make changes to the HET PH Event Processing design due to issues found after the developer completed the majority of the software. Coding and testing can not finish until the design chagne is complete.

| ID | WBS | Task | Type | Duration | Start | Finish | Predecessors | Complete | Remaining | Baseline start | Baseline finish | Baseline duration | Total slack | Free slack | Constraint | Text1 |
| --- | --- | --- | --- | --- | --- | --- | --- | --- | --- | --- | --- | --- | --- | --- | --- | --- |
| 500 | 1.6.3.6.2 | **FM 2** |  | 29d | 2004-06-09 | 2004-07-19 |  |  |  | 2004-05-14 | 2004-06-21 | 26d | 34d |  |  |  |
| 501 | 1.6.3.6.2.1 | Integrate HET FM 2 Electronics Telescope (Behind) |  | 5d | 2004-06-09 | 2004-06-15 | 495, 459, 492, 394, 482 |  |  | 2004-05-14 | 2004-05-20 | 5d | 34d | 0d |  |  |
| 502 | 1.6.3.6.2.2 | Test HET FM 2 Telescope (Behind) |  | 15d | 2004-06-16 | 2004-07-06 | 501 |  |  | 2004-06-01 | 2004-06-21 | 15d | 34d | 0d |  |  |
| 503 | 1.6.3.6.2.3 | Receive HET FM2 from CIT | milestone | 0d | 2004-07-16 | 2004-07-16 | 795, 502 |  |  | 2004-07-15 | 2004-07-15 | 0d | 48d | 0d |  |  |
| 504 | 1.6.3.6.2.4 | Install new HET Flight Detectors in FM 2 |  | 1d | 2004-07-19 | 2004-07-19 | 465, 503 |  |  | 2004-06-17 | 2004-06-17 | 1d | 48d | 0d |  |  |
| 505 | 1.6.4 | **LET - CIT** |  | 243d | 2003-07-14 A | 2004-06-29 |  | 78% | 53.02d | 2003-07-14 | 2004-06-08 | 228d | 41d |  |  |  |
| 506 | 1.6.4.1 | **Deliveries** |  | 39d | 2004-05-04 | 2004-06-29 |  |  |  | 2004-05-04 | 2004-06-08 | 24d | 38d |  |  |  |
| 507 | 1.6.4.1.1 | Deliver LET FM 1 (stays at CIT for SEP I&T) | milestone | 0d | 2004-06-29 | 2004-06-29 | 525 |  |  | 2004-06-08 | 2004-06-08 | 0d | -1d | 0d |  | MS-SEP |
| 508 | 1.6.4.1.2 | Deliver LET FM 2 (stays at CIT for SEP I&T) | milestone | 0d | 2004-06-29 | 2004-06-29 | 527 |  |  | 2004-06-08 | 2004-06-08 | 0d | 41d | 4d |  | MS-SEP |
| 509 | 1.6.4.1.3 | Deliver LET Flight Software Build 3 | milestone | 0d | 2004-05-04 | 2004-05-04 | 522 |  |  | 2004-05-04 | 2004-05-04 | 0d | 38d |  |  |  |
| 510 | 1.6.4.2 | **Detectors** |  | 167d | 2003-07-14 A | 2004-03-12 A |  | 100% |  | 2003-07-14 | 2004-03-12 | 167d |  |  |  |  |
| 511 | 1.6.4.2.1 | Complete LET Flight Detector Testing |  | 167d | 2003-07-14 A | 2004-03-12 A |  | 100% |  | 2003-07-14 | 2004-03-12 | 167d |  |  | start no earlier than 2003-07-14 | MS-SEP |
| 512 | 1.6.4.3 | **Hybrids** |  | 144d | 2003-08-01 A | 2004-03-01 A |  | 100% |  | 2003-08-01 | 2004-03-01 | 144d |  |  |  |  |
| 513 | 1.6.4.3.1 | Complete Test of Flight Hybrids (LET and to GSFC for HET FM 2) |  | 144d | 2003-08-01 A | 2004-03-01 A |  | 100% |  | 2003-08-01 | 2004-03-01 | 144d |  |  | start no earlier than 2003-08-01 |  |
| 514 | 1.6.4.4 | **Detector/Misc Board** |  | 48d | 2004-03-02 A | 2004-05-06 |  | 46% | 26d | 2004-03-02 | 2004-03-30 | 21d | 0d |  |  |  |
| 515 | 1.6.4.4.1 | **Assembly** |  | 10d | 2004-03-02 A | 2004-03-15 A |  | 100% |  | 2004-03-02 | 2004-03-15 | 10d |  |  |  |  |
| 516 | 1.6.4.4.1.1 | Assemble LET FM 1 Detector Board |  | 10d | 2004-03-02 A | 2004-03-15 A | 513 | 100% |  | 2004-03-02 | 2004-03-15 | 10d |  |  |  |  |
| 517 | 1.6.4.4.1.2 | Assemble LET FM 2 Detector Board |  | 10d | 2004-03-02 A | 2004-03-15 A | 513 | 100% |  | 2004-03-02 | 2004-03-15 | 10d |  |  |  |  |
| 518 | 1.6.4.4.2 | **Test** |  | 38d | 2004-03-16 A | 2004-05-06 |  | 32% | 26d | 2004-03-16 | 2004-03-30 | 11d | 0d |  |  |  |
| 519 | 1.6.4.4.2.1 | Test LET FM 1 Detector Board |  | 38d | 2004-03-16 A | 2004-05-06 | 516 | 32% | 26d | 2004-03-16 | 2004-03-30 | 11d | -1d | 0d |  |  |
| 520 | 1.6.4.4.2.2 | Test LET FM 2 Detector Board |  | 38d | 2004-03-16 A | 2004-05-06 | 517 | 32% | 26d | 2004-03-16 | 2004-03-30 | 11d | -1d | 0d |  |  |
| 521 | 1.6.4.5 | **Flight Software** |  | 190d | 2003-08-01 A | 2004-05-04 |  | 75% | 47d | 2003-08-01 | 2004-05-04 | 190d | 38d |  |  |  |
| 522 | 1.6.4.5.1 | Let Flight Software Build 3 |  | 190d | 2003-08-01 A | 2004-05-04 |  | 75% | 47d | 2003-08-01 | 2004-05-04 | 190d | 38d | 0d | start no earlier than 2003-08-01 |  |
| 523 | 1.6.4.6 | **Integration & Test** |  | 20d | 2004-06-02 | 2004-06-29 |  |  |  | 2004-05-11 | 2004-06-08 | 20d | -1d | 0d |  |  |
| 524 | 1.6.4.6.1 | **FM 1** |  | 20d | 2004-06-02 | 2004-06-29 |  |  |  | 2004-05-11 | 2004-06-08 | 20d | -1d | 0d |  |  |
| 525 | 1.6.4.6.1.1 | Integrate LET FM 1 Housing With Detectors |  | 20d | 2004-06-02 | 2004-06-29 | 511, 444, 384 |  |  | 2004-05-11 | 2004-06-08 | 20d | -1d | 0d |  | MS-SEP |

| ID | WBS | Task | Duration | Start | Finish | Predecessors | Complete | Remaining | Baseline start | Baseline finish | Baseline duration | Total slack | Free slack | Constraint | Text1 |
| --- | --- | --- | --- | --- | --- | --- | --- | --- | --- | --- | --- | --- | --- | --- | --- |
| 526 | 1.6.4.6.2 | **FM 2** | 20d | 2004-06-02 | 2004-06-29 |  |  |  | 2004-05-11 | 2004-06-08 | 20d | 41d |  |  |  |
| 527 | 1.6.4.6.2.1 | Integrate LET FM 2 Housing With Detectors | 20d | 2004-06-02 | 2004-06-29 | 511, 444, 384 |  |  | 2004-05-11 | 2004-06-08 | 20d | 41d | 0d |  | MS-SEP |
| 528 | 1.6.5 | **SEPT - Kiel/ESTEC** | 271d | 2003-08-08 A | 2004-09-02 |  | 90% | 28.26d | 2003-08-08 | 2004-07-28 | 245d | 23d |  |  |  |
| 529 | 1.6.5.1 | **Deliveries** | 123d | 2004-03-15 | 2004-09-02 |  |  |  | 2004-03-11 | 2004-07-28 | 99d | 8d |  |  |  |
| 530 | 1.6.5.1.1 | Deliver SEPT-NS FM 1 to CIT for SEP I&T and Suite EMC | 5d | 2004-03-15 | 2004-03-19 | 569, 570 |  |  | 2004-03-11 | 2004-03-17 | 5d | 8d | 0d |  | MS-SEP |
| 531 | 1.6.5.1.2 | Deliver SEPT-E FM 1 to CIT for SEP I&T and Suite EMC | 5d | 2004-03-15 | 2004-03-19 | 577, 576 |  |  | 2004-03-11 | 2004-03-17 | 5d | 8d | 0d |  | MS-SEP |
| 532 | 1.6.5.1.3 | Final Delivery of SEPT FM 1 to APL (after Therm Bal @ GSFC) | 2d | 2004-09-01 | 2004-09-02 | 571, 578, 562 |  |  | 2004-07-27 | 2004-07-28 | 2d | 23d |  |  |  |
| 533 | 1.6.5.1.4 | Deliver SEPT-NS FM 2 to CIT for SEP I&T and Suite EMC | 5d | 2004-03-18 | 2004-03-24 | 584, 585 |  |  | 2004-03-22 | 2004-03-26 | 5d | 107d | 0d |  | MS-SEP |
| 534 | 1.6.5.1.5 | Deliver SEPT-E FM 2 to CIT for SEP I&T and Suite EMC | 5d | 2004-03-18 | 2004-03-24 | 590, 591 |  |  | 2004-03-22 | 2004-03-26 | 5d | 107d | 0d |  | MS-SEP |
| 535 | 1.6.5.2 | **Mechanical Assembly** | 46d | 2003-12-22 A | 2004-02-27 A |  | 100% |  | 2003-12-22 | 2004-02-27 | 46d |  |  |  |  |
| 536 | 1.6.5.2.1 | **FM 1** | 13d | 2003-12-22 A | 2004-01-09 A |  | 100% |  | 2003-12-22 | 2004-01-09 | 13d |  |  |  |  |
| 537 | 1.6.5.2.1.1 | Assemble SEPT-NS FM 1 Sensor and E-Box Housing | 13d | 2003-12-22 A | 2004-01-09 A |  | 100% |  | 2003-12-22 | 2004-01-09 | 13d |  |  | start no earlier than 2003-12-22 |  |
| 538 | 1.6.5.2.1.2 | Assemble SEPT-E FM 1 Sensor and E-Box Housing | 13d | 2003-12-22 A | 2004-01-09 A |  | 100% |  | 2003-12-22 | 2004-01-09 | 13d |  |  | start no earlier than 2003-12-22 |  |
| 539 | 1.6.5.2.2 | **FM 2** | 14d | 2003-12-29 A | 2004-01-16 A |  | 100% |  | 2003-12-29 | 2004-01-16 | 14d |  |  |  |  |
| 540 | 1.6.5.2.2.1 | Assemble SEPT-NS FM 2 Sensor and E-Box Housing | 14d | 2003-12-29 A | 2004-01-16 A | 537SS+4d | 100% |  | 2003-12-29 | 2004-01-16 | 14d |  |  |  |  |
| 541 | 1.6.5.2.2.2 | Assemble SEPT-E FM 2 Sensor and E-Box Housing | 14d | 2003-12-29 A | 2004-01-16 A | 538SS+4d | 100% |  | 2003-12-29 | 2004-01-16 | 14d |  |  |  |  |
| 542 | 1.6.5.2.3 | **Spare** | 28d | 2004-01-20 A | 2004-02-27 A |  | 100% |  | 2004-01-20 | 2004-02-27 | 28d |  |  |  |  |
| 543 | 1.6.5.2.3.1 | Assemble SEPT Spare Sensor and E-Box Housing | 28d | 2004-01-20 A | 2004-02-27 A | 540, 541 | 100% |  | 2004-01-20 | 2004-02-27 | 28d |  |  |  |  |
| 544 | 1.6.5.3 | **Electronics** | 198d | 2003-08-08 A | 2004-05-21 |  | 94% | 12.26d | 2003-08-08 | 2004-05-21 | 198d | 94d |  |  |  |
| 545 | 1.6.5.3.1 | **Assembly** | 172d | 2003-08-08 A | 2004-04-15 |  | 97% | 5.11d | 2003-08-08 | 2004-04-15 | 172d | 105d |  |  |  |
| 546 | 1.6.5.3.1.1 | **FM 2** | 106d | 2003-08-08 A | 2004-01-12 A |  | 100% |  | 2003-08-08 | 2004-01-12 | 106d |  |  |  |  |
| 547 | 1.6.5.3.1.1.1 | Assemble SEPT-NS FM 2 Electronics | 106d | 2003-08-08 A | 2004-01-12 A |  | 100% |  | 2003-08-08 | 2004-01-12 | 106d |  |  | start no earlier than 2003-08-08 |  |
| 548 | 1.6.5.3.1.1.2 | Assemble SEPT-E FM 2 Electronics | 92d | 2003-08-08 A | 2003-12-19 A |  | 100% |  | 2003-08-08 | 2003-12-19 | 92d |  |  | start no earlier than 2003-08-08 |  |
| 549 | 1.6.5.3.1.2 | **Spare** | 172d | 2003-08-08 A | 2004-04-15 |  | 94% | 11d | 2003-08-08 | 2004-04-15 | 172d | 105d |  |  |  |
| 550 | 1.6.5.3.1.2.1 | Assemble SEPT FS Electronics | 172d | 2003-08-08 A | 2004-04-15 | 547SS | 94% | 11d | 2003-08-08 | 2004-04-15 | 172d | 105d | 6d |  |  |

| ID | WBS | Task | Duration | Start | Finish | Predecessors | Complete | Remaining | Baseline start | Baseline finish | Baseline duration | Total slack | Free slack | Constraint | Text1 |
| --- | --- | --- | --- | --- | --- | --- | --- | --- | --- | --- | --- | --- | --- | --- | --- |
| 551 | 1.6.5.3.2 | **Test** | 113d | 2003-12-11 A | 2004-05-21 |  | 70% | 33.9d | 2003-12-11 | 2004-05-21 | 113d | 94d |  |  |  |
| 552 | 1.6.5.3.2.1 | **FM 2** | 34d | 2003-12-11 A | 2004-01-30 A |  | 100% |  | 2003-12-11 | 2004-01-30 | 34d |  |  |  |  |
| 553 | 1.6.5.3.2.1.1 | SEPT-NS FM 2 Electronics Test | 4d | 2004-01-13 A | 2004-01-16 A | 547 | 100% |  | 2004-01-13 | 2004-01-16 | 4d |  |  |  |  |
| 554 | 1.6.5.3.2.1.2 | SEPT-E FM 2 Electronics Test | 4d | 2003-12-11 A | 2003-12-16 A | 548FS-7d | 100% |  | 2003-12-11 | 2003-12-16 | 4d |  |  |  |  |
| 555 | 1.6.5.3.2.1.3 | Coat SEPT-NS FM 2 Electronics Board | 4d | 2004-01-20 A | 2004-01-23 A | 553 | 100% |  | 2004-01-20 | 2004-01-23 | 4d |  |  |  |  |
| 556 | 1.6.5.3.2.1.4 | Coat SEPT-E FM 2 Electronics Board | 5d | 2003-12-17 A | 2003-12-23 A | 554 | 100% |  | 2003-12-17 | 2003-12-23 | 5d |  |  |  |  |
| 557 | 1.6.5.3.2.1.5 | SEPT-NS FM 2 Mechanical Integration | 5d | 2004-01-26 A | 2004-01-30 A | 555 | 100% |  | 2004-01-26 | 2004-01-30 | 5d |  |  |  |  |
| 558 | 1.6.5.3.2.1.6 | SEPT-E FM 2 Mechanical Integration | 13d | 2003-12-24 A | 2004-01-13 A | 556 | 100% |  | 2003-12-24 | 2004-01-13 | 13d |  |  |  |  |
| 559 | 1.6.5.3.2.2 | **Spare** | 20d | 2004-04-26 | 2004-05-21 |  |  |  | 2004-04-26 | 2004-05-21 | 20d | 94d |  |  |  |
| 560 | 1.6.5.3.2.2.1 | SEPT Flight Spare Electronics Test | 5d | 2004-04-26 | 2004-04-30 | 550 |  |  | 2004-04-26 | 2004-04-30 | 5d | 99d | 5d | start no earlier than 2004-04-26 |  |
| 561 | 1.6.5.3.2.2.2 | Coat SEPT FS Electronics Board | 5d | 2004-05-10 | 2004-05-14 | 560 |  |  | 2004-05-10 | 2004-05-14 | 5d | 94d | 0d | start no earlier than 2004-05-10 |  |
| 562 | 1.6.5.3.2.2.3 | SEPT FS Mechanical Integration | 5d | 2004-05-17 | 2004-05-21 | 561 |  |  | 2004-05-17 | 2004-05-21 | 5d | 94d | 71d |  |  |
| 563 | 1.6.5.4 | **Integration & Test** | 164d | 2004-01-12 A | 2004-08-31 |  | 84% | 25.62d | 2004-01-12 | 2004-07-26 | 138d | 23d |  |  |  |
| 564 | 1.6.5.4.1 | **FM 1** | 164d | 2004-01-12 A | 2004-08-31 |  | 73% | 44.32d | 2004-01-12 | 2004-07-26 | 138d | 23d |  |  |  |
| 565 | 1.6.5.4.1.1 | **SEPT-NS** | 155d | 2004-01-26 A | 2004-08-31 |  | 73% | 41.89d | 2004-01-26 | 2004-07-26 | 129d | 23d |  |  |  |
| 566 | 1.6.5.4.1.1.1 | SEPT-NS FM 1 Integration & Test | 5d | 2004-01-26 A | 2004-01-30 A | 537 | 100% |  | 2004-01-26 | 2004-01-30 | 5d |  |  | start no earlier than 2004-01-26 |  |
| 567 | 1.6.5.4.1.1.2 | Muon and Radioactive Source Test | 5d | 2004-02-02 A | 2004-02-06 A | 566 | 100% |  | 2004-02-02 | 2004-02-06 | 5d |  |  |  |  |
| 568 | 1.6.5.4.1.1.3 | SEPT-NS FM 1 Vibration | 4d | 2004-02-19 A | 2004-02-24 A | 567 | 100% |  | 2004-02-17 | 2004-02-20 | 4d |  |  | start no earlier than 2004-02-19 | MS-SEP |
| 569 | 1.6.5.4.1.1.4 | SEPT-NS FM 1 Thermal Vac | 11d | 2004-02-27 A | 2004-03-12 A | 568FS+2d | 100% |  | 2004-02-25 | 2004-03-08 | 9d |  |  |  |  |
| 570 | 1.6.5.4.1.1.5 | SEPT-NS FM 1 Bake Out | 2d | 2004-03-05 A | 2004-03-08 A | 569FS-6d | 100% |  | 2004-03-09 | 2004-03-10 | 2d |  |  |  |  |
| 571 | 1.6.5.4.1.1.6 | SEPT-NS FM 1 Thermal Balance (at GSFC after Suite EMC) | 10d | 2004-08-18 | 2004-08-31 | 19 |  |  | 2004-07-13 | 2004-07-26 | 10d | 23d | 0d |  |  |
| 572 | 1.6.5.4.1.2 | **SEPT-E** | 164d | 2004-01-12 A | 2004-08-31 |  | 73% | 44.32d | 2004-01-12 | 2004-07-26 | 138d | 23d |  |  |  |
| 573 | 1.6.5.4.1.2.1 | SEPT-E FM 1 Integration & Test | 5d | 2004-01-12 A | 2004-01-16 A | 538 | 100% |  | 2004-01-12 | 2004-01-16 | 5d |  |  |  |  |
| 574 | 1.6.5.4.1.2.2 | Muon and Radioactive Source Test | 5d | 2004-01-29 A | 2004-02-04 A | 573 | 100% |  | 2004-01-29 | 2004-02-04 | 5d |  |  | start no earlier than 2004-01-29 |  |
| 575 | 1.6.5.4.1.2.3 | SEPT-E FM 1 Vibration | 4d | 2004-02-19 A | 2004-02-24 A | 574, 568SS | 100% |  | 2004-02-21 | 2004-02-24 | 4d |  |  |  |  |
| 576 | 1.6.5.4.1.2.4 | SEPT-E FM 1 Thermal Vac | 11d | 2004-02-27 A | 2004-03-12 A | 575, 569SS | 100% |  | 2004-02-25 | 2004-03-08 | 9d |  |  |  |  |
| 577 | 1.6.5.4.1.2.5 | SEPT-E FM 1 Bake Out | 2d | 2004-03-05 A | 2004-03-08 A | 576FS-6d | 100% |  | 2004-03-09 | 2004-03-10 | 2d |  |  |  |  |
| 578 | 1.6.5.4.1.2.6 | SEPT-E FM 1 Thermal Balance (at GSFC after Suite EMC) | 10d | 2004-08-18 | 2004-08-31 | 19 |  |  | 2004-07-13 | 2004-07-26 | 10d | 23d | 0d |  |  |

Notes:
- 568: There was a failure on the SEPT door during Vibration Test. Vibration Test will be repeated once the fix to the door is implemented. Time and place is TBD.
- 575: There was a failure on the SEPT door during Vibration Test. Vibration Test will be repeated once the fix to the door is implemented. Time and place is TBD.

| ID | WBS | Task | Duration | Start | Finish | Predecessors | Complete | Remaining | Baseline start | Baseline finish | Baseline duration | Total slack | Free slack | Constraint | Text1 |
| --- | --- | --- | --- | --- | --- | --- | --- | --- | --- | --- | --- | --- | --- | --- | --- |
| 579 | 1.6.5.4.2 | **FM 2** | 46d | 2004-01-12 A | 2004-03-17 A |  | 100% |  | 2004-01-12 | 2004-03-19 | 48d |  |  |  |  |
| 580 | 1.6.5.4.2.1 | **SEPT-NS** | 41d | 2004-01-20 A | 2004-03-17 A |  | 100% |  | 2004-01-20 | 2004-03-19 | 43d |  |  |  |  |
| 581 | 1.6.5.4.2.1.1 | SEPT-NS FM 2 Integration & Test | 8d | 2004-01-20 A | 2004-01-29 A | 540 | 100% |  | 2004-01-20 | 2004-01-29 | 8d |  |  |  |  |
| 582 | 1.6.5.4.2.1.2 | Muon and Radioactive Source Test | 6d | 2004-01-30 A | 2004-02-06 A | 581 | 100% |  | 2004-01-30 | 2004-02-06 | 6d |  |  |  |  |
| 583 | 1.6.5.4.2.1.3 | SEPT-NS FM 2 Vibration | 4d | 2004-02-19 A | 2004-02-24 A | 582, 568SS | 100% |  | 2004-02-17 | 2004-02-20 | 4d |  |  |  |  |
| 584 | 1.6.5.4.2.1.4 | SEPT-NS FM 2 Thermal Vac | 9d | 2004-03-05 A | 2004-03-17 A | 583 | 100% |  | 2004-03-09 | 2004-03-17 | 9d |  |  | start no earlier than 2004-03-05 |  |
| 585 | 1.6.5.4.2.1.5 | SEPT-NS FM 2 Bake Out | 2d | 2004-03-12 A | 2004-03-15 A | 584FS-4d | 100% |  | 2004-03-18 | 2004-03-19 | 2d |  |  |  |  |
| 586 | 1.6.5.4.2.2 | **SEPT-E** | 46d | 2004-01-12 A | 2004-03-17 A |  | 100% |  | 2004-01-12 | 2004-03-19 | 48d |  |  |  |  |
| 587 | 1.6.5.4.2.2.1 | SEPT-E FM 2 Integration & Test | 5d | 2004-01-12 A | 2004-01-16 A | 573SS | 100% |  | 2004-01-12 | 2004-01-16 | 5d |  |  |  |  |
| 588 | 1.6.5.4.2.2.2 | Muon and Radioactive Source Test | 5d | 2004-01-29 A | 2004-02-04 A | 587, 574SS | 100% |  | 2004-01-29 | 2004-02-04 | 5d |  |  |  |  |
| 589 | 1.6.5.4.2.2.3 | SEPT-E FM 2 Vibration | 4d | 2004-02-19 A | 2004-02-24 A | 588, 568SS | 100% |  | 2004-02-21 | 2004-02-24 | 4d |  |  |  |  |
| 590 | 1.6.5.4.2.2.4 | SEPT-E FM 2 Thermal Vac | 9d | 2004-03-05 A | 2004-03-17 A | 589, 584SS | 100% |  | 2004-03-09 | 2004-03-17 | 9d |  |  |  |  |
| 591 | 1.6.5.4.2.2.5 | SEPT-E FM 2 Bake Out | 2d | 2004-03-12 A | 2004-03-15 A | 590FS-4d | 100% |  | 2004-03-18 | 2004-03-19 | 2d |  |  |  |  |
| 592 | 1.6.6 | **SIT - UMD** | 354d | 2003-06-02 A | 2004-10-25 |  | 52% | 169.88d | 2003-06-02 | 2004-10-20 | 351d | 2d |  |  |  |
| 593 | 1.6.6.1 | **Deliveries** | 64d | 2004-07-26 | 2004-10-25 |  |  |  | 2004-06-18 | 2004-10-12 | 81d | -8d | 0d |  |  |
| 594 | 1.6.6.1.1 | Deliver SIT FM 1 to CIT for SEP I&T and Suite EMC | 2d | 2004-07-26 | 2004-07-27 | 405, 687 |  |  | 2004-06-18 | 2004-06-21 | 2d | -8d | 0d |  | MS-SEP |
| 595 | 1.6.6.1.2 | Deliver SIT FM 1 back to GSFC for Environmental Testing (after EMC Test) | 2d | 2004-08-18 | 2004-08-19 | 19, 412 |  |  | 2004-07-13 | 2004-07-14 | 2d | -3d | 0d |  | MS-SEP |
| 596 | 1.6.6.1.3 | Final Delivery of SIT FM 1 to APL | 1d | 2004-10-12 | 2004-10-12 | 721 |  |  | 2004-09-01 | 2004-09-01 | 1d | -3d | 0d |  | MS-SEP |
| 597 | 1.6.6.1.4 | Deliver SIT FM 2 to CIT for SEP I&T | 2d | 2004-08-13 | 2004-08-16 | 692, 405 |  |  | 2004-07-23 | 2004-07-26 | 2d | 1d | 0d |  | MS-SEP |
| 598 | 1.6.6.1.5 | Deliver SIT FM 2 back to GSFC for Environmental Testing | 2d | 2004-08-31 | 2004-09-01 | 783 |  |  | 2004-08-19 | 2004-08-20 | 2d | 2d | 0d |  | MS-SEP |
| 599 | 1.6.6.1.6 | Final Delivery of SIT FM 2 to APL | 1d | 2004-10-25 | 2004-10-25 | 730, 736 |  |  | 2004-10-12 | 2004-10-12 | 1d | 2d | 0d |  | MS-SEP |
| 600 | 1.6.6.2 | **ACTEL - for SIT Logic Board** | 11d | 2004-05-17 | 2004-06-01 |  |  |  | 2004-02-27 | 2004-03-12 | 11d | 13d |  |  |  |
| 601 | 1.6.6.2.1 | Burn Final SIT ACTEL Chip (at GSFC) | 1d | 2004-05-17 | 2004-05-17 |  |  |  | 2004-02-27 | 2004-02-27 | 1d | 13d | 0d | start no earlier than 2004-05-17 |  |
| 602 | 1.6.6.2.2 | Evaluate (Test) SIT Final ACTEL Chip | 10d | 2004-05-18 | 2004-06-01 | 601 |  |  | 2004-03-01 | 2004-03-12 | 10d | 13d |  |  |  |

Notes:
- 583: There was a failure on the SEPT door during Vibration Test. Vibration Test will be repeated once the fix to the door is implemented. Time and place is TBD.
- 589: There was a failure on the SEPT door during Vibration Test. Vibration Test will be repeated once the fix to the door is implemented. Time and place is TBD.

| ID | WBS | Task | Type | Duration | Start | Finish | Predecessors | Complete | Remaining | Baseline start | Baseline finish | Baseline duration | Total slack | Free slack | Constraint |
| --- | --- | --- | --- | --- | --- | --- | --- | --- | --- | --- | --- | --- | --- | --- | --- |
| 603 | 1.6.6.3 | **TOF Boards** |  | 59d | 2004-02-12 A | 2004-05-05 |  | 48% | 30.73d | 2004-02-12 | 2004-03-11 | 20d | 28d |  |  |
| 604 | 1.6.6.3.1 | Receive Analog and Digital TOF Boards (FM 1) | milestone | 0d | 2004-02-12 A | 2004-02-12 A |  | 100% |  | 2004-02-12 | 2004-02-12 | 0d |  |  | start no earlier than 2004-02-12 |
| 605 | 1.6.6.3.2 | Receive Analog and Digital TOF Boards (FM 2) |  | 20d | 2004-03-25 A | 2004-04-21 | 608 | 25% | 15d | 2004-03-15 | 2004-04-09 | 20d | 28d | 0d |  |
| 606 | 1.6.6.3.3 | **Test** |  | 48d | 2004-03-01 A | 2004-05-05 |  | 64% | 17.14d | 2004-02-12 | 2004-03-11 | 20d | 28d |  |  |
| 607 | 1.6.6.3.3.1 | **FM 1** |  | 18d | 2004-03-01 A | 2004-03-24 A |  | 100% |  | 2004-02-12 | 2004-02-26 | 10d |  |  |  |
| 608 | 1.6.6.3.3.1.1 | FM 1 TOF Boards Functional Test |  | 18d | 2004-03-01 A | 2004-03-24 A | 604 | 100% |  | 2004-02-12 | 2004-02-26 | 10d |  |  | start no earlier than 2004-03-01 |
| 609 | 1.6.6.3.3.2 | **FM 2** |  | 10d | 2004-04-22 | 2004-05-05 |  |  |  | 2004-02-27 | 2004-03-11 | 10d | 28d |  |  |
| 610 | 1.6.6.3.3.2.1 | FM 2 TOF Boards Functional Test |  | 10d | 2004-04-22 | 2004-05-05 | 604, 605 |  |  | 2004-02-27 | 2004-03-11 | 10d | 28d | 27d |  |
| 611 | 1.6.6.4 | **Energy Board** |  | 129d | 2003-11-10 A | 2004-05-14 |  | 83% | 21.92d | 2003-11-10 | 2004-04-02 | 99d | 21d |  |  |
| 612 | 1.6.6.4.1 | **Assembly** |  | 114d | 2003-11-10 A | 2004-04-23 |  | 94% | 6.48d | 2003-11-10 | 2004-02-20 | 69d | 21d |  |  |
| 613 | 1.6.6.4.1.1 | **FM 1** |  | 92d | 2003-11-10 A | 2004-03-24 A |  | 100% |  | 2003-11-10 | 2004-02-20 | 69d |  |  |  |
| 614 | 1.6.6.4.1.1.1 | Assemble FM 1 Energy Board |  | 92d | 2003-11-10 A | 2004-03-24 A |  | 100% |  | 2003-11-10 | 2004-02-20 | 69d |  |  | start no earlier than 2003-11-10 |
| 615 | 1.6.6.4.1.2 | **FM 2** |  | 114d | 2003-11-10 A | 2004-04-23 |  | 88% | 13.57d | 2003-11-10 | 2004-02-20 | 69d | 21d |  |  |
| 616 | 1.6.6.4.1.2.1 | Assemble FM 2 Energy Board |  | 84d | 2003-11-10 A | 2004-04-23 | 614FF+22d | 88% | 10d | 2003-11-10 | 2004-02-20 | 69d | 21d | 0d |  |
| 617 | 1.6.6.4.2 | **Test** |  | 37d | 2004-03-25 A | 2004-05-14 |  | 17% | 30.83d | 2004-02-23 | 2004-04-02 | 30d | 21d |  |  |
| 618 | 1.6.6.4.2.1 | **FM 1** |  | 15d | 2004-03-25 A | 2004-04-14 |  | 33% | 10d | 2004-02-23 | 2004-03-12 | 15d | 17d |  |  |
| 619 | 1.6.6.4.2.1.1 | Bench Test/Calibration |  | 10d | 2004-03-25 A | 2004-04-07 | 614 | 50% | 5d | 2004-02-23 | 2004-03-05 | 10d | 17d | 0d |  |
| 620 | 1.6.6.4.2.1.2 | Thermal |  | 3d | 2004-04-08 | 2004-04-12 | 619 |  |  | 2004-03-08 | 2004-03-10 | 3d | 17d | 0d |  |
| 621 | 1.6.6.4.2.1.3 | Voltage Margin |  | 2d | 2004-04-13 | 2004-04-14 | 620 |  |  | 2004-03-11 | 2004-03-12 | 2d | 17d | 7d |  |
| 622 | 1.6.6.4.2.2 | **FM 2** |  | 15d | 2004-04-26 | 2004-05-14 |  |  |  | 2004-03-15 | 2004-04-02 | 15d | 21d |  |  |
| 623 | 1.6.6.4.2.2.1 | FM 2 Energy Board Functional Test |  | 15d | 2004-04-26 | 2004-05-14 | 616, 621 |  |  | 2004-03-15 | 2004-04-02 | 15d | 21d | 20d |  |
| 624 | 1.6.6.5 | **Logic Board** |  | 183d | 2003-11-10 A | 2004-07-30 |  | 61% | 71.41d | 2003-11-10 | 2004-07-09 | 168d | 1d |  |  |
| 625 | 1.6.6.5.1 | **Design** |  | 3d | 2003-11-17 A | 2003-11-19 A |  | 100% |  | 2003-11-17 | 2003-11-19 | 3d |  |  |  |
| 626 | 1.6.6.5.1.1 | Layout new Logic Board Design |  | 3d | 2003-11-17 A | 2003-11-19 A |  | 100% |  | 2003-11-17 | 2003-11-19 | 3d |  |  | start no earlier than 2003-11-17 |

| ID | WBS | Task | Duration | Start | Finish | Predecessors | Complete | Remaining | Baseline start | Baseline finish | Baseline duration | Total slack | Free slack | Constraint |
| --- | --- | --- | --- | --- | --- | --- | --- | --- | --- | --- | --- | --- | --- | --- |
| 627 | 1.6.6.5.2 | **Fabrication** | 10d | 2004-03-08 A | 2004-03-19 A |  | 100% |  | 2004-02-09 | 2004-02-23 | 10d |  |  |  |
| 628 | 1.6.6.5.2.1 | FM 1 & FM 2 Logic Board Fabrication | 10d | 2004-03-08 A | 2004-03-19 A | 626, 642 | 100% |  | 2004-02-09 | 2004-02-23 | 10d |  |  | start no earlier than 2004-02-02 |
| 629 | 1.6.6.5.3 | **Assembly** | 75d | 2004-04-14 | 2004-07-28 |  |  |  | 2004-03-09 | 2004-07-07 | 86d | -8d | 0d |  |
| 630 | 1.6.6.5.3.1 | **FM 1** | 58d | 2004-04-14 | 2004-07-05 |  |  |  | 2004-03-09 | 2004-05-27 | 58d | -8d | 0d |  |
| 631 | 1.6.6.5.3.1.1 | Assemble FM 1 Logic Board with ETU ACTELs | 11d | 2004-04-14 | 2004-04-28 | 644FS+9d |  |  | 2004-03-09 | 2004-03-23 | 11d | -8d | 0d |  |
| 632 | 1.6.6.5.3.1.2 | Disassembel FM 1 Logic Board with ETU ACTELs | 1d | 2004-06-30 | 2004-06-30 | 701 |  |  | 2004-05-24 | 2004-05-24 | 1d | -8d | 0d |  |
| 633 | 1.6.6.5.3.1.3 | Retrofit/Inspect FM 1 Flight ACTELs | 2d | 2004-07-01 | 2004-07-02 | 632, 602 |  |  | 2004-05-25 | 2004-05-26 | 2d | -8d | 0d |  |
| 634 | 1.6.6.5.3.1.4 | Reassemble FM 1 Logic Board with Flight ACTELs | 1d | 2004-07-05 | 2004-07-05 | 633 |  |  | 2004-05-27 | 2004-05-27 | 1d | -8d | 0d |  |
| 635 | 1.6.6.5.3.2 | **FM 2** | 75d | 2004-04-14 | 2004-07-28 |  |  |  | 2004-03-09 | 2004-07-07 | 86d | 1d |  |  |
| 636 | 1.6.6.5.3.2.1 | Assemble FM 2 Logic Board with ETU ACTELS | 11d | 2004-04-14 | 2004-04-28 | 644FS+9d |  |  | 2004-03-09 | 2004-03-23 | 11d | 18d | 15d |  |
| 637 | 1.6.6.5.3.2.2 | Disassemble FM 2 Logic Boards | 1d | 2004-07-23 | 2004-07-23 | 710, 632SS |  |  | 2004-07-02 | 2004-07-02 | 1d | 1d | 0d |  |
| 638 | 1.6.6.5.3.2.3 | Retrofit/Inspect Flight ACTELS | 2d | 2004-07-26 | 2004-07-27 | 637, 602 |  |  | 2004-07-05 | 2004-07-06 | 2d | 1d | 0d |  |
| 639 | 1.6.6.5.3.2.4 | Reassemble FM 2 Logic Boards | 1d | 2004-07-28 | 2004-07-28 | 638 |  |  | 2004-07-07 | 2004-07-07 | 1d | 1d | 0d |  |
| 640 | 1.6.6.5.4 | **Test** | 183d | 2003-11-10 A | 2004-07-30 |  | 72% | 51.42d | 2003-11-10 | 2004-07-09 | 168d | 1d |  |  |
| 641 | 1.6.6.5.4.1 | **ETU** | 79d | 2003-11-10 A | 2004-03-05 A |  | 100% |  | 2003-11-10 | 2004-02-06 | 60d |  |  |  |
| 642 | 1.6.6.5.4.1.1 | Test New ETU Logic Board | 79d | 2003-11-10 A | 2004-03-05 A |  | 100% |  | 2003-11-10 | 2004-02-06 | 60d |  |  | start no earlier than 2003-11-10 |
| 643 | 1.6.6.5.4.2 | **FM1 & FM 2** | 8d | 2004-03-22 A | 2004-03-31 A |  | 100% |  | 2004-02-24 | 2004-03-08 | 10d |  |  |  |
| 644 | 1.6.6.5.4.2.1 | Coupon Testing | 8d | 2004-03-22 A | 2004-03-31 A | 628 | 100% |  | 2004-02-24 | 2004-03-08 | 10d |  |  |  |
| 645 | 1.6.6.5.4.3 | **FM 1** | 49d | 2004-04-29 | 2004-07-07 |  |  |  | 2004-03-24 | 2004-06-01 | 49d | -8d | 0d |  |
| 646 | 1.6.6.5.4.3.1 | Functional Test of FM 1 Logic Board w/ETU ACTELS | 15d | 2004-04-29 | 2004-05-19 | 631 |  |  | 2004-03-24 | 2004-04-13 | 15d | -8d | 0d |  |
| 647 | 1.6.6.5.4.3.2 | Funtional Test of FM 1 Logic Board w/Flight ACTELS | 2d | 2004-07-06 | 2004-07-07 | 634 |  |  | 2004-05-28 | 2004-06-01 | 2d | -8d | 0d |  |
| 648 | 1.6.6.5.4.4 | **FM 2** | 51d | 2004-05-20 | 2004-07-30 |  |  |  | 2004-04-14 | 2004-07-09 | 62d | 1d |  |  |
| 649 | 1.6.6.5.4.4.1 | Functional Test of FM 2 Logic Board w/ETU ACTELS | 15d | 2004-05-20 | 2004-06-10 | 636, 646 |  |  | 2004-04-14 | 2004-05-04 | 15d | 3d | 2d |  |
| 650 | 1.6.6.5.4.4.2 | Functional Test of FM 2 Logic Board w/Flight ACTELS | 2d | 2004-07-29 | 2004-07-30 | 639 |  |  | 2004-07-08 | 2004-07-09 | 2d | 1d | 0d |  |

| ID | WBS | Task | Duration | Start | Finish | Predecessors | Complete | Remaining | Baseline start | Baseline finish | Baseline duration | Total slack | Free slack | Constraint |
| --- | --- | --- | --- | --- | --- | --- | --- | --- | --- | --- | --- | --- | --- | --- |
| 651 | 1.6.6.6 | **Mother Board** | 107d | 2003-12-22 A | 2004-05-24 |  | 59% | 43.9d | 2003-12-22 | 2004-03-25 | 65d | 2d |  |  |
| 652 | 1.6.6.6.1 | **Design** | 67d | 2003-12-22 A | 2004-03-29 A |  | 100% |  | 2003-12-22 | 2004-02-04 | 30d |  |  |  |
| 653 | 1.6.6.6.1.1 | **FM 1 & FM 2** | 67d | 2003-12-22 A | 2004-03-29 A |  | 100% |  | 2003-12-22 | 2004-02-04 | 30d |  |  |  |
| 654 | 1.6.6.6.1.1.1 | Finalize Mother Board Layout | 30d | 2003-12-22 A | 2004-02-04 A |  | 100% |  | 2003-12-22 | 2004-02-04 | 30d |  |  | start no earlier than 2003-12-22 |
| 655 | 1.6.6.6.1.1.2 | Redesign Mother Board Layout | 17d | 2004-03-05 A | 2004-03-29 A | 654, 665 | 100% |  | 2004-03-05 | 2004-03-29 | 17d |  |  |  |
| 656 | 1.6.6.6.2 | **Fabrication** | 52d | 2004-02-05 A | 2004-04-19 |  | 57% | 22.53d | 2004-02-05 | 2004-02-26 | 15d | 0d |  |  |
| 657 | 1.6.6.6.2.1 | **FM 1 & FM 2** | 52d | 2004-02-05 A | 2004-04-19 |  | 57% | 22.53d | 2004-02-05 | 2004-02-26 | 15d | 0d |  |  |
| 658 | 1.6.6.6.2.1.1 | Fabricate FM 1 & FM 2 Mother Boards | 15d | 2004-02-05 A | 2004-02-26 A |  | 100% |  | 2004-02-05 | 2004-02-26 | 15d |  |  |  |
| 659 | 1.6.6.6.2.1.2 | Refabricate FM1 & FM2 Mother Boards | 15d | 2004-03-30 A | 2004-04-19 | 665, 655 | 13% | 13d | 2004-03-30 | 2004-04-19 | 15d | -6d | 0d |  |
| 660 | 1.6.6.6.3 | **Assembly** | 10d | 2004-04-27 | 2004-05-10 |  |  |  | 2004-02-27 | 2004-03-11 | 10d | -6d | 0d |  |
| 661 | 1.6.6.6.3.1 | Assemble FM 1 Mother Board | 10d | 2004-04-27 | 2004-05-10 | 658, 666 |  |  | 2004-02-27 | 2004-03-11 | 10d | -6d | 0d | start no earlier than 2004-03-15 |
| 662 | 1.6.6.6.3.2 | Assemble FM 2 Mother Board | 10d | 2004-04-27 | 2004-05-10 | 661SS |  |  | 2004-02-27 | 2004-03-11 | 10d | 7d | 5d |  |
| 663 | 1.6.6.6.4 | **Test** | 62d | 2004-02-27 A | 2004-05-24 |  | 25% | 46.5d | 2004-02-27 | 2004-03-25 | 20d | 2d |  |  |
| 664 | 1.6.6.6.4.1 | **FM 1 & FM 2** | 42d | 2004-02-27 A | 2004-04-26 |  | 50% | 21d | 2004-02-27 | 2004-03-18 | 15d | -6d | 0d |  |
| 665 | 1.6.6.6.4.1.1 | Coupon Testing of Mother Boards | 5d | 2004-02-27 A | 2004-03-04 A |  | 100% |  | 2004-02-27 | 2004-03-18 | 15d |  |  |  |
| 666 | 1.6.6.6.4.1.2 | Coupon Testing of 2nd Mother Boards | 5d | 2004-04-20 | 2004-04-26 | 659 |  |  | 2004-04-20 | 2004-04-26 | 5d | -6d | 0d |  |
| 667 | 1.6.6.6.4.2 | **FM 1** | 5d | 2004-05-11 | 2004-05-17 |  |  |  | 2004-03-12 | 2004-03-18 | 5d | -6d | 0d |  |
| 668 | 1.6.6.6.4.2.1 | Functional Test FM 1 Mother Board | 5d | 2004-05-11 | 2004-05-17 | 661 |  |  | 2004-03-12 | 2004-03-18 | 5d | -6d | 0d |  |
| 669 | 1.6.6.6.4.3 | **FM 2** | 5d | 2004-05-18 | 2004-05-24 |  |  |  | 2004-03-19 | 2004-03-25 | 5d | 2d |  |  |
| 670 | 1.6.6.6.4.3.1 | Functional Test FM 2 Mother Board | 5d | 2004-05-18 | 2004-05-24 | 662, 668 |  |  | 2004-03-19 | 2004-03-25 | 5d | 2d | 0d |  |
| 671 | 1.6.6.7 | **HVPS** | 104d | 2004-01-12 A | 2004-06-08 |  | 75% | 26d | 2004-01-12 | 2004-04-27 | 75d | 2d |  |  |
| 672 | 1.6.6.7.1 | **Test** | 104d | 2004-01-12 A | 2004-06-08 |  | 75% | 26d | 2004-01-12 | 2004-04-27 | 75d | 2d |  |  |
| 673 | 1.6.6.7.1.1 | **FM 1** | 30d | 2004-01-12 A | 2004-02-24 A |  | 100% |  | 2004-01-12 | 2004-02-09 | 20d |  |  |  |
| 674 | 1.6.6.7.1.1.1 | Functional Test SIT FM 1 HVPS | 30d | 2004-01-12 A | 2004-02-24 A | 71 | 100% |  | 2004-01-12 | 2004-02-09 | 20d |  |  | start no earlier than 2004-01-12 |

Notes:
- 665: After Coupon testing a Mechnical Interface error was found in the board. The design was changed and sent out for Fabrication again.

| ID | WBS | Task | Duration | Start | Finish | Predecessors | Complete | Remaining | Baseline start | Baseline finish | Baseline duration | Total slack | Free slack | Constraint | Text1 |
| --- | --- | --- | --- | --- | --- | --- | --- | --- | --- | --- | --- | --- | --- | --- | --- |
| 675 | 1.6.6.7.1.2 | **FM 2** | 10d | 2004-05-25 | 2004-06-08 |  |  |  | 2004-04-14 | 2004-04-27 | 10d | 2d |  |  |  |
| 676 | 1.6.6.7.1.2.1 | Functional Test SIT FM 2 HVPS | 10d | 2004-05-25 | 2004-06-08 | 77, 670 |  |  | 2004-04-14 | 2004-04-27 | 10d | 2d | 1d |  |  |
| 677 | 1.6.6.8 | **Flight Software** | 210d | 2003-06-02 A | 2004-04-01 |  | 89% | 24d | 2003-06-02 | 2004-04-01 | 210d | 53d |  |  |  |
| 678 | 1.6.6.8.1 | **Test** | 210d | 2003-06-02 A | 2004-04-01 |  | 89% | 24d | 2003-06-02 | 2004-04-01 | 210d | 53d |  |  |  |
| 679 | 1.6.6.8.1.1 | **FM 1 & FM 2** | 210d | 2003-06-02 A | 2004-04-01 |  | 89% | 24d | 2003-06-02 | 2004-04-01 | 210d | 53d |  |  |  |
| 680 | 1.6.6.8.1.1.1 | Validate SIT On-Board Code | 210d | 2003-06-02 A | 2004-04-01 |  | 89% | 24d | 2003-06-02 | 2004-04-01 | 210d | 53d |  | start no earlier than 2003-06-02 |  |
| 681 | 1.6.6.9 | **Integration & Test (using ETU Telescope for FM 1)** | 121d | 2004-02-25 A | 2004-08-12 |  | 4% | 116.63d | 2004-03-31 | 2004-07-22 | 81d | 1d |  |  |  |
| 682 | 1.6.6.9.1 | **FM 1 (Flight Telescope)** | 12d | 2004-07-08 | 2004-07-23 |  |  |  | 2004-06-02 | 2004-06-17 | 12d | -8d | 0d |  |  |
| 683 | 1.6.6.9.1.1 | Disassemble SIT FM 1 | 1d | 2004-07-08 | 2004-07-08 | 647 |  |  | 2004-06-02 | 2004-06-02 | 1d | -8d | 0d |  |  |
| 684 | 1.6.6.9.1.2 | Conformal Coat SIT FM 1 Boards (includes FM 1 LVPS) | 2d | 2004-07-09 | 2004-07-12 | 683 |  |  | 2004-06-03 | 2004-06-04 | 2d | -8d | 0d |  |  |
| 685 | 1.6.6.9.1.3 | Reassemble SIT FM 1 with Flight Telescope | 1d | 2004-07-13 | 2004-07-13 | 684, 399, 365 |  |  | 2004-06-07 | 2004-06-07 | 1d | -8d | 0d |  |  |
| 686 | 1.6.6.9.1.4 | Bench Calibration SIT FM 1 w/Flight Telescope | 3d | 2004-07-14 | 2004-07-16 | 685 |  |  | 2004-06-08 | 2004-06-10 | 3d | -8d | 0d |  |  |
| 687 | 1.6.6.9.1.5 | Vacuum Test SIT FM 1 w/Flight Telescope | 5d | 2004-07-19 | 2004-07-23 | 686 |  |  | 2004-06-11 | 2004-06-17 | 5d | -8d | 0d |  |  |
| 688 | 1.6.6.9.2 | **FM 2** | 9d | 2004-08-02 | 2004-08-12 |  |  |  | 2004-07-12 | 2004-07-22 | 9d | 1d |  |  |  |
| 689 | 1.6.6.9.2.1 | Disassemble SIT FM 2 | 1d | 2004-08-02 | 2004-08-02 | 650 |  |  | 2004-07-12 | 2004-07-12 | 1d | 1d | 0d |  |  |
| 690 | 1.6.6.9.2.2 | Conformal Coat SIT FM 2 Boards | 2d | 2004-08-03 | 2004-08-04 | 689 |  |  | 2004-07-13 | 2004-07-14 | 2d | 1d | 0d |  |  |
| 691 | 1.6.6.9.2.3 | Reassemble SIT FM 2 | 1d | 2004-08-05 | 2004-08-05 | 690 |  |  | 2004-07-15 | 2004-07-15 | 1d | 1d | 0d |  |  |
| 692 | 1.6.6.9.2.4 | Post-Coat Retest SIT FM 2 | 5d | 2004-08-06 | 2004-08-12 | 691 |  |  | 2004-07-16 | 2004-07-22 | 5d | 1d | 0d |  |  |
| 693 | 1.6.6.9.3 | **FM 1 (ETU Telescope)** | 89d | 2004-02-25 A | 2004-06-29 |  | 10% | 80.39d | 2004-03-31 | 2004-05-21 | 38d | -8d | 0d |  |  |
| 694 | 1.6.6.9.3.1 | Integrate SIT FM 1 HVPS and SIT ETU Telescope Without Electronics | 3d | 2004-02-25 A | 2004-02-27 A | 674 | 100% |  | 2004-03-31 | 2004-04-02 | 3d |  |  |  | MS-SEP |
| 695 | 1.6.6.9.3.2 | Integrate Electronics to SIT ETU Telescope | 2d | 2004-05-20 | 2004-05-21 | 646, 608, 668, 621, 694 |  |  | 2004-04-14 | 2004-04-15 | 2d | -8d | 0d |  |  |
| 696 | 1.6.6.9.3.3 | SIT FM 1 Debug | 5d | 2004-05-24 | 2004-05-28 | 695 |  |  | 2004-04-16 | 2004-04-22 | 5d | -8d | 0d |  |  |
| 697 | 1.6.6.9.3.4 | SIT FM 1 Bench Test | 5d | 2004-06-01 | 2004-06-07 | 696 |  |  | 2004-04-23 | 2004-04-29 | 5d | -8d | 0d |  |  |
| 698 | 1.6.6.9.3.5 | SIT FM 1 Alpha TEST | 5d | 2004-06-08 | 2004-06-14 | 697 |  |  | 2004-04-30 | 2004-05-06 | 5d | -8d | 0d |  |  |
| 699 | 1.6.6.9.3.6 | SIT FM 1 Noise Removal | 5d | 2004-06-15 | 2004-06-21 | 698 |  |  | 2004-05-07 | 2004-05-13 | 5d | -8d | 0d |  |  |
| 700 | 1.6.6.9.3.7 | SIT FM 1 Thermal Test | 5d | 2004-06-22 | 2004-06-28 | 699 |  |  | 2004-05-14 | 2004-05-20 | 5d | -8d | 0d |  |  |
| 701 | 1.6.6.9.3.8 | SIT FM 1 Functional Test | 1d | 2004-06-29 | 2004-06-29 | 700, 680 |  |  | 2004-05-21 | 2004-05-21 | 1d | -8d | 0d |  |  |

| ID | WBS | Task | Duration | Start | Finish | Predecessors | Baseline start | Baseline finish | Baseline duration | Total slack | Free slack | Constraint | Text1 |
| --- | --- | --- | --- | --- | --- | --- | --- | --- | --- | --- | --- | --- | --- |
| 702 | 1.6.6.9.4 | **FM 2** | 31d | 2004-06-10 | 2004-07-22 |  | 2004-05-19 | 2004-07-01 | 31d | 1d |  |  |  |
| 703 | 1.6.6.9.4.1 | Integrate SIT FM 2 HVPS and SIT FM 2 Telescope Without Electronics | 3d | 2004-06-10 | 2004-06-14 | 676, 399, 365 | 2004-05-19 | 2004-05-21 | 3d | 1d | 0d |  | MS-SEP |
| 704 | 1.6.6.9.4.2 | Integrate Electronics to SIT FM 2 Telescope | 2d | 2004-06-15 | 2004-06-16 | 649, 610, 670, 623, 703 | 2004-05-24 | 2004-05-25 | 2d | 1d | 0d |  |  |
| 705 | 1.6.6.9.4.3 | SIT FM 2 Debug | 5d | 2004-06-17 | 2004-06-23 | 704 | 2004-05-26 | 2004-06-02 | 5d | 1d | 0d |  |  |
| 706 | 1.6.6.9.4.4 | SIT FM 2 Bench Test | 5d | 2004-06-24 | 2004-06-30 | 705 | 2004-06-03 | 2004-06-09 | 5d | 1d | 0d |  |  |
| 707 | 1.6.6.9.4.5 | SIT FM 2 Alpha Test | 5d | 2004-07-01 | 2004-07-07 | 706 | 2004-06-10 | 2004-06-16 | 5d | 1d | 0d |  |  |
| 708 | 1.6.6.9.4.6 | SIT FM 2 Noise Removal | 5d | 2004-07-08 | 2004-07-14 | 707, 699 | 2004-06-17 | 2004-06-23 | 5d | 1d | 0d |  |  |
| 709 | 1.6.6.9.4.7 | SIT FM 2 Thermal Test | 5d | 2004-07-15 | 2004-07-21 | 708 | 2004-06-24 | 2004-06-30 | 5d | 1d | 0d |  |  |
| 710 | 1.6.6.9.4.8 | SIT FM 2 Functional Test | 1d | 2004-07-22 | 2004-07-22 | 709 | 2004-07-01 | 2004-07-01 | 1d | 1d | 0d |  |  |
| 711 | 1.6.6.10 | Integrate SIT Door FM 1 | 1d | 2004-08-20 | 2004-08-20 | 595, 412 | 2004-08-20 | 2004-08-20 | 1d | -3d | 0d |  |  |
| 712 | 1.6.6.11 | Integrate SIT Door FM 2 | 1d | 2004-09-02 | 2004-09-02 | 598, 711 | 2004-09-01 | 2004-09-01 | 1d | 2d | 0d |  |  |
| 713 | 1.6.6.12 | **Environmental Testing at GSFC (FM 1)** | 34d | 2004-08-23 | 2004-10-08 |  | 2004-07-15 | 2004-08-31 | 34d | -3d | 0d |  |  |
| 714 | 1.6.6.12.1 | SIT FM 1 Vibration and Acoustics | 10d | 2004-08-23 | 2004-09-03 | 595, 711 | 2004-07-15 | 2004-07-28 | 10d | -3d | 0d | start no earlier than 2004-08-23 |  |
| 715 | 1.6.6.12.2 | Functional Test | 1d | 2004-09-07 | 2004-09-07 | 714 | 2004-07-29 | 2004-07-29 | 1d | -3d | 0d |  |  |
| 716 | 1.6.6.12.3 | SIT FM 1 Thermal Balance | 5d | 2004-09-08 | 2004-09-14 | 715 | 2004-07-30 | 2004-08-05 | 5d | -3d | 0d |  |  |
| 717 | 1.6.6.12.4 | SIT FM 1 Thermal Vac | 10d | 2004-09-15 | 2004-09-28 | 716 | 2004-08-06 | 2004-08-19 | 10d | -3d | 0d |  |  |
| 718 | 1.6.6.12.5 | Disassemble SIT Instruments | 2d | 2004-09-29 | 2004-09-30 | 717 | 2004-08-20 | 2004-08-23 | 2d | -3d | 0d |  |  |
| 719 | 1.6.6.12.6 | Bake Out | 3d | 2004-10-01 | 2004-10-05 | 718 | 2004-08-24 | 2004-08-26 | 3d | -3d | 0d |  |  |
| 720 | 1.6.6.12.7 | Reassemble Instruments | 2d | 2004-10-06 | 2004-10-07 | 719 | 2004-08-27 | 2004-08-30 | 2d | -3d | 0d |  |  |
| 721 | 1.6.6.12.8 | Functional Test | 1d | 2004-10-08 | 2004-10-08 | 720 | 2004-08-31 | 2004-08-31 | 1d | -3d | 0d |  |  |
| 722 | 1.6.6.13 | **Environmental Testing at GSFC (FM 2)** | 34d | 2004-09-03 | 2004-10-22 |  | 2004-08-23 | 2004-10-08 | 34d | 2d |  |  |  |
| 723 | 1.6.6.13.1 | SIT FM 2 Vibration and Acoustics | 10d | 2004-09-03 | 2004-09-17 | 598, 712 | 2004-08-23 | 2004-09-03 | 10d | 2d | 0d | start no earlier than 2004-09-02 |  |
| 724 | 1.6.6.13.2 | Functional Test | 1d | 2004-09-20 | 2004-09-20 | 723 | 2004-09-07 | 2004-09-07 | 1d | 2d | 0d |  |  |
| 725 | 1.6.6.13.3 | SIT FM 2 Thermal Balance | 5d | 2004-09-21 | 2004-09-27 | 724 | 2004-09-08 | 2004-09-14 | 5d | 2d | 0d |  |  |
| 726 | 1.6.6.13.4 | SIT FM 2 Thermal Vac | 10d | 2004-09-28 | 2004-10-12 | 725 | 2004-09-15 | 2004-09-28 | 10d | 2d | 0d |  |  |
| 727 | 1.6.6.13.5 | Disassemble SIT Instruments | 2d | 2004-10-13 | 2004-10-14 | 726 | 2004-09-29 | 2004-09-30 | 2d | 2d | 0d |  |  |
| 728 | 1.6.6.13.6 | Bake Out | 3d | 2004-10-15 | 2004-10-19 | 727 | 2004-10-01 | 2004-10-05 | 3d | 2d | 0d |  |  |
| 729 | 1.6.6.13.7 | Reassemble Instruments | 2d | 2004-10-20 | 2004-10-21 | 728 | 2004-10-06 | 2004-10-07 | 2d | 2d | 0d |  |  |
| 730 | 1.6.6.13.8 | Functional Test | 1d | 2004-10-22 | 2004-10-22 | 729 | 2004-10-08 | 2004-10-08 | 1d | 2d | 0d |  |  |

| ID | WBS | Task | Duration | Start | Finish | Predecessors | Complete | Remaining | Baseline start | Baseline finish | Baseline duration | Total slack | Free slack | Constraint | Text1 |
| --- | --- | --- | --- | --- | --- | --- | --- | --- | --- | --- | --- | --- | --- | --- | --- |
| 731 | 1.6.6.14 | **Emulators/Simulators/GSE** | 209d | 2003-12-17 A | 2004-10-13 |  | 10% | 187.26d | 2003-12-17 | 2004-10-20 | 214d | 9d |  |  |  |
| 732 | 1.6.6.14.1 | **Simulators** | 80d | 2003-12-17 A | 2004-04-12 |  | 13% | 69.6d | 2003-12-17 | 2004-04-12 | 80d | 98d |  |  |  |
| 733 | 1.6.6.14.1.1 | Labview CPU Ready | 80d | 2003-12-17 A | 2004-04-12 |  | 13% | 69.6d | 2003-12-17 | 2004-04-12 | 80d | 0d |  | must start on 2003-12-17 |  |
| 734 | 1.6.6.14.1.2 | Test Simulator | 80d | 2003-12-17 A | 2004-04-12 | 733SS | 13% | 69.6d | 2003-12-17 | 2004-04-12 | 80d | 98d | 89d |  |  |
| 735 | 1.6.6.14.2 | **GSE** | 40d | 2004-08-17 | 2004-10-13 |  |  |  | 2004-07-27 | 2004-10-20 | 60d | 9d |  |  |  |
| 736 | 1.6.6.14.2.1 | Pulse Generator | 40d | 2004-08-17 | 2004-10-13 | 594, 597, 734 |  |  | 2004-07-27 | 2004-10-20 | 60d | 9d | 7d |  |  |
| 737 | 1.6.7 | **SEP Suite I&T - CIT** | 309d | 2003-08-01 A | 2004-10-21 |  | 33% | 207.84d | 2003-08-01 | 2004-10-21 | 309d | 5d |  |  |  |
| 738 | 1.6.7.1 | **ETU** | 5d | 2004-01-26 A | 2004-01-30 A |  | 100% |  | 2004-01-26 | 2004-01-30 | 5d |  |  |  |  |
| 739 | 1.6.7.1.1 | Complete Integration/Test of SEP Central EM with Sensors | 5d | 2004-01-26 A | 2004-01-30 A |  | 100% |  | 2004-01-26 | 2004-01-30 | 5d |  |  | start no earlier than 2004-01-26 |  |
| 740 | 1.6.7.2 | **FM 1 & FM 2** | 97d | 2004-03-09 | 2004-07-22 |  |  |  | 2004-03-05 | 2004-10-21 | 162d | -3d | 0d |  |  |
| 741 | 1.6.7.2.1 | Generate SEPT integration & test procedure | 70d | 2004-03-09 | 2004-06-15 | 750FS-10d |  |  | 2004-03-05 | 2004-03-11 | 5d | 8d | 0d |  |  |
| 742 | 1.6.7.2.2 | Generate LET integration & test procedure | 5d | 2004-06-03 | 2004-06-09 | 751FS-10d |  |  | 2004-05-05 | 2004-05-11 | 5d | 13d |  |  |  |
| 743 | 1.6.7.2.3 | Generate HET integration & test procedure | 5d | 2004-06-21 | 2004-06-25 | 753FS-10d |  |  | 2004-05-20 | 2004-05-26 | 5d | 2d |  |  |  |
| 744 | 1.6.7.2.4 | Generate SIT integration & test procedure | 5d | 2004-07-15 | 2004-07-21 | 757FS-10d |  |  | 2004-06-09 | 2004-06-15 | 5d | -3d | 0d |  |  |
| 745 | 1.6.7.2.5 | Generate SEP system test procedure | 5d | 2004-07-16 | 2004-07-22 | 758FS-10d |  |  | 2004-06-10 | 2004-06-16 | 5d | -3d | 0d |  |  |
| 746 | 1.6.7.2.6 | Generate SEP-IDPU integration procedure | 5d | 2004-06-22 | 2004-06-28 | 754FS-10d |  |  | 2004-05-27 | 2004-06-03 | 5d | 8d | 0d |  |  |
| 747 | 1.6.7.2.7 | Generate SEP-IDPU test procedure | 5d | 2004-06-29 | 2004-07-05 | 746 |  |  | 2004-06-04 | 2004-06-10 | 5d | 8d |  |  |  |
| 748 | 1.6.7.3 | **FM 1** | 96d | 2004-03-22 | 2004-08-03 |  |  |  | 2004-03-18 | 2004-06-28 | 72d | -8d | 0d |  | MS-SEP |
| 749 | 1.6.7.3.1 | Integrate/test SEP Central FM 1 | 5d | 2004-06-02 | 2004-06-08 | 420, 422, 375 |  |  | 2004-05-11 | 2004-05-17 | 5d | 13d | 4d |  |  |
| 750 | 1.6.7.3.2 | Receive & inspect SEPT FM 1 | 1d | 2004-03-22 | 2004-03-22 | 530, 531 |  |  | 2004-03-18 | 2004-03-18 | 1d | 8d | 0d |  |  |
| 751 | 1.6.7.3.3 | Integrate & test SEPT FM 1 | 1d | 2004-06-16 | 2004-06-16 | 741, 749, 750 |  |  | 2004-05-18 | 2004-05-18 | 1d | 8d | 0d |  |  |
| 752 | 1.6.7.3.4 | Integrate & test LET FM 1 | 1d | 2004-06-30 | 2004-06-30 | 742, 751, 507, 509 |  |  | 2004-06-09 | 2004-06-09 | 1d | -1d | 0d |  |  |
| 753 | 1.6.7.3.5 | Receive & inspect HET FM 1 | 1d | 2004-07-02 | 2004-07-02 | 450, 454 |  |  | 2004-06-03 | 2004-06-03 | 1d | -3d | 0d |  |  |
| 754 | 1.6.7.3.6 | Integrate & test HET FM 1 | 1d | 2004-07-05 | 2004-07-05 | 743, 752, 753 |  |  | 2004-06-10 | 2004-06-10 | 1d | -3d | 0d |  |  |
| 755 | 1.6.7.3.7 | Integrate SEP FM 1 - IDPU FM 1 | 1d | 2004-07-22 | 2004-07-22 | 746, 754, 160, 790, 451 |  |  | 2004-06-11 | 2004-06-11 | 1d | -5d | 0d |  |  |
| 756 | 1.6.7.3.8 | Test SEP FM 1 - IDPU FM 1 | 1d | 2004-07-23 | 2004-07-23 | 747, 755 |  |  | 2004-06-22 | 2004-06-22 | 1d | -5d | 0d |  |  |
| 757 | 1.6.7.3.9 | Receive & inspect SIT FM 1 | 1d | 2004-07-28 | 2004-07-28 | 594 |  |  | 2004-06-22 | 2004-06-22 | 1d | -8d | 0d |  |  |
| 758 | 1.6.7.3.10 | Integrate & test SIT FM 1 | 1d | 2004-07-29 | 2004-07-29 | 744, 754, 757, 756 |  |  | 2004-06-23 | 2004-06-23 | 1d | -8d | 0d |  |  |
| 759 | 1.6.7.3.11 | SEP system test FM 1 | 3d | 2004-07-30 | 2004-08-03 | 745, 758, 417 |  |  | 2004-06-24 | 2004-06-28 | 3d | -8d | 0d |  |  |

| ID | WBS | Task | Duration | Start | Finish | Predecessors | Baseline start | Baseline finish | Baseline duration | Total slack | Free slack | Constraint | Text1 |
| --- | --- | --- | --- | --- | --- | --- | --- | --- | --- | --- | --- | --- | --- |
| 760 | 1.6.7.4 | **FM 2** | 107d | 2004-03-25 | 2004-08-23 |  | 2004-03-29 | 2004-08-11 | 97d | 26d |  |  | MS-SEP |
| 761 | 1.6.7.4.1 | Integrate/testSEP Central FM 2 | 5d | 2004-06-28 | 2004-07-02 | 421, 422, 375 | 2004-05-11 | 2004-05-17 | 5d | 37d | 0d |  |  |
| 762 | 1.6.7.4.2 | Receive & inspect SEPT FM 2 | 1d | 2004-03-25 | 2004-03-25 | 533, 534 | 2004-03-29 | 2004-03-29 | 1d | 107d | 70d |  |  |
| 763 | 1.6.7.4.3 | Integrate & test SEPT FM 2 | 1d | 2004-07-05 | 2004-07-05 | 741, 761, 762 | 2004-05-18 | 2004-05-18 | 1d | 37d | 0d |  |  |
| 764 | 1.6.7.4.4 | Integrate & test LET FM 2 | 1d | 2004-07-06 | 2004-07-06 | 742, 763, 508, 509 | 2004-06-09 | 2004-06-09 | 1d | 37d | 3d |  |  |
| 765 | 1.6.7.4.5 | Receive & inspect HET FM 2 | 1d | 2004-07-09 | 2004-07-09 | 452 | 2004-06-24 | 2004-06-24 | 1d | 34d | 0d |  |  |
| 766 | 1.6.7.4.6 | Integrate & test HET FM 2 | 1d | 2004-07-12 | 2004-07-12 | 743, 764, 765 | 2004-06-25 | 2004-06-25 | 1d | 34d | 0d |  |  |
| 767 | 1.6.7.4.7 | Integrate SEP FM 2 - IDPU FM 2 | 1d | 2004-08-05 | 2004-08-05 | 746, 766, 161 | 2004-06-28 | 2004-06-28 | 1d | 37d | 0d |  |  |
| 768 | 1.6.7.4.8 | Test SEP FM 2 - IDPU FM 2 | 1d | 2004-08-06 | 2004-08-06 | 747, 767, 453 | 2004-06-29 | 2004-06-29 | 1d | 37d | 23d |  |  |
| 769 | 1.6.7.4.9 | Receive & inspect SIT FM 2 | 1d | 2004-08-17 | 2004-08-17 | 597 | 2004-07-27 | 2004-07-27 | 1d | 1d | 0d |  |  |
| 770 | 1.6.7.4.10 | Integrate & test SIT FM 2 | 1d | 2004-08-18 | 2004-08-18 | 744, 769 | 2004-08-06 | 2004-08-06 | 1d | 1d | 0d |  |  |
| 771 | 1.6.7.4.11 | SEP FM 2 system test | 3d | 2004-08-19 | 2004-08-23 | 745, 770 | 2004-08-09 | 2004-08-11 | 3d | 1d | 0d |  |  |
| 772 | 1.6.7.5 | **Environmental Test (at JPL)** | 111d | 2004-05-17 | 2004-10-21 |  | 2004-05-17 | 2004-09-24 | 93d | 5d |  |  |  |
| 773 | 1.6.7.5.1 | Generate Environmental Test Procedures | 15d | 2004-05-17 | 2004-06-07 |  | 2004-05-17 | 2004-06-07 | 15d | 46d |  | start no earlier than 2004-05-17 |  |
| 774 | 1.6.7.5.2 | Manufacture test cables (JPL) | 20d | 2004-06-01 | 2004-06-28 |  | 2004-06-01 | 2004-06-28 | 20d | 31d |  | start no earlier than 2004-06-01 |  |
| 775 | 1.6.7.5.3 | **FM 1** | 40d | 2004-08-23 | 2004-10-19 |  | 2004-07-23 | 2004-09-24 | 45d | -8d | 0d |  |  |
| 776 | 1.6.7.5.3.1 | FM 1 LET/HET/SEP Central Vibration/Acoustics Test | 10d | 2004-08-23 | 2004-09-03 | 19FS+3d, 773, 774, 790FS+3d | 2004-07-23 | 2004-08-05 | 10d | -8d | 0d |  |  |
| 777 | 1.6.7.5.3.2 | FM 1 LET/HET/SEP Central Thermal Balance Test | 5d | 2004-09-07 | 2004-09-13 | 776 | 2004-08-06 | 2004-08-12 | 5d | -8d | 0d |  |  |
| 778 | 1.6.7.5.3.3 | FM 1 LET/HET/SEP Central T/V Test | 15d | 2004-09-14 | 2004-10-04 | 777, 783 | 2004-08-19 | 2004-09-09 | 15d | -8d | 0d |  |  |
| 779 | 1.6.7.5.3.4 | Evaluate SEP performance | 10d | 2004-10-05 | 2004-10-19 | 778 | 2004-09-10 | 2004-09-23 | 10d | -8d | 0d |  |  |
| 780 | 1.6.7.5.3.5 | Generate test reports | 11d | 2004-09-23 | 2004-10-07 | 779SS | 2004-09-10 | 2004-09-24 | 11d | -8d | 0d | finish no later than 2004-10-07 |  |
| 781 | 1.6.7.5.3.6 | Bakeout Clean SEP exterior & prepare for delivery | 3d | 2004-10-05 | 2004-10-07 | 778 | 2004-09-10 | 2004-09-14 | 3d | -1d | 0d |  |  |
| 782 | 1.6.7.5.4 | **FM 2** | 41d | 2004-08-24 | 2004-10-21 |  | 2004-07-23 | 2004-09-24 | 45d | 1d |  |  |  |
| 783 | 1.6.7.5.4.1 | FM 2 EMI/EMC Test at CalTech | 5d | 2004-08-24 | 2004-08-30 | 771 | 2004-08-12 | 2004-08-18 | 5d | 1d | 0d |  | MS-SEP |
| 784 | 1.6.7.5.4.2 | FM 2 LET/HET/SEP Central Vibration/Acoustics Test | 10d | 2004-08-31 | 2004-09-14 | 793FS+3d, 783 | 2004-07-23 | 2004-08-05 | 10d | 5d | 0d |  |  |
| 785 | 1.6.7.5.4.3 | FM 2 LET/HET/SEP Central T/V Test | 15d | 2004-09-15 | 2004-10-05 | 783, 784 | 2004-08-19 | 2004-09-09 | 15d | 5d | 0d |  |  |
| 786 | 1.6.7.5.4.4 | Evaluate SEP performance | 10d | 2004-10-06 | 2004-10-20 | 785 | 2004-09-10 | 2004-09-23 | 10d | 5d | 0d |  |  |
| 787 | 1.6.7.5.4.5 | Generate test reports | 11d | 2004-10-06 | 2004-10-21 | 786SS | 2004-09-10 | 2004-09-24 | 11d | 5d |  | finish no later than 2004-10-28 |  |
| 788 | 1.6.7.5.4.6 | Bakeout Clean SEP exterior & prepare for delivery | 3d | 2004-10-06 | 2004-10-08 | 785 | 2004-09-10 | 2004-09-14 | 3d | 12d | 0d |  |  |

| ID | WBS | Task | Duration | Start | Finish | Predecessors | Complete | Remaining | Baseline start | Baseline finish | Baseline duration | Total slack | Free slack | Constraint | Calendar |
| --- | --- | --- | --- | --- | --- | --- | --- | --- | --- | --- | --- | --- | --- | --- | --- |
| 789 | 1.6.7.6 | **Accelerator Test (at MSU)** | 5d | 2004-07-10 | 2004-07-16 |  |  |  | 2004-07-13 | 2004-07-19 | 5d | -7d | 0d |  |  |
| 790 | 1.6.7.6.1 | FM 1 LET/SEP Cen end-to-end test at Accelerator | 3d | 2004-07-10 | 2004-07-12 | 800, 406, 754 |  |  | 2004-07-13 | 2004-07-19 | 5d | -7d | 0d | start no earlier than 2004-07-10 | Weekend |
| 791 | 1.6.7.6.2 | Detach HET FM1 from SEP Suite | 1d | 2004-07-13 | 2004-07-13 | 790 |  |  | 2004-07-12 | 2004-07-12 | 1d | -5d | 0d |  |  |
| 792 | 1.6.7.6.3 | Deliver HET FM1 to GSFC for Replacement Detectors | 2d | 2004-07-14 | 2004-07-15 | 791 |  |  | 2004-07-13 | 2004-07-14 | 2d | -5d | 0d |  |  |
| 793 | 1.6.7.6.4 | FM 2 LET/SEP Cen end-to-end test at Accelerator | 3d | 2004-07-13 | 2004-07-15 | 790SS, 766 |  |  | 2004-07-13 | 2004-07-19 | 5d | 34d | 0d |  | Weekend |
| 794 | 1.6.7.6.5 | Detach HET FM2 from SEP Suite | 1d | 2004-07-14 | 2004-07-14 | 791, 793SS |  |  | 2004-07-13 | 2004-07-13 | 1d | 48d | 0d |  |  |
| 795 | 1.6.7.6.6 | Deliver HET FM2 to GSFC for Replacement Detectors | 2d | 2004-07-15 | 2004-07-16 | 794, 792SS |  |  | 2004-07-14 | 2004-07-15 | 2d | 48d | 0d |  |  |
| 796 | 1.6.7.7 | **GSE** | 305d | 2003-08-01 A | 2004-10-15 |  | 48% | 158.53d | 2003-08-01 | 2004-10-15 | 305d | 9d |  |  |  |
| 797 | 1.6.7.7.1 | **End-to-End Test Equipment** | 218d | 2003-08-11 A | 2004-06-22 |  | 84% | 35.3d | 2003-08-11 | 2004-06-22 | 218d | 6d |  |  |  |
| 798 | 1.6.7.7.1.1 | Design | 192d | 2003-08-11 A | 2004-05-14 |  | 95% | 9.3d | 2003-08-11 | 2004-05-14 | 192d | 6d | 0d | start no earlier than 2003-08-11 |  |
| 799 | 1.6.7.7.1.2 | Assemble | 21d | 2004-05-17 | 2004-06-15 | 798 |  |  | 2004-05-17 | 2004-06-15 | 21d | 6d | 0d |  |  |
| 800 | 1.6.7.7.1.3 | Test | 5d | 2004-06-16 | 2004-06-22 | 799 |  |  | 2004-06-16 | 2004-06-22 | 5d | 6d |  |  |  |
| 801 | 1.6.7.7.2 | **GSE software** | 305d | 2003-08-01 A | 2004-10-15 |  | 27% | 221.31d | 2003-08-01 | 2004-10-15 | 305d | 9d |  |  |  |
| 802 | 1.6.7.7.2.1 | Build GSE software release 2 | 232d | 2003-08-01 A | 2004-07-02 |  | 45% | 128d | 2003-08-01 | 2004-03-18 | 157d | 0d |  | must start on 2003-08-01 |  |
| 803 | 1.6.7.7.2.2 | Write user's guide | 10d | 2004-06-21 | 2004-07-02 | 802FS-10d |  |  | 2004-03-22 | 2004-03-31 | 8d | 10d | 0d | start no earlier than 2004-03-22 |  |
| 804 | 1.6.7.7.2.3 | Build GSE software release 3 | 117d | 2004-05-03 | 2004-10-15 | 803FS-45d |  |  | 2004-05-03 | 2004-10-15 | 117d | 9d | 0d | start no earlier than 2004-05-03 |  |
| 805 | 1.6.7.7.2.4 | Write user's guide supplement | 20d | 2004-09-17 | 2004-10-15 | 804FS-20d |  |  | 2004-09-15 | 2004-10-15 | 22d | 9d |  | finish no later than 2004-10-28 |  |
| 806 | 1.7 | **SWEA and SIT Refurbishment (after S/C Environmental Testing)** | 40d | 2005-09-27 | 2005-11-21 |  |  |  | 2005-09-27 | 2005-11-18 | 39d | 0d |  |  |  |
| 807 | 1.7.1 | Ship SWEA FM 1 to UCB | 3d | 2005-09-27 | 2005-09-29 |  |  |  | 2005-09-27 | 2005-09-29 | 3d | 25d | 0d | start no earlier than 2005-09-27 |  |
| 808 | 1.7.2 | Ship (Hand Carry) SIT FM 1 to UMD | 1d | 2005-09-27 | 2005-09-27 |  |  |  | 2005-09-27 | 2005-09-27 | 1d | 27d | 0d | start no earlier than 2005-09-27 |  |
| 809 | 1.7.3 | Ship SWEA FM 2 to UCB | 3d | 2005-10-04 | 2005-10-06 |  |  |  | 2005-10-04 | 2005-10-06 | 3d | 20d | 0d | start no earlier than 2005-10-04 |  |
| 810 | 1.7.4 | Ship (Hand Carry) SIT FM 2 to UMD | 1d | 2005-10-04 | 2005-10-04 |  |  |  | 2005-10-04 | 2005-10-04 | 1d | 22d | 0d | start no earlier than 2005-10-04 |  |
| 811 | 1.7.5 | Vacuum Testing of SWEA FM 1 @ UCB | 5d | 2005-09-30 | 2005-10-06 | 807 |  |  | 2005-09-30 | 2005-10-06 | 5d | 25d | 5d |  |  |
| 812 | 1.7.6 | Vacuum Testing of SIT FM 1 @ UMD | 5d | 2005-09-28 | 2005-10-04 | 808 |  |  | 2005-09-28 | 2005-10-04 | 5d | 27d | 5d |  |  |
| 813 | 1.7.7 | Vacuum Testing of SWEA FM 2 @ UCB | 5d | 2005-10-07 | 2005-10-13 | 809 |  |  | 2005-10-07 | 2005-10-13 | 5d | 20d | 0d |  |  |
| 814 | 1.7.8 | Vacuum Testing of SIT FM 2 @ UMD | 5d | 2005-10-05 | 2005-10-11 | 810 |  |  | 2005-10-05 | 2005-10-11 | 5d | 22d | 0d |  |  |
| 815 | 1.7.9 | Ship SWEA FM 1 & 2 to Launch Site for Re-integration to S/C | 3d | 2005-10-14 | 2005-10-18 | 811, 813 |  |  | 2005-10-07 | 2005-10-11 | 3d | 20d | 0d |  |  |
| 816 | 1.7.10 | Ship SIT FM 1 & 2 to Launch Site for Re-integration to S/C | 3d | 2005-10-12 | 2005-10-14 | 812, 814 |  |  | 2005-10-05 | 2005-10-07 | 3d | 22d | 2d |  |  |
| 817 | 1.7.11 | Reintegration of SWEA and SIT to S/C (at Launch Site) | 3d | 2005-10-19 | 2005-10-21 | 815, 816 |  |  | 2005-10-12 | 2005-10-14 | 3d | 20d |  |  |  |
| 818 | 1.7.12 | Target Date for Reintegration to S/C | 1d | 2005-11-19 | 2005-11-21 | 817 |  |  | 2005-11-18 | 2005-11-18 | 1d | 0d |  | must start on 2005-11-19 |  |

Notes:
- 789: The Accelerator Test Date is still TBD. The actual testing date will depend on availability of the facility at MSU and the readiness of our flight hardware. The date currently reflected in the schedule is therefore subject to change as required.
