# IMPACT Master Schedule

Schedule from MS Project, 2003-02-26 to 2005-11-18, status date 2004-01-31, A marks actual dates.
IMPACT Instrument Suites
NASA GSFC - STEREO
This is the IMPACT Consolidated Schedule. Creation began in October 2003 and was then put on hold and subsequently completed in January 2004. Completed tasks, redundant milestones, contingency blocks and obsolete tasks were deleted from this schedule. / Schedule was baselined on 2/18/04 with status through January 31, 2004.

## Calendars

- Standard: Mon-Fri 08:00-12:00, 13:00-17:00; Sat-Sun off. Exceptions (off unless hours are given): 2003-05-26, 2003-07-04, 2003-09-01, 2003-10-13, 2003-11-11, 2003-11-27, 2003-12-25, 2004-01-01, 2004-01-19, 2004-02-16, 2004-05-31, 2004-09-06, 2004-10-11, 2004-11-11, 2004-11-25.
- Boom Test Calendar: Mon-Fri 08:00-12:00, 13:00-17:00; Sat-Sun off. Exceptions (off unless hours are given): 2003-05-26, 2003-07-04, 2003-09-01, 2003-10-13, 2003-11-11, 2003-11-27, 2003-12-25, 2004-01-01, 2004-01-19, 2004-02-16, 2004-02-28 to 2004-02-29 08:00-12:00, 13:00-17:00, 2004-03-06 to 2004-03-07 08:00-12:00, 13:00-17:00, 2004-05-31, 2004-09-06, 2004-10-11, 2004-11-11, 2004-11-25.
- SEPT Test Calendar: Mon-Fri 08:00-12:00, 13:00-17:00; Sat-Sun off. Exceptions (off unless hours are given): 2003-05-26, 2003-07-04, 2003-09-01, 2003-10-13, 2003-11-11, 2003-11-27, 2003-12-25, 2004-01-01, 2004-01-19, 2004-02-16, 2004-02-21 to 2004-02-22 08:00-12:00, 13:00-17:00, 2004-03-13 to 2004-03-14 08:00-12:00, 13:00-17:00, 2004-05-31, 2004-09-06, 2004-10-11, 2004-11-11, 2004-11-25.

## Schedule

| ID | WBS | Task | Type | Duration | Start | Finish | Predecessors | Complete | Remaining | Baseline start | Baseline finish | Baseline duration | Total slack | Free slack | Constraint |
| --- | --- | --- | --- | --- | --- | --- | --- | --- | --- | --- | --- | --- | --- | --- | --- |
| 1 | 1 | **IMPACT - Dave Curtis (UCB) & Lil Reichenthal (GSFC)** |  | 698d | 2003-02-26 A | 2005-11-18 |  | 50% | 347.04d | 2003-02-26 | 2005-11-18 | 698d | 0d |  |  |
| 2 | 1.1 | **Suite Deliveries to APL** |  | 51d | 2004-08-13 | 2004-10-28 |  |  |  | 2004-08-13 | 2004-10-28 | 51d | 0d |  |  |
| 3 | 1.1.1 | FM 1 Target Delivery Date | milestone | 0d | 2004-10-07 | 2004-10-07 | 5, 7 |  |  | 2004-10-07 | 2004-10-07 | 0d | 0d |  | must start on 2004-10-07 |
| 4 | 1.1.2 | FM 1 Target Delivery Date | milestone | 0d | 2004-10-28 | 2004-10-28 | 8, 6 |  |  | 2004-10-28 | 2004-10-28 | 0d | 0d |  | must start on 2004-10-28 |
| 5 | 1.1.3 | Boom Suite FM 1 Ready for Delivery to APL | milestone | 0d | 2004-08-13 | 2004-08-13 | 354 |  |  | 2004-08-13 | 2004-08-13 | 0d | 37d |  |  |
| 6 | 1.1.4 | Boom Suite FM 2 Ready for Delivery to APL | milestone | 0d | 2004-09-28 | 2004-09-28 | 360 |  |  | 2004-09-28 | 2004-09-28 | 0d | 20d |  |  |
| 7 | 1.1.5 | SEP Suite FM 1 Ready for Delivery to APL | milestone | 0d | 2004-09-14 | 2004-09-14 | 774, 582, 518 |  |  | 2004-09-14 | 2004-09-14 | 0d | 16d |  |  |
| 8 | 1.1.6 | SEP Suite FM 2 Ready for Delivery to APL | milestone | 0d | 2004-10-12 | 2004-10-12 | 781, 585 |  |  | 2004-10-12 | 2004-10-12 | 0d | 11d |  |  |
| 9 | 1.2 | **Environmental Testing - PER, Impact Suite EMC, Snapshots of Boom & SEP Suite Test Flows** |  | 186d | 2004-01-14 A | 2004-10-05 |  | 1% | 184.91d | 2004-01-14 | 2004-10-05 | 186d | 290d |  |  |
| 10 | 1.2.1 | **Reviews (PER and TRR's) - TRR Dates are Tentative** |  | 124d | 2004-01-14 A | 2004-07-08 |  | 25% | 93d | 2004-01-14 | 2004-07-08 | 124d | 352d |  |  |
| 11 | 1.2.1.1 | Instrument PER at UCB |  | 1d | 2004-01-14 A | 2004-01-14 A |  | 100% |  | 2004-01-14 | 2004-01-14 | 1d |  |  | start no earlier than 2004-01-14 |
| 12 | 1.2.1.2 | TRR 1 - Prior to FM 1 SEPT Thermal Vac |  | 1d | 2004-02-13 A | 2004-02-13 A | 39SS-6d | 100% |  | 2004-02-13 | 2004-02-13 | 1d |  |  |  |
| 13 | 1.2.1.3 | TRR 2 - Prior to FM 1 STE-U Thermal Vac/Thermal Balance |  | 1d | 2004-03-25 | 2004-03-25 | 21SS-5d |  |  | 2004-03-25 | 2004-03-25 | 1d | 426d |  |  |
| 14 | 1.2.1.4 | TRR 3 - Prior to FM 1 Boom Structure Vibration |  | 1d | 2004-04-20 | 2004-04-20 | 22SS-5d |  |  | 2004-04-20 | 2004-04-20 | 1d | 408d |  |  |
| 15 | 1.2.1.5 | TRR 4 - Prior to FM 1 IDPU Vibration |  | 1d | 2004-04-26 | 2004-04-26 | 23SS-5d |  |  | 2004-04-26 | 2004-04-26 | 1d | 404d |  |  |
| 16 | 1.2.1.6 | TRR 5 - Prior to FM 1 SWEA Vibration |  | 1d | 2004-05-28 | 2004-05-28 | 26SS-5d |  |  | 2004-05-28 | 2004-05-28 | 1d | 380d |  |  |
| 17 | 1.2.1.7 | TRR 6 - Prior to FM 1 Impact Suite EMC (for Boom and SEP) |  | 1d | 2004-06-22 | 2004-06-22 | 19SS-5d |  |  | 2004-06-22 | 2004-06-22 | 1d | 364d |  |  |
| 18 | 1.2.1.8 | TRR 7 - Prior to FM 1 SIT Vibration |  | 1d | 2004-07-08 | 2004-07-08 | 43SS-5d |  |  | 2004-07-08 | 2004-07-08 | 1d | 352d |  |  |
| 19 | 1.2.2 | IMPACT Suite FM 1 EMC Testing at UCB |  | 10d | 2004-06-29 | 2004-07-12 | 353, 752, 419 |  |  | 2004-06-29 | 2004-07-12 | 10d | 9d | 0d |  |
| 20 | 1.2.3 | **Boom Suite FM 1 Environmental Test Flow Snapshot - UCB** |  | 86d | 2004-04-01 | 2004-07-30 |  |  |  | 2004-04-01 | 2004-07-30 | 86d | 336d |  |  |
| 21 | 1.2.3.1 | STE-U Thermal Vac/Thermal Balance/Bake Out |  | 14d | 2004-04-01 | 2004-04-20 | 273SS |  |  | 2004-04-01 | 2004-04-20 | 14d | 408d | 0d |  |
| 22 | 1.2.3.2 | Boom Structure Vibration |  | 4d | 2004-04-27 | 2004-04-30 | 213SS |  |  | 2004-04-27 | 2004-04-30 | 4d | 400d | 0d |  |
| 23 | 1.2.3.3 | IDPU Vibration |  | 5d | 2004-05-03 | 2004-05-07 | 176SS |  |  | 2004-05-03 | 2004-05-07 | 5d | 395d | 0d |  |
| 24 | 1.2.3.4 | Boom Structure Thermal Vac & Bake Out |  | 15d | 2004-05-03 | 2004-05-21 | 214SS |  |  | 2004-05-03 | 2004-05-21 | 15d | 385d |  |  |
| 25 | 1.2.3.5 | IDPU Thermal Vac & Bake Out |  | 10d | 2004-05-10 | 2004-05-21 | 177SS |  |  | 2004-05-10 | 2004-05-21 | 10d | 385d |  |  |
| 26 | 1.2.3.6 | SWEA/STE Vibration |  | 5d | 2004-06-07 | 2004-06-11 | 339SS |  |  | 2004-06-07 | 2004-06-11 | 5d | 371d | 0d |  |
| 27 | 1.2.3.7 | SWEA/STE Thermal Vac/Thermal Balance/Bake Out |  | 14d | 2004-07-13 | 2004-07-30 | 340SS |  |  | 2004-07-13 | 2004-07-30 | 14d | 336d |  |  |

Notes:
- 1: This is the new IMPACT Consolidated Schedule. Creation began in October 2003 and was then put on hold and subsequently completed in January 2004. Completed tasks, redundant milestones, contingency blocks and obsolete tasks were deleted from this schedule. / Schedule was baselined on 2/18/04 with status through January 31, 2004.
- 7: The SEPT (FM 1) and SIT (FM 1 & 2) instruments are being delivered directly to APL after their environmental testing at GSFC and seperate from the other SEP Suite instruments (SEP Central, LET and HET).
- 8: The SEPT (FM 1) and SIT (FM 1 & 2) instruments are being delivered directly to APL after their environmental testing at GSFC and seperate from the other SEP Suite instruments (SEP Central, LET and HET).
- 11: This is the initial IMPACT PER. Additional TRR's (Test Readiness Reviews) will be scheduled and held as the suite instruments become ready for their environmental testing.
- 20: This section is a "snapshot" of the environmental test flow for the FM 1 Boom Suite. It reflects the details of the testing activities found within the body of the schedule. It was placed in the schedule to allow someone to get a quick look at the test flow and the associated dates. The tasks contained within this section are not tied to any other activities (and do not drive any other activities) and so therefore you will see large float values associated with them. It is simply a quick look at the test flow so that one does not have to filter through the schedule to locate the environmental test activities.

| ID | WBS | Task | Duration | Start | Finish | Predecessors | Baseline start | Baseline finish | Baseline duration | Total slack | Free slack | Calendar |
| --- | --- | --- | --- | --- | --- | --- | --- | --- | --- | --- | --- | --- |
| 28 | 1.2.4 | **Boom Suite FM 2 Environmental Test Flow Snapshot - UCB** | 99d | 2004-04-27 | 2004-09-14 |  | 2004-04-27 | 2004-09-14 | 99d | 305d |  |  |
| 29 | 1.2.4.1 | STE-U Thermal Vac/Bake Out | 10d | 2004-04-27 | 2004-05-10 | 281SS | 2004-04-27 | 2004-05-10 | 10d | 394d |  |  |
| 30 | 1.2.4.2 | IDPU Vibration | 5d | 2004-05-10 | 2004-05-14 | 180SS | 2004-05-10 | 2004-05-14 | 5d | 390d |  |  |
| 31 | 1.2.4.3 | Boom Structure Vibration | 4d | 2004-05-17 | 2004-05-20 | 235SS | 2004-05-17 | 2004-05-20 | 4d | 386d |  |  |
| 32 | 1.2.4.4 | IDPU Thermal Vac & Bake Out | 10d | 2004-05-17 | 2004-05-28 | 181SS | 2004-05-17 | 2004-05-28 | 10d | 380d |  |  |
| 33 | 1.2.4.5 | Boom Structure Thermal Vac & Bake Out | 15d | 2004-05-24 | 2004-06-14 | 236SS | 2004-05-24 | 2004-06-14 | 15d | 370d |  |  |
| 34 | 1.2.4.6 | SWEA/STE Vibration | 5d | 2004-08-09 | 2004-08-13 | 347SS | 2004-08-09 | 2004-08-13 | 5d | 326d |  |  |
| 35 | 1.2.4.7 | SWEA/STE Thermal Vac & Bake Out | 10d | 2004-08-16 | 2004-08-27 | 348SS | 2004-08-16 | 2004-08-27 | 10d | 316d |  |  |
| 36 | 1.2.4.8 | Boom Suite FM 2 EMC | 5d | 2004-09-08 | 2004-09-14 | 359SS | 2004-09-08 | 2004-09-14 | 5d | 305d |  |  |
| 37 | 1.2.5 | **SEP Suite FM 1 Environmental Test Flow Snapshot** | 149d | 2004-02-17 | 2004-09-14 |  | 2004-02-17 | 2004-09-14 | 149d | 305d |  |  |
| 38 | 1.2.5.1 | SEPT (NS & E) Vibration (in Europe) | 8d | 2004-02-17 | 2004-02-24 | 554SS, 561FF | 2004-02-17 | 2004-02-24 | 8d | 450d |  | SEPT Test Calendar |
| 39 | 1.2.5.2 | SEPT (NS & E) Thermal Vac (in Europe) | 9d | 2004-02-25 | 2004-03-08 | 555SS, 562SS | 2004-02-25 | 2004-03-08 | 9d | 439d | 0d |  |
| 40 | 1.2.5.3 | SEPT (NS & E) Bake Out (in Europe) | 2d | 2004-03-09 | 2004-03-10 | 556SS, 563SS | 2004-03-09 | 2004-03-10 | 2d | 437d |  |  |
| 41 | 1.2.5.4 | SEPT (NS & E) Thermal Balance (at GSFC) | 10d | 2004-07-13 | 2004-07-26 | 557SS, 564SS | 2004-07-13 | 2004-07-26 | 10d | 340d |  |  |
| 42 | 1.2.5.5 | LET/HET/SEP Cen Accelerator Test (at MSU) | 11d | 2004-07-13 | 2004-07-27 | 783SS | 2004-07-13 | 2004-07-27 | 11d | 339d |  |  |
| 43 | 1.2.5.6 | SIT Vibe and Acoustics (at GSFC) | 10d | 2004-07-15 | 2004-07-28 | 704SS | 2004-07-15 | 2004-07-28 | 10d | 338d | 0d |  |
| 44 | 1.2.5.7 | LET/HET/SEP Cen Vibe and Acoustics (at JPL) | 10d | 2004-07-23 | 2004-08-05 | 769SS | 2004-07-23 | 2004-08-05 | 10d | 332d |  |  |
| 45 | 1.2.5.8 | SIT Thermal Balance (at GSFC) | 5d | 2004-07-30 | 2004-08-05 | 706SS | 2004-07-30 | 2004-08-05 | 5d | 332d |  |  |
| 46 | 1.2.5.9 | LET/HET/SEP Cen Thermal Balance (at JPL) | 5d | 2004-08-06 | 2004-08-12 | 770SS | 2004-08-06 | 2004-08-12 | 5d | 327d |  |  |
| 47 | 1.2.5.10 | SIT Thermal Vac (at GSFC) | 10d | 2004-08-06 | 2004-08-19 | 707SS | 2004-08-06 | 2004-08-19 | 10d | 322d |  |  |
| 48 | 1.2.5.11 | LET/HET/SEP Cen Thermal Vac (at JPL) | 15d | 2004-08-19 | 2004-09-09 | 771SS | 2004-08-19 | 2004-09-09 | 15d | 308d |  |  |
| 49 | 1.2.5.12 | SIT Bake Out (at GSFC) | 3d | 2004-08-24 | 2004-08-26 | 709SS | 2004-08-24 | 2004-08-26 | 3d | 317d |  |  |
| 50 | 1.2.5.13 | LET/HET/SEP Cen Bake Out (at JPL) | 3d | 2004-09-10 | 2004-09-14 | 774SS | 2004-09-10 | 2004-09-14 | 3d | 305d |  |  |
| 51 | 1.2.6 | **SEP Suite FM 2 Environmental Test Flow Snapshot** | 164d | 2004-02-17 | 2004-10-05 |  | 2004-02-17 | 2004-10-05 | 164d | 290d |  |  |
| 52 | 1.2.6.1 | SEPT (NS & E) Vibe and Acoustics (in Europe) | 8d | 2004-02-17 | 2004-02-24 | 569SS, 575FF | 2004-02-17 | 2004-02-24 | 8d | 450d |  | SEPT Test Calendar |
| 53 | 1.2.6.2 | SEPT (NS & E) Thermal Vac (in Europe) | 9d | 2004-03-09 | 2004-03-17 | 570SS, 576SS | 2004-03-09 | 2004-03-17 | 9d | 432d |  | SEPT Test Calendar |
| 54 | 1.2.6.3 | SEPT (NS & E) Bake Out (in Europe) | 2d | 2004-03-18 | 2004-03-19 | 571SS, 577SS | 2004-03-18 | 2004-03-19 | 2d | 430d |  |  |
| 55 | 1.2.6.4 | LET/HET/SEP Cen Accelerator Test (at MSU) | 11d | 2004-07-13 | 2004-07-27 | 784SS | 2004-07-13 | 2004-07-27 | 11d | 339d |  |  |
| 56 | 1.2.6.5 | LET/HET/SEP Cen Vibe and Acoustics (at JPL) | 10d | 2004-07-23 | 2004-08-05 | 777SS | 2004-07-23 | 2004-08-05 | 10d | 332d |  |  |
| 57 | 1.2.6.6 | SEP Suite FM 2 EMC (at Caltech) | 5d | 2004-08-12 | 2004-08-18 | 776SS | 2004-08-12 | 2004-08-18 | 5d | 323d |  |  |
| 58 | 1.2.6.7 | LET/HET/SEP Cen Thermal Vac (at JPL) | 15d | 2004-08-19 | 2004-09-09 | 778SS | 2004-08-19 | 2004-09-09 | 15d | 308d |  |  |
| 59 | 1.2.6.8 | SIT Vibe and Acoustics (at GSFC) | 10d | 2004-08-23 | 2004-09-03 | 713SS | 2004-08-23 | 2004-09-03 | 10d | 311d |  |  |
| 60 | 1.2.6.9 | SIT Thermal Balance (at GSFC) | 5d | 2004-09-08 | 2004-09-14 | 715SS | 2004-09-08 | 2004-09-14 | 5d | 305d |  |  |
| 61 | 1.2.6.10 | LET/HET/SEP Cen Bake Out (at JPL) | 3d | 2004-09-10 | 2004-09-14 | 781SS | 2004-09-10 | 2004-09-14 | 3d | 305d |  |  |
| 62 | 1.2.6.11 | SIT Thermal Vac (at GSFC) | 10d | 2004-09-15 | 2004-09-28 | 716SS | 2004-09-15 | 2004-09-28 | 10d | 295d |  |  |
| 63 | 1.2.6.12 | SIT Bake Out (at GSFC) | 3d | 2004-10-01 | 2004-10-05 | 718SS | 2004-10-01 | 2004-10-05 | 3d | 290d |  |  |

Notes:
- 28: This section is a "snapshot" of the environmental test flow for the FM 2 Boom Suite. It reflects the details of the testing activities found within the body of the schedule. It was placed in the schedule to allow someone to get a quick look at the test flow and the associated dates. The tasks contained within this section are not tied to any other activities (and do not drive any other activities) and so therefore you will see large float values associated with them. It is simply a quick look at the test flow so that one does not have to filter through the schedule to locate the environmental test activities.
- 37: This section is a "snapshot" of the environmental test flow for the FM 1 SEP Suite. It reflects the details of the testing activities found within the body of the schedule. It was placed in the schedule to allow someone to get a quick look at the test flow and the associated dates. The tasks contained within this section are not tied to any other activities (and do not drive any other activities) and so therefore you will see large float values associated with them. It is simply a quick look at the test flow so that one does not have to filter through the schedule to locate the environmental test activities.
- 51: This section is a "snapshot" of the environmental test flow for the FM 2 SEP Suite. It reflects the details of the testing activities found within the body of the schedule. It was placed in the schedule to allow someone to get a quick look at the test flow and the associated dates. The tasks contained within this section are not tied to any other activities (and do not drive any other activities) and so therefore you will see large float values associated with them. It is simply a quick look at the test flow so that one does not have to filter through the schedule to locate the environmental test activities.

| ID | WBS | Task | Type | Duration | Start | Finish | Predecessors | Complete | Remaining | Baseline start | Baseline finish | Baseline duration | Total slack | Free slack | Constraint |
| --- | --- | --- | --- | --- | --- | --- | --- | --- | --- | --- | --- | --- | --- | --- | --- |
| 64 | 1.3 | **Power Converters - UCB** |  | 335d | 2003-02-26 A | 2004-06-23 |  | 57% | 144.65d | 2003-02-26 | 2004-06-23 | 335d | 363d |  |  |
| 65 | 1.3.1 | **Deliveries** |  | 100d | 2003-12-09 A | 2004-04-30 |  | 20% | 80d | 2003-12-09 | 2004-04-30 | 100d | 49d |  |  |
| 66 | 1.3.1.1 | **FM 1** |  | 95d | 2003-12-09 A | 2004-04-23 |  | 40% | 57d | 2003-12-09 | 2004-04-23 | 95d | 25d |  |  |
| 67 | 1.3.1.1.1 | Deliver IDPU FM 1 LVPS (stays at UCB) | milestone | 0d | 2004-04-23 | 2004-04-23 | 121 |  |  | 2004-04-23 | 2004-04-23 | 0d | 25d | 0d |  |
| 68 | 1.3.1.1.2 | Deliver SEP FM 1 LVPS (to Caltech) |  | 1d | 2004-04-06 | 2004-04-06 | 125 |  |  | 2004-04-06 | 2004-04-06 | 1d | 36d | 21d |  |
| 69 | 1.3.1.1.3 | Deliver SWEA/STE FM 1 LVPS (stays at UCB) | milestone | 0d | 2004-04-15 | 2004-04-15 | 129 |  |  | 2004-04-15 | 2004-04-15 | 0d | 9d | 0d |  |
| 70 | 1.3.1.1.4 | Deliver PLASTIC FM 1 LVPS (to UNH) |  | 2d | 2004-03-24 | 2004-03-25 | 133 |  |  | 2004-03-24 | 2004-03-25 | 2d | 28d |  | finish no later than 2004-05-04 |
| 71 | 1.3.1.1.5 | Deliver SIT FM 1 HVPS (to UMD) |  | 2d | 2003-12-09 A | 2003-12-10 A | 135 | 100% |  | 2003-12-09 | 2003-12-10 | 2d |  |  |  |
| 72 | 1.3.1.2 | **FM 2** |  | 15d | 2004-04-12 | 2004-04-30 |  |  |  | 2004-04-12 | 2004-04-30 | 15d | 31d |  |  |
| 73 | 1.3.1.2.1 | Deliver IDPU FM 2 LVPS (stays at UCB) | milestone | 0d | 2004-04-30 | 2004-04-30 | 142 |  |  | 2004-04-30 | 2004-04-30 | 0d | 37d | 0d |  |
| 74 | 1.3.1.2.2 | Deliver SEP FM 2 LVPS (to Caltech) |  | 1d | 2004-04-19 | 2004-04-19 | 146 |  |  | 2004-04-19 | 2004-04-19 | 1d | 27d | 12d |  |
| 75 | 1.3.1.2.3 | Deliver SWEA/STE FM 2 LVPS (stays at UCB) | milestone | 0d | 2004-04-26 | 2004-04-26 | 150 |  |  | 2004-04-26 | 2004-04-26 | 0d | 53d | 33d |  |
| 76 | 1.3.1.2.4 | Deliver PLASTIC FM 2 LVPS (to UNH) |  | 2d | 2004-04-12 | 2004-04-13 | 154 |  |  | 2004-04-12 | 2004-04-13 | 2d | 41d |  | finish no later than 2004-06-10 |
| 77 | 1.3.1.2.5 | Deliver SIT FM 2 HVPS (to UMD) |  | 2d | 2004-04-12 | 2004-04-13 | 158 |  |  | 2004-04-12 | 2004-04-13 | 2d | 31d | 0d |  |
| 78 | 1.3.2 | **Remaining Flight Procurements** |  | 79d | 2003-10-24 A | 2004-02-19 |  | 75% | 19.75d | 2003-10-24 | 2004-02-19 | 79d | 25d |  |  |
| 79 | 1.3.2.1 | Procure IDPU Flight Printed Wiring Board |  | 10d | 2004-02-05 | 2004-02-19 | 85 |  |  | 2004-02-05 | 2004-02-19 | 10d | 25d | 0d | start no earlier than 2004-02-05 |
| 80 | 1.3.2.2 | Procure SEP Flight Printed Wiring Board |  | 10d | 2003-11-24 A | 2003-12-08 A | 86 | 100% |  | 2003-11-24 | 2003-12-08 | 10d |  |  | start no earlier than 2003-11-24 |
| 81 | 1.3.2.3 | Procure SWEA Flight Printed Wiring Board |  | 10d | 2003-12-04 A | 2003-12-17 A | 87 | 100% |  | 2003-12-04 | 2003-12-17 | 10d |  |  |  |
| 82 | 1.3.2.4 | Procure PLASTIC Flight Printed Wiring Board |  | 10d | 2003-10-24 A | 2003-11-06 A |  | 100% |  | 2003-10-24 | 2003-11-06 | 10d |  |  | start no earlier than 2003-10-24 |
| 83 | 1.3.3 | **Fabrication** |  | 239d | 2003-02-26 A | 2004-02-06 A |  | 100% |  | 2003-02-26 | 2004-02-06 | 239d |  |  |  |
| 84 | 1.3.3.1 | **FM 1 & FM 2** |  | 195d | 2003-02-26 A | 2003-12-03 A |  | 100% |  | 2003-02-26 | 2003-12-03 | 195d |  |  |  |
| 85 | 1.3.3.1.1 | Re-layout IDPU LVPS Flight Printed Wiring Board |  | 186d | 2003-02-26 A | 2003-11-19 A |  | 100% |  | 2003-02-26 | 2003-11-19 | 186d |  |  | start no earlier than 2003-02-26 |
| 86 | 1.3.3.1.2 | Re-layout SEP LVPS Flight Printed Wiring Board |  | 32d | 2003-09-24 A | 2003-11-07 A |  | 100% |  | 2003-09-24 | 2003-11-07 | 32d |  |  | start no earlier than 2003-09-24 |
| 87 | 1.3.3.1.3 | Re-layout SWEA LVPS Flight Printed Wiring Board |  | 5d | 2003-11-26 A | 2003-12-03 A |  | 100% |  | 2003-11-26 | 2003-12-03 | 5d |  |  | start no earlier than 2003-11-26 |

| ID | WBS | Task | Duration | Start | Finish | Predecessors | Complete | Remaining | Baseline start | Baseline finish | Baseline duration | Total slack | Free slack | Constraint |
| --- | --- | --- | --- | --- | --- | --- | --- | --- | --- | --- | --- | --- | --- | --- |
| 88 | 1.3.3.2 | **FM 1** | 45d | 2003-09-29 A | 2003-12-03 A |  | 100% |  | 2003-09-29 | 2003-12-03 | 45d |  |  |  |
| 89 | 1.3.3.2.1 | Wind IDPU LVPS FM 1 Magnets | 10d | 2003-10-17 A | 2003-10-30 A |  | 100% |  | 2003-10-17 | 2003-10-30 | 10d |  |  | start no earlier than 2003-10-17 |
| 90 | 1.3.3.2.2 | Wind SEP LVPS FM 1 Magnets | 15d | 2003-09-29 A | 2003-10-20 A |  | 100% |  | 2003-09-29 | 2003-10-20 | 15d |  |  | start no earlier than 2003-09-29 |
| 91 | 1.3.3.2.3 | Wind SWEA LVPS FM 1 Magnets | 5d | 2003-11-26 A | 2003-12-03 A |  | 100% |  | 2003-11-26 | 2003-12-03 | 5d |  |  | start no earlier than 2003-11-26 |
| 92 | 1.3.3.2.4 | Wind PLASTIC LVPS FM 1 Magnets | 45d | 2003-09-29 A | 2003-12-03 A |  | 100% |  | 2003-09-29 | 2003-12-03 | 45d |  |  | start no earlier than 2003-09-29 |
| 93 | 1.3.3.3 | **FM 2** | 28d | 2003-12-29 A | 2004-02-06 A |  | 100% |  | 2003-12-29 | 2004-02-06 | 28d |  |  |  |
| 94 | 1.3.3.3.1 | Wind HVPS FM 2 Magnets | 28d | 2003-12-29 A | 2004-02-06 A |  | 100% |  | 2003-12-29 | 2004-02-06 | 28d |  |  | start no earlier than 2003-12-29 |
| 95 | 1.3.3.3.2 | Wind IDPU LVPS FM 2 Magnets | 28d | 2003-12-29 A | 2004-02-06 A | 94SS | 100% |  | 2003-12-29 | 2004-02-06 | 28d |  |  |  |
| 96 | 1.3.3.3.3 | Wind SEP LVPS FM 2 Magnets | 28d | 2003-12-29 A | 2004-02-06 A | 94SS | 100% |  | 2003-12-29 | 2004-02-06 | 28d |  |  |  |
| 97 | 1.3.3.3.4 | Wind SWEA LVPS FM 2 Magnets | 28d | 2003-12-29 A | 2004-02-06 A | 94SS | 100% |  | 2003-12-29 | 2004-02-06 | 28d |  |  |  |
| 98 | 1.3.3.3.5 | Wind PLASTIC LVPS FM 2 Magnets | 28d | 2003-12-29 A | 2004-02-06 A | 94SS | 100% |  | 2003-12-29 | 2004-02-06 | 28d |  |  |  |
| 99 | 1.3.4 | **Assembly** | 57d | 2003-12-29 A | 2004-03-19 |  | 27% | 41.39d | 2003-12-29 | 2004-03-19 | 57d | 49d |  |  |
| 100 | 1.3.4.1 | **FM 1** | 52d | 2003-12-29 A | 2004-03-12 |  | 51% | 25.38d | 2003-12-29 | 2004-03-12 | 52d | 25d |  |  |
| 101 | 1.3.4.1.1 | Assemble IDPU FM 1 LVPS | 12d | 2004-02-26 | 2004-03-12 | 89, 113 |  |  | 2004-02-26 | 2004-03-12 | 12d | 25d | 0d |  |
| 102 | 1.3.4.1.2 | Assemble SEP FM 1 LVPS | 29d | 2004-01-12 A | 2004-02-23 | 114, 90 | 48% | 15d | 2004-01-12 | 2004-02-23 | 29d | 36d | 0d | start no earlier than 2004-01-12 |
| 103 | 1.3.4.1.3 | Assemble SWEA FM 1 LVPS | 14d | 2004-02-13 | 2004-03-04 | 91, 115 |  |  | 2004-02-13 | 2004-03-04 | 14d | 9d | 0d | start no earlier than 2004-02-13 |
| 104 | 1.3.4.1.4 | Assemble PLASTIC FM 1 LVPS | 29d | 2003-12-29 A | 2004-02-09 A | 116, 92 | 100% |  | 2003-12-29 | 2004-02-09 | 29d |  |  | start no earlier than 2003-12-29 |
| 105 | 1.3.4.2 | **FM 2** | 29d | 2004-02-09 | 2004-03-19 |  |  |  | 2004-02-09 | 2004-03-19 | 29d | 31d |  |  |
| 106 | 1.3.4.2.1 | Assemble IDPU FM 2 LVPS | 15d | 2004-03-01 | 2004-03-19 | 95 |  |  | 2004-03-01 | 2004-03-19 | 15d | 37d | 0d | start no earlier than 2004-03-01 |
| 107 | 1.3.4.2.2 | Assemble SEP FM 2 LVPS | 15d | 2004-02-13 | 2004-03-05 | 96 |  |  | 2004-02-13 | 2004-03-05 | 15d | 27d | 0d | start no earlier than 2004-02-13 |
| 108 | 1.3.4.2.3 | Assemble SWEA FM 2 LVPS | 15d | 2004-02-24 | 2004-03-15 | 97 |  |  | 2004-02-24 | 2004-03-15 | 15d | 53d | 0d | start no earlier than 2004-02-24 |
| 109 | 1.3.4.2.4 | Assemble PLASTIC FM 2 LVPS | 14d | 2004-02-09 | 2004-02-27 | 98 |  |  | 2004-02-09 | 2004-02-27 | 14d | 41d | 0d | start no earlier than 2004-02-09 |
| 110 | 1.3.4.2.5 | Assemble SIT FM 2 HVPS | 14d | 2004-02-09 | 2004-02-27 | 94 |  |  | 2004-02-09 | 2004-02-27 | 14d | 31d | 0d |  |
| 111 | 1.3.5 | **Testing** | 162d | 2003-10-31 A | 2004-06-23 |  | 12% | 141.87d | 2003-10-31 | 2004-06-23 | 162d | 363d |  |  |
| 112 | 1.3.5.1 | **FM 1 & FM 2** | 63d | 2003-11-24 A | 2004-02-25 |  | 80% | 12.6d | 2003-11-24 | 2004-02-25 | 63d | 25d |  |  |
| 113 | 1.3.5.1.1 | Coupon Test IDPU Flight Printed Wiring Board | 4d | 2004-02-20 | 2004-02-25 | 79 |  |  | 2004-02-20 | 2004-02-25 | 4d | 25d | 0d |  |
| 114 | 1.3.5.1.2 | Coupon Test SEP Flight Printed Wiring Board | 5d | 2003-12-09 A | 2003-12-15 A | 80 | 100% |  | 2003-12-09 | 2003-12-15 | 5d |  |  |  |
| 115 | 1.3.5.1.3 | Coupon Test SWEA Flight Printed Wiring Board | 6d | 2004-01-09 A | 2004-01-16 A | 81 | 100% |  | 2004-01-09 | 2004-01-16 | 6d |  |  | start no earlier than 2004-01-09 |
| 116 | 1.3.5.1.4 | Coupon Test PLASTIC Flight Printed Wiring Board | 5d | 2003-11-24 A | 2003-12-01 A | 82 | 100% |  | 2003-11-24 | 2003-12-01 | 5d |  |  | start no earlier than 2003-11-24 |

| ID | WBS | Task | Duration | Start | Finish | Predecessors | Complete | Remaining | Baseline start | Baseline finish | Baseline duration | Total slack | Free slack | Constraint |
| --- | --- | --- | --- | --- | --- | --- | --- | --- | --- | --- | --- | --- | --- | --- |
| 117 | 1.3.5.2 | **FM 1** | 162d | 2003-10-31 A | 2004-06-23 |  | 16% | 136.69d | 2003-10-31 | 2004-06-23 | 162d | 363d |  |  |
| 118 | 1.3.5.2.1 | **IDPU** | 30d | 2004-03-15 | 2004-04-23 |  |  |  | 2004-03-15 | 2004-04-23 | 30d | 25d |  |  |
| 119 | 1.3.5.2.1.1 | Test IDPU FM 1 LVPS | 15d | 2004-03-15 | 2004-04-02 | 101 |  |  | 2004-03-15 | 2004-04-02 | 15d | 25d | 0d |  |
| 120 | 1.3.5.2.1.2 | Coat & Stake IDPU LVPS FM 1 Boards | 5d | 2004-04-05 | 2004-04-09 | 119 |  |  | 2004-04-05 | 2004-04-09 | 5d | 25d | 0d |  |
| 121 | 1.3.5.2.1.3 | Retest IDPU LVPS FM 1 Boards | 10d | 2004-04-12 | 2004-04-23 | 120 |  |  | 2004-04-12 | 2004-04-23 | 10d | 25d | 0d |  |
| 122 | 1.3.5.2.2 | **SEP** | 30d | 2004-02-24 | 2004-04-05 |  |  |  | 2004-02-24 | 2004-04-05 | 30d | 36d |  |  |
| 123 | 1.3.5.2.2.1 | Test SEP FM 1 LVPS | 15d | 2004-02-24 | 2004-03-15 | 102 |  |  | 2004-02-24 | 2004-03-15 | 15d | 36d | 0d |  |
| 124 | 1.3.5.2.2.2 | Coat & Stake SEP LVPS FM 1 Boards | 5d | 2004-03-16 | 2004-03-22 | 123 |  |  | 2004-03-16 | 2004-03-22 | 5d | 36d | 0d |  |
| 125 | 1.3.5.2.2.3 | Retest SEP LVPS FM 1 Boards | 10d | 2004-03-23 | 2004-04-05 | 124, 372 |  |  | 2004-03-23 | 2004-04-05 | 10d | 36d | 0d |  |
| 126 | 1.3.5.2.3 | **SWEA** | 30d | 2004-03-05 | 2004-04-15 |  |  |  | 2004-03-05 | 2004-04-15 | 30d | 9d |  |  |
| 127 | 1.3.5.2.3.1 | Test SWEA FM 1 LVPS | 15d | 2004-03-05 | 2004-03-25 | 103 |  |  | 2004-03-05 | 2004-03-25 | 15d | 9d | 0d |  |
| 128 | 1.3.5.2.3.2 | Coat & Stake SWEA LVPS FM 1 Boards | 5d | 2004-03-26 | 2004-04-01 | 127 |  |  | 2004-03-26 | 2004-04-01 | 5d | 9d | 0d |  |
| 129 | 1.3.5.2.3.3 | Retest SWEA LVPS FM 1 Boards | 10d | 2004-04-02 | 2004-04-15 | 128 |  |  | 2004-04-02 | 2004-04-15 | 10d | 9d | 0d |  |
| 130 | 1.3.5.2.4 | **PLASTIC** | 30d | 2004-02-10 | 2004-03-23 |  |  |  | 2004-02-10 | 2004-03-23 | 30d | 28d |  |  |
| 131 | 1.3.5.2.4.1 | Test PLASTIC FM 1 LVPS | 15d | 2004-02-10 | 2004-03-02 | 104 |  |  | 2004-02-10 | 2004-03-02 | 15d | 28d | 0d |  |
| 132 | 1.3.5.2.4.2 | Coat & Stake PLASTIC LVPS FM 1 Boards | 5d | 2004-03-03 | 2004-03-09 | 131 |  |  | 2004-03-03 | 2004-03-09 | 5d | 28d | 0d |  |
| 133 | 1.3.5.2.4.3 | Retest PLASTIC LVPS FM 1 Boards | 10d | 2004-03-10 | 2004-03-23 | 132 |  |  | 2004-03-10 | 2004-03-23 | 10d | 28d | 0d |  |
| 134 | 1.3.5.2.5 | **SIT** | 162d | 2003-10-31 A | 2004-06-23 |  | 63% | 60.75d | 2003-10-31 | 2004-06-23 | 162d | 363d |  |  |
| 135 | 1.3.5.2.5.1 | Test SIT FM 1 HVPS | 25d | 2003-10-31 A | 2003-12-08 A |  | 100% |  | 2003-10-31 | 2003-12-08 | 25d |  |  | start no earlier than 2003-10-31 |
| 136 | 1.3.5.2.5.2 | Coat & Stake SIT FM 1 HVPS Boards (at UMD) | 5d | 2004-06-03 | 2004-06-09 | 676SS |  |  | 2004-06-03 | 2004-06-09 | 5d | 363d | 0d |  |
| 137 | 1.3.5.2.5.3 | Retest SIT FM 1 HVPS Boards (at UMD) | 10d | 2004-06-10 | 2004-06-23 | 136 |  |  | 2004-06-10 | 2004-06-23 | 10d | 363d |  |  |
| 138 | 1.3.5.3 | **FM 2** | 45d | 2004-03-01 | 2004-04-30 |  |  |  | 2004-03-01 | 2004-04-30 | 45d | 31d |  |  |
| 139 | 1.3.5.3.1 | **IDPU** | 30d | 2004-03-22 | 2004-04-30 |  |  |  | 2004-03-22 | 2004-04-30 | 30d | 37d |  |  |
| 140 | 1.3.5.3.1.1 | Test IDPU FM 2 LVPS | 15d | 2004-03-22 | 2004-04-09 | 106 |  |  | 2004-03-22 | 2004-04-09 | 15d | 37d | 0d |  |
| 141 | 1.3.5.3.1.2 | Coat & Stake IDPU LVPS FM 2 Boards | 5d | 2004-04-12 | 2004-04-16 | 140 |  |  | 2004-04-12 | 2004-04-16 | 5d | 37d | 0d |  |
| 142 | 1.3.5.3.1.3 | Retest IDPU LVPS FM 2 Boards | 10d | 2004-04-19 | 2004-04-30 | 141 |  |  | 2004-04-19 | 2004-04-30 | 10d | 37d | 0d |  |

| ID | WBS | Task | Type | Duration | Start | Finish | Predecessors | Complete | Remaining | Baseline start | Baseline finish | Baseline duration | Total slack | Free slack | Constraint |
| --- | --- | --- | --- | --- | --- | --- | --- | --- | --- | --- | --- | --- | --- | --- | --- |
| 143 | 1.3.5.3.2 | **SEP** |  | 30d | 2004-03-08 | 2004-04-16 |  |  |  | 2004-03-08 | 2004-04-16 | 30d | 27d |  |  |
| 144 | 1.3.5.3.2.1 | Test SEP FM 2 LVPS |  | 15d | 2004-03-08 | 2004-03-26 | 107 |  |  | 2004-03-08 | 2004-03-26 | 15d | 27d | 0d |  |
| 145 | 1.3.5.3.2.2 | Coat & Stake SEP LVPS FM 2 Boards |  | 5d | 2004-03-29 | 2004-04-02 | 144 |  |  | 2004-03-29 | 2004-04-02 | 5d | 27d | 0d |  |
| 146 | 1.3.5.3.2.3 | Retest SEP LVPS FM 2 Boards |  | 10d | 2004-04-05 | 2004-04-16 | 145, 372 |  |  | 2004-04-05 | 2004-04-16 | 10d | 27d | 0d |  |
| 147 | 1.3.5.3.3 | **SWEA** |  | 30d | 2004-03-16 | 2004-04-26 |  |  |  | 2004-03-16 | 2004-04-26 | 30d | 53d |  |  |
| 148 | 1.3.5.3.3.1 | Test SWEA FM 2 LVPS |  | 15d | 2004-03-16 | 2004-04-05 | 108 |  |  | 2004-03-16 | 2004-04-05 | 15d | 53d | 0d |  |
| 149 | 1.3.5.3.3.2 | Coat & Stake SWEA LVPS FM 2 Boards |  | 5d | 2004-04-06 | 2004-04-12 | 148 |  |  | 2004-04-06 | 2004-04-12 | 5d | 53d | 0d |  |
| 150 | 1.3.5.3.3.3 | Retest SWEA LVPS FM 2 Boards |  | 10d | 2004-04-13 | 2004-04-26 | 149 |  |  | 2004-04-13 | 2004-04-26 | 10d | 53d | 0d |  |
| 151 | 1.3.5.3.4 | **PLASTIC** |  | 30d | 2004-03-01 | 2004-04-09 |  |  |  | 2004-03-01 | 2004-04-09 | 30d | 41d |  |  |
| 152 | 1.3.5.3.4.1 | Test PLASTIC FM 2 LVPS |  | 15d | 2004-03-01 | 2004-03-19 | 109 |  |  | 2004-03-01 | 2004-03-19 | 15d | 41d | 0d |  |
| 153 | 1.3.5.3.4.2 | Coat & Stake PLASTIC LVPS FM 2 Boards |  | 5d | 2004-03-22 | 2004-03-26 | 152 |  |  | 2004-03-22 | 2004-03-26 | 5d | 41d | 0d |  |
| 154 | 1.3.5.3.4.3 | Retest PLASTIC LVPS FM 2 Boards |  | 10d | 2004-03-29 | 2004-04-09 | 153 |  |  | 2004-03-29 | 2004-04-09 | 10d | 41d | 0d |  |
| 155 | 1.3.5.3.5 | **SIT** |  | 30d | 2004-03-01 | 2004-04-09 |  |  |  | 2004-03-01 | 2004-04-09 | 30d | 31d |  |  |
| 156 | 1.3.5.3.5.1 | Test SIT FM 2 HVPS |  | 15d | 2004-03-01 | 2004-03-19 | 110 |  |  | 2004-03-01 | 2004-03-19 | 15d | 31d | 0d |  |
| 157 | 1.3.5.3.5.2 | Coat & Stake SIT FM 2 HVPS Boards |  | 5d | 2004-03-22 | 2004-03-26 | 156 |  |  | 2004-03-22 | 2004-03-26 | 5d | 31d | 0d |  |
| 158 | 1.3.5.3.5.3 | Retest SIT FM 2 HVPS Boards |  | 10d | 2004-03-29 | 2004-04-09 | 157 |  |  | 2004-03-29 | 2004-04-09 | 10d | 31d | 0d |  |
| 159 | 1.4 | **IDPU - UCB** |  | 340d | 2003-05-05 A | 2004-09-07 |  | 69% | 105.11d | 2003-05-05 | 2004-09-07 | 340d | 310d |  |  |
| 160 | 1.4.1 | **Deliveries** |  | 33d | 2004-04-13 | 2004-05-28 |  |  |  | 2004-04-13 | 2004-05-28 | 33d | 53d |  |  |
| 161 | 1.4.1.1 | IDPU FM 1 Complete (to UCB for Boom I&T, then to CIT for SEP I&T, Suite EMC, BO & Final Boom I&T) | milestone | 0d | 2004-05-21 | 2004-05-21 | 177 |  |  | 2004-05-21 | 2004-05-21 | 0d | 25d | 16d |  |
| 162 | 1.4.1.2 | IDPU FM 2 Complete (to CIT for SEP I&T, then to UCB for Boom I&T, Boom EMC, BO & Final Boom I&T) | milestone | 0d | 2004-05-28 | 2004-05-28 | 181 |  |  | 2004-05-28 | 2004-05-28 | 0d | 37d | 19d |  |
| 163 | 1.4.1.3 | Deliver IDPU S/W Build 3 (to UNH) | milestone | 0d | 2004-04-13 | 2004-04-13 | 166 |  |  | 2004-04-13 | 2004-04-13 | 0d | 413d |  |  |
| 164 | 1.4.2 | **Flight Software** |  | 237d | 2003-05-05 A | 2004-04-13 |  | 83% | 40.83d | 2003-05-05 | 2004-04-13 | 237d | 60d |  |  |
| 165 | 1.4.2.1 | IDPU S/W Build #2.5 |  | 131d | 2003-05-05 A | 2003-11-07 A |  | 100% |  | 2003-05-05 | 2003-11-07 | 131d |  |  | start no earlier than 2003-05-05 |
| 166 | 1.4.2.2 | IDPU S/W Build #3 |  | 165d | 2003-08-15 A | 2004-04-13 |  | 69% | 51d | 2003-08-15 | 2004-04-13 | 165d | 60d | 0d | start no earlier than 2003-08-15 |

| ID | WBS | Task | Type | Duration | Start | Finish | Predecessors | Complete | Remaining | Baseline start | Baseline finish | Baseline duration | Total slack | Free slack | Constraint |
| --- | --- | --- | --- | --- | --- | --- | --- | --- | --- | --- | --- | --- | --- | --- | --- |
| 167 | 1.4.3 | **GSE** |  | 301d | 2003-06-30 A | 2004-09-07 |  | 65% | 105.98d | 2003-06-30 | 2004-09-07 | 301d | 310d |  |  |
| 168 | 1.4.3.1 | STE Science Display |  | 27d | 2003-10-23 A | 2003-12-02 A |  | 100% |  | 2003-10-23 | 2003-12-02 | 27d |  |  | start no earlier than 2003-10-23 |
| 169 | 1.4.3.2 | SWEA Science Display |  | 162d | 2003-06-30 A | 2004-02-23 |  | 91% | 15d | 2003-06-30 | 2004-02-23 | 162d | 449d |  | start no earlier than 2003-06-30 |
| 170 | 1.4.3.3 | GSE Continued Development |  | 291d | 2003-07-15 A | 2004-09-07 |  | 47% | 154d | 2003-07-15 | 2004-09-07 | 291d | 310d |  | start no earlier than 2003-07-15 |
| 171 | 1.4.4 | **Integration & Test** |  | 162d | 2003-10-07 A | 2004-05-28 |  | 38% | 99.69d | 2003-10-07 | 2004-05-28 | 162d | 37d |  |  |
| 172 | 1.4.4.1 | IDPU DCB FM 2 Board Level Testing |  | 15d | 2003-10-07 A | 2003-10-28 A |  | 100% |  | 2003-10-07 | 2003-10-28 | 15d |  |  | start no earlier than 2003-10-07 |
| 173 | 1.4.4.2 | IDPU DCB Clean/Stake/Coat (FM 1 & FM 2) |  | 10d | 2003-12-26 A | 2004-01-09 A | 172 | 100% |  | 2003-12-26 | 2004-01-09 | 10d |  |  | start no earlier than 2003-12-26 |
| 174 | 1.4.4.3 | **FM 1** |  | 20d | 2004-04-26 | 2004-05-21 |  |  |  | 2004-04-26 | 2004-05-21 | 20d | 25d |  |  |
| 175 | 1.4.4.3.1 | IDPU FM 1 I & T |  | 5d | 2004-04-26 | 2004-04-30 | 165, 67, 240, 284, 173 |  |  | 2004-04-26 | 2004-04-30 | 5d | 25d | 0d |  |
| 176 | 1.4.4.3.2 | IDPU FM 1 Vibration |  | 5d | 2004-05-03 | 2004-05-07 | 175 |  |  | 2004-05-03 | 2004-05-07 | 5d | 25d | 0d |  |
| 177 | 1.4.4.3.3 | IDPU FM 1 Thermal Vacuum & Bake Out |  | 10d | 2004-05-10 | 2004-05-21 | 176 |  |  | 2004-05-10 | 2004-05-21 | 10d | 25d | 0d |  |
| 178 | 1.4.4.4 | **FM 2** |  | 20d | 2004-05-03 | 2004-05-28 |  |  |  | 2004-05-03 | 2004-05-28 | 20d | 37d |  |  |
| 179 | 1.4.4.4.1 | IDPU FM 2 I & T |  | 5d | 2004-05-03 | 2004-05-07 | 73, 241, 285, 172, 173 |  |  | 2004-05-03 | 2004-05-07 | 5d | 37d | 0d |  |
| 180 | 1.4.4.4.2 | IDPU FM 2 Vibration |  | 5d | 2004-05-10 | 2004-05-14 | 179 |  |  | 2004-05-10 | 2004-05-14 | 5d | 37d | 0d |  |
| 181 | 1.4.4.4.3 | IDPU FM 2 Thermal Vacuum & Bake Out |  | 10d | 2004-05-17 | 2004-05-28 | 166, 180 |  |  | 2004-05-17 | 2004-05-28 | 10d | 37d | 0d |  |
| 182 | 1.5 | **BOOM Suite - UCB** |  | 315d | 2003-07-01 A | 2004-09-28 |  | 67% | 105.41d | 2003-07-01 | 2004-09-28 | 315d | 20d |  |  |
| 183 | 1.5.1 | **BOOM Structure - UCB** |  | 195d | 2003-09-10 A | 2004-06-18 |  | 73% | 52.2d | 2003-09-10 | 2004-06-18 | 195d | 70d |  |  |
| 184 | 1.5.1.1 | **Deliveries** |  | 112d | 2004-01-09 A | 2004-06-18 |  |  | 112d | 2004-01-09 | 2004-06-18 | 112d | 70d |  |  |
| 185 | 1.5.1.1.1 | Protoflight Boom available for I&T (if needed) | milestone | 0d | 2004-01-09 A | 2004-01-09 A | 190 | 100% |  | 2004-01-09 | 2004-01-09 | 0d |  |  |  |
| 186 | 1.5.1.1.2 | Deliver Boom Structure FM 1 (stays at UCB for Boom Suite FM 1 I&T) | milestone | 0d | 2004-05-27 | 2004-05-27 | 215 |  |  | 2004-05-27 | 2004-05-27 | 0d | 19d | 10d |  |
| 187 | 1.5.1.1.3 | Deliver Boom Structure FM 2 (stays at UCB for Boom Suite FM 2 I&T) | milestone | 0d | 2004-06-18 | 2004-06-18 | 237 |  |  | 2004-06-18 | 2004-06-18 | 0d | 70d | 50d |  |
| 188 | 1.5.1.2 | **Protoflight** |  | 79d | 2003-09-16 A | 2004-01-09 A |  | 100% |  | 2003-09-16 | 2004-01-09 | 79d |  |  |  |
| 189 | 1.5.1.2.1 | Protoflight Boom Post Environmental Deployment Test |  | 35d | 2003-09-16 A | 2003-11-04 A |  | 100% |  | 2003-09-16 | 2003-11-04 | 35d |  |  | start no earlier than 2003-09-16 |
| 190 | 1.5.1.2.2 | Document Protoflight Boom Test Results |  | 44d | 2003-11-05 A | 2004-01-09 A | 189 | 100% |  | 2003-11-05 | 2004-01-09 | 44d |  |  |  |

| ID | WBS | Task | Duration | Start | Finish | Predecessors | Complete | Remaining | Baseline start | Baseline finish | Baseline duration | Total slack | Free slack | Constraint | Calendar |
| --- | --- | --- | --- | --- | --- | --- | --- | --- | --- | --- | --- | --- | --- | --- | --- |
| 191 | 1.5.1.3 | **Flight Procurements** | 40d | 2003-09-10 A | 2003-11-05 A |  | 100% |  | 2003-09-10 | 2003-11-05 | 40d |  |  |  |  |
| 192 | 1.5.1.3.1 | Receive and Inspect Flight Boom Structure Tubes (FM 1) | 32d | 2003-09-10 A | 2003-10-24 A |  | 100% |  | 2003-09-10 | 2003-10-24 | 32d |  |  | start no earlier than 2003-09-10 |  |
| 193 | 1.5.1.3.2 | Receive and Inspect Flight Boom Structure Tubes (FM 2) | 40d | 2003-09-10 A | 2003-11-05 A |  | 100% |  | 2003-09-10 | 2003-11-05 | 40d |  |  | start no earlier than 2003-09-10 |  |
| 194 | 1.5.1.4 | **FM 1** | 167d | 2003-09-29 A | 2004-05-27 |  | 65% | 57.65d | 2003-09-29 | 2004-05-27 | 167d | 19d |  |  |  |
| 195 | 1.5.1.4.1 | **Telescoping** | 84d | 2003-10-27 A | 2004-02-29 |  | 86% | 11.76d | 2003-10-27 | 2004-02-29 | 84d | 26d |  |  |  |
| 196 | 1.5.1.4.1.1 | **Fabrication, Assembly & Test** | 84d | 2003-10-27 A | 2004-02-29 |  | 86% | 11.76d | 2003-10-27 | 2004-02-29 | 84d | 26d |  |  |  |
| 197 | 1.5.1.4.1.1.1 | Machine FM 1 Boom Structure Tubes as necessary | 5d | 2003-10-27 A | 2003-10-31 A | 192 | 100% |  | 2003-10-27 | 2003-10-31 | 5d |  |  |  |  |
| 198 | 1.5.1.4.1.1.2 | Machine FM 1 Boom Structure Parts (Rings) | 38d | 2003-11-07 A | 2004-01-05 A | 192FF+47d | 100% |  | 2003-11-07 | 2004-01-05 | 38d |  |  |  |  |
| 199 | 1.5.1.4.1.1.3 | Assemble FM 1 Boom Structure Telescoping Assembly | 5d | 2004-02-23 | 2004-02-27 | 197, 198 |  |  | 2004-02-23 | 2004-02-27 | 5d | 24d | 0d | start no earlier than 2004-02-23 |  |
| 200 | 1.5.1.4.1.1.4 | Test FM 1 Boom Structure Telescoping Assembly | 2d | 2004-02-28 | 2004-02-29 | 199 |  |  | 2004-02-28 | 2004-02-29 | 2d | 28d | 6d |  | Boom Test Calendar |
| 201 | 1.5.1.4.2 | **Harness** | 109d | 2003-09-29 A | 2004-03-08 |  | 76% | 26.51d | 2003-09-29 | 2004-03-08 | 109d | 20d |  |  |  |
| 202 | 1.5.1.4.2.1 | **Fabrication** | 103d | 2003-09-29 A | 2004-02-27 |  | 82% | 19d | 2003-09-29 | 2004-02-27 | 103d | 18d |  |  |  |
| 203 | 1.5.1.4.2.1.1 | Machine FM 1 Harness Parts | 103d | 2003-09-29 A | 2004-02-27 |  | 82% | 19d | 2003-09-29 | 2004-02-27 | 103d | 18d | 0d | start no earlier than 2003-09-29 |  |
| 204 | 1.5.1.4.2.2 | **Assembly & Test** | 6d | 2004-03-01 | 2004-03-08 |  |  |  | 2004-03-01 | 2004-03-08 | 6d | 18d |  |  |  |
| 205 | 1.5.1.4.2.2.1 | Assemble FM 1 Harness subassembly | 7d | 2004-03-01 | 2004-03-07 | 203 |  |  | 2004-03-01 | 2004-03-07 | 7d | 20d | 0d | start no earlier than 2004-03-01 | Boom Test Calendar |
| 206 | 1.5.1.4.2.2.2 | FM1 Harness Test | 1d | 2004-03-08 | 2004-03-08 | 205 |  |  | 2004-03-08 | 2004-03-08 | 1d | 20d | 0d |  |  |
| 207 | 1.5.1.4.3 | **Mounting** | 38d | 2003-09-29 A | 2003-11-21 A |  | 100% |  | 2003-09-29 | 2003-11-21 | 38d |  |  |  |  |
| 208 | 1.5.1.4.3.1 | FM 1Boom Structure Mounting Fabrication | 28d | 2003-09-29 A | 2003-11-06 A |  | 100% |  | 2003-09-29 | 2003-11-06 | 28d |  |  | start no earlier than 2003-09-29 |  |
| 209 | 1.5.1.4.3.2 | FM 1Boom Structure Mounting Assembly | 10d | 2003-11-07 A | 2003-11-21 A | 208 | 100% |  | 2003-11-07 | 2003-11-21 | 10d |  |  |  |  |
| 210 | 1.5.1.4.4 | **Integration & Test** | 58d | 2004-03-09 | 2004-05-27 |  |  |  | 2004-03-09 | 2004-05-27 | 58d | 19d |  |  |  |
| 211 | 1.5.1.4.4.1 | Integrate FM 1 Boom Structure subassemblies & Harness Completion | 20d | 2004-03-09 | 2004-04-05 | 200, 206 |  |  | 2004-03-09 | 2004-04-05 | 20d | 20d | 0d |  |  |
| 212 | 1.5.1.4.4.2 | FM 1 Boom Structure Deployment Test | 10d | 2004-04-06 | 2004-04-19 | 211 |  |  | 2004-04-06 | 2004-04-19 | 10d | 20d | 1d |  |  |
| 213 | 1.5.1.4.4.3 | FM 1 Boom Structure Vibration Test | 4d | 2004-04-27 | 2004-04-30 | 212, 351 |  |  | 2004-04-27 | 2004-04-30 | 4d | 19d | 0d |  |  |
| 214 | 1.5.1.4.4.4 | FM 1 Boom Structure Themal Vac & Bake Out | 15d | 2004-05-03 | 2004-05-21 | 213 |  |  | 2004-05-03 | 2004-05-21 | 15d | 19d | 0d |  |  |
| 215 | 1.5.1.4.4.5 | FM 1 Boom Structure Post Environmental Deployment Test | 4d | 2004-05-24 | 2004-05-27 | 214 |  |  | 2004-05-24 | 2004-05-27 | 4d | 19d | 0d |  |  |

| ID | WBS | Task | Duration | Start | Finish | Predecessors | Complete | Remaining | Baseline start | Baseline finish | Baseline duration | Total slack | Free slack |
| --- | --- | --- | --- | --- | --- | --- | --- | --- | --- | --- | --- | --- | --- |
| 216 | 1.5.1.5 | **FM 2** | 182d | 2003-09-29 A | 2004-06-18 |  | 65% | 63.21d | 2003-09-29 | 2004-06-18 | 182d | 70d |  |
| 217 | 1.5.1.5.1 | **Telescoping** | 88d | 2003-11-06 A | 2004-03-16 |  | 88% | 11d | 2003-11-06 | 2004-03-16 | 88d | 80d |  |
| 218 | 1.5.1.5.1.1 | **Fabrication, Assembly & Test** | 88d | 2003-11-06 A | 2004-03-16 |  | 88% | 11d | 2003-11-06 | 2004-03-16 | 88d | 80d |  |
| 219 | 1.5.1.5.1.1.1 | Machine FM 2 Boom Structure Tubes as necessary | 11d | 2003-11-06 A | 2003-11-21 A | 193 | 100% |  | 2003-11-06 | 2003-11-21 | 11d |  |  |
| 220 | 1.5.1.5.1.1.2 | Machine FM 2 Boom Structure Parts (Rings) | 38d | 2003-11-07 A | 2004-01-05 A | 198SS | 100% |  | 2003-11-07 | 2004-01-05 | 38d |  |  |
| 221 | 1.5.1.5.1.1.3 | Assemble FM 2 Boom Structure Telescoping Assembly | 5d | 2004-02-23 | 2004-02-27 | 219, 220, 199SS |  |  | 2004-02-23 | 2004-02-27 | 5d | 80d | 0d |
| 222 | 1.5.1.5.1.1.4 | Test FM 2 Boom Structure Telescoping Assembly | 2d | 2004-03-15 | 2004-03-16 | 221FS+10d |  |  | 2004-03-15 | 2004-03-16 | 2d | 80d | 0d |
| 223 | 1.5.1.5.2 | **Harness** | 115d | 2003-09-29 A | 2004-03-16 |  | 73% | 31d | 2003-09-29 | 2004-03-16 | 115d | 80d |  |
| 224 | 1.5.1.5.2.1 | **Fabrication** | 103d | 2003-09-29 A | 2004-02-27 |  | 82% | 19d | 2003-09-29 | 2004-02-27 | 103d | 80d |  |
| 225 | 1.5.1.5.2.1.1 | Machine FM 2 Harness Parts | 103d | 2003-09-29 A | 2004-02-27 | 203SS | 82% | 19d | 2003-09-29 | 2004-02-27 | 103d | 80d | 0d |
| 226 | 1.5.1.5.2.2 | **Assembly & Test** | 12d | 2004-03-01 | 2004-03-16 |  |  |  | 2004-03-01 | 2004-03-16 | 12d | 80d |  |
| 227 | 1.5.1.5.2.2.1 | Assemble FM 2 Harness subassembly | 11d | 2004-03-01 | 2004-03-15 | 225 |  |  | 2004-03-01 | 2004-03-15 | 11d | 80d | 0d |
| 228 | 1.5.1.5.2.2.2 | FM 2 Harness Test | 1d | 2004-03-16 | 2004-03-16 | 227 |  |  | 2004-03-16 | 2004-03-16 | 1d | 80d | 0d |
| 229 | 1.5.1.5.3 | **Mounting** | 38d | 2003-09-29 A | 2003-11-21 A |  | 100% |  | 2003-09-29 | 2003-11-21 | 38d |  |  |
| 230 | 1.5.1.5.3.1 | FM 2 Boom Structure Mountings Fabrication | 28d | 2003-09-29 A | 2003-11-06 A | 208SS | 100% |  | 2003-09-29 | 2003-11-06 | 28d |  |  |
| 231 | 1.5.1.5.3.2 | FM 2 Boom Structure Mountings Assembly | 10d | 2003-11-07 A | 2003-11-21 A | 230 | 100% |  | 2003-11-07 | 2003-11-21 | 10d |  |  |
| 232 | 1.5.1.5.4 | **Integration & Test** | 67d | 2004-03-17 | 2004-06-18 |  |  |  | 2004-03-17 | 2004-06-18 | 67d | 70d |  |
| 233 | 1.5.1.5.4.1 | Integrate FM 2 Boom Structure subassemblies & Harness Completion | 20d | 2004-03-17 | 2004-04-13 | 222, 228 |  |  | 2004-03-17 | 2004-04-13 | 20d | 80d | 0d |
| 234 | 1.5.1.5.4.2 | FM 2 Boom Structure Deployment Test | 10d | 2004-04-14 | 2004-04-27 | 233 |  |  | 2004-04-14 | 2004-04-27 | 10d | 80d | 9d |
| 235 | 1.5.1.5.4.3 | FM 2 Boom Structure Vibration Test | 4d | 2004-05-17 | 2004-05-20 | 234, 356 |  |  | 2004-05-17 | 2004-05-20 | 4d | 71d | 0d |
| 236 | 1.5.1.5.4.4 | FM 2 Boom Structure Themal Vac & Bake Out | 15d | 2004-05-24 | 2004-06-14 | 235, 214 |  |  | 2004-05-24 | 2004-06-14 | 15d | 70d | 0d |
| 237 | 1.5.1.5.4.5 | FM 2 Boom Structure Post Environmental Deployment Test | 4d | 2004-06-15 | 2004-06-18 | 236 |  |  | 2004-06-15 | 2004-06-18 | 4d | 70d | 0d |
| 238 | 1.5.2 | **MAG - GSFC** | 27d | 2004-02-20 | 2004-03-29 |  |  |  | 2004-02-20 | 2004-03-29 | 27d | 35d |  |
| 239 | 1.5.2.1 | **Deliveries** | 2d | 2004-03-26 | 2004-03-29 |  |  |  | 2004-03-26 | 2004-03-29 | 2d | 35d |  |
| 240 | 1.5.2.1.1 | Deliver MAG FM 1 (to UCB for IDPU/BOOM Suite FM 1 I&T) | 2d | 2004-03-26 | 2004-03-29 | 244 |  |  | 2004-03-26 | 2004-03-29 | 2d | 35d | 16d |
| 241 | 1.5.2.1.2 | Deliver MAG FM 2 (to UCB for IDPU/BOOM Suite FM 2 I&T) | 2d | 2004-03-26 | 2004-03-29 | 247 |  |  | 2004-03-26 | 2004-03-29 | 2d | 61d | 24d |

| ID | WBS | Task | Type | Duration | Start | Finish | Predecessors | Complete | Remaining | Baseline start | Baseline finish | Baseline duration | Total slack | Free slack | Constraint |
| --- | --- | --- | --- | --- | --- | --- | --- | --- | --- | --- | --- | --- | --- | --- | --- |
| 242 | 1.5.2.2 | **FM 1** |  | 25d | 2004-02-20 | 2004-03-25 |  |  |  | 2004-02-20 | 2004-03-25 | 25d | 35d |  |  |
| 243 | 1.5.2.2.1 | FM 1 MAG Testing |  | 10d | 2004-02-20 | 2004-03-04 |  |  |  | 2004-02-20 | 2004-03-04 | 10d | 35d | 0d | start no earlier than 2004-02-20 |
| 244 | 1.5.2.2.2 | MAG FM 1 Calibration |  | 15d | 2004-03-05 | 2004-03-25 | 243 |  |  | 2004-03-05 | 2004-03-25 | 15d | 35d | 0d |  |
| 245 | 1.5.2.3 | **FM 2** |  | 25d | 2004-02-20 | 2004-03-25 |  |  |  | 2004-02-20 | 2004-03-25 | 25d | 61d |  |  |
| 246 | 1.5.2.3.1 | FM 2 MAG Testing |  | 10d | 2004-02-20 | 2004-03-04 |  |  |  | 2004-02-20 | 2004-03-04 | 10d | 61d | 0d | start no earlier than 2004-02-20 |
| 247 | 1.5.2.3.2 | MAG FM 2 Calibration |  | 15d | 2004-03-05 | 2004-03-25 | 246 |  |  | 2004-03-05 | 2004-03-25 | 15d | 61d | 0d |  |
| 248 | 1.5.3 | **SWEA - CESR** |  | 93d | 2003-12-08 A | 2004-04-20 |  | 6% | 87.74d | 2003-12-08 | 2004-04-20 | 93d | 67d |  |  |
| 249 | 1.5.3.1 | **Deliveries** |  | 93d | 2003-12-08 A | 2004-04-20 |  | 50% | 46.5d | 2003-12-08 | 2004-04-20 | 93d | 67d |  |  |
| 250 | 1.5.3.1.1 | SWEA FM 1 Delivery to UCB |  | 3d | 2003-12-08 A | 2003-12-10 A |  | 100% |  | 2003-12-08 | 2003-12-10 | 3d |  |  | start no earlier than 2003-12-08 |
| 251 | 1.5.3.1.2 | SWEA FM 2 Delivery to UCB |  | 3d | 2004-04-16 | 2004-04-20 | 254 |  |  | 2004-04-16 | 2004-04-20 | 3d | 67d | 47d |  |
| 252 | 1.5.3.2 | **FM 2** |  | 47d | 2004-02-10 | 2004-04-15 |  |  |  | 2004-02-10 | 2004-04-15 | 47d | 67d |  |  |
| 253 | 1.5.3.2.1 | SWEA FM 2 Final Assembly (Block 2) |  | 3d | 2004-02-10 | 2004-02-12 |  |  |  | 2004-02-10 | 2004-02-12 | 3d | 67d | 0d | start no earlier than 2004-02-10 |
| 254 | 1.5.3.2.2 | SWEA FM 2 Calibration |  | 44d | 2004-02-13 | 2004-04-15 | 253 |  |  | 2004-02-13 | 2004-04-15 | 44d | 67d | 0d |  |
| 255 | 1.5.4 | **STE - UCB** |  | 174d | 2003-08-29 A | 2004-05-10 |  | 67% | 57.3d | 2003-08-29 | 2004-05-10 | 174d | 71d |  |  |
| 256 | 1.5.4.1 | **Deliveries** |  | 18d | 2004-04-14 | 2004-05-10 |  |  |  | 2004-04-14 | 2004-05-10 | 18d | 20d |  |  |
| 257 | 1.5.4.1.1 | Deliver STE-D FM 1 (stays at UCB for SWEA/STE-D FM 1 I&T) | milestone | 0d | 2004-04-14 | 2004-04-14 | 272 |  |  | 2004-04-14 | 2004-04-14 | 0d | 20d | 11d |  |
| 258 | 1.5.4.1.2 | Deliver STE-D FM 2 (stays at UCB for SWEA/STE-D FM 2 I&T) | milestone | 0d | 2004-05-10 | 2004-05-10 | 280 |  |  | 2004-05-10 | 2004-05-10 | 0d | 53d | 33d |  |
| 259 | 1.5.4.1.3 | Deliver STE-U FM 1 (stays at UCB for BOOM Suite FM 1 I&T) | milestone | 0d | 2004-04-20 | 2004-04-20 | 273 |  |  | 2004-04-20 | 2004-04-20 | 0d | 19d | 0d |  |
| 260 | 1.5.4.1.4 | Deliver STE-U FM 2 (stays at UCB for BOOM Suite FM 2 I&T) | milestone | 0d | 2004-05-10 | 2004-05-10 | 281 |  |  | 2004-05-10 | 2004-05-10 | 0d | 71d | 0d |  |
| 261 | 1.5.4.2 | **STE-U/D Housing** |  | 53d | 2003-11-21 A | 2004-02-09 A |  | 100% |  | 2003-11-21 | 2004-02-09 | 53d |  |  |  |
| 262 | 1.5.4.2.1 | Fabricate STE FM 1 Box |  | 53d | 2003-11-21 A | 2004-02-09 A |  | 100% |  | 2003-11-21 | 2004-02-09 | 53d |  |  | start no earlier than 2003-11-21 |
| 263 | 1.5.4.2.2 | Fabricate STE FM 2 Box |  | 53d | 2003-11-21 A | 2004-02-09 A |  | 100% |  | 2003-11-21 | 2004-02-09 | 53d |  |  | start no earlier than 2003-11-21 |
| 264 | 1.5.4.3 | **STE-U/D Detector Boards** |  | 174d | 2003-08-29 A | 2004-05-10 |  | 56% | 76.9d | 2003-08-29 | 2004-05-10 | 174d | 71d |  |  |
| 265 | 1.5.4.3.1 | Coupon Test STE FM 1 & FM 2 Detector Printed Wiring Board |  | 17d | 2003-10-10 A | 2003-11-04 A | 267, 275 | 100% |  | 2003-10-10 | 2003-11-04 | 17d |  |  | start no earlier than 2003-10-10 |

| ID | WBS | Task | Type | Duration | Start | Finish | Predecessors | Complete | Remaining | Baseline start | Baseline finish | Baseline duration | Total slack | Free slack | Constraint |
| --- | --- | --- | --- | --- | --- | --- | --- | --- | --- | --- | --- | --- | --- | --- | --- |
| 266 | 1.5.4.3.2 | **FM 1** |  | 160d | 2003-08-29 A | 2004-04-20 |  | 58% | 66.93d | 2003-08-29 | 2004-04-20 | 160d | 19d |  |  |
| 267 | 1.5.4.3.2.1 | Fabrication STE FM 1 Detector Printed Wiring Board |  | 29d | 2003-08-29 A | 2003-10-09 A |  | 100% |  | 2003-08-29 | 2003-10-09 | 29d |  |  | start no earlier than 2003-08-29 |
| 268 | 1.5.4.3.2.2 | Load STE FM 1 Detector Printed Wiring Board |  | 60d | 2003-11-05 A | 2004-02-03 A | 265 | 100% |  | 2003-11-05 | 2004-02-03 | 60d |  |  |  |
| 269 | 1.5.4.3.2.3 | Test STE FM 1 Detector Printed Wiring Board |  | 10d | 2004-02-04 | 2004-02-18 | 268 |  |  | 2004-02-04 | 2004-02-18 | 10d | 19d | 0d |  |
| 270 | 1.5.4.3.2.4 | **Integration & Test** |  | 44d | 2004-02-19 | 2004-04-20 |  |  |  | 2004-02-19 | 2004-04-20 | 44d | 19d |  |  |
| 271 | 1.5.4.3.2.4.1 | Integrate & Test STE-U/D FM 1 Detectors W/ FM 1 Housings |  | 20d | 2004-02-19 | 2004-03-17 | 262, 269 |  |  | 2004-02-19 | 2004-03-17 | 20d | 19d | 0d |  |
| 272 | 1.5.4.3.2.4.2 | Calibrate STE-U/D FM 1 |  | 20d | 2004-03-18 | 2004-04-14 | 271 |  |  | 2004-03-18 | 2004-04-14 | 20d | 19d | 0d |  |
| 273 | 1.5.4.3.2.4.3 | STE-U FM 1 Thermal Vacuum/Balance/Bake Out |  | 14d | 2004-04-01 | 2004-04-20 | 272FS-10d |  |  | 2004-04-01 | 2004-04-20 | 14d | 19d | 0d |  |
| 274 | 1.5.4.3.3 | **FM 2** |  | 174d | 2003-08-29 A | 2004-05-10 |  | 48% | 90.73d | 2003-08-29 | 2004-05-10 | 174d | 71d |  |  |
| 275 | 1.5.4.3.3.1 | Fabricate STE FM 2 Detector Printed Wiring Board |  | 29d | 2003-08-29 A | 2003-10-09 A |  | 100% |  | 2003-08-29 | 2003-10-09 | 29d |  |  | start no earlier than 2003-08-29 |
| 276 | 1.5.4.3.3.2 | Load STE FM 2 Detector Printed Wiring Board |  | 63d | 2003-11-05 A | 2004-03-17 | 265, 269FF+20d | 60% | 25d | 2003-11-05 | 2004-03-17 | 63d | 53d | 0d |  |
| 277 | 1.5.4.3.3.3 | Test STE FM 2 Detector Printed Wiring Board |  | 10d | 2004-03-18 | 2004-03-31 | 276 |  |  | 2004-03-18 | 2004-03-31 | 10d | 53d | 0d |  |
| 278 | 1.5.4.3.3.4 | **Integration & Test** |  | 28d | 2004-04-01 | 2004-05-10 |  |  |  | 2004-04-01 | 2004-05-10 | 28d | 53d |  |  |
| 279 | 1.5.4.3.3.4.1 | Integrate & Test STE-U/D FM 2 Detectors W/ FM 2 Housings |  | 10d | 2004-04-01 | 2004-04-14 | 263, 277, 271 |  |  | 2004-04-01 | 2004-04-14 | 10d | 53d | 0d |  |
| 280 | 1.5.4.3.3.4.2 | Calibrate STE-U/D FM 2 |  | 18d | 2004-04-15 | 2004-05-10 | 279 |  |  | 2004-04-15 | 2004-05-10 | 18d | 53d | 0d |  |
| 281 | 1.5.4.3.3.4.3 | STE-U FM 2 Thermal Vacuum/Bake Out |  | 10d | 2004-04-27 | 2004-05-10 | 280FS-10d |  |  | 2004-04-27 | 2004-05-10 | 10d | 71d | 0d |  |
| 282 | 1.5.5 | **STE and SWEA - UCB** |  | 294d | 2003-07-01 A | 2004-08-27 |  | 73% | 79.34d | 2003-07-01 | 2004-08-27 | 294d | 20d |  |  |
| 283 | 1.5.5.1 | **Deliveries** |  | 129d | 2004-02-27 | 2004-08-27 |  |  |  | 2004-02-27 | 2004-08-27 | 129d | 20d |  |  |
| 284 | 1.5.5.1.1 | Deliver STE-U FM 1 Interface (stays at UCB for IDPU FM 1 I&T) | milestone | 0d | 2004-02-27 | 2004-02-27 | 333 |  |  | 2004-02-27 | 2004-02-27 | 0d | 65d | 40d |  |
| 285 | 1.5.5.1.2 | Deliver STE-U FM 2 Interface (stays at UCB for IDPU FM 2 I&T) | milestone | 0d | 2004-03-01 | 2004-03-01 | 342 |  |  | 2004-03-01 | 2004-03-01 | 0d | 81d | 44d |  |
| 286 | 1.5.5.1.3 | Deliver SWEA/STE-D FM 1 (stays at UCB for Boom Suite FM 1 I&T) | milestone | 0d | 2004-06-11 | 2004-06-11 | 339 |  |  | 2004-06-11 | 2004-06-11 | 0d | 9d | 0d |  |
| 287 | 1.5.5.1.4 | Deliver SWEA/STE-D FM 2 (stays at UCB for Boom Suite FM 2 I&T) | milestone | 0d | 2004-08-27 | 2004-08-27 | 348 |  |  | 2004-08-27 | 2004-08-27 | 0d | 20d | 0d |  |
| 288 | 1.5.5.2 | **SWEA Pedestal** |  | 152d | 2003-07-01 A | 2004-02-09 A |  | 100% |  | 2003-07-01 | 2004-02-09 | 152d |  |  |  |
| 289 | 1.5.5.2.1 | Fabricate SWEA FM 1 Baseplate |  | 152d | 2003-07-01 A | 2004-02-09 A |  | 100% |  | 2003-07-01 | 2004-02-09 | 152d |  |  | start no earlier than 2003-07-01 |
| 290 | 1.5.5.2.2 | Fabricate SWEA FM 2 Baseplate |  | 152d | 2003-07-01 A | 2004-02-09 A |  | 100% |  | 2003-07-01 | 2004-02-09 | 152d |  |  | start no earlier than 2003-07-01 |

| ID | WBS | Task | Duration | Start | Finish | Predecessors | Complete | Remaining | Baseline start | Baseline finish | Baseline duration | Total slack | Free slack | Constraint |
| --- | --- | --- | --- | --- | --- | --- | --- | --- | --- | --- | --- | --- | --- | --- |
| 291 | 1.5.5.3 | **STE-D Pre-Amp Board** | 104d | 2003-09-22 A | 2004-02-23 |  | 89% | 11.18d | 2003-09-22 | 2004-02-23 | 104d | 78d |  |  |
| 292 | 1.5.5.3.1 | **FM 1** | 104d | 2003-09-22 A | 2004-02-23 |  | 87% | 13.33d | 2003-09-22 | 2004-02-23 | 104d | 27d |  |  |
| 293 | 1.5.5.3.1.1 | Fabricate STE-D FM 1 Preamp Printed Wiring Board | 34d | 2003-09-22 A | 2003-11-07 A |  | 100% |  | 2003-09-22 | 2003-11-07 | 34d |  |  | start no earlier than 2003-09-22 |
| 294 | 1.5.5.3.1.2 | Load STE-D FM 1 Preamp Printed Wiring Board | 5d | 2004-02-17 | 2004-02-23 | 298 |  |  | 2004-02-17 | 2004-02-23 | 5d | 27d | 0d | start no earlier than 2004-02-17 |
| 295 | 1.5.5.3.2 | **FM 2** | 104d | 2003-09-22 A | 2004-02-23 |  | 87% | 13.33d | 2003-09-22 | 2004-02-23 | 104d | 78d |  |  |
| 296 | 1.5.5.3.2.1 | Fabricate STE-D FM 2 Preamp Printed Wiring Board | 34d | 2003-09-22 A | 2003-11-07 A |  | 100% |  | 2003-09-22 | 2003-11-07 | 34d |  |  | start no earlier than 2003-09-22 |
| 297 | 1.5.5.3.2.2 | Load STE-D FM 2 Preamp Printed Wiring Board | 5d | 2004-02-17 | 2004-02-23 | 294SS |  |  | 2004-02-17 | 2004-02-23 | 5d | 78d | 58d |  |
| 298 | 1.5.5.3.3 | Coupon Test STE-D FM 1 & FM 2 Pre-Amp Printed Wiring Boards | 15d | 2003-11-10 A | 2003-12-02 A | 293, 296 | 100% |  | 2003-11-10 | 2003-12-02 | 15d |  |  |  |
| 299 | 1.5.5.4 | **STE-D Shaper Board** | 112d | 2003-12-04 A | 2004-05-13 |  | 78% | 24.89d | 2003-12-04 | 2004-05-13 | 112d | 20d |  |  |
| 300 | 1.5.5.4.1 | **FM 1** | 53d | 2003-12-04 A | 2004-02-20 |  | 67% | 17.67d | 2003-12-04 | 2004-02-20 | 53d | 28d |  |  |
| 301 | 1.5.5.4.1.1 | Fabricate STE-D FM 1 Shaper Printed Wiring Board | 10d | 2003-12-04 A | 2003-12-17 A |  | 100% |  | 2003-12-04 | 2003-12-17 | 10d |  |  | start no earlier than 2003-12-04 |
| 302 | 1.5.5.4.1.2 | Load STE-D FM 1 Shaper Printed Wiring Board | 5d | 2004-02-13 | 2004-02-20 | 306 |  |  | 2004-02-13 | 2004-02-20 | 5d | 28d | 0d | start no earlier than 2004-02-13 |
| 303 | 1.5.5.4.2 | **FM 2** | 112d | 2003-12-04 A | 2004-05-13 |  | 67% | 37.33d | 2003-12-04 | 2004-05-13 | 112d | 20d |  |  |
| 304 | 1.5.5.4.2.1 | Fabricate STE-D FM 2 Shaper Printed Wiring Board | 10d | 2003-12-04 A | 2003-12-17 A |  | 100% |  | 2003-12-04 | 2003-12-17 | 10d |  |  | start no earlier than 2003-12-04 |
| 305 | 1.5.5.4.2.2 | Load STE-D FM 2 Shaper Printed Wiring Board | 5d | 2004-05-07 | 2004-05-13 | 306, 337 |  |  | 2004-05-07 | 2004-05-13 | 5d | 20d | 0d |  |
| 306 | 1.5.5.4.3 | Coupon Test STE-D FM 1 & FM 2 Shaper Printed Wiring Boards | 15d | 2003-12-18 A | 2004-01-09 A | 301, 304 | 100% |  | 2003-12-18 | 2004-01-09 | 15d |  |  |  |
| 307 | 1.5.5.5 | **STE-D Interface Board** | 112d | 2003-12-04 A | 2004-05-13 |  | 78% | 24.89d | 2003-12-04 | 2004-05-13 | 112d | 20d |  |  |
| 308 | 1.5.5.5.1 | **FM 1** | 53d | 2003-12-04 A | 2004-02-20 |  | 67% | 17.67d | 2003-12-04 | 2004-02-20 | 53d | 28d |  |  |
| 309 | 1.5.5.5.1.1 | Fabricate SWEA / STE-D FM 1 Digital to Analog Converter Printed Wiring Board | 10d | 2003-12-04 A | 2003-12-17 A |  | 100% |  | 2003-12-04 | 2003-12-17 | 10d |  |  | start no earlier than 2003-12-04 |
| 310 | 1.5.5.5.1.2 | Load SWEA / STE-D FM 1 Digital to Analog Converter Printed Wiring Board | 5d | 2004-02-13 | 2004-02-20 | 302SS |  |  | 2004-02-13 | 2004-02-20 | 5d | 28d | 1d |  |
| 311 | 1.5.5.5.2 | **FM 2** | 112d | 2003-12-04 A | 2004-05-13 |  | 67% | 37.33d | 2003-12-04 | 2004-05-13 | 112d | 20d |  |  |
| 312 | 1.5.5.5.2.1 | Fabricate SWEA / STE-D FM 2 Digital to Analog Converter Printed Wiring Board | 10d | 2003-12-04 A | 2003-12-17 A |  | 100% |  | 2003-12-04 | 2003-12-17 | 10d |  |  | start no earlier than 2003-12-04 |
| 313 | 1.5.5.5.2.2 | Load SWEA / STE-D FM 2 Digital to Analog Converter Printed Wiring Board | 5d | 2004-05-07 | 2004-05-13 | 305SS |  |  | 2004-05-07 | 2004-05-13 | 5d | 20d | 0d |  |
| 314 | 1.5.5.5.3 | Coupon Test STE-D FM 1 & FM 2 D/A Converter Printed Wiring Boards | 15d | 2003-12-18 A | 2004-01-09 A | 309, 312 | 100% |  | 2003-12-18 | 2004-01-09 | 15d |  |  |  |

| ID | WBS | Task | Duration | Start | Finish | Predecessors | Complete | Remaining | Baseline start | Baseline finish | Baseline duration | Total slack | Free slack | Constraint |
| --- | --- | --- | --- | --- | --- | --- | --- | --- | --- | --- | --- | --- | --- | --- |
| 315 | 1.5.5.6 | **STE-U Pre-Amp Board** | 104d | 2003-09-22 A | 2004-02-23 |  | 95% | 5.65d | 2003-09-22 | 2004-02-23 | 104d | 81d |  |  |
| 316 | 1.5.5.6.1 | **FM 1** | 79d | 2003-09-22 A | 2004-01-15 A |  | 100% |  | 2003-09-22 | 2004-01-15 | 79d |  |  |  |
| 317 | 1.5.5.6.1.1 | Fabricate STE-U FM 1 Preamp Printed Wiring Board | 34d | 2003-09-22 A | 2003-11-07 A |  | 100% |  | 2003-09-22 | 2003-11-07 | 34d |  |  | start no earlier than 2003-09-22 |
| 318 | 1.5.5.6.1.2 | Load STE-U FM 1 Preamp Printed Wiring Board | 4d | 2004-01-12 A | 2004-01-15 A | 322 | 100% |  | 2004-01-12 | 2004-01-15 | 4d |  |  | start no earlier than 2004-01-12 |
| 319 | 1.5.5.6.2 | **FM 2** | 104d | 2003-09-22 A | 2004-02-23 |  | 87% | 13.33d | 2003-09-22 | 2004-02-23 | 104d | 81d |  |  |
| 320 | 1.5.5.6.2.1 | Fabricate STE-U FM 2 Preamp Printed Wiring Board | 34d | 2003-09-22 A | 2003-11-07 A |  | 100% |  | 2003-09-22 | 2003-11-07 | 34d |  |  | start no earlier than 2003-09-22 |
| 321 | 1.5.5.6.2.2 | Load STE-U FM 2 Preamp Printed Wiring Board | 5d | 2004-02-17 | 2004-02-23 | 322 |  |  | 2004-02-17 | 2004-02-23 | 5d | 81d | 0d | start no earlier than 2004-02-17 |
| 322 | 1.5.5.6.3 | Coupon Test STE-U FM 1 & FM 2 Pre-Amp Printed Wiring Boards | 15d | 2003-11-10 A | 2003-12-02 A | 317, 320 | 100% |  | 2003-11-10 | 2003-12-02 | 15d |  |  |  |
| 323 | 1.5.5.7 | **STE-U Shaper & Interface Board** | 53d | 2003-12-04 A | 2004-02-20 |  | 78% | 11.78d | 2003-12-04 | 2004-02-20 | 53d | 82d |  |  |
| 324 | 1.5.5.7.1 | **FM 1** | 53d | 2003-12-04 A | 2004-02-20 |  | 67% | 17.67d | 2003-12-04 | 2004-02-20 | 53d | 65d |  |  |
| 325 | 1.5.5.7.1.1 | Fabricate STE-U FM 1Shaper & Interface Printed Wiring Board | 10d | 2003-12-04 A | 2003-12-17 A |  | 100% |  | 2003-12-04 | 2003-12-17 | 10d |  |  | start no earlier than 2003-12-04 |
| 326 | 1.5.5.7.1.2 | Load STE-U FM 1 Shaper & Interface Printed Wiring Board | 5d | 2004-02-13 | 2004-02-20 | 330 |  |  | 2004-02-13 | 2004-02-20 | 5d | 65d | 0d | start no earlier than 2004-02-13 |
| 327 | 1.5.5.7.2 | **FM 2** | 53d | 2003-12-04 A | 2004-02-20 |  | 67% | 17.67d | 2003-12-04 | 2004-02-20 | 53d | 82d |  |  |
| 328 | 1.5.5.7.2.1 | Fabricate STE-U FM 2 Shaper & Interface Printed Wiring Board | 10d | 2003-12-04 A | 2003-12-17 A |  | 100% |  | 2003-12-04 | 2003-12-17 | 10d |  |  | start no earlier than 2003-12-04 |
| 329 | 1.5.5.7.2.2 | Load STE-U FM 2 Shaper & Interface Printed Wiring Board | 5d | 2004-02-13 | 2004-02-20 | 326SS |  |  | 2004-02-13 | 2004-02-20 | 5d | 82d | 1d |  |
| 330 | 1.5.5.7.3 | Coupon Test STE-U FM 1 & FM 2 Shaper & Interface Printed Wiring Boards | 15d | 2003-12-18 A | 2004-01-09 A | 325, 328 | 100% |  | 2003-12-18 | 2004-01-09 | 15d |  |  |  |
| 331 | 1.5.5.8 | **Integration & Test** | 134d | 2004-02-23 | 2004-08-27 |  |  |  | 2004-02-23 | 2004-08-27 | 134d | 20d |  |  |
| 332 | 1.5.5.8.1 | **FM 1** | 114d | 2004-02-23 | 2004-07-30 |  |  |  | 2004-02-23 | 2004-07-30 | 114d | 28d |  |  |
| 333 | 1.5.5.8.1.1 | Integrate & Test STE-U FM 1 Interface Boards | 5d | 2004-02-23 | 2004-02-27 | 318, 326 |  |  | 2004-02-23 | 2004-02-27 | 5d | 65d | 0d |  |
| 334 | 1.5.5.8.1.2 | Integrate & Test SWEA/STE-D FM 1 Interface Boards | 20d | 2004-02-24 | 2004-03-22 | 289, 294, 302, 310 |  |  | 2004-02-24 | 2004-03-22 | 20d | 27d | 0d |  |
| 335 | 1.5.5.8.1.3 | Integrate & Test SWEA/STE-D FM 1 Interface with SWEA/STE-D FM 1 LVPS | 10d | 2004-04-16 | 2004-04-29 | 334, 69 |  |  | 2004-04-16 | 2004-04-29 | 10d | 9d | 0d |  |
| 336 | 1.5.5.8.1.4 | Clean/Coat/Stake SWEA/STE-D Interface | 10d | 2004-03-23 | 2004-04-05 | 334 |  |  | 2004-03-23 | 2004-04-05 | 10d | 27d | 18d |  |
| 337 | 1.5.5.8.1.5 | Integrate & Test SWEA/STE-D FM 1 Combined | 5d | 2004-04-30 | 2004-05-06 | 335, 336, 250, 257 |  |  | 2004-04-30 | 2004-05-06 | 5d | 9d | 0d |  |
| 338 | 1.5.5.8.1.6 | Calibrate SWEA/STE FM 1 | 20d | 2004-05-07 | 2004-06-04 | 337 |  |  | 2004-05-07 | 2004-06-04 | 20d | 9d | 0d |  |
| 339 | 1.5.5.8.1.7 | SWEA/STE FM 1 Vibration | 5d | 2004-06-07 | 2004-06-11 | 338 |  |  | 2004-06-07 | 2004-06-11 | 5d | 9d | 0d |  |
| 340 | 1.5.5.8.1.8 | SWEA/STE-D FM 1 Thermal Vac/Thermal Balance/Bake Out | 14d | 2004-07-13 | 2004-07-30 | 19 |  |  | 2004-07-13 | 2004-07-30 | 14d | 37d | 0d |  |

| ID | WBS | Task | Duration | Start | Finish | Predecessors | Complete | Remaining | Baseline start | Baseline finish | Baseline duration | Total slack | Free slack | Constraint |
| --- | --- | --- | --- | --- | --- | --- | --- | --- | --- | --- | --- | --- | --- | --- |
| 341 | 1.5.5.8.2 | **FM 2** | 133d | 2004-02-24 | 2004-08-27 |  |  |  | 2004-02-24 | 2004-08-27 | 133d | 20d |  |  |
| 342 | 1.5.5.8.2.1 | Integrate & Test STE-U FM 2 Interface Boards | 5d | 2004-02-24 | 2004-03-01 | 321, 329 |  |  | 2004-02-24 | 2004-03-01 | 5d | 81d | 0d |  |
| 343 | 1.5.5.8.2.2 | Integrate & Test SWEA/STE-D FM 2 Interface Boards | 20d | 2004-05-14 | 2004-06-11 | 290, 297, 305, 313 |  |  | 2004-05-14 | 2004-06-11 | 20d | 20d | 0d |  |
| 344 | 1.5.5.8.2.3 | Integrate & Test SWEA/STE-D FM 2 Interface with SWEA/STE-D FM 2 LVPS | 10d | 2004-06-14 | 2004-06-25 | 343, 75 |  |  | 2004-06-14 | 2004-06-25 | 10d | 20d | 0d |  |
| 345 | 1.5.5.8.2.4 | Integrate & Test SWEA/STE-D FM 2 Combined | 10d | 2004-06-28 | 2004-07-09 | 344, 251, 258 |  |  | 2004-06-28 | 2004-07-09 | 10d | 20d | 0d |  |
| 346 | 1.5.5.8.2.5 | Calibrate SWEA/STE FM 2 | 20d | 2004-07-12 | 2004-08-06 | 345 |  |  | 2004-07-12 | 2004-08-06 | 20d | 20d | 0d |  |
| 347 | 1.5.5.8.2.6 | SWEA/STE FM 2 Vibration | 5d | 2004-08-09 | 2004-08-13 | 346 |  |  | 2004-08-09 | 2004-08-13 | 5d | 20d | 0d |  |
| 348 | 1.5.5.8.2.7 | SWEA/STE-D FM 2 Thermal Vac & bake Out | 10d | 2004-08-16 | 2004-08-27 | 347 |  |  | 2004-08-16 | 2004-08-27 | 10d | 20d | 0d |  |
| 349 | 1.5.6 | **Boom Suite I&T - UCB** | 113d | 2004-04-21 | 2004-09-28 |  |  |  | 2004-04-21 | 2004-09-28 | 113d | 19d |  |  |
| 350 | 1.5.6.1 | **FM 1** | 82d | 2004-04-21 | 2004-08-13 |  |  |  | 2004-04-21 | 2004-08-13 | 82d | 19d |  |  |
| 351 | 1.5.6.1.1 | FM 1 Boom/MAG/STE-U I&T | 4d | 2004-04-21 | 2004-04-26 | 212, 240, 259 |  |  | 2004-04-21 | 2004-04-26 | 4d | 19d | 0d |  |
| 352 | 1.5.6.1.2 | FM 1 Boom/SWEA/STE/MAG I&T | 2d | 2004-06-14 | 2004-06-15 | 286, 186 |  |  | 2004-06-14 | 2004-06-15 | 2d | 9d | 0d |  |
| 353 | 1.5.6.1.3 | FM 1 Integrated Boom/IDPU I&T | 4d | 2004-06-16 | 2004-06-21 | 352, 186, 161 |  |  | 2004-06-16 | 2004-06-21 | 4d | 9d | 0d |  |
| 354 | 1.5.6.1.4 | Final BOOM Suite FM 1 I & T | 10d | 2004-08-02 | 2004-08-13 | 353, 340 |  |  | 2004-08-02 | 2004-08-13 | 10d | 37d | 0d |  |
| 355 | 1.5.6.2 | **FM 2** | 99d | 2004-05-11 | 2004-09-28 |  |  |  | 2004-05-11 | 2004-09-28 | 99d | 20d |  |  |
| 356 | 1.5.6.2.1 | FM 2 Boom/MAG/STE-U I&T | 4d | 2004-05-11 | 2004-05-14 | 234, 241, 260 |  |  | 2004-05-11 | 2004-05-14 | 4d | 71d | 0d |  |
| 357 | 1.5.6.2.2 | FM 2 Boom/SWEA/STE/MAG I&T | 2d | 2004-08-30 | 2004-08-31 | 287, 187 |  |  | 2004-08-30 | 2004-08-31 | 2d | 20d | 0d |  |
| 358 | 1.5.6.2.3 | FM 2 Integrated Boom/IDPU I&T | 4d | 2004-09-01 | 2004-09-07 | 357, 187, 761 |  |  | 2004-09-01 | 2004-09-07 | 4d | 20d | 0d |  |
| 359 | 1.5.6.2.4 | Boom Suite FM 2 EMC | 5d | 2004-09-08 | 2004-09-14 | 358 |  |  | 2004-09-08 | 2004-09-14 | 5d | 20d | 0d |  |
| 360 | 1.5.6.2.5 | Final BOOM Suite FM 2 I & T | 10d | 2004-09-15 | 2004-09-28 | 359 |  |  | 2004-09-15 | 2004-09-28 | 10d | 20d | 0d |  |
| 361 | 1.6 | **SEP Suite - CIT** | 352d | 2003-06-02 A | 2004-10-21 |  | 42% | 204.11d | 2003-06-02 | 2004-10-21 | 352d | 279d |  |  |
| 362 | 1.6.1 | **SEP Mechanical - Sandy Shuman (GSFC)** | 90d | 2004-01-27 A | 2004-06-02 |  | 1% | 88.75d | 2004-01-27 | 2004-06-02 | 90d | 37d |  |  |
| 363 | 1.6.1.1 | **SIT Electronics Enclosure (Priority 1)** | 26d | 2004-02-09 | 2004-03-16 |  |  |  | 2004-02-09 | 2004-03-16 | 26d | 15d |  |  |
| 364 | 1.6.1.1.1 | Complete Design/Drawings for SIT Enclosure | 10d | 2004-02-09 | 2004-02-23 |  |  |  | 2004-02-09 | 2004-02-23 | 10d | 15d | 0d | start no earlier than 2004-02-09 |
| 365 | 1.6.1.1.2 | Fabrication of SIT Enclosure | 10d | 2004-02-24 | 2004-03-08 | 364 |  |  | 2004-02-24 | 2004-03-08 | 10d | 16d | 0d |  |
| 366 | 1.6.1.1.3 | Inspection and Final Assembly of SIT Enclosure | 5d | 2004-03-09 | 2004-03-15 | 365 |  |  | 2004-03-09 | 2004-03-15 | 5d | 16d | 0d |  |
| 367 | 1.6.1.1.4 | Deliver SIT Enclosure to UMD | 1d | 2004-03-16 | 2004-03-16 | 366 |  |  | 2004-03-16 | 2004-03-16 | 1d | 16d | 0d |  |

| ID | WBS | Task | Type | Duration | Start | Finish | Predecessors | Baseline start | Baseline finish | Baseline duration | Total slack | Free slack |
| --- | --- | --- | --- | --- | --- | --- | --- | --- | --- | --- | --- | --- |
| 368 | 1.6.1.2 | **SEP FM 1 & FM 2 LVPS Boxes (Priority 2)** |  | 23d | 2004-02-09 | 2004-03-11 |  | 2004-02-09 | 2004-03-11 | 23d | 15d |  |
| 369 | 1.6.1.2.1 | Complete Design/Drawings for SEP LVPS Boxes |  | 5d | 2004-02-09 | 2004-02-13 | 364SS | 2004-02-09 | 2004-02-13 | 5d | 15d | 0d |
| 370 | 1.6.1.2.2 | Fabrication of SEP LVPS Boxes |  | 10d | 2004-02-17 | 2004-03-01 | 369 | 2004-02-17 | 2004-03-01 | 10d | 43d | 0d |
| 371 | 1.6.1.2.3 | Inspection and Final Assembly of SEP LVPS Boxes |  | 5d | 2004-03-02 | 2004-03-08 | 370 | 2004-03-02 | 2004-03-08 | 5d | 43d | 0d |
| 372 | 1.6.1.2.4 | Deliver SEP LVPS Boxes to UCB |  | 3d | 2004-03-09 | 2004-03-11 | 371 | 2004-03-09 | 2004-03-11 | 3d | 43d | 7d |
| 373 | 1.6.1.3 | **SEP Electronics Enclosure (Priority 3)** |  | 31d | 2004-02-17 | 2004-03-30 |  | 2004-02-17 | 2004-03-30 | 31d | 15d |  |
| 374 | 1.6.1.3.1 | Complete Design/Drawings for SEP Enclosure |  | 13d | 2004-02-17 | 2004-03-04 | 369 | 2004-02-17 | 2004-03-04 | 13d | 15d | 0d |
| 375 | 1.6.1.3.2 | Fabrication of SEP Enclosure |  | 10d | 2004-03-05 | 2004-03-18 | 374 | 2004-03-05 | 2004-03-18 | 10d | 58d | 0d |
| 376 | 1.6.1.3.3 | Inspection and Final Assembly of SEP Enclosure |  | 5d | 2004-03-19 | 2004-03-25 | 375 | 2004-03-19 | 2004-03-25 | 5d | 58d | 0d |
| 377 | 1.6.1.3.4 | Deliver SEP Enclosure to CIT |  | 3d | 2004-03-26 | 2004-03-30 | 376 | 2004-03-26 | 2004-03-30 | 3d | 58d | 29d |
| 378 | 1.6.1.4 | **SEP Central Bias Supply Shields (Priority 4)** |  | 20d | 2004-03-05 | 2004-04-01 |  | 2004-03-05 | 2004-04-01 | 20d | 15d |  |
| 379 | 1.6.1.4.1 | Complete Design/Drawings for Bias Supply Shields |  | 5d | 2004-03-05 | 2004-03-11 | 374 | 2004-03-05 | 2004-03-11 | 5d | 15d | 0d |
| 380 | 1.6.1.4.2 | Fabrication of Bias Supply Shields |  | 10d | 2004-03-12 | 2004-03-25 | 379 | 2004-03-12 | 2004-03-25 | 10d | 15d | 0d |
| 381 | 1.6.1.4.3 | Inspection and Delivery (to CIT) of Bias Supply Shields |  | 5d | 2004-03-26 | 2004-04-01 | 380 | 2004-03-26 | 2004-04-01 | 5d | 15d | 0d |
| 382 | 1.6.1.5 | **LET Telescope (Priority 5)** |  | 26d | 2004-03-12 | 2004-04-16 |  | 2004-03-12 | 2004-04-16 | 26d | 18d |  |
| 383 | 1.6.1.5.1 | Complete Design/Drawings for LET Telescope |  | 8d | 2004-03-12 | 2004-03-23 | 379 | 2004-03-12 | 2004-03-23 | 8d | 18d | 0d |
| 384 | 1.6.1.5.2 | Fabrication of LET Telescope |  | 10d | 2004-03-24 | 2004-04-06 | 383 | 2004-03-24 | 2004-04-06 | 10d | 31d | 0d |
| 385 | 1.6.1.5.3 | Inspection and Final Assembly of LET Telescope |  | 5d | 2004-04-07 | 2004-04-13 | 384 | 2004-04-07 | 2004-04-13 | 5d | 31d | 0d |
| 386 | 1.6.1.5.4 | Deliver LET Telescope to CIT |  | 3d | 2004-04-14 | 2004-04-16 | 385 | 2004-04-14 | 2004-04-16 | 3d | 31d | 16d |
| 387 | 1.6.1.6 | **HET Electronics Enclosure (Priority 6)** |  | 23d | 2004-03-24 | 2004-04-23 |  | 2004-03-24 | 2004-04-23 | 23d | 18d |  |
| 388 | 1.6.1.6.1 | Complete Design/Drawings for HET Enclosure |  | 8d | 2004-03-24 | 2004-04-02 | 383 | 2004-03-24 | 2004-04-02 | 8d | 18d | 0d |
| 389 | 1.6.1.6.2 | Fabrication of HET Enclosure |  | 10d | 2004-04-05 | 2004-04-16 | 388 | 2004-04-05 | 2004-04-16 | 10d | 18d | 0d |
| 390 | 1.6.1.6.3 | Inspection and Final Assembly of HET Enclosure |  | 5d | 2004-04-19 | 2004-04-23 | 389 | 2004-04-19 | 2004-04-23 | 5d | 18d | 0d |
| 391 | 1.6.1.6.4 | Deliver HET Enclosure (stays at GSFC) | milestone | 0d | 2004-04-23 | 2004-04-23 | 390 | 2004-04-23 | 2004-04-23 | 0d | 18d | 0d |

| ID | WBS | Task | Type | Duration | Start | Finish | Predecessors | Complete | Remaining | Baseline start | Baseline finish | Baseline duration | Total slack | Free slack | Constraint |
| --- | --- | --- | --- | --- | --- | --- | --- | --- | --- | --- | --- | --- | --- | --- | --- |
| 392 | 1.6.1.7 | **HET Telescope (Priority 7)** |  | 68d | 2004-01-27 A | 2004-04-30 |  | 7% | 63.54d | 2004-01-27 | 2004-04-30 | 68d | 18d |  |  |
| 393 | 1.6.1.7.1 | On Going work for HET Telescope (Complete Design/Drawings & Prep for Fab) |  | 46d | 2004-01-27 A | 2004-03-31 |  | 9% | 42d | 2004-01-27 | 2004-03-31 | 46d | 16d | 0d | start no earlier than 2004-01-27 |
| 394 | 1.6.1.7.2 | Fabrication of HET Telescope |  | 10d | 2004-04-01 | 2004-04-14 | 393 |  |  | 2004-04-01 | 2004-04-14 | 10d | 25d | 7d |  |
| 395 | 1.6.1.7.3 | Inspection and Final Assembly of HET Telescope |  | 5d | 2004-04-26 | 2004-04-30 | 394, 391 |  |  | 2004-04-26 | 2004-04-30 | 5d | 18d | 0d |  |
| 396 | 1.6.1.7.4 | Deliver HET Telescope (stays at GSFC) | milestone | 0d | 2004-04-30 | 2004-04-30 | 395 |  |  | 2004-04-30 | 2004-04-30 | 0d | 18d | 0d |  |
| 397 | 1.6.1.8 | **SIT Telescope (Priority 8)** |  | 34d | 2004-04-01 | 2004-05-18 |  |  |  | 2004-04-01 | 2004-05-18 | 34d | 16d |  |  |
| 398 | 1.6.1.8.1 | Complete Design/Drawings for SIT Telescope |  | 18d | 2004-04-01 | 2004-04-26 | 393 |  |  | 2004-04-01 | 2004-04-26 | 18d | 16d | 0d |  |
| 399 | 1.6.1.8.2 | Fabrication of SIT Telescope |  | 10d | 2004-04-27 | 2004-05-10 | 398 |  |  | 2004-04-27 | 2004-05-10 | 10d | 16d | 0d |  |
| 400 | 1.6.1.8.3 | Inspection and Final Assembly of SIT Telescope |  | 5d | 2004-05-11 | 2004-05-17 | 399 |  |  | 2004-05-11 | 2004-05-17 | 5d | 16d | 0d |  |
| 401 | 1.6.1.8.4 | Deliver SIT Telescope to UMD |  | 1d | 2004-05-18 | 2004-05-18 | 400 |  |  | 2004-05-18 | 2004-05-18 | 1d | 16d | 0d |  |
| 402 | 1.6.1.9 | **Shipping Containers for HET, SIT & SEP Central (Priority 9)** |  | 23d | 2004-04-27 | 2004-05-27 |  |  |  | 2004-04-27 | 2004-05-27 | 23d | 23d |  |  |
| 403 | 1.6.1.9.1 | Design |  | 5d | 2004-04-27 | 2004-05-03 | 398 |  |  | 2004-04-27 | 2004-05-03 | 5d | 23d | 0d |  |
| 404 | 1.6.1.9.2 | Fabrication/Machining |  | 10d | 2004-05-04 | 2004-05-17 | 403 |  |  | 2004-05-04 | 2004-05-17 | 10d | 23d | 0d |  |
| 405 | 1.6.1.9.3 | Inspection and Assembly |  | 5d | 2004-05-18 | 2004-05-24 | 404 |  |  | 2004-05-18 | 2004-05-24 | 5d | 23d | 0d |  |
| 406 | 1.6.1.9.4 | HET Container stays at GSFC | milestone | 0d | 2004-05-24 | 2004-05-24 | 405 |  |  | 2004-05-24 | 2004-05-24 | 0d | 23d | 4d |  |
| 407 | 1.6.1.9.5 | SIT Container to UMD |  | 1d | 2004-05-25 | 2004-05-25 | 405 |  |  | 2004-05-25 | 2004-05-25 | 1d | 25d | 16d |  |
| 408 | 1.6.1.9.6 | SEP Central Container to CIT |  | 3d | 2004-05-25 | 2004-05-27 | 405 |  |  | 2004-05-25 | 2004-05-27 | 3d | 40d | 31d |  |
| 409 | 1.6.1.10 | **LET Radiation Test Fixture (Priority 10)** |  | 21d | 2004-05-04 | 2004-06-02 |  |  |  | 2004-05-04 | 2004-06-02 | 21d | 24d |  |  |
| 410 | 1.6.1.10.1 | Design |  | 5d | 2004-05-04 | 2004-05-10 | 403 |  |  | 2004-05-04 | 2004-05-10 | 5d | 24d | 0d |  |
| 411 | 1.6.1.10.2 | Fabrication |  | 10d | 2004-05-11 | 2004-05-24 | 410 |  |  | 2004-05-11 | 2004-05-24 | 10d | 24d | 0d |  |
| 412 | 1.6.1.10.3 | Inspection and Assembly |  | 5d | 2004-05-25 | 2004-06-01 | 411 |  |  | 2004-05-25 | 2004-06-01 | 5d | 24d | 0d |  |
| 413 | 1.6.1.10.4 | Deliver to CIT for SEP I&T |  | 1d | 2004-06-02 | 2004-06-02 | 412 |  |  | 2004-06-02 | 2004-06-02 | 1d | 24d | 15d |  |
| 414 | 1.6.2 | **SEP Central - CIT** |  | 211d | 2003-08-01 A | 2004-06-03 |  | 31% | 144.65d | 2003-08-01 | 2004-06-03 | 211d | 26d |  |  |
| 415 | 1.6.2.1 | **Deliveries** |  | 35d | 2004-04-14 | 2004-06-03 |  |  |  | 2004-04-14 | 2004-06-03 | 35d | 26d |  |  |
| 416 | 1.6.2.1.1 | Deliver all SEP Cen FM 1 Boards to SEP I&T (stays at CIT) | milestone | 0d | 2004-05-10 | 2004-05-10 | 440 |  |  | 2004-05-10 | 2004-05-10 | 0d | 29d | 0d |  |
| 417 | 1.6.2.1.2 | Deliver all SEP Cen FM 2 Boards & FM 2 LVPS to SEP I&T (stays at CIT) | milestone | 0d | 2004-05-10 | 2004-05-10 | 440 |  |  | 2004-05-10 | 2004-05-10 | 0d | 43d | 0d |  |
| 418 | 1.6.2.1.3 | SEP Central Build 3 Software Complete | milestone | 0d | 2004-04-14 | 2004-04-14 | 442 |  |  | 2004-04-14 | 2004-04-14 | 0d | 47d | 18d |  |
| 419 | 1.6.2.1.4 | Final SEP Central Flight Software Complete | milestone | 0d | 2004-06-03 | 2004-06-03 | 443 |  |  | 2004-06-03 | 2004-06-03 | 0d | 26d | 17d |  |

| ID | WBS | Task | Type | Duration | Start | Finish | Predecessors | Complete | Remaining | Baseline start | Baseline finish | Baseline duration | Total slack | Free slack | Constraint |
| --- | --- | --- | --- | --- | --- | --- | --- | --- | --- | --- | --- | --- | --- | --- | --- |
| 420 | 1.6.2.2 | **Logic Board** |  | 30d | 2004-02-13 | 2004-03-26 |  |  |  | 2004-02-13 | 2004-03-26 | 30d | 29d |  |  |
| 421 | 1.6.2.2.1 | **Assembly** |  | 10d | 2004-02-13 | 2004-02-27 |  |  |  | 2004-02-13 | 2004-02-27 | 10d | 29d |  |  |
| 422 | 1.6.2.2.1.1 | Assemble FM 1 SEP Central Logic board |  | 10d | 2004-02-13 | 2004-02-27 |  |  |  | 2004-02-13 | 2004-02-27 | 10d | 29d | 0d | start no earlier than 2004-02-13 |
| 423 | 1.6.2.2.1.2 | Assemble FM 2 SEP Central Logic board |  | 10d | 2004-02-13 | 2004-02-27 | 422SS |  |  | 2004-02-13 | 2004-02-27 | 10d | 29d | 0d |  |
| 424 | 1.6.2.2.2 | **Test** |  | 20d | 2004-03-01 | 2004-03-26 |  |  |  | 2004-03-01 | 2004-03-26 | 20d | 29d |  |  |
| 425 | 1.6.2.2.2.1 | Test FM 1 SEP Central Logic board (initial) |  | 20d | 2004-03-01 | 2004-03-26 | 422 |  |  | 2004-03-01 | 2004-03-26 | 20d | 29d | 14d |  |
| 426 | 1.6.2.2.2.2 | Test FM 2 SEP Central Logic board (initial) |  | 20d | 2004-03-01 | 2004-03-26 | 423 |  |  | 2004-03-01 | 2004-03-26 | 20d | 29d | 14d |  |
| 427 | 1.6.2.3 | **Analog/Post-Reg Board** |  | 0d | 2004-01-27 A | 2004-01-27 A |  | 100% |  | 2004-01-27 | 2004-01-27 | 0d |  |  |  |
| 428 | 1.6.2.3.1 | FM 1 Analog/Post-Reg Board Complete Test and awaiting Conformal Coat with other SEP Central Boards | milestone | 0d | 2004-01-27 A | 2004-01-27 A |  | 100% |  | 2004-01-27 | 2004-01-27 | 0d |  |  | start no earlier than 2004-01-27 |
| 429 | 1.6.2.3.2 | FM 2 Analog/Post-Reg Board Complete Test and awaiting Conformal Coat with other SEP Central Boards | milestone | 0d | 2004-01-27 A | 2004-01-27 A |  | 100% |  | 2004-01-27 | 2004-01-27 | 0d |  |  | start no earlier than 2004-01-27 |
| 430 | 1.6.2.4 | **SEP Solid State Detector Bias Supply Board** |  | 62d | 2004-01-20 A | 2004-04-15 |  | 18% | 50.84d | 2004-01-20 | 2004-04-15 | 62d | 15d |  |  |
| 431 | 1.6.2.4.1 | **Assembly & Initial Test** |  | 40d | 2004-01-20 A | 2004-03-16 |  | 23% | 31d | 2004-01-20 | 2004-03-16 | 40d | 27d |  |  |
| 432 | 1.6.2.4.1.1 | Assemble and Initial Test FM 1 SSD Bias Supply Board |  | 40d | 2004-01-20 A | 2004-03-16 |  | 23% | 31d | 2004-01-20 | 2004-03-16 | 40d | 27d | 0d | start no earlier than 2004-01-20 |
| 433 | 1.6.2.4.1.2 | Assemble and Initial Test FM 2 SSD Bias Supply Board |  | 40d | 2004-01-20 A | 2004-03-16 | 432SS | 23% | 31d | 2004-01-20 | 2004-03-16 | 40d | 27d | 12d |  |
| 434 | 1.6.2.4.2 | **Final Test** |  | 10d | 2004-04-02 | 2004-04-15 |  |  |  | 2004-04-02 | 2004-04-15 | 10d | 15d |  |  |
| 435 | 1.6.2.4.2.1 | Final Test FM 1 SSD Bias Supply Board |  | 10d | 2004-04-02 | 2004-04-15 | 432, 381 |  |  | 2004-04-02 | 2004-04-15 | 10d | 15d | 0d |  |
| 436 | 1.6.2.4.2.2 | Final Test FM 2 SSD Bias Supply Board |  | 10d | 2004-04-02 | 2004-04-15 | 433, 381 |  |  | 2004-04-02 | 2004-04-15 | 10d | 15d | 0d |  |
| 437 | 1.6.2.5 | **Conformal Coat, Mass Properties and Bake Out (SEP Central, LET, SEP LVPS)** |  | 17d | 2004-04-16 | 2004-05-10 |  |  |  | 2004-04-16 | 2004-05-10 | 17d | 15d |  |  |
| 438 | 1.6.2.5.1 | Stake/Conformal Coat All SEP Central and LET Boards |  | 10d | 2004-04-16 | 2004-04-29 | 425, 426, 428, 429, 435, 436, 505, 506 |  |  | 2004-04-16 | 2004-04-29 | 10d | 15d | 0d |  |
| 439 | 1.6.2.5.2 | Mass Properties/Photo All SEP Central and LET Boards |  | 4d | 2004-04-30 | 2004-05-05 | 438 |  |  | 2004-04-30 | 2004-05-05 | 4d | 15d | 0d |  |
| 440 | 1.6.2.5.3 | Bake Out All SEP Central/LET Boards and SEP LVPS (FM 1 & 2) |  | 3d | 2004-05-06 | 2004-05-10 | 439, 74, 68 |  |  | 2004-05-06 | 2004-05-10 | 3d | 15d | 0d |  |
| 441 | 1.6.2.6 | **Flight Software** |  | 211d | 2003-08-01 A | 2004-06-03 |  | 49% | 107d | 2003-08-01 | 2004-06-03 | 211d | 26d |  |  |
| 442 | 1.6.2.6.1 | SEP Central Build 3 |  | 176d | 2003-08-01 A | 2004-04-14 |  | 59% | 72d | 2003-08-01 | 2004-04-14 | 176d | 26d | 0d | start no earlier than 2003-08-01 |
| 443 | 1.6.2.6.2 | Final Flight S/W Build |  | 35d | 2004-04-15 | 2004-06-03 | 442 |  |  | 2004-04-15 | 2004-06-03 | 35d | 26d | 0d |  |

| ID | WBS | Task | Duration | Start | Finish | Predecessors | Complete | Remaining | Baseline start | Baseline finish | Baseline duration | Total slack | Free slack | Constraint |
| --- | --- | --- | --- | --- | --- | --- | --- | --- | --- | --- | --- | --- | --- | --- |
| 444 | 1.6.3 | **HET - GSFC** | 119d | 2004-01-06 A | 2004-06-23 |  | 19% | 96.4d | 2004-01-06 | 2004-06-23 | 119d | 363d |  |  |
| 445 | 1.6.3.1 | **Deliveries** | 38d | 2004-04-30 | 2004-06-23 |  |  |  | 2004-04-30 | 2004-06-23 | 38d | 18d |  |  |
| 446 | 1.6.3.1.1 | Deliver HET FM 1 (to CIT for SEP Suite I&T) | 2d | 2004-06-01 | 2004-06-02 | 487, 406 |  |  | 2004-06-01 | 2004-06-02 | 2d | 19d | 0d |  |
| 447 | 1.6.3.1.2 | Deliver HET FM 2 (to CIT for SEP Suite I&T) | 2d | 2004-06-22 | 2004-06-23 | 490, 406 |  |  | 2004-06-22 | 2004-06-23 | 2d | 18d | 0d |  |
| 448 | 1.6.3.1.3 | Deliver Final HET Flight Software to SEP I&T | 2d | 2004-04-30 | 2004-05-03 | 483 |  |  | 2004-04-30 | 2004-05-03 | 2d | 40d | 21d |  |
| 449 | 1.6.3.2 | **Detectors** | 60d | 2004-01-06 A | 2004-03-31 |  | 34% | 39.75d | 2004-01-06 | 2004-03-31 | 60d | 422d |  |  |
| 450 | 1.6.3.2.1 | Receive & Inspect HET Flight Detectors | 40d | 2004-01-06 A | 2004-03-03 |  | 45% | 22d | 2004-01-06 | 2004-03-03 | 40d | 442d | 0d | start no earlier than 2004-01-06 |
| 451 | 1.6.3.2.2 | **Detector Testing** | 60d | 2004-01-06 A | 2004-03-31 |  | 30% | 42d | 2004-01-06 | 2004-03-31 | 60d | 422d |  |  |
| 452 | 1.6.3.2.2.1 | Capacitance, Current, Depletion, Alpha Resolution Testing | 60d | 2004-01-06 A | 2004-03-31 | 450SS | 30% | 42d | 2004-01-06 | 2004-03-31 | 60d | 422d | 0d |  |
| 453 | 1.6.3.2.2.2 | Life Test HET Detectors | 60d | 2004-01-06 A | 2004-03-31 | 452SS | 30% | 42d | 2004-01-06 | 2004-03-31 | 60d | 40d | 22d |  |
| 454 | 1.6.3.3 | **Electronics Board** | 80d | 2004-01-22 A | 2004-05-13 |  | 9% | 73.17d | 2004-01-22 | 2004-05-13 | 80d | 24d |  |  |
| 455 | 1.6.3.3.1 | **Assembly** | 36d | 2004-01-22 A | 2004-03-12 |  | 50% | 18d | 2004-01-22 | 2004-03-12 | 36d | 30d |  |  |
| 456 | 1.6.3.3.1.1 | Install Socket on HET Electronics FM 1 Board for ETU ACTEL | 1d | 2004-01-22 A | 2004-01-22 A |  | 100% |  | 2004-01-22 | 2004-01-22 | 1d |  |  | start no earlier than 2004-01-22 |
| 457 | 1.6.3.3.1.2 | Complete Population of HET Electronics FM 1 Board (ETU ACTEL) | 1d | 2004-01-23 A | 2004-01-23 A | 456 | 100% |  | 2004-01-23 | 2004-01-23 | 1d |  |  |  |
| 458 | 1.6.3.3.1.3 | Complete Population of HET Electronics FM 2 Board (Flight ACTEL) | 2d | 2004-03-11 | 2004-03-12 | 457, 464, 499 |  |  | 2004-03-11 | 2004-03-12 | 2d | 30d | 6d |  |
| 459 | 1.6.3.3.2 | **Test** | 78d | 2004-01-26 A | 2004-05-13 |  | 6% | 73d | 2004-01-26 | 2004-05-13 | 78d | 24d |  |  |
| 460 | 1.6.3.3.2.1 | **FM 1** | 40d | 2004-01-26 A | 2004-03-22 |  | 13% | 35d | 2004-01-26 | 2004-03-22 | 40d | 24d |  |  |
| 461 | 1.6.3.3.2.1.1 | Test HET FM 1 Electronics Board w/ETU ACTEL | 20d | 2004-01-26 A | 2004-02-23 | 457 | 25% | 15d | 2004-01-26 | 2004-02-23 | 20d | 24d | 0d |  |
| 462 | 1.6.3.3.2.1.2 | Remove ETU ACTEL and socket from HET FM 1 Electronics Board | 1d | 2004-02-24 | 2004-02-24 | 461 |  |  | 2004-02-24 | 2004-02-24 | 1d | 24d | 0d |  |
| 463 | 1.6.3.3.2.1.3 | Install Flight ACTEL on HET FM 1 Electronics Board | 1d | 2004-02-25 | 2004-02-25 | 462 |  |  | 2004-02-25 | 2004-02-25 | 1d | 24d | 0d |  |
| 464 | 1.6.3.3.2.1.4 | Retest HET FM 1 Electronics Board w/Flight ACTEL | 10d | 2004-02-26 | 2004-03-10 | 463 |  |  | 2004-02-26 | 2004-03-10 | 10d | 24d | 0d |  |
| 465 | 1.6.3.3.2.1.5 | Conformal Coat HET FM 1 Electronics Board | 2d | 2004-03-11 | 2004-03-12 | 464 |  |  | 2004-03-11 | 2004-03-12 | 2d | 24d | 0d |  |
| 466 | 1.6.3.3.2.1.6 | Retest Conformal Coated HET FM 1 Electronics Board | 2d | 2004-03-15 | 2004-03-16 | 465 |  |  | 2004-03-15 | 2004-03-16 | 2d | 24d | 0d |  |
| 467 | 1.6.3.3.2.1.7 | Bakeout HET FM 1 Electronics Board | 2d | 2004-03-17 | 2004-03-18 | 466 |  |  | 2004-03-17 | 2004-03-18 | 2d | 24d | 0d |  |
| 468 | 1.6.3.3.2.1.8 | Retest Bakedout HET FM 1 Electronics Board | 2d | 2004-03-19 | 2004-03-22 | 467 |  |  | 2004-03-19 | 2004-03-22 | 2d | 24d | 0d |  |

| ID | WBS | Task | Type | Duration | Start | Finish | Predecessors | Complete | Remaining | Baseline start | Baseline finish | Baseline duration | Total slack | Free slack | Constraint |
| --- | --- | --- | --- | --- | --- | --- | --- | --- | --- | --- | --- | --- | --- | --- | --- |
| 469 | 1.6.3.3.2.2 | **FM 2** |  | 38d | 2004-03-23 | 2004-05-13 |  |  |  | 2004-03-23 | 2004-05-13 | 38d | 24d |  |  |
| 470 | 1.6.3.3.2.2.1 | Test HET FM 2 Electronics Board |  | 30d | 2004-03-23 | 2004-05-03 | 458, 461, 468 |  |  | 2004-03-23 | 2004-05-03 | 30d | 24d | 0d |  |
| 471 | 1.6.3.3.2.2.2 | Conformal Coat HET FM 2 Electronics Board |  | 2d | 2004-05-04 | 2004-05-05 | 470 |  |  | 2004-05-04 | 2004-05-05 | 2d | 24d | 0d |  |
| 472 | 1.6.3.3.2.2.3 | Retest Conformal Coated HET FM 2 Electronics Board |  | 2d | 2004-05-06 | 2004-05-07 | 471, 466 |  |  | 2004-05-06 | 2004-05-07 | 2d | 24d | 0d |  |
| 473 | 1.6.3.3.2.2.4 | Bakeout HET FM 2 Electronics Board |  | 2d | 2004-05-10 | 2004-05-11 | 472 |  |  | 2004-05-10 | 2004-05-11 | 2d | 24d | 0d |  |
| 474 | 1.6.3.3.2.2.5 | Retest Bakedout HET FM 2 Electronics Board |  | 2d | 2004-05-12 | 2004-05-13 | 473, 468 |  |  | 2004-05-12 | 2004-05-13 | 2d | 24d | 0d |  |
| 475 | 1.6.3.4 | **Flight Software** |  | 70d | 2004-01-22 A | 2004-04-29 |  | 10% | 63d | 2004-01-22 | 2004-04-29 | 70d | 19d |  |  |
| 476 | 1.6.3.4.1 | **Design** |  | 10d | 2004-01-22 A | 2004-02-04 |  | 70% | 3d | 2004-01-22 | 2004-02-04 | 10d | 19d |  |  |
| 477 | 1.6.3.4.1.1 | Complete Definition of HET PH Event Processing |  | 10d | 2004-01-22 A | 2004-02-04 |  | 70% | 3d | 2004-01-22 | 2004-02-04 | 10d | 19d | 0d | start no earlier than 2004-01-22 |
| 478 | 1.6.3.4.2 | **Coding** |  | 20d | 2004-02-05 | 2004-03-04 |  |  |  | 2004-02-05 | 2004-03-04 | 20d | 19d |  |  |
| 479 | 1.6.3.4.2.1 | Code HET PH Event Processing Update for Flight |  | 10d | 2004-02-05 | 2004-02-19 | 477 |  |  | 2004-02-05 | 2004-02-19 | 10d | 19d | 0d |  |
| 480 | 1.6.3.4.2.2 | Code HET Telemetry Formatting Update for Flight |  | 10d | 2004-02-20 | 2004-03-04 | 479 |  |  | 2004-02-20 | 2004-03-04 | 10d | 19d | 0d |  |
| 481 | 1.6.3.4.3 | **Test** |  | 40d | 2004-03-05 | 2004-04-29 |  |  |  | 2004-03-05 | 2004-04-29 | 40d | 19d |  |  |
| 482 | 1.6.3.4.3.1 | Test Integrated HET S/W with Simulated Data |  | 15d | 2004-03-05 | 2004-03-25 | 480 |  |  | 2004-03-05 | 2004-03-25 | 15d | 19d | 0d |  |
| 483 | 1.6.3.4.3.2 | Verify HET On-Board Software |  | 25d | 2004-03-26 | 2004-04-29 | 482 |  |  | 2004-03-26 | 2004-04-29 | 25d | 19d | 0d |  |
| 484 | 1.6.3.5 | **Integration & Test** |  | 35d | 2004-05-03 | 2004-06-21 |  |  |  | 2004-05-03 | 2004-06-21 | 35d | 18d |  |  |
| 485 | 1.6.3.5.1 | **FM 1** |  | 20d | 2004-05-03 | 2004-05-28 |  |  |  | 2004-05-03 | 2004-05-28 | 20d | 18d |  |  |
| 486 | 1.6.3.5.1.1 | Integrate HET FM 1 Electronics Telescope (Ahead) |  | 5d | 2004-05-03 | 2004-05-07 | 468, 453, 483, 396 |  |  | 2004-05-03 | 2004-05-07 | 5d | 18d | 0d |  |
| 487 | 1.6.3.5.1.2 | Test HET FM 1 Telescope (Ahead) |  | 15d | 2004-05-10 | 2004-05-28 | 486 |  |  | 2004-05-10 | 2004-05-28 | 15d | 18d | 0d |  |
| 488 | 1.6.3.5.2 | **FM 2** |  | 26d | 2004-05-14 | 2004-06-21 |  |  |  | 2004-05-14 | 2004-06-21 | 26d | 18d |  |  |
| 489 | 1.6.3.5.2.1 | Integrate HET FM 2 Electronics Telescope (Behind) |  | 5d | 2004-05-14 | 2004-05-20 | 474, 486, 453, 483, 396 |  |  | 2004-05-14 | 2004-05-20 | 5d | 24d | 6d |  |
| 490 | 1.6.3.5.2.2 | Test HET FM 2 Telescope (Behind) |  | 15d | 2004-06-01 | 2004-06-21 | 487, 489 |  |  | 2004-06-01 | 2004-06-21 | 15d | 18d | 0d |  |
| 491 | 1.6.4 | **LET - CIT** |  | 228d | 2003-07-14 A | 2004-06-08 |  | 66% | 77.04d | 2003-07-14 | 2004-06-08 | 228d | 29d |  |  |
| 492 | 1.6.4.1 | **Deliveries** |  | 24d | 2004-05-04 | 2004-06-08 |  |  |  | 2004-05-04 | 2004-06-08 | 24d | 29d |  |  |
| 493 | 1.6.4.1.1 | Deliver LET FM 1 (stays at CIT for SEP I&T) | milestone | 0d | 2004-06-08 | 2004-06-08 | 511 |  |  | 2004-06-08 | 2004-06-08 | 0d | 15d | 0d |  |
| 494 | 1.6.4.1.2 | Deliver LET FM 2 (stays at CIT for SEP I&T) | milestone | 0d | 2004-06-08 | 2004-06-08 | 513 |  |  | 2004-06-08 | 2004-06-08 | 0d | 29d | 0d |  |
| 495 | 1.6.4.1.3 | Deliver LET Flight Software Build 3 | milestone | 0d | 2004-05-04 | 2004-05-04 | 508 |  |  | 2004-05-04 | 2004-05-04 | 0d | 39d | 24d |  |

| ID | WBS | Task | Duration | Start | Finish | Predecessors | Complete | Remaining | Baseline start | Baseline finish | Baseline duration | Total slack | Free slack | Constraint |
| --- | --- | --- | --- | --- | --- | --- | --- | --- | --- | --- | --- | --- | --- | --- |
| 496 | 1.6.4.2 | **Detectors** | 167d | 2003-07-14 A | 2004-03-12 |  | 83% | 29d | 2003-07-14 | 2004-03-12 | 167d | 56d |  |  |
| 497 | 1.6.4.2.1 | Complete LET Flight Detector Testing | 167d | 2003-07-14 A | 2004-03-12 |  | 83% | 29d | 2003-07-14 | 2004-03-12 | 167d | 56d | 41d | start no earlier than 2003-07-14 |
| 498 | 1.6.4.3 | **Hybrids** | 144d | 2003-08-01 A | 2004-03-01 |  | 86% | 20d | 2003-08-01 | 2004-03-01 | 144d | 27d |  |  |
| 499 | 1.6.4.3.1 | Complete Test of Flight Hybrids (LET and to GSFC for HET FM 2) | 144d | 2003-08-01 A | 2004-03-01 |  | 86% | 20d | 2003-08-01 | 2004-03-01 | 144d | 27d | 0d | start no earlier than 2003-08-01 |
| 500 | 1.6.4.4 | **Detector/Misc Board** | 21d | 2004-03-02 | 2004-03-30 |  |  |  | 2004-03-02 | 2004-03-30 | 21d | 27d |  |  |
| 501 | 1.6.4.4.1 | **Assembly** | 10d | 2004-03-02 | 2004-03-15 |  |  |  | 2004-03-02 | 2004-03-15 | 10d | 27d |  |  |
| 502 | 1.6.4.4.1.1 | Assemble LET FM 1 Detector Board | 10d | 2004-03-02 | 2004-03-15 | 499 |  |  | 2004-03-02 | 2004-03-15 | 10d | 27d | 0d |  |
| 503 | 1.6.4.4.1.2 | Assemble LET FM 2 Detector Board | 10d | 2004-03-02 | 2004-03-15 | 499 |  |  | 2004-03-02 | 2004-03-15 | 10d | 27d | 0d |  |
| 504 | 1.6.4.4.2 | **Test** | 11d | 2004-03-16 | 2004-03-30 |  |  |  | 2004-03-16 | 2004-03-30 | 11d | 27d |  |  |
| 505 | 1.6.4.4.2.1 | Test LET FM 1 Detector Board | 11d | 2004-03-16 | 2004-03-30 | 502 |  |  | 2004-03-16 | 2004-03-30 | 11d | 27d | 12d |  |
| 506 | 1.6.4.4.2.2 | Test LET FM 2 Detector Board | 11d | 2004-03-16 | 2004-03-30 | 503 |  |  | 2004-03-16 | 2004-03-30 | 11d | 27d | 12d |  |
| 507 | 1.6.4.5 | **Flight Software** | 190d | 2003-08-01 A | 2004-05-04 |  | 65% | 66d | 2003-08-01 | 2004-05-04 | 190d | 39d |  |  |
| 508 | 1.6.4.5.1 | Let Flight Software Build 3 | 190d | 2003-08-01 A | 2004-05-04 |  | 65% | 66d | 2003-08-01 | 2004-05-04 | 190d | 39d | 0d | start no earlier than 2003-08-01 |
| 509 | 1.6.4.6 | **Integration & Test** | 20d | 2004-05-11 | 2004-06-08 |  |  |  | 2004-05-11 | 2004-06-08 | 20d | 15d |  |  |
| 510 | 1.6.4.6.1 | **FM 1** | 20d | 2004-05-11 | 2004-06-08 |  |  |  | 2004-05-11 | 2004-06-08 | 20d | 15d |  |  |
| 511 | 1.6.4.6.1.1 | Integrate LET FM 1 Housing With Detectors | 20d | 2004-05-11 | 2004-06-08 | 497, 440, 386 |  |  | 2004-05-11 | 2004-06-08 | 20d | 15d | 0d |  |
| 512 | 1.6.4.6.2 | **FM 2** | 20d | 2004-05-11 | 2004-06-08 |  |  |  | 2004-05-11 | 2004-06-08 | 20d | 29d |  |  |
| 513 | 1.6.4.6.2.1 | Integrate LET FM 2 Housing With Detectors | 20d | 2004-05-11 | 2004-06-08 | 497, 440, 386 |  |  | 2004-05-11 | 2004-06-08 | 20d | 29d | 0d |  |
| 514 | 1.6.5 | **SEPT - Kiel/ESTEC** | 245d | 2003-08-08 A | 2004-07-28 |  | 71% | 71.46d | 2003-08-08 | 2004-07-28 | 245d | 338d |  |  |
| 515 | 1.6.5.1 | **Deliveries** | 99d | 2004-03-11 | 2004-07-28 |  |  |  | 2004-03-11 | 2004-07-28 | 99d | 49d |  |  |
| 516 | 1.6.5.1.1 | Deliver SEPT-NS FM 1 to CIT for SEP I&T and Suite EMC | 5d | 2004-03-11 | 2004-03-17 | 555, 556 |  |  | 2004-03-11 | 2004-03-17 | 5d | 71d | 0d |  |
| 517 | 1.6.5.1.2 | Deliver SEPT-E FM 1 to CIT for SEP I&T and Suite EMC | 5d | 2004-03-11 | 2004-03-17 | 563, 562 |  |  | 2004-03-11 | 2004-03-17 | 5d | 71d | 0d |  |
| 518 | 1.6.5.1.3 | Final Delivery of SEPT FM 1 to APL (after Therm Bal @ GSFC) | 2d | 2004-07-27 | 2004-07-28 | 557, 564 |  |  | 2004-07-27 | 2004-07-28 | 2d | 49d | 33d |  |
| 519 | 1.6.5.1.4 | Deliver SEPT-NS FM 2 to CIT for SEP I&T and Suite EMC | 5d | 2004-03-22 | 2004-03-26 | 570, 571 |  |  | 2004-03-22 | 2004-03-26 | 5d | 78d | 0d |  |
| 520 | 1.6.5.1.5 | Deliver SEPT-E FM 2 to CIT for SEP I&T and Suite EMC | 5d | 2004-03-22 | 2004-03-26 | 576, 577 |  |  | 2004-03-22 | 2004-03-26 | 5d | 78d | 0d |  |

| ID | WBS | Task | Duration | Start | Finish | Predecessors | Complete | Remaining | Baseline start | Baseline finish | Baseline duration | Total slack | Free slack | Constraint |
| --- | --- | --- | --- | --- | --- | --- | --- | --- | --- | --- | --- | --- | --- | --- |
| 521 | 1.6.5.2 | **Mechanical Assembly** | 46d | 2003-12-22 A | 2004-02-27 |  | 77% | 10.66d | 2003-12-22 | 2004-02-27 | 46d | 445d |  |  |
| 522 | 1.6.5.2.1 | **FM 1** | 13d | 2003-12-22 A | 2004-01-09 A |  | 100% |  | 2003-12-22 | 2004-01-09 | 13d |  |  |  |
| 523 | 1.6.5.2.1.1 | Assemble SEPT-NS FM 1 Sensor and E-Box Housing | 13d | 2003-12-22 A | 2004-01-09 A |  | 100% |  | 2003-12-22 | 2004-01-09 | 13d |  |  | start no earlier than 2003-12-22 |
| 524 | 1.6.5.2.1.2 | Assemble SEPT-E FM 1 Sensor and E-Box Housing | 13d | 2003-12-22 A | 2004-01-09 A |  | 100% |  | 2003-12-22 | 2004-01-09 | 13d |  |  | start no earlier than 2003-12-22 |
| 525 | 1.6.5.2.2 | **FM 2** | 14d | 2003-12-29 A | 2004-01-16 A |  | 100% |  | 2003-12-29 | 2004-01-16 | 14d |  |  |  |
| 526 | 1.6.5.2.2.1 | Assemble SEPT-NS FM 2 Sensor and E-Box Housing | 14d | 2003-12-29 A | 2004-01-16 A | 523SS+4d | 100% |  | 2003-12-29 | 2004-01-16 | 14d |  |  |  |
| 527 | 1.6.5.2.2.2 | Assemble SEPT-E FM 2 Sensor and E-Box Housing | 14d | 2003-12-29 A | 2004-01-16 A | 524SS+4d | 100% |  | 2003-12-29 | 2004-01-16 | 14d |  |  |  |
| 528 | 1.6.5.2.3 | **Spare** | 28d | 2004-01-20 A | 2004-02-27 |  | 32% | 19d | 2004-01-20 | 2004-02-27 | 28d | 445d |  |  |
| 529 | 1.6.5.2.3.1 | Assemble SEPT Spare Sensor and E-Box Housing | 28d | 2004-01-20 A | 2004-02-27 | 526, 527 | 32% | 19d | 2004-01-20 | 2004-02-27 | 28d | 445d |  |  |
| 530 | 1.6.5.3 | **Electronics** | 198d | 2003-08-08 A | 2004-05-21 |  | 84% | 32.06d | 2003-08-08 | 2004-05-21 | 198d | 385d |  |  |
| 531 | 1.6.5.3.1 | **Assembly** | 172d | 2003-08-08 A | 2004-04-15 |  | 86% | 24.64d | 2003-08-08 | 2004-04-15 | 172d | 396d |  |  |
| 532 | 1.6.5.3.1.1 | **FM 2** | 106d | 2003-08-08 A | 2004-01-12 A |  | 100% |  | 2003-08-08 | 2004-01-12 | 106d |  |  |  |
| 533 | 1.6.5.3.1.1.1 | Assemble SEPT-NS FM 2 Electronics | 106d | 2003-08-08 A | 2004-01-12 A |  | 100% |  | 2003-08-08 | 2004-01-12 | 106d |  |  | start no earlier than 2003-08-08 |
| 534 | 1.6.5.3.1.1.2 | Assemble SEPT-E FM 2 Electronics | 92d | 2003-08-08 A | 2003-12-19 A |  | 100% |  | 2003-08-08 | 2003-12-19 | 92d |  |  | start no earlier than 2003-08-08 |
| 535 | 1.6.5.3.1.2 | **Spare** | 172d | 2003-08-08 A | 2004-04-15 |  | 69% | 53d | 2003-08-08 | 2004-04-15 | 172d | 396d |  |  |
| 536 | 1.6.5.3.1.2.1 | Assemble SEPT FS Electronics | 172d | 2003-08-08 A | 2004-04-15 | 533SS | 69% | 53d | 2003-08-08 | 2004-04-15 | 172d | 396d | 6d |  |
| 537 | 1.6.5.3.2 | **Test** | 113d | 2003-12-11 A | 2004-05-21 |  | 70% | 33.9d | 2003-12-11 | 2004-05-21 | 113d | 385d |  |  |
| 538 | 1.6.5.3.2.1 | **FM 2** | 34d | 2003-12-11 A | 2004-01-30 A |  | 100% |  | 2003-12-11 | 2004-01-30 | 34d |  |  |  |
| 539 | 1.6.5.3.2.1.1 | SEPT-NS FM 2 Electronics Test | 4d | 2004-01-13 A | 2004-01-16 A | 533 | 100% |  | 2004-01-13 | 2004-01-16 | 4d |  |  |  |
| 540 | 1.6.5.3.2.1.2 | SEPT-E FM 2 Electronics Test | 4d | 2003-12-11 A | 2003-12-16 A | 534FS-7d | 100% |  | 2003-12-11 | 2003-12-16 | 4d |  |  |  |
| 541 | 1.6.5.3.2.1.3 | Coat SEPT-NS FM 2 Electronics Board | 4d | 2004-01-20 A | 2004-01-23 A | 539 | 100% |  | 2004-01-20 | 2004-01-23 | 4d |  |  |  |
| 542 | 1.6.5.3.2.1.4 | Coat SEPT-E FM 2 Electronics Board | 5d | 2003-12-17 A | 2003-12-23 A | 540 | 100% |  | 2003-12-17 | 2003-12-23 | 5d |  |  |  |
| 543 | 1.6.5.3.2.1.5 | SEPT-NS FM 2 Mechanical Integration | 5d | 2004-01-26 A | 2004-01-30 A | 541 | 100% |  | 2004-01-26 | 2004-01-30 | 5d |  |  |  |
| 544 | 1.6.5.3.2.1.6 | SEPT-E FM 2 Mechanical Integration | 13d | 2003-12-24 A | 2004-01-13 A | 542 | 100% |  | 2003-12-24 | 2004-01-13 | 13d |  |  |  |

| ID | WBS | Task | Duration | Start | Finish | Predecessors | Complete | Remaining | Baseline start | Baseline finish | Baseline duration | Total slack | Free slack | Constraint | Calendar |
| --- | --- | --- | --- | --- | --- | --- | --- | --- | --- | --- | --- | --- | --- | --- | --- |
| 545 | 1.6.5.3.2.2 | **Spare** | 20d | 2004-04-26 | 2004-05-21 |  |  |  | 2004-04-26 | 2004-05-21 | 20d | 385d |  |  |  |
| 546 | 1.6.5.3.2.2.1 | SEPT Flight Spare Electronics Test | 5d | 2004-04-26 | 2004-04-30 | 536 |  |  | 2004-04-26 | 2004-04-30 | 5d | 390d | 5d | start no earlier than 2004-04-26 |  |
| 547 | 1.6.5.3.2.2.2 | Coat SEPT FS Electronics Board | 5d | 2004-05-10 | 2004-05-14 | 546 |  |  | 2004-05-10 | 2004-05-14 | 5d | 385d | 0d | start no earlier than 2004-05-10 |  |
| 548 | 1.6.5.3.2.2.3 | SEPT FS Mechanical Integration | 5d | 2004-05-17 | 2004-05-21 | 547 |  |  | 2004-05-17 | 2004-05-21 | 5d | 385d |  |  |  |
| 549 | 1.6.5.4 | **Integration & Test** | 138d | 2004-01-12 A | 2004-07-26 |  | 35% | 89.03d | 2004-01-12 | 2004-07-26 | 138d | 49d |  |  |  |
| 550 | 1.6.5.4.1 | **FM 1** | 138d | 2004-01-12 A | 2004-07-26 |  | 29% | 98.57d | 2004-01-12 | 2004-07-26 | 138d | 49d |  |  |  |
| 551 | 1.6.5.4.1.1 | **SEPT-NS** | 129d | 2004-01-26 A | 2004-07-26 |  | 29% | 92.14d | 2004-01-26 | 2004-07-26 | 129d | 49d |  |  |  |
| 552 | 1.6.5.4.1.1.1 | SEPT-NS FM 1 Integration & Test | 5d | 2004-01-26 A | 2004-01-30 A | 523 | 100% |  | 2004-01-26 | 2004-01-30 | 5d |  |  | start no earlier than 2004-01-26 |  |
| 553 | 1.6.5.4.1.1.2 | Muon and Radioactive Source Test | 5d | 2004-02-02 A | 2004-02-06 A | 552 | 100% |  | 2004-02-02 | 2004-02-06 | 5d |  |  |  |  |
| 554 | 1.6.5.4.1.1.3 | SEPT-NS FM 1 Vibration | 4d | 2004-02-17 | 2004-02-20 | 553 |  |  | 2004-02-17 | 2004-02-20 | 4d | 69d | 0d | start no earlier than 2004-02-17 |  |
| 555 | 1.6.5.4.1.1.4 | SEPT-NS FM 1 Thermal Vac | 9d | 2004-02-25 | 2004-03-08 | 554FS+2d |  |  | 2004-02-25 | 2004-03-08 | 9d | 71d | 0d |  |  |
| 556 | 1.6.5.4.1.1.5 | SEPT-NS FM 1 Bake Out | 2d | 2004-03-09 | 2004-03-10 | 555 |  |  | 2004-03-09 | 2004-03-10 | 2d | 71d | 0d |  |  |
| 557 | 1.6.5.4.1.1.6 | SEPT-NS FM 1 Thermal Balance (at GSFC after Suite EMC) | 10d | 2004-07-13 | 2004-07-26 | 19 |  |  | 2004-07-13 | 2004-07-26 | 10d | 49d | 0d |  |  |
| 558 | 1.6.5.4.1.2 | **SEPT-E** | 138d | 2004-01-12 A | 2004-07-26 |  | 29% | 98.57d | 2004-01-12 | 2004-07-26 | 138d | 49d |  |  |  |
| 559 | 1.6.5.4.1.2.1 | SEPT-E FM 1 Integration & Test | 5d | 2004-01-12 A | 2004-01-16 A | 524 | 100% |  | 2004-01-12 | 2004-01-16 | 5d |  |  |  |  |
| 560 | 1.6.5.4.1.2.2 | Muon and Radioactive Source Test | 5d | 2004-01-29 A | 2004-02-04 A | 559 | 100% |  | 2004-01-29 | 2004-02-04 | 5d |  |  | start no earlier than 2004-01-29 |  |
| 561 | 1.6.5.4.1.2.3 | SEPT-E FM 1 Vibration | 4d | 2004-02-21 | 2004-02-24 | 554, 560 |  |  | 2004-02-21 | 2004-02-24 | 4d | 73d | 0d |  | SEPT Test Calendar |
| 562 | 1.6.5.4.1.2.4 | SEPT-E FM 1 Thermal Vac | 9d | 2004-02-25 | 2004-03-08 | 561, 555SS |  |  | 2004-02-25 | 2004-03-08 | 9d | 71d | 0d |  |  |
| 563 | 1.6.5.4.1.2.5 | SEPT-E FM 1 Bake Out | 2d | 2004-03-09 | 2004-03-10 | 562 |  |  | 2004-03-09 | 2004-03-10 | 2d | 71d | 0d |  |  |
| 564 | 1.6.5.4.1.2.6 | SEPT-E FM 1 Thermal Balance (at GSFC after Suite EMC) | 10d | 2004-07-13 | 2004-07-26 | 19 |  |  | 2004-07-13 | 2004-07-26 | 10d | 49d | 0d |  |  |
| 565 | 1.6.5.4.2 | **FM 2** | 48d | 2004-01-12 A | 2004-03-19 |  | 44% | 26.67d | 2004-01-12 | 2004-03-19 | 48d | 78d |  |  |  |
| 566 | 1.6.5.4.2.1 | **SEPT-NS** | 43d | 2004-01-20 A | 2004-03-19 |  | 48% | 22.24d | 2004-01-20 | 2004-03-19 | 43d | 78d |  |  |  |
| 567 | 1.6.5.4.2.1.1 | SEPT-NS FM 2 Integration & Test | 8d | 2004-01-20 A | 2004-01-29 A | 526 | 100% |  | 2004-01-20 | 2004-01-29 | 8d |  |  |  |  |
| 568 | 1.6.5.4.2.1.2 | Muon and Radioactive Source Test | 6d | 2004-01-30 A | 2004-02-06 A | 567 | 100% |  | 2004-01-30 | 2004-02-06 | 6d |  |  |  |  |
| 569 | 1.6.5.4.2.1.3 | SEPT-NS FM 2 Vibration | 4d | 2004-02-17 | 2004-02-20 | 568, 554SS |  |  | 2004-02-17 | 2004-02-20 | 4d | 87d | 0d |  |  |
| 570 | 1.6.5.4.2.1.4 | SEPT-NS FM 2 Thermal Vac | 9d | 2004-03-09 | 2004-03-17 | 569, 555 |  |  | 2004-03-09 | 2004-03-17 | 9d | 78d | 0d |  | SEPT Test Calendar |
| 571 | 1.6.5.4.2.1.5 | SEPT-NS FM 2 Bake Out | 2d | 2004-03-18 | 2004-03-19 | 570 |  |  | 2004-03-18 | 2004-03-19 | 2d | 78d | 0d |  |  |

| ID | WBS | Task | Duration | Start | Finish | Predecessors | Complete | Remaining | Baseline start | Baseline finish | Baseline duration | Total slack | Free slack | Constraint | Calendar |
| --- | --- | --- | --- | --- | --- | --- | --- | --- | --- | --- | --- | --- | --- | --- | --- |
| 572 | 1.6.5.4.2.2 | **SEPT-E** | 48d | 2004-01-12 A | 2004-03-19 |  | 40% | 28.8d | 2004-01-12 | 2004-03-19 | 48d | 78d |  |  |  |
| 573 | 1.6.5.4.2.2.1 | SEPT-E FM 2 Integration & Test | 5d | 2004-01-12 A | 2004-01-16 A | 559SS | 100% |  | 2004-01-12 | 2004-01-16 | 5d |  |  |  |  |
| 574 | 1.6.5.4.2.2.2 | Muon and Radioactive Source Test | 5d | 2004-01-29 A | 2004-02-04 A | 573, 560SS | 100% |  | 2004-01-29 | 2004-02-04 | 5d |  |  |  |  |
| 575 | 1.6.5.4.2.2.3 | SEPT-E FM 2 Vibration | 4d | 2004-02-21 | 2004-02-24 | 574, 561SS |  |  | 2004-02-21 | 2004-02-24 | 4d | 87d | 0d |  | SEPT Test Calendar |
| 576 | 1.6.5.4.2.2.4 | SEPT-E FM 2 Thermal Vac | 9d | 2004-03-09 | 2004-03-17 | 575, 570SS |  |  | 2004-03-09 | 2004-03-17 | 9d | 78d | 0d |  | SEPT Test Calendar |
| 577 | 1.6.5.4.2.2.5 | SEPT-E FM 2 Bake Out | 2d | 2004-03-18 | 2004-03-19 | 576 |  |  | 2004-03-18 | 2004-03-19 | 2d | 78d | 0d |  |  |
| 578 | 1.6.6 | **SIT - UMD** | 351d | 2003-06-02 A | 2004-10-20 |  | 42% | 202.35d | 2003-06-02 | 2004-10-20 | 351d | 280d |  |  |  |
| 579 | 1.6.6.1 | **Deliveries** | 81d | 2004-06-18 | 2004-10-12 |  |  |  | 2004-06-18 | 2004-10-12 | 81d | 9d |  |  |  |
| 580 | 1.6.6.1.1 | Deliver SIT FM 1 to CIT for SEP I&T and Suite EMC | 2d | 2004-06-18 | 2004-06-21 | 407, 679 |  |  | 2004-06-18 | 2004-06-21 | 2d | 9d | 0d |  |  |
| 581 | 1.6.6.1.2 | Deliver SIT FM 1 back to GSFC for Environmental Testing (after EMC Test) | 2d | 2004-07-13 | 2004-07-14 | 19 |  |  | 2004-07-13 | 2004-07-14 | 2d | 24d | 0d |  |  |
| 582 | 1.6.6.1.3 | Final Delivery of SIT FM 1 to APL | 1d | 2004-09-01 | 2004-09-01 | 711 |  |  | 2004-09-01 | 2004-09-01 | 1d | 24d | 8d |  |  |
| 583 | 1.6.6.1.4 | Deliver SIT FM 2 to CIT for SEP I&T | 2d | 2004-07-23 | 2004-07-26 | 684, 407 |  |  | 2004-07-23 | 2004-07-26 | 2d | 16d | 0d |  |  |
| 584 | 1.6.6.1.5 | Deliver SIT FM 2 back to GSFC for Environmental Testing | 2d | 2004-08-19 | 2004-08-20 | 776 |  |  | 2004-08-19 | 2004-08-20 | 2d | 11d | 0d |  |  |
| 585 | 1.6.6.1.6 | Final Delivery of SIT FM 2 to APL | 1d | 2004-10-12 | 2004-10-12 | 720 |  |  | 2004-10-12 | 2004-10-12 | 1d | 11d | 0d |  |  |
| 586 | 1.6.6.2 | **Detectors** | 60d | 2004-01-05 A | 2004-03-30 |  | 50% | 30d | 2004-01-05 | 2004-03-30 | 60d | 51d |  |  |  |
| 587 | 1.6.6.2.1 | **Detector Testing** | 60d | 2004-01-05 A | 2004-03-30 |  | 50% | 30d | 2004-01-05 | 2004-03-30 | 60d | 51d |  |  |  |
| 588 | 1.6.6.2.1.1 | **FM 1** | 60d | 2004-01-05 A | 2004-03-30 |  | 50% | 30d | 2004-01-05 | 2004-03-30 | 60d | 16d |  |  |  |
| 589 | 1.6.6.2.1.1.1 | Test FM 1 Solid States Detectors | 33d | 2004-01-05 A | 2004-02-20 |  | 58% | 14d | 2004-01-05 | 2004-02-20 | 33d | 33d | 0d | start no earlier than 2004-01-05 |  |
| 590 | 1.6.6.2.1.1.2 | Test FM 1 Foils | 33d | 2004-01-05 A | 2004-02-20 | 589SS | 58% | 14d | 2004-01-05 | 2004-02-20 | 33d | 33d | 0d |  |  |
| 591 | 1.6.6.2.1.1.3 | Alpha Tests FM 1 w/Proto Elect | 10d | 2004-03-17 | 2004-03-30 | 589, 590, 367 |  |  | 2004-03-17 | 2004-03-30 | 10d | 16d | 0d |  |  |
| 592 | 1.6.6.2.1.2 | **FM 2** | 60d | 2004-01-05 A | 2004-03-30 |  | 50% | 30d | 2004-01-05 | 2004-03-30 | 60d | 51d |  |  |  |
| 593 | 1.6.6.2.1.2.1 | Test FM 2 Solid States Detectors | 33d | 2004-01-05 A | 2004-02-20 | 589SS | 58% | 14d | 2004-01-05 | 2004-02-20 | 33d | 68d | 17d |  |  |
| 594 | 1.6.6.2.1.2.2 | Test FM 2 Foils | 33d | 2004-01-05 A | 2004-02-20 | 590SS | 58% | 14d | 2004-01-05 | 2004-02-20 | 33d | 68d | 17d |  |  |
| 595 | 1.6.6.2.1.2.3 | Alpha Tests FM 2 w/Proto Elect | 10d | 2004-03-17 | 2004-03-30 | 593, 594, 367 |  |  | 2004-03-17 | 2004-03-30 | 10d | 51d | 35d |  |  |

| ID | WBS | Task | Type | Duration | Start | Finish | Predecessors | Complete | Remaining | Baseline start | Baseline finish | Baseline duration | Total slack | Free slack | Constraint |
| --- | --- | --- | --- | --- | --- | --- | --- | --- | --- | --- | --- | --- | --- | --- | --- |
| 596 | 1.6.6.3 | **ACTEL - for SIT Logic Board** |  | 11d | 2004-02-27 | 2004-03-12 |  |  |  | 2004-02-27 | 2004-03-12 | 11d | 60d |  |  |
| 597 | 1.6.6.3.1 | Burn Final SIT ACTEL Chip (at GSFC) |  | 1d | 2004-02-27 | 2004-02-27 |  |  |  | 2004-02-27 | 2004-02-27 | 1d | 60d | 0d | start no earlier than 2004-02-27 |
| 598 | 1.6.6.3.2 | Evaluate (Test) SIT Final ACTEL Chip |  | 10d | 2004-03-01 | 2004-03-12 | 597 |  |  | 2004-03-01 | 2004-03-12 | 10d | 60d | 51d |  |
| 599 | 1.6.6.4 | **TOF Boards** |  | 20d | 2004-02-12 A | 2004-03-11 |  |  | 20d | 2004-02-12 | 2004-03-11 | 20d | 67d |  |  |
| 600 | 1.6.6.4.1 | Receive Analog and Digital TOF Boards (FM 1 & FM 2) | milestone | 0d | 2004-02-12 A | 2004-02-12 A |  | 100% |  | 2004-02-12 | 2004-02-12 | 0d |  |  | start no earlier than 2004-02-12 |
| 601 | 1.6.6.4.2 | **Test** |  | 20d | 2004-02-12 | 2004-03-11 |  |  |  | 2004-02-12 | 2004-03-11 | 20d | 42d |  |  |
| 602 | 1.6.6.4.2.1 | **FM 1** |  | 10d | 2004-02-12 | 2004-02-26 |  |  |  | 2004-02-12 | 2004-02-26 | 10d | 42d |  |  |
| 603 | 1.6.6.4.2.1.1 | FM 1 TOF Boards Functional Test |  | 10d | 2004-02-12 | 2004-02-26 | 600 |  |  | 2004-02-12 | 2004-02-26 | 10d | 42d | 0d |  |
| 604 | 1.6.6.4.2.2 | **FM 2** |  | 10d | 2004-02-27 | 2004-03-11 |  |  |  | 2004-02-27 | 2004-03-11 | 10d | 67d |  |  |
| 605 | 1.6.6.4.2.2.1 | FM 2 TOF Boards Functional Test |  | 10d | 2004-02-27 | 2004-03-11 | 600, 603 |  |  | 2004-02-27 | 2004-03-11 | 10d | 67d | 51d |  |
| 606 | 1.6.6.5 | **Energy Board** |  | 99d | 2003-11-10 A | 2004-04-02 |  | 65% | 34.18d | 2003-11-10 | 2004-04-02 | 99d | 51d |  |  |
| 607 | 1.6.6.5.1 | **Assembly** |  | 69d | 2003-11-10 A | 2004-02-20 |  | 80% | 14d | 2003-11-10 | 2004-02-20 | 69d | 66d |  |  |
| 608 | 1.6.6.5.1.1 | **FM 1** |  | 69d | 2003-11-10 A | 2004-02-20 |  | 80% | 14d | 2003-11-10 | 2004-02-20 | 69d | 31d |  |  |
| 609 | 1.6.6.5.1.1.1 | Assemble FM 1 Energy Board |  | 69d | 2003-11-10 A | 2004-02-20 |  | 80% | 14d | 2003-11-10 | 2004-02-20 | 69d | 31d | 0d | start no earlier than 2003-11-10 |
| 610 | 1.6.6.5.1.2 | **FM 2** |  | 69d | 2003-11-10 A | 2004-02-20 |  | 80% | 14d | 2003-11-10 | 2004-02-20 | 69d | 66d |  |  |
| 611 | 1.6.6.5.1.2.1 | Assemble FM 2 Energy Board |  | 69d | 2003-11-10 A | 2004-02-20 | 609SS | 80% | 14d | 2003-11-10 | 2004-02-20 | 69d | 66d | 15d |  |
| 612 | 1.6.6.5.2 | **Test** |  | 30d | 2004-02-23 | 2004-04-02 |  |  |  | 2004-02-23 | 2004-04-02 | 30d | 31d |  |  |
| 613 | 1.6.6.5.2.1 | **FM 1** |  | 15d | 2004-02-23 | 2004-03-12 |  |  |  | 2004-02-23 | 2004-03-12 | 15d | 31d |  |  |
| 614 | 1.6.6.5.2.1.1 | Bench Test/Calibration |  | 10d | 2004-02-23 | 2004-03-05 | 609 |  |  | 2004-02-23 | 2004-03-05 | 10d | 31d | 0d |  |
| 615 | 1.6.6.5.2.1.2 | Thermal |  | 3d | 2004-03-08 | 2004-03-10 | 614 |  |  | 2004-03-08 | 2004-03-10 | 3d | 31d | 0d |  |
| 616 | 1.6.6.5.2.1.3 | Voltage Margin |  | 2d | 2004-03-11 | 2004-03-12 | 615 |  |  | 2004-03-11 | 2004-03-12 | 2d | 31d | 0d |  |
| 617 | 1.6.6.5.2.2 | **FM 2** |  | 15d | 2004-03-15 | 2004-04-02 |  |  |  | 2004-03-15 | 2004-04-02 | 15d | 51d |  |  |
| 618 | 1.6.6.5.2.2.1 | FM 2 Energy Board Functional Test |  | 15d | 2004-03-15 | 2004-04-02 | 611, 616 |  |  | 2004-03-15 | 2004-04-02 | 15d | 51d | 35d |  |
| 619 | 1.6.6.6 | **Logic Board** |  | 168d | 2003-11-10 A | 2004-07-09 |  | 39% | 101.71d | 2003-11-10 | 2004-07-09 | 168d | 16d |  |  |
| 620 | 1.6.6.6.1 | **Design** |  | 3d | 2003-11-17 A | 2003-11-19 A |  | 100% |  | 2003-11-17 | 2003-11-19 | 3d |  |  |  |
| 621 | 1.6.6.6.1.1 | Layout new Logic Board Design |  | 3d | 2003-11-17 A | 2003-11-19 A |  | 100% |  | 2003-11-17 | 2003-11-19 | 3d |  |  | start no earlier than 2003-11-17 |

| ID | WBS | Task | Duration | Start | Finish | Predecessors | Complete | Remaining | Baseline start | Baseline finish | Baseline duration | Total slack | Free slack | Constraint |
| --- | --- | --- | --- | --- | --- | --- | --- | --- | --- | --- | --- | --- | --- | --- |
| 622 | 1.6.6.6.2 | **Fabrication** | 10d | 2004-02-09 | 2004-02-23 |  |  |  | 2004-02-09 | 2004-02-23 | 10d | 9d |  |  |
| 623 | 1.6.6.6.2.1 | FM 1 & FM 2 Logic Board Fabrication | 10d | 2004-02-09 | 2004-02-23 | 621, 637 |  |  | 2004-02-09 | 2004-02-23 | 10d | 9d | 0d | start no earlier than 2004-02-02 |
| 624 | 1.6.6.6.3 | **Assembly** | 86d | 2004-03-09 | 2004-07-07 |  |  |  | 2004-03-09 | 2004-07-07 | 86d | 9d |  |  |
| 625 | 1.6.6.6.3.1 | **FM 1** | 58d | 2004-03-09 | 2004-05-27 |  |  |  | 2004-03-09 | 2004-05-27 | 58d | 9d |  |  |
| 626 | 1.6.6.6.3.1.1 | Assemble FM 1 Logic Board with ETU ACTELs | 11d | 2004-03-09 | 2004-03-23 | 639 |  |  | 2004-03-09 | 2004-03-23 | 11d | 9d | 0d |  |
| 627 | 1.6.6.6.3.1.2 | Disassembel FM 1 Logic Board with ETU ACTELs | 1d | 2004-05-24 | 2004-05-24 | 693 |  |  | 2004-05-24 | 2004-05-24 | 1d | 9d | 0d |  |
| 628 | 1.6.6.6.3.1.3 | Retrofit/Inspect FM 1 Flight ACTELs | 2d | 2004-05-25 | 2004-05-26 | 627, 598 |  |  | 2004-05-25 | 2004-05-26 | 2d | 9d | 0d |  |
| 629 | 1.6.6.6.3.1.4 | Reassemble FM 1 Logic Board with Flight ACTELs | 1d | 2004-05-27 | 2004-05-27 | 628 |  |  | 2004-05-27 | 2004-05-27 | 1d | 9d | 0d |  |
| 630 | 1.6.6.6.3.2 | **FM 2** | 86d | 2004-03-09 | 2004-07-07 |  |  |  | 2004-03-09 | 2004-07-07 | 86d | 16d |  |  |
| 631 | 1.6.6.6.3.2.1 | Assemble FM 2 Logic Board with ETU ACTELS | 11d | 2004-03-09 | 2004-03-23 | 639 |  |  | 2004-03-09 | 2004-03-23 | 11d | 44d | 15d |  |
| 632 | 1.6.6.6.3.2.2 | Disassemble FM 2 Logic Boards | 1d | 2004-07-02 | 2004-07-02 | 702, 627SS |  |  | 2004-07-02 | 2004-07-02 | 1d | 16d | 0d |  |
| 633 | 1.6.6.6.3.2.3 | Retrofit/Inspect Flight ACTELS | 2d | 2004-07-05 | 2004-07-06 | 632, 598 |  |  | 2004-07-05 | 2004-07-06 | 2d | 16d | 0d |  |
| 634 | 1.6.6.6.3.2.4 | Reassemble FM 2 Logic Boards | 1d | 2004-07-07 | 2004-07-07 | 633 |  |  | 2004-07-07 | 2004-07-07 | 1d | 16d | 0d |  |
| 635 | 1.6.6.6.4 | **Test** | 168d | 2003-11-10 A | 2004-07-09 |  | 53% | 79.15d | 2003-11-10 | 2004-07-09 | 168d | 16d |  |  |
| 636 | 1.6.6.6.4.1 | **ETU** | 60d | 2003-11-10 A | 2004-02-06 |  | 92% | 5d | 2003-11-10 | 2004-02-06 | 60d | 9d |  |  |
| 637 | 1.6.6.6.4.1.1 | Test New ETU Logic Board | 60d | 2003-11-10 A | 2004-02-06 |  | 92% | 5d | 2003-11-10 | 2004-02-06 | 60d | 9d | 0d | start no earlier than 2003-11-10 |
| 638 | 1.6.6.6.4.2 | **FM1 & FM 2** | 10d | 2004-02-24 | 2004-03-08 |  |  |  | 2004-02-24 | 2004-03-08 | 10d | 9d |  |  |
| 639 | 1.6.6.6.4.2.1 | Coupon Testing | 10d | 2004-02-24 | 2004-03-08 | 623 |  |  | 2004-02-24 | 2004-03-08 | 10d | 9d | 0d |  |
| 640 | 1.6.6.6.4.3 | **FM 1** | 49d | 2004-03-24 | 2004-06-01 |  |  |  | 2004-03-24 | 2004-06-01 | 49d | 9d |  |  |
| 641 | 1.6.6.6.4.3.1 | Functional Test of FM 1 Logic Board w/ETU ACTELS | 15d | 2004-03-24 | 2004-04-13 | 626 |  |  | 2004-03-24 | 2004-04-13 | 15d | 9d | 0d |  |
| 642 | 1.6.6.6.4.3.2 | Funtional Test of FM 1 Logic Board w/Flight ACTELS | 2d | 2004-05-28 | 2004-06-01 | 629 |  |  | 2004-05-28 | 2004-06-01 | 2d | 9d | 0d |  |
| 643 | 1.6.6.6.4.4 | **FM 2** | 62d | 2004-04-14 | 2004-07-09 |  |  |  | 2004-04-14 | 2004-07-09 | 62d | 16d |  |  |
| 644 | 1.6.6.6.4.4.1 | Functional Test of FM 2 Logic Board w/ETU ACTELS | 15d | 2004-04-14 | 2004-05-04 | 631, 641 |  |  | 2004-04-14 | 2004-05-04 | 15d | 29d | 13d |  |
| 645 | 1.6.6.6.4.4.2 | Functional Test of FM 2 Logic Board w/Flight ACTELS | 2d | 2004-07-08 | 2004-07-09 | 634 |  |  | 2004-07-08 | 2004-07-09 | 2d | 16d | 0d |  |

| ID | WBS | Task | Duration | Start | Finish | Predecessors | Complete | Remaining | Baseline start | Baseline finish | Baseline duration | Total slack | Free slack | Constraint |
| --- | --- | --- | --- | --- | --- | --- | --- | --- | --- | --- | --- | --- | --- | --- |
| 646 | 1.6.6.7 | **Mother Board** | 65d | 2003-12-22 A | 2004-03-25 |  | 30% | 45.5d | 2003-12-22 | 2004-03-25 | 65d | 426d |  |  |
| 647 | 1.6.6.7.1 | **Design** | 30d | 2003-12-22 A | 2004-02-04 |  | 90% | 3d | 2003-12-22 | 2004-02-04 | 30d | 27d |  |  |
| 648 | 1.6.6.7.1.1 | **FM 1 & FM 2** | 30d | 2003-12-22 A | 2004-02-04 |  | 90% | 3d | 2003-12-22 | 2004-02-04 | 30d | 27d |  |  |
| 649 | 1.6.6.7.1.1.1 | Finalize Mother Board Layout | 30d | 2003-12-22 A | 2004-02-04 |  | 90% | 3d | 2003-12-22 | 2004-02-04 | 30d | 27d | 0d | start no earlier than 2003-12-22 |
| 650 | 1.6.6.7.2 | **Fabrication** | 15d | 2004-02-05 | 2004-02-26 |  |  |  | 2004-02-05 | 2004-02-26 | 15d | 27d |  |  |
| 651 | 1.6.6.7.2.1 | **FM 1 & FM 2** | 15d | 2004-02-05 | 2004-02-26 |  |  |  | 2004-02-05 | 2004-02-26 | 15d | 27d |  |  |
| 652 | 1.6.6.7.2.1.1 | Fabricate FM 1 & FM 2 Mother Boards | 15d | 2004-02-05 | 2004-02-26 | 649 |  |  | 2004-02-05 | 2004-02-26 | 15d | 27d | 0d |  |
| 653 | 1.6.6.7.3 | **Assembly** | 10d | 2004-02-27 | 2004-03-11 |  |  |  | 2004-02-27 | 2004-03-11 | 10d | 27d |  |  |
| 654 | 1.6.6.7.3.1 | Assemble FM 1 Mother Board | 10d | 2004-02-27 | 2004-03-11 | 652 |  |  | 2004-02-27 | 2004-03-11 | 10d | 27d | 0d |  |
| 655 | 1.6.6.7.3.2 | Assemble FM 2 Mother Board | 10d | 2004-02-27 | 2004-03-11 | 654SS |  |  | 2004-02-27 | 2004-03-11 | 10d | 49d | 5d |  |
| 656 | 1.6.6.7.4 | **Test** | 20d | 2004-02-27 | 2004-03-25 |  |  |  | 2004-02-27 | 2004-03-25 | 20d | 37d |  |  |
| 657 | 1.6.6.7.4.1 | **FM 1 & FM 2** | 15d | 2004-02-27 | 2004-03-18 |  |  |  | 2004-02-27 | 2004-03-18 | 15d | 431d |  |  |
| 658 | 1.6.6.7.4.1.1 | Coupon Testing of Mother Boards | 15d | 2004-02-27 | 2004-03-18 | 652 |  |  | 2004-02-27 | 2004-03-18 | 15d | 431d |  |  |
| 659 | 1.6.6.7.4.2 | **FM 1** | 5d | 2004-03-12 | 2004-03-18 |  |  |  | 2004-03-12 | 2004-03-18 | 5d | 27d |  |  |
| 660 | 1.6.6.7.4.2.1 | Functional Test FM 1 Mother Board | 5d | 2004-03-12 | 2004-03-18 | 654 |  |  | 2004-03-12 | 2004-03-18 | 5d | 27d | 0d |  |
| 661 | 1.6.6.7.4.3 | **FM 2** | 5d | 2004-03-19 | 2004-03-25 |  |  |  | 2004-03-19 | 2004-03-25 | 5d | 44d |  |  |
| 662 | 1.6.6.7.4.3.1 | Functional Test FM 2 Mother Board | 5d | 2004-03-19 | 2004-03-25 | 655, 660 |  |  | 2004-03-19 | 2004-03-25 | 5d | 44d | 13d |  |
| 663 | 1.6.6.8 | **HVPS** | 75d | 2004-01-12 A | 2004-04-27 |  | 47% | 40d | 2004-01-12 | 2004-04-27 | 75d | 31d |  |  |
| 664 | 1.6.6.8.1 | **Test** | 75d | 2004-01-12 A | 2004-04-27 |  | 47% | 40d | 2004-01-12 | 2004-04-27 | 75d | 31d |  |  |
| 665 | 1.6.6.8.1.1 | **FM 1** | 20d | 2004-01-12 A | 2004-02-09 |  | 70% | 6d | 2004-01-12 | 2004-02-09 | 20d | 51d |  |  |
| 666 | 1.6.6.8.1.1.1 | Functional Test SIT FM 1 HVPS | 20d | 2004-01-12 A | 2004-02-09 | 71 | 70% | 6d | 2004-01-12 | 2004-02-09 | 20d | 51d | 35d | start no earlier than 2004-01-12 |
| 667 | 1.6.6.8.1.2 | **FM 2** | 10d | 2004-04-14 | 2004-04-27 |  |  |  | 2004-04-14 | 2004-04-27 | 10d | 31d |  |  |
| 668 | 1.6.6.8.1.2.1 | Functional Test SIT FM 2 HVPS | 10d | 2004-04-14 | 2004-04-27 | 77, 662 |  |  | 2004-04-14 | 2004-04-27 | 10d | 31d | 15d |  |
| 669 | 1.6.6.9 | **Flight Software** | 210d | 2003-06-02 A | 2004-04-01 |  | 80% | 43d | 2003-06-02 | 2004-04-01 | 210d | 44d |  |  |
| 670 | 1.6.6.9.1 | **Test** | 210d | 2003-06-02 A | 2004-04-01 |  | 80% | 43d | 2003-06-02 | 2004-04-01 | 210d | 44d |  |  |
| 671 | 1.6.6.9.1.1 | **FM 1 & FM 2** | 210d | 2003-06-02 A | 2004-04-01 |  | 80% | 43d | 2003-06-02 | 2004-04-01 | 210d | 44d |  |  |
| 672 | 1.6.6.9.1.1.1 | Validate SIT On-Board Code | 210d | 2003-06-02 A | 2004-04-01 |  | 80% | 43d | 2003-06-02 | 2004-04-01 | 210d | 44d | 35d | start no earlier than 2003-06-02 |

| ID | WBS | Task | Duration | Start | Finish | Predecessors | Baseline start | Baseline finish | Baseline duration | Total slack | Free slack |
| --- | --- | --- | --- | --- | --- | --- | --- | --- | --- | --- | --- |
| 673 | 1.6.6.10 | **Integration & Test (using ETU Telescope for FM 1)** | 81d | 2004-03-31 | 2004-07-22 |  | 2004-03-31 | 2004-07-22 | 81d | 16d |  |
| 674 | 1.6.6.10.1 | **FM 1 (Flight Telescope)** | 12d | 2004-06-02 | 2004-06-17 |  | 2004-06-02 | 2004-06-17 | 12d | 9d |  |
| 675 | 1.6.6.10.1.1 | Disassemble SIT FM 1 | 1d | 2004-06-02 | 2004-06-02 | 642 | 2004-06-02 | 2004-06-02 | 1d | 9d | 0d |
| 676 | 1.6.6.10.1.2 | Conformal Coat SIT FM 1 Boards | 2d | 2004-06-03 | 2004-06-04 | 675 | 2004-06-03 | 2004-06-04 | 2d | 9d | 0d |
| 677 | 1.6.6.10.1.3 | Reassemble SIT FM 1 with Flight Telescope | 1d | 2004-06-07 | 2004-06-07 | 676, 401 | 2004-06-07 | 2004-06-07 | 1d | 9d | 0d |
| 678 | 1.6.6.10.1.4 | Bench Calibration SIT FM 1 w/Flight Telescope | 3d | 2004-06-08 | 2004-06-10 | 677 | 2004-06-08 | 2004-06-10 | 3d | 9d | 0d |
| 679 | 1.6.6.10.1.5 | Vacuum Test SIT FM 1 w/Flight Telescope | 5d | 2004-06-11 | 2004-06-17 | 678 | 2004-06-11 | 2004-06-17 | 5d | 9d | 0d |
| 680 | 1.6.6.10.2 | **FM 2** | 9d | 2004-07-12 | 2004-07-22 |  | 2004-07-12 | 2004-07-22 | 9d | 16d |  |
| 681 | 1.6.6.10.2.1 | Disassemble SIT FM 2 | 1d | 2004-07-12 | 2004-07-12 | 645 | 2004-07-12 | 2004-07-12 | 1d | 16d | 0d |
| 682 | 1.6.6.10.2.2 | Conformal Coat SIT FM 2 Boards | 2d | 2004-07-13 | 2004-07-14 | 681 | 2004-07-13 | 2004-07-14 | 2d | 16d | 0d |
| 683 | 1.6.6.10.2.3 | Reassemble SIT FM 2 | 1d | 2004-07-15 | 2004-07-15 | 682 | 2004-07-15 | 2004-07-15 | 1d | 16d | 0d |
| 684 | 1.6.6.10.2.4 | Post-Coat Retest SIT FM 2 | 5d | 2004-07-16 | 2004-07-22 | 683 | 2004-07-16 | 2004-07-22 | 5d | 16d | 0d |
| 685 | 1.6.6.10.3 | **FM 1 (ETU Telescope)** | 38d | 2004-03-31 | 2004-05-21 |  | 2004-03-31 | 2004-05-21 | 38d | 9d |  |
| 686 | 1.6.6.10.3.1 | Integrate SIT FM 1 HVPS and SIT ETU Telescope Without Electronics | 3d | 2004-03-31 | 2004-04-02 | 666, 591 | 2004-03-31 | 2004-04-02 | 3d | 16d | 7d |
| 687 | 1.6.6.10.3.2 | Integrate Electronics to SIT ETU Telescope | 2d | 2004-04-14 | 2004-04-15 | 641, 603, 660, 616, 686 | 2004-04-14 | 2004-04-15 | 2d | 9d | 0d |
| 688 | 1.6.6.10.3.3 | SIT FM 1 Debug | 5d | 2004-04-16 | 2004-04-22 | 687 | 2004-04-16 | 2004-04-22 | 5d | 9d | 0d |
| 689 | 1.6.6.10.3.4 | SIT FM 1 Bench Test | 5d | 2004-04-23 | 2004-04-29 | 688 | 2004-04-23 | 2004-04-29 | 5d | 9d | 0d |
| 690 | 1.6.6.10.3.5 | SIT FM 1 Alpha TEST | 5d | 2004-04-30 | 2004-05-06 | 689 | 2004-04-30 | 2004-05-06 | 5d | 9d | 0d |
| 691 | 1.6.6.10.3.6 | SIT FM 1 Noise Removal | 5d | 2004-05-07 | 2004-05-13 | 690 | 2004-05-07 | 2004-05-13 | 5d | 9d | 0d |
| 692 | 1.6.6.10.3.7 | SIT FM 1 Thermal Test | 5d | 2004-05-14 | 2004-05-20 | 691 | 2004-05-14 | 2004-05-20 | 5d | 9d | 0d |
| 693 | 1.6.6.10.3.8 | SIT FM 1 Functional Test | 1d | 2004-05-21 | 2004-05-21 | 692, 672 | 2004-05-21 | 2004-05-21 | 1d | 9d | 0d |
| 694 | 1.6.6.10.4 | **FM 2** | 31d | 2004-05-19 | 2004-07-01 |  | 2004-05-19 | 2004-07-01 | 31d | 16d |  |
| 695 | 1.6.6.10.4.1 | Integrate SIT FM 2 HVPS and SIT FM 2 Telescope Without Electronics | 3d | 2004-05-19 | 2004-05-21 | 668, 595, 401 | 2004-05-19 | 2004-05-21 | 3d | 16d | 0d |
| 696 | 1.6.6.10.4.2 | Integrate Electronics to SIT FM 2 Telescope | 2d | 2004-05-24 | 2004-05-25 | 644, 605, 662, 618, 695 | 2004-05-24 | 2004-05-25 | 2d | 16d | 0d |
| 697 | 1.6.6.10.4.3 | SIT FM 2 Debug | 5d | 2004-05-26 | 2004-06-02 | 696 | 2004-05-26 | 2004-06-02 | 5d | 16d | 0d |
| 698 | 1.6.6.10.4.4 | SIT FM 2 Bench Test | 5d | 2004-06-03 | 2004-06-09 | 697 | 2004-06-03 | 2004-06-09 | 5d | 16d | 0d |
| 699 | 1.6.6.10.4.5 | SIT FM 2 Alpha Test | 5d | 2004-06-10 | 2004-06-16 | 698 | 2004-06-10 | 2004-06-16 | 5d | 16d | 0d |
| 700 | 1.6.6.10.4.6 | SIT FM 2 Noise Removal | 5d | 2004-06-17 | 2004-06-23 | 699, 691 | 2004-06-17 | 2004-06-23 | 5d | 16d | 0d |
| 701 | 1.6.6.10.4.7 | SIT FM 2 Thermal Test | 5d | 2004-06-24 | 2004-06-30 | 700 | 2004-06-24 | 2004-06-30 | 5d | 16d | 0d |
| 702 | 1.6.6.10.4.8 | SIT FM 2 Functional Test | 1d | 2004-07-01 | 2004-07-01 | 701 | 2004-07-01 | 2004-07-01 | 1d | 16d | 0d |

| ID | WBS | Task | Duration | Start | Finish | Predecessors | Complete | Remaining | Baseline start | Baseline finish | Baseline duration | Total slack | Free slack | Constraint |
| --- | --- | --- | --- | --- | --- | --- | --- | --- | --- | --- | --- | --- | --- | --- |
| 703 | 1.6.6.11 | **Environmental Testing at GSFC (FM 1)** | 34d | 2004-07-15 | 2004-08-31 |  |  |  | 2004-07-15 | 2004-08-31 | 34d | 24d |  |  |
| 704 | 1.6.6.11.1 | SIT FM 1 Vibration and Acoustics | 10d | 2004-07-15 | 2004-07-28 | 581 |  |  | 2004-07-15 | 2004-07-28 | 10d | 24d | 0d |  |
| 705 | 1.6.6.11.2 | Functional Test | 1d | 2004-07-29 | 2004-07-29 | 704 |  |  | 2004-07-29 | 2004-07-29 | 1d | 24d | 0d |  |
| 706 | 1.6.6.11.3 | SIT FM 1 Thermal Balance | 5d | 2004-07-30 | 2004-08-05 | 705 |  |  | 2004-07-30 | 2004-08-05 | 5d | 24d | 0d |  |
| 707 | 1.6.6.11.4 | SIT FM 1 Thermal Vac | 10d | 2004-08-06 | 2004-08-19 | 706 |  |  | 2004-08-06 | 2004-08-19 | 10d | 24d | 0d |  |
| 708 | 1.6.6.11.5 | Disassemble SIT Instruments | 2d | 2004-08-20 | 2004-08-23 | 707 |  |  | 2004-08-20 | 2004-08-23 | 2d | 24d | 0d |  |
| 709 | 1.6.6.11.6 | Bake Out | 3d | 2004-08-24 | 2004-08-26 | 708 |  |  | 2004-08-24 | 2004-08-26 | 3d | 24d | 0d |  |
| 710 | 1.6.6.11.7 | Reassemble Instruments | 2d | 2004-08-27 | 2004-08-30 | 709 |  |  | 2004-08-27 | 2004-08-30 | 2d | 24d | 0d |  |
| 711 | 1.6.6.11.8 | Functional Test | 1d | 2004-08-31 | 2004-08-31 | 710 |  |  | 2004-08-31 | 2004-08-31 | 1d | 24d | 0d |  |
| 712 | 1.6.6.12 | **Environmental Testing at GSFC (FM 2)** | 34d | 2004-08-23 | 2004-10-08 |  |  |  | 2004-08-23 | 2004-10-08 | 34d | 11d |  |  |
| 713 | 1.6.6.12.1 | SIT FM 2 Vibration and Acoustics | 10d | 2004-08-23 | 2004-09-03 | 584 |  |  | 2004-08-23 | 2004-09-03 | 10d | 11d | 0d |  |
| 714 | 1.6.6.12.2 | Functional Test | 1d | 2004-09-07 | 2004-09-07 | 713 |  |  | 2004-09-07 | 2004-09-07 | 1d | 11d | 0d |  |
| 715 | 1.6.6.12.3 | SIT FM 2 Thermal Balance | 5d | 2004-09-08 | 2004-09-14 | 714 |  |  | 2004-09-08 | 2004-09-14 | 5d | 11d | 0d |  |
| 716 | 1.6.6.12.4 | SIT FM 2 Thermal Vac | 10d | 2004-09-15 | 2004-09-28 | 715 |  |  | 2004-09-15 | 2004-09-28 | 10d | 11d | 0d |  |
| 717 | 1.6.6.12.5 | Disassemble SIT Instruments | 2d | 2004-09-29 | 2004-09-30 | 716 |  |  | 2004-09-29 | 2004-09-30 | 2d | 11d | 0d |  |
| 718 | 1.6.6.12.6 | Bake Out | 3d | 2004-10-01 | 2004-10-05 | 717 |  |  | 2004-10-01 | 2004-10-05 | 3d | 11d | 0d |  |
| 719 | 1.6.6.12.7 | Reassemble Instruments | 2d | 2004-10-06 | 2004-10-07 | 718 |  |  | 2004-10-06 | 2004-10-07 | 2d | 11d | 0d |  |
| 720 | 1.6.6.12.8 | Functional Test | 1d | 2004-10-08 | 2004-10-08 | 719 |  |  | 2004-10-08 | 2004-10-08 | 1d | 11d | 0d |  |
| 721 | 1.6.6.13 | **Emulators/Simulators/GSE** | 214d | 2003-12-17 A | 2004-10-20 |  | 27% | 155.64d | 2003-12-17 | 2004-10-20 | 214d | 280d |  |  |
| 722 | 1.6.6.13.1 | **Simulators** | 80d | 2003-12-17 A | 2004-04-12 |  | 38% | 50d | 2003-12-17 | 2004-04-12 | 80d | 414d |  |  |
| 723 | 1.6.6.13.1.1 | Labview CPU Ready | 80d | 2003-12-17 A | 2004-04-12 |  | 38% | 50d | 2003-12-17 | 2004-04-12 | 80d | 414d | 0d | start no earlier than 2003-12-17 |
| 724 | 1.6.6.13.1.2 | Test Simulator | 80d | 2003-12-17 A | 2004-04-12 | 723SS | 38% | 50d | 2003-12-17 | 2004-04-12 | 80d | 414d |  |  |
| 725 | 1.6.6.13.2 | **GSE** | 60d | 2004-07-27 | 2004-10-20 |  |  |  | 2004-07-27 | 2004-10-20 | 60d | 280d |  |  |
| 726 | 1.6.6.13.2.1 | Pulse Generator | 60d | 2004-07-27 | 2004-10-20 | 580, 583 |  |  | 2004-07-27 | 2004-10-20 | 60d | 280d |  |  |

| ID | WBS | Task | Duration | Start | Finish | Predecessors | Complete | Remaining | Baseline start | Baseline finish | Baseline duration | Total slack | Free slack | Constraint |
| --- | --- | --- | --- | --- | --- | --- | --- | --- | --- | --- | --- | --- | --- | --- |
| 727 | 1.6.7 | **SEP Suite I&T - CIT** | 309d | 2003-08-01 A | 2004-10-21 |  | 32% | 210.06d | 2003-08-01 | 2004-10-21 | 309d | 279d |  |  |
| 728 | 1.6.7.1 | **ETU** | 5d | 2004-01-26 A | 2004-01-30 A |  | 100% |  | 2004-01-26 | 2004-01-30 | 5d |  |  |  |
| 729 | 1.6.7.1.1 | Complete Integration/Test of SEP Central EM with Sensors | 5d | 2004-01-26 A | 2004-01-30 A |  | 100% |  | 2004-01-26 | 2004-01-30 | 5d |  |  | start no earlier than 2004-01-26 |
| 730 | 1.6.7.2 | **FM 1 & FM 2** | 162d | 2004-03-05 | 2004-10-21 |  |  |  | 2004-03-05 | 2004-10-21 | 162d | 75d |  |  |
| 731 | 1.6.7.2.1 | Software Support For SEP Integration | 115d | 2004-05-11 | 2004-10-21 | 742SS |  |  | 2004-05-11 | 2004-10-21 | 115d | 279d |  |  |
| 732 | 1.6.7.2.2 | Generate SEPT integration & test procedure | 5d | 2004-03-05 | 2004-03-11 | 743FS-10d |  |  | 2004-03-05 | 2004-03-11 | 5d | 76d | 47d |  |
| 733 | 1.6.7.2.3 | Generate LET integration & test procedure | 5d | 2004-05-05 | 2004-05-11 | 744FS-10d |  |  | 2004-05-05 | 2004-05-11 | 5d | 34d | 19d |  |
| 734 | 1.6.7.2.4 | Generate HET integration & test procedure | 5d | 2004-05-20 | 2004-05-26 | 746FS-10d |  |  | 2004-05-20 | 2004-05-26 | 5d | 24d | 9d |  |
| 735 | 1.6.7.2.5 | Generate SIT integration & test procedure | 5d | 2004-06-09 | 2004-06-15 | 750FS-10d |  |  | 2004-06-09 | 2004-06-15 | 5d | 14d | 5d |  |
| 736 | 1.6.7.2.6 | Generate SEP system test procedure | 5d | 2004-06-10 | 2004-06-16 | 751FS-10d |  |  | 2004-06-10 | 2004-06-16 | 5d | 14d | 5d |  |
| 737 | 1.6.7.2.7 | Software Support For Acceptance Testing of SEP Instruments | 27d | 2004-06-24 | 2004-07-30 | 752SS |  |  | 2004-06-24 | 2004-07-30 | 27d | 336d |  |  |
| 738 | 1.6.7.2.8 | Generate SEP-IDPU integration procedure | 5d | 2004-05-27 | 2004-06-03 | 747FS-10d |  |  | 2004-05-27 | 2004-06-03 | 5d | 16d | 0d |  |
| 739 | 1.6.7.2.9 | Generate SEP-IDPU test procedure | 5d | 2004-06-04 | 2004-06-10 | 738 |  |  | 2004-06-04 | 2004-06-10 | 5d | 16d | 7d |  |
| 740 | 1.6.7.2.10 | Software Support of SEP Accelerator Tests | 20d | 2004-06-29 | 2004-07-26 | 783SS-10d |  |  | 2004-06-29 | 2004-07-26 | 20d | 340d |  |  |
| 741 | 1.6.7.3 | **FM 1** | 72d | 2004-03-18 | 2004-06-28 |  |  |  | 2004-03-18 | 2004-06-28 | 72d | 9d |  |  |
| 742 | 1.6.7.3.1 | Integrate/test SEP Central FM 1 | 5d | 2004-05-11 | 2004-05-17 | 416, 418, 377 |  |  | 2004-05-11 | 2004-05-17 | 5d | 29d | 0d |  |
| 743 | 1.6.7.3.2 | Receive & inspect SEPT FM 1 | 1d | 2004-03-18 | 2004-03-18 | 516, 517 |  |  | 2004-03-18 | 2004-03-18 | 1d | 71d | 0d |  |
| 744 | 1.6.7.3.3 | Integrate & test SEPT FM 1 | 1d | 2004-05-18 | 2004-05-18 | 732, 742, 743 |  |  | 2004-05-18 | 2004-05-18 | 1d | 29d | 0d |  |
| 745 | 1.6.7.3.4 | Integrate & test LET FM 1 | 1d | 2004-06-09 | 2004-06-09 | 733, 744, 493, 495 |  |  | 2004-06-09 | 2004-06-09 | 1d | 15d | 0d |  |
| 746 | 1.6.7.3.5 | Receive & inspect HET FM 1 | 1d | 2004-06-03 | 2004-06-03 | 446, 448 |  |  | 2004-06-03 | 2004-06-03 | 1d | 19d | 0d |  |
| 747 | 1.6.7.3.6 | Integrate & test HET FM 1 | 1d | 2004-06-10 | 2004-06-10 | 734, 745, 746 |  |  | 2004-06-10 | 2004-06-10 | 1d | 15d | 0d |  |
| 748 | 1.6.7.3.7 | Integrate SEP FM 1 - IDPU FM 1 | 1d | 2004-06-11 | 2004-06-11 | 738, 747 |  |  | 2004-06-11 | 2004-06-11 | 1d | 15d | 6d |  |
| 749 | 1.6.7.3.8 | Test SEP FM 1 - IDPU FM 1 | 1d | 2004-06-22 | 2004-06-22 | 739, 748, 353 |  |  | 2004-06-22 | 2004-06-22 | 1d | 9d | 0d |  |
| 750 | 1.6.7.3.9 | Receive & inspect SIT FM 1 | 1d | 2004-06-22 | 2004-06-22 | 580 |  |  | 2004-06-22 | 2004-06-22 | 1d | 9d | 0d |  |
| 751 | 1.6.7.3.10 | Integrate & test SIT FM 1 | 1d | 2004-06-23 | 2004-06-23 | 735, 747, 750, 749 |  |  | 2004-06-23 | 2004-06-23 | 1d | 9d | 0d |  |
| 752 | 1.6.7.3.11 | SEP system test FM 1 | 3d | 2004-06-24 | 2004-06-28 | 736, 751, 413 |  |  | 2004-06-24 | 2004-06-28 | 3d | 9d | 0d |  |

| ID | WBS | Task | Duration | Start | Finish | Predecessors | Baseline start | Baseline finish | Baseline duration | Total slack | Free slack | Constraint |
| --- | --- | --- | --- | --- | --- | --- | --- | --- | --- | --- | --- | --- |
| 753 | 1.6.7.4 | **FM 2** | 97d | 2004-03-29 | 2004-08-11 |  | 2004-03-29 | 2004-08-11 | 97d | 9d |  |  |
| 754 | 1.6.7.4.1 | Integrate/testSEP Central FM 2 | 5d | 2004-05-11 | 2004-05-17 | 417, 418, 377 | 2004-05-11 | 2004-05-17 | 5d | 43d | 0d |  |
| 755 | 1.6.7.4.2 | Receive & inspect SEPT FM 2 | 1d | 2004-03-29 | 2004-03-29 | 519, 520 | 2004-03-29 | 2004-03-29 | 1d | 78d | 35d |  |
| 756 | 1.6.7.4.3 | Integrate & test SEPT FM 2 | 1d | 2004-05-18 | 2004-05-18 | 732, 754, 755 | 2004-05-18 | 2004-05-18 | 1d | 43d | 14d |  |
| 757 | 1.6.7.4.4 | Integrate & test LET FM 2 | 1d | 2004-06-09 | 2004-06-09 | 733, 756, 494, 495 | 2004-06-09 | 2004-06-09 | 1d | 29d | 11d |  |
| 758 | 1.6.7.4.5 | Receive & inspect HET FM 2 | 1d | 2004-06-24 | 2004-06-24 | 447 | 2004-06-24 | 2004-06-24 | 1d | 18d | 0d |  |
| 759 | 1.6.7.4.6 | Integrate & test HET FM 2 | 1d | 2004-06-25 | 2004-06-25 | 734, 757, 758 | 2004-06-25 | 2004-06-25 | 1d | 18d | 0d |  |
| 760 | 1.6.7.4.7 | Integrate SEP FM 2 - IDPU FM 2 | 1d | 2004-06-28 | 2004-06-28 | 738, 759, 162 | 2004-06-28 | 2004-06-28 | 1d | 18d | 0d |  |
| 761 | 1.6.7.4.8 | Test SEP FM 2 - IDPU FM 2 | 1d | 2004-06-29 | 2004-06-29 | 739, 760 | 2004-06-29 | 2004-06-29 | 1d | 18d | 9d |  |
| 762 | 1.6.7.4.9 | Receive & inspect SIT FM 2 | 1d | 2004-07-27 | 2004-07-27 | 583 | 2004-07-27 | 2004-07-27 | 1d | 16d | 7d |  |
| 763 | 1.6.7.4.10 | Integrate & test SIT FM 2 | 1d | 2004-08-06 | 2004-08-06 | 735, 762, 777 | 2004-08-06 | 2004-08-06 | 1d | 9d | 0d |  |
| 764 | 1.6.7.4.11 | SEP FM 2 system test | 3d | 2004-08-09 | 2004-08-11 | 736, 763 | 2004-08-09 | 2004-08-11 | 3d | 9d | 0d |  |
| 765 | 1.6.7.5 | **Environmental Test (at JPL)** | 93d | 2004-05-17 | 2004-09-24 |  | 2004-05-17 | 2004-09-24 | 93d | 23d |  |  |
| 766 | 1.6.7.5.1 | Generate Environmental Test Procedures | 15d | 2004-05-17 | 2004-06-07 |  | 2004-05-17 | 2004-06-07 | 15d | 46d | 33d | start no earlier than 2004-05-17 |
| 767 | 1.6.7.5.2 | Manufacture test cables (JPL) | 20d | 2004-06-01 | 2004-06-28 |  | 2004-06-01 | 2004-06-28 | 20d | 31d | 18d | start no earlier than 2004-06-01 |
| 768 | 1.6.7.5.3 | **FM 1** | 45d | 2004-07-23 | 2004-09-24 |  | 2004-07-23 | 2004-09-24 | 45d | 9d |  |  |
| 769 | 1.6.7.5.3.1 | FM 1 LET/HET/SEP Central Vibration/Acoustics Test | 10d | 2004-07-23 | 2004-08-05 | 19FS+3d, 766, 767, 783FS+3d | 2004-07-23 | 2004-08-05 | 10d | 13d | 0d |  |
| 770 | 1.6.7.5.3.2 | FM 1 LET/HET/SEP Central Thermal Balance Test | 5d | 2004-08-06 | 2004-08-12 | 769 | 2004-08-06 | 2004-08-12 | 5d | 13d | 0d |  |
| 771 | 1.6.7.5.3.3 | FM 1 LET/HET/SEP Central T/V Test | 15d | 2004-08-19 | 2004-09-09 | 770, 776 | 2004-08-19 | 2004-09-09 | 15d | 9d | 0d |  |
| 772 | 1.6.7.5.3.4 | Evaluate SEP performance | 10d | 2004-09-10 | 2004-09-23 | 771 | 2004-09-10 | 2004-09-23 | 10d | 9d | 0d |  |
| 773 | 1.6.7.5.3.5 | Generate test reports | 11d | 2004-09-10 | 2004-09-24 | 772SS | 2004-09-10 | 2004-09-24 | 11d | 9d |  | finish no later than 2004-10-07 |
| 774 | 1.6.7.5.3.6 | Bakeout Clean SEP exterior & prepare for delivery | 3d | 2004-09-10 | 2004-09-14 | 771 | 2004-09-10 | 2004-09-14 | 3d | 16d | 0d |  |
| 775 | 1.6.7.5.4 | **FM 2** | 45d | 2004-07-23 | 2004-09-24 |  | 2004-07-23 | 2004-09-24 | 45d | 9d |  |  |
| 776 | 1.6.7.5.4.1 | FM 2 EMI/EMC Test at CalTech | 5d | 2004-08-12 | 2004-08-18 | 764 | 2004-08-12 | 2004-08-18 | 5d | 9d | 0d |  |
| 777 | 1.6.7.5.4.2 | FM 2 LET/HET/SEP Central Vibration/Acoustics Test | 10d | 2004-07-23 | 2004-08-05 | 784FS+3d | 2004-07-23 | 2004-08-05 | 10d | 9d | 0d |  |
| 778 | 1.6.7.5.4.3 | FM 2 LET/HET/SEP Central T/V Test | 15d | 2004-08-19 | 2004-09-09 | 776 | 2004-08-19 | 2004-09-09 | 15d | 23d | 0d |  |
| 779 | 1.6.7.5.4.4 | Evaluate SEP performance | 10d | 2004-09-10 | 2004-09-23 | 778 | 2004-09-10 | 2004-09-23 | 10d | 23d | 0d |  |
| 780 | 1.6.7.5.4.5 | Generate test reports | 11d | 2004-09-10 | 2004-09-24 | 779SS | 2004-09-10 | 2004-09-24 | 11d | 23d |  | finish no later than 2004-10-28 |
| 781 | 1.6.7.5.4.6 | Bakeout Clean SEP exterior & prepare for delivery | 3d | 2004-09-10 | 2004-09-14 | 778 | 2004-09-10 | 2004-09-14 | 3d | 30d | 0d |  |

| ID | WBS | Task | Duration | Start | Finish | Predecessors | Complete | Remaining | Baseline start | Baseline finish | Baseline duration | Total slack | Free slack | Constraint |
| --- | --- | --- | --- | --- | --- | --- | --- | --- | --- | --- | --- | --- | --- | --- |
| 782 | 1.6.7.6 | **Accelerator Test (at MSU)** | 5d | 2004-07-13 | 2004-07-19 |  |  |  | 2004-07-13 | 2004-07-19 | 5d | 9d |  |  |
| 783 | 1.6.7.6.1 | FM 1 LET/SEP Cen end-to-end test at Accelerator | 5d | 2004-07-13 | 2004-07-19 | 789, 19, 408 |  |  | 2004-07-13 | 2004-07-19 | 5d | 9d | 0d |  |
| 784 | 1.6.7.6.2 | FM 2 LET/SEP Cen end-to-end test at Accelerator | 5d | 2004-07-13 | 2004-07-19 | 783SS, 761 |  |  | 2004-07-13 | 2004-07-19 | 5d | 9d | 0d |  |
| 785 | 1.6.7.7 | **GSE** | 305d | 2003-08-01 A | 2004-10-15 |  | 55% | 137.48d | 2003-08-01 | 2004-10-15 | 305d | 283d |  |  |
| 786 | 1.6.7.7.1 | **End-to-End Test Equipment** | 218d | 2003-08-11 A | 2004-06-22 |  | 84% | 35.3d | 2003-08-11 | 2004-06-22 | 218d | 23d |  |  |
| 787 | 1.6.7.7.1.1 | Design | 192d | 2003-08-11 A | 2004-05-14 |  | 95% | 9.3d | 2003-08-11 | 2004-05-14 | 192d | 23d | 0d | start no earlier than 2003-08-11 |
| 788 | 1.6.7.7.1.2 | Assemble | 21d | 2004-05-17 | 2004-06-15 | 787 |  |  | 2004-05-17 | 2004-06-15 | 21d | 23d | 0d |  |
| 789 | 1.6.7.7.1.3 | Test | 5d | 2004-06-16 | 2004-06-22 | 788 |  |  | 2004-06-16 | 2004-06-22 | 5d | 23d | 14d |  |
| 790 | 1.6.7.7.2 | **GSE software** | 305d | 2003-08-01 A | 2004-10-15 |  | 34% | 200.66d | 2003-08-01 | 2004-10-15 | 305d | 283d |  |  |
| 791 | 1.6.7.7.2.1 | Build GSE software release 2 | 157d | 2003-08-01 A | 2004-03-18 |  | 66% | 53d | 2003-08-01 | 2004-03-18 | 157d | 306d | 1d | start no earlier than 2003-08-01 |
| 792 | 1.6.7.7.2.2 | Write user's guide | 8d | 2004-03-22 | 2004-03-31 | 791 |  |  | 2004-03-22 | 2004-03-31 | 8d | 305d | 22d | start no earlier than 2004-03-22 |
| 793 | 1.6.7.7.2.3 | Build GSE software release 3 | 117d | 2004-05-03 | 2004-10-15 | 792 |  |  | 2004-05-03 | 2004-10-15 | 117d | 283d | 0d | start no earlier than 2004-05-03 |
| 794 | 1.6.7.7.2.4 | Write user's guide supplement | 22d | 2004-09-15 | 2004-10-15 | 793FS-22d |  |  | 2004-09-15 | 2004-10-15 | 22d | 283d |  |  |
| 795 | 1.7 | **SWEA and SIT Refurbishment (after S/C Environmental Testing)** | 39d | 2005-09-27 | 2005-11-18 |  |  |  | 2005-09-27 | 2005-11-18 | 39d | 0d |  |  |
| 796 | 1.7.1 | Ship SWEA FM 1 to UCB | 3d | 2005-09-27 | 2005-09-29 |  |  |  | 2005-09-27 | 2005-09-29 | 3d | 24d | 0d | start no earlier than 2005-09-27 |
| 797 | 1.7.2 | Ship (Hand Carry) SIT FM 1 to UMD | 1d | 2005-09-27 | 2005-09-27 |  |  |  | 2005-09-27 | 2005-09-27 | 1d | 26d | 0d | start no earlier than 2005-09-27 |
| 798 | 1.7.3 | Ship SWEA FM 2 to UCB | 3d | 2005-10-04 | 2005-10-06 |  |  |  | 2005-10-04 | 2005-10-06 | 3d | 26d | 0d | start no earlier than 2005-10-04 |
| 799 | 1.7.4 | Ship (Hand Carry) SIT FM 2 to UMD | 1d | 2005-10-04 | 2005-10-04 |  |  |  | 2005-10-04 | 2005-10-04 | 1d | 28d | 0d | start no earlier than 2005-10-04 |
| 800 | 1.7.5 | Vacuum Testing of SWEA FM 1 @ UCB | 5d | 2005-09-30 | 2005-10-06 | 796 |  |  | 2005-09-30 | 2005-10-06 | 5d | 24d | 0d |  |
| 801 | 1.7.6 | Vacuum Testing of SIT FM 1 @ UMD | 5d | 2005-09-28 | 2005-10-04 | 797 |  |  | 2005-09-28 | 2005-10-04 | 5d | 26d | 0d |  |
| 802 | 1.7.7 | Vacuum Testing of SWEA FM 2 @ UCB | 5d | 2005-10-07 | 2005-10-13 | 798 |  |  | 2005-10-07 | 2005-10-13 | 5d | 26d |  |  |
| 803 | 1.7.8 | Vacuum Testing of SIT FM 2 @ UMD | 5d | 2005-10-05 | 2005-10-11 | 799 |  |  | 2005-10-05 | 2005-10-11 | 5d | 28d |  |  |
| 804 | 1.7.9 | Ship SWEA FM 1 & 2 to Launch Site for Re-integration to S/C | 3d | 2005-10-07 | 2005-10-11 | 800 |  |  | 2005-10-07 | 2005-10-11 | 3d | 24d | 0d |  |
| 805 | 1.7.10 | Ship SIT FM 1 & 2 to Launch Site for Re-integration to S/C | 3d | 2005-10-05 | 2005-10-07 | 801 |  |  | 2005-10-05 | 2005-10-07 | 3d | 26d | 2d |  |
| 806 | 1.7.11 | Reintegration of SWEA and SIT to S/C (at Launch Site) | 3d | 2005-10-12 | 2005-10-14 | 804, 805 |  |  | 2005-10-12 | 2005-10-14 | 3d | 24d |  |  |
| 807 | 1.7.12 | Target Date for Reintegration to S/C | 1d | 2005-11-18 | 2005-11-18 | 806 |  |  | 2005-11-18 | 2005-11-18 | 1d | 0d |  | must start on 2005-11-18 |

Notes:
- 782: The Accelerator Test Date is still TBD. The actually testing date will depend on availability of the facility at MSU and the readiness of our flight hardware. The date currently reflected in the schedule is therefore subject to change as required.
