# IMPACT Master Schedule

Schedule from MS Project, 2003-02-26 to 2004-11-26, status date 2003-12-31, A marks actual dates.
IMPACT Instrument Suites
NASA GSFC - STEREO
This is the IMPACT Consolidated Schedule. Creation began in October 2003 and was then put on hold and subsequently completed in January 2004. Completed tasks, redundant milestones, contingency blocks and obsolete tasks were deleted from this schedule. / Schedule was baselined on

## Calendars

- Standard: Mon-Fri 08:00-12:00, 13:00-17:00; Sat-Sun off. Exceptions (off unless hours are given): 2003-05-26, 2003-07-04, 2003-09-01, 2003-10-13, 2003-11-11, 2003-11-27, 2003-12-25, 2004-01-01, 2004-01-19, 2004-02-16, 2004-05-31, 2004-09-06, 2004-10-11, 2004-11-11, 2004-11-25.

## Schedule

| ID | WBS | Task | Type | Duration | Start | Finish | Predecessors | Complete | Remaining | Total slack | Free slack | Constraint |
| --- | --- | --- | --- | --- | --- | --- | --- | --- | --- | --- | --- | --- |
| 1 | 1 | **IMPACT - Dave Curtis (UCB) & Lil Reichenthal (GSFC)** |  | 443d | 2003-02-26 A | 2004-11-26 |  | 39% | 268.62d | 0d |  |  |
| 2 | 1.1 | **Suite Deliveries to APL** |  | 25d | 2004-08-31 | 2004-10-06 |  |  |  | 15d |  |  |
| 3 | 1.1.1 | Boom Suite FM 1 Ready for Delivery to APL | milestone | 0d | 2004-09-13 | 2004-09-13 | 358 |  |  | 18d |  | finish no later than 2004-10-07 |
| 4 | 1.1.2 | Boom Suite FM 2 Ready for Delivery to APL | milestone | 0d | 2004-08-31 | 2004-08-31 | 365 |  |  | 40d |  | finish no later than 2004-10-28 |
| 5 | 1.1.3 | SEP Suite FM 1 Ready for Delivery to APL | milestone | 0d | 2004-09-30 | 2004-09-30 | 863, 678, 607 |  |  | 5d |  | finish no later than 2004-10-07 |
| 6 | 1.1.4 | SEP Suite FM 2 Ready for Delivery to APL | milestone | 0d | 2004-10-06 | 2004-10-06 | 871, 681, 610 |  |  | 15d |  | finish no later than 2004-10-28 |
| 7 | 1.2 | **Environmental Testing - PER, Impact Suite EMC, Snapshots of Boom & SEP Suite Test Flows** |  | 187d | 2004-01-14 A | 2004-10-06 |  |  | 186.52d | 34d |  |  |
| 8 | 1.2.1 | **Reviews (PER and TRR's) - TRR Dates are Tentative** |  | 137d | 2004-01-14 A | 2004-07-27 |  | 14% | 117.43d | 84d |  |  |
| 9 | 1.2.1.1 | Instrument PER at UCB |  | 1d | 2004-01-14 A | 2004-01-14 A |  | 100% |  |  |  | start no earlier than 2004-01-14 |
| 10 | 1.2.1.2 | TRR 1 - Prior to FM 1 SEPT Vibration/Acoustics |  | 1d | 2004-02-02 | 2004-02-02 | 38SS-5d |  |  | 208d |  |  |
| 11 | 1.2.1.3 | TRR 2 - Prior to FM 1 IDPU Vibration |  | 1d | 2004-03-08 | 2004-03-08 | 18SS-5d |  |  | 184d |  |  |
| 12 | 1.2.1.4 | TRR 3 - Prior to FM 1 STE-U Thermal Vac/Thermal Balance |  | 1d | 2004-03-10 | 2004-03-10 | 21SS-5d |  |  | 182d |  |  |
| 13 | 1.2.1.5 | TRR 4 - Prior to FM 1 Boom Structure Vibration |  | 1d | 2004-04-08 | 2004-04-08 | 20SS-5d |  |  | 161d |  |  |
| 14 | 1.2.1.6 | TRR 5 - Prior to FM 1 SWEA Vibration |  | 1d | 2004-05-03 | 2004-05-03 | 23SS-5d |  |  | 144d |  |  |
| 15 | 1.2.1.7 | TRR 6 - Prior to FM 2 SEP Suite EMC |  | 1d | 2004-07-27 | 2004-07-27 | 55SS-5d |  |  | 84d |  |  |
| 16 | 1.2.2 | IMPACT Suite FM 1 EMC Testing at UCB |  | 10d | 2004-07-20 | 2004-08-02 | 839, 356 |  |  | 10d | 0d |  |
| 17 | 1.2.3 | **Boom Suite FM 1 Environmental Test Flow Snapshot - UCB** |  | 119d | 2004-03-15 | 2004-08-27 |  |  |  | 61d |  |  |
| 18 | 1.2.3.1 | IDPU Vibration |  | 5d | 2004-03-15 | 2004-03-19 | 177SS |  |  | 175d | 0d |  |
| 19 | 1.2.3.2 | IDPU Thermal Vac |  | 10d | 2004-03-22 | 2004-04-02 | 178SS |  |  | 165d |  |  |
| 20 | 1.2.3.3 | Boom Structure Vibration |  | 4d | 2004-04-15 | 2004-04-20 | 216SS |  |  | 153d | 0d |  |
| 21 | 1.2.3.4 | STE-U Thermal Vac and Thermal Balance |  | 14d | 2004-03-17 | 2004-04-05 | 276SS |  |  | 164d | 0d |  |
| 22 | 1.2.3.5 | Boom Structure Thermal Vac |  | 30d | 2004-04-21 | 2004-06-02 | 217SS |  |  | 123d |  |  |
| 23 | 1.2.3.6 | SWEA/STE Vibration |  | 5d | 2004-05-10 | 2004-05-14 | 342SS |  |  | 135d | 0d |  |
| 24 | 1.2.3.7 | SWEA/STE Thermal Vac and Thermal Balance |  | 14d | 2004-08-03 | 2004-08-20 | 343SS |  |  | 66d |  |  |
| 25 | 1.2.3.8 | IDPU Bake Out |  | 5d | 2004-08-03 | 2004-08-09 | 179SS |  |  | 75d |  |  |
| 26 | 1.2.3.9 | Boom Suite Bake Out |  | 5d | 2004-08-23 | 2004-08-27 | 357SS |  |  | 61d |  |  |

Notes:
- 1: This is the new IMPACT Consolidated Schedule. Creation began in October 2003 and was then put on hold and subsequently completed in January 2004. Completed tasks, redundant milestones, contingency blocks and obsolete tasks were deleted from this schedule. / Schedule was baselined on
- 5: The SEPT and SIT instruments are being delivered directly to APL after their environmental testing at GSFC and seperate from the other SEP Suite instruments (SEP Central, LET and HET).
- 6: The SEPT and SIT instruments are being delivered directly to APL after their environmental testing at GSFC and seperate from the other SEP Suite instruments (SEP Central, LET and HET).
- 9: This is the initial IMPACT PER. Additional TRR's (Test Readiness Reviews) will be scheduled and held as the suite instruments become ready for their environmental testing.

| ID | WBS | Task | Duration | Start | Finish | Predecessors | Total slack | Free slack |
| --- | --- | --- | --- | --- | --- | --- | --- | --- |
| 27 | 1.2.4 | **Boom Suite FM 2 Environmental Test Flow Snapshot - UCB** | 87d | 2004-04-16 | 2004-08-17 |  | 69d |  |
| 28 | 1.2.4.1 | Boom Structure Vibration | 4d | 2004-04-16 | 2004-04-21 | 238SS | 152d |  |
| 29 | 1.2.4.2 | IDPU Vibration | 5d | 2004-05-10 | 2004-05-14 | 182SS | 135d |  |
| 30 | 1.2.4.3 | IDPU Thermal Vac | 10d | 2004-05-17 | 2004-05-28 | 183SS | 125d |  |
| 31 | 1.2.4.4 | Boom Structure Thermal Vac | 30d | 2004-05-12 | 2004-06-23 | 239SS | 108d |  |
| 32 | 1.2.4.5 | SWEA/STE Vibration | 5d | 2004-06-23 | 2004-06-29 | 350SS | 104d |  |
| 33 | 1.2.4.6 | SWEA/STE Thermal Vac | 10d | 2004-06-30 | 2004-07-13 | 351SS | 94d |  |
| 34 | 1.2.4.7 | Boom Suite FM 2 EMC | 5d | 2004-08-04 | 2004-08-10 | 363SS | 74d |  |
| 35 | 1.2.4.8 | IDPU Bake Out | 5d | 2004-08-11 | 2004-08-17 | 184SS | 69d |  |
| 36 | 1.2.4.9 | Boom Suite Bake Out | 5d | 2004-08-11 | 2004-08-17 | 364SS | 69d |  |
| 37 | 1.2.5 | **SEP Suite FM 1 Environmental Test Flow Snapshot** | 162d | 2004-02-09 | 2004-09-24 |  | 42d |  |
| 38 | 1.2.5.1 | SEPT Vibe and Acoustics (in Europe) | 10d | 2004-02-09 | 2004-02-23 | 648SS, 655SS | 194d | 0d |
| 39 | 1.2.5.2 | SEPT Thermal Vac (in Europe) | 10d | 2004-02-24 | 2004-03-08 | 649SS, 656SS | 184d |  |
| 40 | 1.2.5.3 | SEPT Bake Out (in Europe) | 3d | 2004-03-09 | 2004-03-11 | 650SS, 657SS | 181d |  |
| 41 | 1.2.5.4 | SEPT Thermal Balance (at GSFC) | 10d | 2004-08-03 | 2004-08-16 | 651SS, 658SS | 70d |  |
| 42 | 1.2.5.5 | LET/HET/SEP Cen Vibe and Acoustics (at JPL) | 10d | 2004-08-06 | 2004-08-19 | 858SS | 67d |  |
| 43 | 1.2.5.6 | LET/HET/SEP Cen Thermal Balance (at JPL) | 5d | 2004-08-20 | 2004-08-26 | 859SS | 62d |  |
| 44 | 1.2.5.7 | LET/HET/SEP Cen Thermal Vac (at JPL) | 15d | 2004-08-27 | 2004-09-17 | 860SS | 47d |  |
| 45 | 1.2.5.8 | LET/HET/SEP Cen Bake Out (at JPL) | 3d | 2004-09-20 | 2004-09-22 | 863SS | 44d |  |
| 46 | 1.2.5.9 | LET/HET/SEP Cen Accelerator Test (at MSU) | 10d | 2004-07-15 | 2004-07-28 | 873SS | 83d |  |
| 47 | 1.2.5.10 | SIT Vibe and Acoustics (at GSFC) | 10d | 2004-08-12 | 2004-08-25 | 799SS | 63d |  |
| 48 | 1.2.5.11 | SIT Thermal Balance (at GSFC) | 5d | 2004-08-27 | 2004-09-02 | 801SS | 57d |  |
| 49 | 1.2.5.12 | SIT Thermal Vac (at GSFC) | 10d | 2004-09-03 | 2004-09-17 | 802SS | 47d |  |
| 50 | 1.2.5.13 | SIT Bake Out (at GSFC) | 3d | 2004-09-22 | 2004-09-24 | 804SS | 42d |  |

| ID | WBS | Task | Type | Duration | Start | Finish | Predecessors | Complete | Remaining | Total slack | Free slack |
| --- | --- | --- | --- | --- | --- | --- | --- | --- | --- | --- | --- |
| 51 | 1.2.6 | **SEP Suite FM 2 Environmental Test Flow Snapshot** |  | 174d | 2004-02-03 | 2004-10-06 |  |  |  | 34d |  |
| 52 | 1.2.6.1 | SEPT Vibe and Acoustics (in Europe) |  | 10d | 2004-02-03 | 2004-02-17 | 663SS, 670SS |  |  | 198d |  |
| 53 | 1.2.6.2 | SEPT Thermal Vac (in Europe) |  | 10d | 2004-02-18 | 2004-03-02 | 664SS, 671SS |  |  | 188d |  |
| 54 | 1.2.6.3 | SEPT Bake Out (in Europe) |  | 3d | 2004-03-03 | 2004-03-05 | 665SS, 672SS |  |  | 185d |  |
| 55 | 1.2.6.4 | SEP Suite FM 2 EMC (at Caltech) |  | 5d | 2004-08-03 | 2004-08-09 | 865SS |  |  | 75d | 0d |
| 56 | 1.2.6.5 | SEPT Thermal Balance (at GSFC) |  | 10d | 2004-08-03 | 2004-08-16 | 666SS, 673SS |  |  | 70d |  |
| 57 | 1.2.6.6 | LET/HET/SEP Cen Vibe and Acoustics (at JPL) |  | 10d | 2004-08-20 | 2004-09-02 | 866SS |  |  | 57d |  |
| 58 | 1.2.6.7 | LET/HET/SEP Cen Thermal Balance (at JPL) |  | 5d | 2004-09-03 | 2004-09-10 | 867SS |  |  | 52d |  |
| 59 | 1.2.6.8 | LET/HET/SEP Cen Thermal Vac (at JPL) |  | 15d | 2004-09-13 | 2004-10-01 | 868SS |  |  | 37d |  |
| 60 | 1.2.6.9 | LET/HET/SEP Cen Bake Out (at JPL) |  | 3d | 2004-10-04 | 2004-10-06 | 871SS |  |  | 34d |  |
| 61 | 1.2.6.10 | SIT Vibe and Acoustics (at GSFC) |  | 10d | 2004-08-12 | 2004-08-25 | 799SS |  |  | 63d |  |
| 62 | 1.2.6.11 | SIT Thermal Balance (at GSFC) |  | 5d | 2004-08-27 | 2004-09-02 | 801SS |  |  | 57d |  |
| 63 | 1.2.6.12 | SIT Thermal Vac (at GSFC) |  | 10d | 2004-09-03 | 2004-09-17 | 802SS |  |  | 47d |  |
| 64 | 1.2.6.13 | SIT Bake Out (at GSFC) |  | 3d | 2004-09-22 | 2004-09-24 | 804SS |  |  | 42d |  |
| 65 | 1.3 | **Power Converters - UCB** |  | 355d | 2003-02-26 A | 2004-07-21 |  | 44% | 197.65d | 88d |  |
| 66 | 1.3.1 | **Deliveries** |  | 100d | 2003-12-09 A | 2004-04-30 |  | 20% | 80d | 145d |  |
| 67 | 1.3.1.1 | **FM 1** |  | 70d | 2003-12-09 A | 2004-03-19 |  | 40% | 42d | 175d |  |
| 68 | 1.3.1.1.1 | Deliver IDPU FM 1 LVPS (stays at UCB) | milestone | 0d | 2004-03-05 | 2004-03-05 | 122 |  |  | 74d | 0d |
| 69 | 1.3.1.1.2 | Deliver SEP FM 1 LVPS (to Cal Tech) |  | 1d | 2004-03-17 | 2004-03-17 | 126 |  |  | 62d | 20d |
| 70 | 1.3.1.1.3 | Deliver SWEA/STE FM 1 LVPS (stays at UCB) | milestone | 0d | 2004-03-19 | 2004-03-19 | 130 |  |  | 49d | 0d |
| 71 | 1.3.1.1.4 | Deliver PLASTIC FM 1 LVPS (to UNH) |  | 2d | 2004-03-04 | 2004-03-05 | 134 |  |  | 185d |  |
| 72 | 1.3.1.1.5 | Deliver SIT FM 1 HVPS (to UMD) |  | 2d | 2003-12-09 A | 2003-12-10 A | 136 | 100% |  |  |  |
| 73 | 1.3.1.2 | **FM 2** |  | 28d | 2004-03-24 | 2004-04-30 |  |  |  | 34d |  |
| 74 | 1.3.1.2.1 | Deliver IDPU FM 2 LVPS (stays at UCB) | milestone | 0d | 2004-04-30 | 2004-04-30 | 143 |  |  | 40d | 0d |
| 75 | 1.3.1.2.2 | Deliver SEP FM 2 LVPS (to Cal Tech) |  | 1d | 2004-04-19 | 2004-04-19 | 147 |  |  | 77d | 72d |
| 76 | 1.3.1.2.3 | Deliver SWEA/STE FM 2 LVPS (stays at UCB) | milestone | 0d | 2004-04-26 | 2004-04-26 | 151 |  |  | 49d | 0d |
| 77 | 1.3.1.2.4 | Deliver PLASTIC FM 2 LVPS (to UNH) |  | 2d | 2004-04-12 | 2004-04-13 | 155 |  |  | 158d |  |
| 78 | 1.3.1.2.5 | Deliver SIT FM 2 HVPS (to UMD) |  | 2d | 2004-03-24 | 2004-03-25 | 159 |  |  | 34d | 0d |

| ID | WBS | Task | Duration | Start | Finish | Predecessors | Complete | Remaining | Total slack | Free slack | Constraint |
| --- | --- | --- | --- | --- | --- | --- | --- | --- | --- | --- | --- |
| 79 | 1.3.2 | **Remaining Flight Procurements** | 44d | 2003-10-24 A | 2003-12-29 |  | 75% | 11d | 74d |  |  |
| 80 | 1.3.2.1 | Procure IDPU Flight Printed Wiring Board | 10d | 2003-12-15 | 2003-12-29 | 86 |  |  | 74d | 0d | start no earlier than 2003-12-15 |
| 81 | 1.3.2.2 | Procure SEP Flight Printed Wiring Board | 10d | 2003-11-24 A | 2003-12-08 A | 87 | 100% |  |  |  | start no earlier than 2003-11-24 |
| 82 | 1.3.2.3 | Procure SWEA Flight Printed Wiring Board | 10d | 2003-12-04 A | 2003-12-17 A | 88 | 100% |  |  |  |  |
| 83 | 1.3.2.4 | Procure PLASTIC Flight Printed Wiring Board | 10d | 2003-10-24 A | 2003-11-06 A |  | 100% |  |  |  | start no earlier than 2003-10-24 |
| 84 | 1.3.3 | **Fabrication** | 226d | 2003-02-26 A | 2004-01-20 |  | 86% | 31.81d | 171d |  |  |
| 85 | 1.3.3.1 | **FM 1 & FM 2** | 195d | 2003-02-26 A | 2003-12-03 A |  | 100% |  |  |  |  |
| 86 | 1.3.3.1.1 | Re-layout IDPU LVPS Flight Printed Wiring Board | 186d | 2003-02-26 A | 2003-11-19 A |  | 100% |  |  |  | start no earlier than 2003-02-26 |
| 87 | 1.3.3.1.2 | Re-layout SEP LVPS Flight Printed Wiring Board | 32d | 2003-09-24 A | 2003-11-07 A |  | 100% |  |  |  | start no earlier than 2003-09-24 |
| 88 | 1.3.3.1.3 | Re-layout SWEA LVPS Flight Printed Wiring Board | 5d | 2003-11-26 A | 2003-12-03 A |  | 100% |  |  |  | start no earlier than 2003-11-26 |
| 89 | 1.3.3.2 | **FM 1** | 45d | 2003-09-29 A | 2003-12-03 A |  | 100% |  |  |  |  |
| 90 | 1.3.3.2.1 | Wind IDPU LVPS FM 1 Magnets | 10d | 2003-10-17 A | 2003-10-30 A |  | 100% |  |  |  | start no earlier than 2003-10-17 |
| 91 | 1.3.3.2.2 | Wind SEP LVPS FM 1 Magnets | 15d | 2003-09-29 A | 2003-10-20 A |  | 100% |  |  |  | start no earlier than 2003-09-29 |
| 92 | 1.3.3.2.3 | Wind SWEA LVPS FM 1 Magnets | 5d | 2003-11-26 A | 2003-12-03 A |  | 100% |  |  |  | start no earlier than 2003-11-26 |
| 93 | 1.3.3.2.4 | Wind PLASTIC LVPS FM 1 Magnets | 45d | 2003-09-29 A | 2003-12-03 A |  | 100% |  |  |  | start no earlier than 2003-09-29 |
| 94 | 1.3.3.3 | **FM 2** | 15d | 2003-12-29 A | 2004-01-20 |  | 30% | 10.5d | 171d |  |  |
| 95 | 1.3.3.3.1 | Wind HVPS FM 2 Magnets | 15d | 2003-12-29 A | 2004-01-20 |  | 30% | 10.5d | 34d | 0d | start no earlier than 2003-12-29 |
| 96 | 1.3.3.3.2 | Wind IDPU LVPS FM 2 Magnets | 15d | 2003-12-29 A | 2004-01-20 | 95SS | 30% | 10.5d | 67d | 27d |  |
| 97 | 1.3.3.3.3 | Wind SEP LVPS FM 2 Magnets | 15d | 2003-12-29 A | 2004-01-20 | 95SS | 30% | 10.5d | 94d | 17d |  |
| 98 | 1.3.3.3.4 | Wind SWEA LVPS FM 2 Magnets | 15d | 2003-12-29 A | 2004-01-20 | 95SS | 30% | 10.5d | 72d | 23d |  |
| 99 | 1.3.3.3.5 | Wind PLASTIC LVPS FM 2 Magnets | 15d | 2003-12-29 A | 2004-01-20 | 95SS | 30% | 10.5d | 171d | 13d |  |
| 100 | 1.3.4 | **Assembly** | 57d | 2003-12-29 A | 2004-03-19 |  | 2% | 55.67d | 143d |  |  |
| 101 | 1.3.4.1 | **FM 1** | 27d | 2003-12-29 A | 2004-02-05 |  | 5% | 25.55d | 173d |  |  |
| 102 | 1.3.4.1.1 | Assemble IDPU FM 1 LVPS | 12d | 2004-01-06 | 2004-01-22 | 90, 114 |  |  | 74d | 0d |  |
| 103 | 1.3.4.1.2 | Assemble SEP FM 1 LVPS | 15d | 2004-01-12 | 2004-02-02 | 115, 91 |  |  | 62d | 0d | start no earlier than 2004-01-12 |
| 104 | 1.3.4.1.3 | Assemble SWEA FM 1 LVPS | 14d | 2004-01-16 | 2004-02-05 | 92, 116 |  |  | 49d | 0d | start no earlier than 2004-01-12 |
| 105 | 1.3.4.1.4 | Assemble PLASTIC FM 1 LVPS | 15d | 2003-12-29 A | 2004-01-20 | 117, 93 | 20% | 12d | 185d | 0d | start no earlier than 2003-12-29 |

| ID | WBS | Task | Duration | Start | Finish | Predecessors | Complete | Remaining | Total slack | Free slack | Constraint |
| --- | --- | --- | --- | --- | --- | --- | --- | --- | --- | --- | --- |
| 106 | 1.3.4.2 | **FM 2** | 42d | 2004-01-21 | 2004-03-19 |  |  |  | 34d |  |  |
| 107 | 1.3.4.2.1 | Assemble IDPU FM 2 LVPS | 15d | 2004-03-01 | 2004-03-19 | 96 |  |  | 40d | 0d | start no earlier than 2004-03-01 |
| 108 | 1.3.4.2.2 | Assemble SEP FM 2 LVPS | 15d | 2004-02-13 | 2004-03-05 | 97 |  |  | 77d | 0d | start no earlier than 2004-02-13 |
| 109 | 1.3.4.2.3 | Assemble SWEA FM 2 LVPS | 15d | 2004-02-24 | 2004-03-15 | 98 |  |  | 49d | 0d | start no earlier than 2004-02-24 |
| 110 | 1.3.4.2.4 | Assemble PLASTIC FM 2 LVPS | 14d | 2004-02-09 | 2004-02-27 | 99 |  |  | 158d | 0d | start no earlier than 2004-02-09 |
| 111 | 1.3.4.2.5 | Assemble SIT FM 2 HVPS | 14d | 2004-01-21 | 2004-02-09 | 95 |  |  | 34d | 0d |  |
| 112 | 1.3.5 | **Testing** | 182d | 2003-10-31 A | 2004-07-21 |  | 11% | 162.64d | 88d |  |  |
| 113 | 1.3.5.1 | **FM 1 & FM 2** | 36d | 2003-11-24 A | 2004-01-15 |  | 53% | 17.05d | 66d |  |  |
| 114 | 1.3.5.1.1 | Coupon Test IDPU Flight Printed Wiring Board | 4d | 2003-12-30 | 2004-01-05 | 80 |  |  | 74d | 0d |  |
| 115 | 1.3.5.1.2 | Coupon Test SEP Flight Printed Wiring Board | 5d | 2003-12-09 A | 2003-12-15 A | 81 | 100% |  |  |  |  |
| 116 | 1.3.5.1.3 | Coupon Test SWEA Flight Printed Wiring Board | 5d | 2004-01-09 | 2004-01-15 | 82 |  |  | 49d | 0d | start no earlier than 2004-01-09 |
| 117 | 1.3.5.1.4 | Coupon Test PLASTIC Flight Printed Wiring Board | 5d | 2003-11-24 A | 2003-12-01 A | 83 | 100% |  |  |  | start no earlier than 2003-11-24 |
| 118 | 1.3.5.2 | **FM 1** | 182d | 2003-10-31 A | 2004-07-21 |  | 16% | 153.56d | 88d |  |  |
| 119 | 1.3.5.2.1 | **IDPU** | 30d | 2004-01-23 | 2004-03-05 |  |  |  | 74d |  |  |
| 120 | 1.3.5.2.1.1 | Test IDPU FM 1 LVPS | 15d | 2004-01-23 | 2004-02-12 | 102 |  |  | 74d | 0d |  |
| 121 | 1.3.5.2.1.2 | Coat & Stake IDPU LVPS FM 1 Boards | 5d | 2004-02-13 | 2004-02-20 | 120 |  |  | 74d | 0d |  |
| 122 | 1.3.5.2.1.3 | Retest IDPU LVPS FM 1 Boards | 10d | 2004-02-23 | 2004-03-05 | 121 |  |  | 74d | 0d |  |
| 123 | 1.3.5.2.2 | **SEP** | 30d | 2004-02-03 | 2004-03-16 |  |  |  | 62d |  |  |
| 124 | 1.3.5.2.2.1 | Test SEP FM 1 LVPS | 15d | 2004-02-03 | 2004-02-24 | 103 |  |  | 62d | 0d |  |
| 125 | 1.3.5.2.2.2 | Coat & Stake SEP LVPS FM 1 Boards | 5d | 2004-02-25 | 2004-03-02 | 124 |  |  | 62d | 0d |  |
| 126 | 1.3.5.2.2.3 | Retest SEP LVPS FM 1 Boards | 10d | 2004-03-03 | 2004-03-16 | 125, 377 |  |  | 62d | 0d |  |
| 127 | 1.3.5.2.3 | **SWEA** | 30d | 2004-02-06 | 2004-03-19 |  |  |  | 49d |  |  |
| 128 | 1.3.5.2.3.1 | Test SWEA FM 1 LVPS | 15d | 2004-02-06 | 2004-02-27 | 104 |  |  | 49d | 0d |  |
| 129 | 1.3.5.2.3.2 | Coat & Stake SWEA LVPS FM 1 Boards | 5d | 2004-03-01 | 2004-03-05 | 128 |  |  | 49d | 0d |  |
| 130 | 1.3.5.2.3.3 | Retest SWEA LVPS FM 1 Boards | 10d | 2004-03-08 | 2004-03-19 | 129 |  |  | 49d | 0d |  |

| ID | WBS | Task | Duration | Start | Finish | Predecessors | Complete | Remaining | Total slack | Free slack | Constraint |
| --- | --- | --- | --- | --- | --- | --- | --- | --- | --- | --- | --- |
| 131 | 1.3.5.2.4 | **PLASTIC** | 30d | 2004-01-21 | 2004-03-03 |  |  |  | 185d |  |  |
| 132 | 1.3.5.2.4.1 | Test PLASTIC FM 1 LVPS | 15d | 2004-01-21 | 2004-02-10 | 105 |  |  | 185d | 0d |  |
| 133 | 1.3.5.2.4.2 | Coat & Stake PLASTIC LVPS FM 1 Boards | 5d | 2004-02-11 | 2004-02-18 | 132 |  |  | 185d | 0d |  |
| 134 | 1.3.5.2.4.3 | Retest PLASTIC LVPS FM 1 Boards | 10d | 2004-02-19 | 2004-03-03 | 133 |  |  | 185d | 0d |  |
| 135 | 1.3.5.2.5 | **SIT** | 182d | 2003-10-31 A | 2004-07-21 |  | 63% | 68.25d | 88d |  |  |
| 136 | 1.3.5.2.5.1 | Test SIT FM 1 HVPS | 25d | 2003-10-31 A | 2003-12-08 A |  | 100% |  |  |  | start no earlier than 2003-10-31 |
| 137 | 1.3.5.2.5.2 | Coat & Stake SIT FM 1 HVPS Boards (at UMD) | 5d | 2004-07-01 | 2004-07-07 | 772SS |  |  | 88d | 0d |  |
| 138 | 1.3.5.2.5.3 | Retest SIT FM 1 HVPS Boards (at UMD) | 10d | 2004-07-08 | 2004-07-21 | 137 |  |  | 88d |  |  |
| 139 | 1.3.5.3 | **FM 2** | 58d | 2004-02-10 | 2004-04-30 |  |  |  | 34d |  |  |
| 140 | 1.3.5.3.1 | **IDPU** | 30d | 2004-03-22 | 2004-04-30 |  |  |  | 40d |  |  |
| 141 | 1.3.5.3.1.1 | Test IDPU FM 2 LVPS | 15d | 2004-03-22 | 2004-04-09 | 107 |  |  | 40d | 0d |  |
| 142 | 1.3.5.3.1.2 | Coat & Stake IDPU LVPS FM 2 Boards | 5d | 2004-04-12 | 2004-04-16 | 141 |  |  | 40d | 0d |  |
| 143 | 1.3.5.3.1.3 | Retest IDPU LVPS FM 2 Boards | 10d | 2004-04-19 | 2004-04-30 | 142 |  |  | 40d | 0d |  |
| 144 | 1.3.5.3.2 | **SEP** | 30d | 2004-03-08 | 2004-04-16 |  |  |  | 77d |  |  |
| 145 | 1.3.5.3.2.1 | Test SEP FM 2 LVPS | 15d | 2004-03-08 | 2004-03-26 | 108 |  |  | 77d | 0d |  |
| 146 | 1.3.5.3.2.2 | Coat & Stake SEP LVPS FM 2 Boards | 5d | 2004-03-29 | 2004-04-02 | 145 |  |  | 77d | 0d |  |
| 147 | 1.3.5.3.2.3 | Retest SEP LVPS FM 2 Boards | 10d | 2004-04-05 | 2004-04-16 | 146, 377 |  |  | 77d | 0d |  |
| 148 | 1.3.5.3.3 | **SWEA** | 30d | 2004-03-16 | 2004-04-26 |  |  |  | 49d |  |  |
| 149 | 1.3.5.3.3.1 | Test SWEA FM 2 LVPS | 15d | 2004-03-16 | 2004-04-05 | 109 |  |  | 49d | 0d |  |
| 150 | 1.3.5.3.3.2 | Coat & Stake SWEA LVPS FM 2 Boards | 5d | 2004-04-06 | 2004-04-12 | 149 |  |  | 49d | 0d |  |
| 151 | 1.3.5.3.3.3 | Retest SWEA LVPS FM 2 Boards | 10d | 2004-04-13 | 2004-04-26 | 150 |  |  | 49d | 0d |  |
| 152 | 1.3.5.3.4 | **PLASTIC** | 30d | 2004-03-01 | 2004-04-09 |  |  |  | 158d |  |  |
| 153 | 1.3.5.3.4.1 | Test PLASTIC FM 2 LVPS | 15d | 2004-03-01 | 2004-03-19 | 110 |  |  | 158d | 0d |  |
| 154 | 1.3.5.3.4.2 | Coat & Stake PLASTIC LVPS FM 2 Boards | 5d | 2004-03-22 | 2004-03-26 | 153 |  |  | 158d | 0d |  |
| 155 | 1.3.5.3.4.3 | Retest PLASTIC LVPS FM 2 Boards | 10d | 2004-03-29 | 2004-04-09 | 154 |  |  | 158d | 0d |  |

| ID | WBS | Task | Type | Duration | Start | Finish | Predecessors | Complete | Remaining | Total slack | Free slack | Constraint |
| --- | --- | --- | --- | --- | --- | --- | --- | --- | --- | --- | --- | --- |
| 156 | 1.3.5.3.5 | **SIT** |  | 30d | 2004-02-10 | 2004-03-23 |  |  |  | 34d |  |  |
| 157 | 1.3.5.3.5.1 | Test SIT FM 2 HVPS |  | 15d | 2004-02-10 | 2004-03-02 | 111 |  |  | 34d | 0d |  |
| 158 | 1.3.5.3.5.2 | Coat & Stake SIT FM 2 HVPS Boards |  | 5d | 2004-03-03 | 2004-03-09 | 157 |  |  | 34d | 0d |  |
| 159 | 1.3.5.3.5.3 | Retest SIT FM 2 HVPS Boards |  | 10d | 2004-03-10 | 2004-03-23 | 158 |  |  | 34d | 0d |  |
| 160 | 1.4 | **IDPU - UCB** |  | 340d | 2003-05-05 A | 2004-09-07 |  | 59% | 141.03d | 55d |  |  |
| 161 | 1.4.1 | **Deliveries** |  | 78d | 2004-02-09 | 2004-05-28 |  |  |  | 112d |  |  |
| 162 | 1.4.1.1 | IDPU FM 1 Complete (to CIT for SEP I&T, then to UCB for Boom I&T, Suite EMC, BO & Final Boom I&T) | milestone | 0d | 2004-04-02 | 2004-04-02 | 178 |  |  | 74d | 55d |  |
| 163 | 1.4.1.2 | IDPU FM 2 Complete (to CIT for SEP I&T, then to UCB for Boom I&T, Boom EMC, BO & Final Boom I&T) | milestone | 0d | 2004-05-28 | 2004-05-28 | 183 |  |  | 40d | 35d |  |
| 164 | 1.4.1.3 | Deliver IDPU S/W Build 3 (to UNH) | milestone | 0d | 2004-02-09 | 2004-02-09 | 167 |  |  | 203d |  |  |
| 165 | 1.4.2 | **Flight Software** |  | 192d | 2003-05-05 A | 2004-02-09 |  | 81% | 36.72d | 108d |  |  |
| 166 | 1.4.2.1 | IDPU S/W Build #2.5 |  | 131d | 2003-05-05 A | 2003-11-07 A |  | 100% |  |  |  | start no earlier than 2003-05-05 |
| 167 | 1.4.2.2 | IDPU S/W Build #3 |  | 120d | 2003-08-15 A | 2004-02-09 |  | 60% | 48d | 108d | 0d | start no earlier than 2003-08-15 |
| 168 | 1.4.3 | **GSE** |  | 301d | 2003-06-30 A | 2004-09-07 |  | 50% | 149.32d | 55d |  |  |
| 169 | 1.4.3.1 | STE Science Display |  | 27d | 2003-10-23 A | 2003-12-02 A |  | 100% |  |  |  | start no earlier than 2003-10-23 |
| 170 | 1.4.3.2 | SWEA Science Display |  | 140d | 2003-06-30 A | 2004-01-21 |  | 62% | 53.2d | 216d |  | start no earlier than 2003-06-30 |
| 171 | 1.4.3.3 | GSE Continued Development |  | 291d | 2003-07-15 A | 2004-09-07 |  | 40% | 174d | 55d |  | start no earlier than 2003-07-15 |
| 172 | 1.4.4 | **Integration & Test** |  | 218d | 2003-10-07 A | 2004-08-17 |  | 33% | 145.33d | 40d |  |  |
| 173 | 1.4.4.1 | IDPU DCB FM 2 Board Level Testing |  | 15d | 2003-10-07 A | 2003-10-28 A |  | 100% |  |  |  | start no earlier than 2003-10-07 |
| 174 | 1.4.4.2 | IDPU DCB Clean/Stake/Coat (FM 1 & FM 2) |  | 10d | 2003-12-26 A | 2004-01-09 A | 173 | 100% |  |  |  | start no earlier than 2003-12-26 |
| 175 | 1.4.4.3 | **FM 1** |  | 110d | 2004-03-08 | 2004-08-09 |  |  |  | 32d |  |  |
| 176 | 1.4.4.3.1 | IDPU FM 1 I & T |  | 5d | 2004-03-08 | 2004-03-12 | 166, 68, 243, 287, 174 |  |  | 74d | 0d |  |
| 177 | 1.4.4.3.2 | IDPU FM 1 Vibration |  | 5d | 2004-03-15 | 2004-03-19 | 176 |  |  | 74d | 0d |  |
| 178 | 1.4.4.3.3 | IDPU FM 1 Thermal Vacuum |  | 10d | 2004-03-22 | 2004-04-02 | 177 |  |  | 74d | 0d |  |
| 179 | 1.4.4.3.4 | IDPU FM 1 Bakeout |  | 5d | 2004-08-03 | 2004-08-09 | 16, 178 |  |  | 32d | 0d |  |

| ID | WBS | Task | Type | Duration | Start | Finish | Predecessors | Complete | Remaining | Total slack | Free slack | Constraint |
| --- | --- | --- | --- | --- | --- | --- | --- | --- | --- | --- | --- | --- |
| 180 | 1.4.4.4 | **FM 2** |  | 76d | 2004-05-03 | 2004-08-17 |  |  |  | 40d |  |  |
| 181 | 1.4.4.4.1 | IDPU FM 2 I & T |  | 5d | 2004-05-03 | 2004-05-07 | 74, 244, 288, 173, 174 |  |  | 40d | 0d |  |
| 182 | 1.4.4.4.2 | IDPU FM 2 Vibration |  | 5d | 2004-05-10 | 2004-05-14 | 181 |  |  | 40d | 0d |  |
| 183 | 1.4.4.4.3 | IDPU FM 2 Thermal Vacuum |  | 10d | 2004-05-17 | 2004-05-28 | 167, 182 |  |  | 40d | 0d |  |
| 184 | 1.4.4.4.4 | IDPU FM 2 Bakeout |  | 5d | 2004-08-11 | 2004-08-17 | 183, 364SS |  |  | 40d | 0d |  |
| 185 | 1.5 | **BOOM Suite - UCB** |  | 304d | 2003-07-01 A | 2004-09-13 |  | 56% | 132.78d | 32d |  |  |
| 186 | 1.5.1 | **BOOM Structure - UCB** |  | 187d | 2003-09-10 A | 2004-06-08 |  | 59% | 77.56d | 74d |  |  |
| 187 | 1.5.1.1 | **Deliveries** |  | 104d | 2004-01-09 A | 2004-06-08 |  |  | 104d | 74d |  |  |
| 188 | 1.5.1.1.1 | Protoflight Boom available for I&T (if needed) | milestone | 0d | 2004-01-09 A | 2004-01-09 A | 193 | 100% |  |  |  |  |
| 189 | 1.5.1.1.2 | Deliver Boom Structure FM 1 (stays at UCB for Boom Suite FM 1 I&T) | milestone | 0d | 2004-05-17 | 2004-05-17 | 218 |  |  | 48d | 0d |  |
| 190 | 1.5.1.1.3 | Deliver Boom Structure FM 2 (stays at UCB for Boom Suite FM 2 I&T) | milestone | 0d | 2004-06-08 | 2004-06-08 | 240 |  |  | 74d | 25d |  |
| 191 | 1.5.1.2 | **Protoflight** |  | 79d | 2003-09-16 A | 2004-01-09 A |  | 100% |  |  |  |  |
| 192 | 1.5.1.2.1 | Protoflight Boom Post Environmental Deployment Test |  | 35d | 2003-09-16 A | 2003-11-04 A |  | 100% |  |  |  | start no earlier than 2003-09-16 |
| 193 | 1.5.1.2.2 | Document Protoflight Boom Test Results |  | 44d | 2003-11-05 A | 2004-01-09 A | 192 | 100% |  |  |  |  |
| 194 | 1.5.1.3 | **Flight Procurements** |  | 40d | 2003-09-10 A | 2003-11-05 A |  | 100% |  |  |  |  |
| 195 | 1.5.1.3.1 | Receive and Inspect Flight Boom Structure Tubes (FM 1) |  | 32d | 2003-09-10 A | 2003-10-24 A |  | 100% |  |  |  | start no earlier than 2003-09-10 |
| 196 | 1.5.1.3.2 | Receive and Inspect Flight Boom Structure Tubes (FM 2) |  | 40d | 2003-09-10 A | 2003-11-05 A |  | 100% |  |  |  | start no earlier than 2003-09-10 |
| 197 | 1.5.1.4 | **FM 1** |  | 159d | 2003-09-29 A | 2004-05-17 |  | 46% | 85.41d | 48d |  |  |
| 198 | 1.5.1.4.1 | **Telescoping** |  | 81d | 2003-10-27 A | 2004-02-24 |  | 59% | 33.29d | 50d |  |  |
| 199 | 1.5.1.4.1.1 | **Fabrication, Assembly & Test** |  | 81d | 2003-10-27 A | 2004-02-24 |  | 59% | 33.29d | 50d |  |  |
| 200 | 1.5.1.4.1.1.1 | Machine FM 1 Boom Structure Tubes as necessary |  | 5d | 2003-10-27 A | 2003-10-31 A | 195 | 100% |  |  |  |  |
| 201 | 1.5.1.4.1.1.2 | Machine FM 1 Boom Structure Parts (Rings) |  | 38d | 2003-11-07 A | 2004-01-05 A | 195FF+47d | 100% |  |  |  |  |
| 202 | 1.5.1.4.1.1.3 | Assemble FM 1 Boom Structure Telescoping Assembly |  | 20d | 2004-01-12 | 2004-02-09 | 200, 201 |  |  | 50d | 0d | start no earlier than 2004-01-12 |
| 203 | 1.5.1.4.1.1.4 | Test FM 1 Boom Structure Telescoping Assembly |  | 10d | 2004-02-10 | 2004-02-24 | 202 |  |  | 50d | 2d |  |

| ID | WBS | Task | Duration | Start | Finish | Predecessors | Complete | Remaining | Total slack | Free slack | Constraint |
| --- | --- | --- | --- | --- | --- | --- | --- | --- | --- | --- | --- |
| 204 | 1.5.1.4.2 | **Harness** | 102d | 2003-09-29 A | 2004-02-26 |  | 41% | 59.88d | 48d |  |  |
| 205 | 1.5.1.4.2.1 | **Fabrication** | 72d | 2003-09-29 A | 2004-01-13 |  | 59% | 29.88d | 48d |  |  |
| 206 | 1.5.1.4.2.1.1 | Machine FM 1 Harness Parts | 72d | 2003-09-29 A | 2004-01-13 |  | 59% | 29.88d | 48d | 0d | start no earlier than 2003-09-29 |
| 207 | 1.5.1.4.2.2 | **Assembly & Test** | 30d | 2004-01-14 | 2004-02-26 |  |  |  | 48d |  |  |
| 208 | 1.5.1.4.2.2.1 | Assemble FM 1 Harness subassembly | 20d | 2004-01-14 | 2004-02-11 | 206 |  |  | 48d | 0d |  |
| 209 | 1.5.1.4.2.2.2 | FM1 Harness Test | 10d | 2004-02-12 | 2004-02-26 | 208 |  |  | 48d | 0d |  |
| 210 | 1.5.1.4.3 | **Mounting** | 38d | 2003-09-29 A | 2003-11-21 A |  | 100% |  |  |  |  |
| 211 | 1.5.1.4.3.1 | FM 1Boom Structure Mounting Fabrication | 28d | 2003-09-29 A | 2003-11-06 A |  | 100% |  |  |  | start no earlier than 2003-09-29 |
| 212 | 1.5.1.4.3.2 | FM 1Boom Structure Mounting Assembly | 10d | 2003-11-07 A | 2003-11-21 A | 211 | 100% |  |  |  |  |
| 213 | 1.5.1.4.4 | **Integration & Test** | 57d | 2004-02-27 | 2004-05-17 |  |  |  | 48d |  |  |
| 214 | 1.5.1.4.4.1 | Integrate FM 1 Boom Structure subassemblies | 20d | 2004-02-27 | 2004-03-25 | 203, 209 |  |  | 48d | 0d |  |
| 215 | 1.5.1.4.4.2 | FM 1 Boom Structure Deployment Test | 10d | 2004-03-26 | 2004-04-08 | 214 |  |  | 48d | 0d |  |
| 216 | 1.5.1.4.4.3 | FM 1 Boom Structure Vibration Testing Completed | 4d | 2004-04-15 | 2004-04-20 | 215, 354 |  |  | 48d | 0d |  |
| 217 | 1.5.1.4.4.4 | FM 1 Boom Structure Themal Vac Testing Completed | 15d | 2004-04-21 | 2004-05-11 | 216 |  |  | 48d | 0d |  |
| 218 | 1.5.1.4.4.5 | FM 1 Boom Structure Post Environmental Deployment Test Completed | 4d | 2004-05-12 | 2004-05-17 | 217 |  |  | 48d | 0d |  |
| 219 | 1.5.1.5 | **FM 2** | 174d | 2003-09-29 A | 2004-06-08 |  | 47% | 91.4d | 74d |  |  |
| 220 | 1.5.1.5.1 | **Telescoping** | 73d | 2003-11-06 A | 2004-02-24 |  | 62% | 27.72d | 91d |  |  |
| 221 | 1.5.1.5.1.1 | **Fabrication, Assembly & Test** | 73d | 2003-11-06 A | 2004-02-24 |  | 62% | 27.72d | 91d |  |  |
| 222 | 1.5.1.5.1.1.1 | Machine FM 2 Boom Structure Tubes as necessary | 11d | 2003-11-06 A | 2003-11-21 A | 196 | 100% |  |  |  |  |
| 223 | 1.5.1.5.1.1.2 | Machine FM 2 Boom Structure Parts (Rings) | 38d | 2003-11-07 A | 2004-01-05 A | 201SS | 100% |  |  |  |  |
| 224 | 1.5.1.5.1.1.3 | Assemble FM 2 Boom Structure Telescoping Assembly | 20d | 2004-01-12 | 2004-02-09 | 222, 223 |  |  | 91d | 0d | start no earlier than 2004-01-12 |
| 225 | 1.5.1.5.1.1.4 | Test FM 2 Boom Structure Telescoping Assembly | 10d | 2004-02-10 | 2004-02-24 | 224 |  |  | 91d | 2d |  |
| 226 | 1.5.1.5.2 | **Harness** | 102d | 2003-09-29 A | 2004-02-26 |  | 41% | 59.88d | 89d |  |  |
| 227 | 1.5.1.5.2.1 | **Fabrication** | 72d | 2003-09-29 A | 2004-01-13 |  | 59% | 29.88d | 89d |  |  |
| 228 | 1.5.1.5.2.1.1 | Machine FM 2 Harness Parts | 72d | 2003-09-29 A | 2004-01-13 | 206SS | 59% | 29.88d | 89d | 0d |  |

| ID | WBS | Task | Duration | Start | Finish | Predecessors | Complete | Remaining | Total slack | Free slack | Constraint |
| --- | --- | --- | --- | --- | --- | --- | --- | --- | --- | --- | --- |
| 229 | 1.5.1.5.2.2 | **Assembly & Test** | 30d | 2004-01-14 | 2004-02-26 |  |  |  | 89d |  |  |
| 230 | 1.5.1.5.2.2.1 | Assemble FM 2 Harness subassembly | 20d | 2004-01-14 | 2004-02-11 | 228 |  |  | 89d | 0d |  |
| 231 | 1.5.1.5.2.2.2 | FM 2 Harness Test | 10d | 2004-02-12 | 2004-02-26 | 230 |  |  | 89d | 0d |  |
| 232 | 1.5.1.5.3 | **Mounting** | 38d | 2003-09-29 A | 2003-11-21 A |  | 100% |  |  |  |  |
| 233 | 1.5.1.5.3.1 | FM 2 Boom Structure Mountings Fabrication | 28d | 2003-09-29 A | 2003-11-06 A | 211SS | 100% |  |  |  |  |
| 234 | 1.5.1.5.3.2 | FM 2 Boom Structure Mountings Assembly | 10d | 2003-11-07 A | 2003-11-21 A | 233 | 100% |  |  |  |  |
| 235 | 1.5.1.5.4 | **Integration & Test** | 72d | 2004-02-27 | 2004-06-08 |  |  |  | 74d |  |  |
| 236 | 1.5.1.5.4.1 | Integrate FM 2 Boom Structure subassemblies | 20d | 2004-02-27 | 2004-03-25 | 225, 231 |  |  | 89d | 0d |  |
| 237 | 1.5.1.5.4.2 | FM 2 Boom Structure Deployment Test | 10d | 2004-03-26 | 2004-04-08 | 236 |  |  | 89d | 1d |  |
| 238 | 1.5.1.5.4.3 | FM 2 Boom Structure Vibration Test | 4d | 2004-04-16 | 2004-04-21 | 237, 360 |  |  | 88d | 0d |  |
| 239 | 1.5.1.5.4.4 | FM 2 Boom Structure Themal Vac Testing | 15d | 2004-05-12 | 2004-06-02 | 238, 217 |  |  | 74d | 0d |  |
| 240 | 1.5.1.5.4.5 | FM 2 Boom Structure Post Environmental Deployment Test | 4d | 2004-06-03 | 2004-06-08 | 239 |  |  | 74d | 0d |  |
| 241 | 1.5.2 | **MAG - GSFC** | 47d | 2004-01-09 | 2004-03-17 |  |  |  | 72d |  |  |
| 242 | 1.5.2.1 | **Deliveries** | 22d | 2004-02-17 | 2004-03-17 |  |  |  | 72d |  |  |
| 243 | 1.5.2.1.1 | Deliver MAG FM 1 (to UCB for IDPU/BOOM Suite FM 1 I&T) | 2d | 2004-02-17 | 2004-02-18 | 247 |  |  | 84d | 12d |  |
| 244 | 1.5.2.1.2 | Deliver MAG FM 2 (to UCB for IDPU/BOOM Suite FM 2 I&T) | 2d | 2004-03-16 | 2004-03-17 | 250 |  |  | 72d | 17d |  |
| 245 | 1.5.2.2 | **FM 1** | 25d | 2004-01-09 | 2004-02-13 |  |  |  | 84d |  |  |
| 246 | 1.5.2.2.1 | FM 1 MAG Testing | 10d | 2004-01-09 | 2004-01-23 |  |  |  | 84d | 0d | start no earlier than 2004-01-09 |
| 247 | 1.5.2.2.2 | MAG FM 1 Calibration | 15d | 2004-01-26 | 2004-02-13 | 246 |  |  | 84d | 0d |  |
| 248 | 1.5.2.3 | **FM 2** | 25d | 2004-02-09 | 2004-03-15 |  |  |  | 72d |  |  |
| 249 | 1.5.2.3.1 | FM 2 MAG Testing | 10d | 2004-02-09 | 2004-02-23 |  |  |  | 72d | 0d | start no earlier than 2004-02-09 |
| 250 | 1.5.2.3.2 | MAG FM 2 Calibration | 15d | 2004-02-24 | 2004-03-15 | 249 |  |  | 72d | 0d |  |
| 251 | 1.5.3 | **SWEA - CESR** | 79d | 2003-12-08 A | 2004-03-31 |  | 6% | 74.53d | 77d |  |  |
| 252 | 1.5.3.1 | **Deliveries** | 79d | 2003-12-08 A | 2004-03-31 |  | 50% | 39.5d | 77d |  |  |
| 253 | 1.5.3.1.1 | SWEA FM 1 Delivery to UCB | 3d | 2003-12-08 A | 2003-12-10 A |  | 100% |  |  |  | start no earlier than 2003-12-08 |
| 254 | 1.5.3.1.2 | SWEA FM 2 Delivery to UCB | 3d | 2004-03-29 | 2004-03-31 | 257 |  |  | 77d | 28d |  |

| ID | WBS | Task | Type | Duration | Start | Finish | Predecessors | Complete | Remaining | Total slack | Free slack | Constraint |
| --- | --- | --- | --- | --- | --- | --- | --- | --- | --- | --- | --- | --- |
| 255 | 1.5.3.2 | **FM 2** |  | 47d | 2004-01-21 | 2004-03-26 |  |  |  | 77d |  |  |
| 256 | 1.5.3.2.1 | SWEA FM 2 Final Assembly (Block 2) |  | 3d | 2004-01-21 | 2004-01-23 |  |  |  | 77d | 0d | start no earlier than 2004-01-21 |
| 257 | 1.5.3.2.2 | SWEA FM 2 Calibration |  | 44d | 2004-01-26 | 2004-03-26 | 256 |  |  | 77d | 0d |  |
| 258 | 1.5.4 | **STE - UCB** |  | 153d | 2003-08-29 A | 2004-04-09 |  | 55% | 69.36d | 88d |  |  |
| 259 | 1.5.4.1 | **Deliveries** |  | 8d | 2004-03-30 | 2004-04-09 |  |  |  | 52d |  |  |
| 260 | 1.5.4.1.1 | Deliver STE-D FM 1 (stays at UCB for SWEA/STE-D FM 1 I&T) | milestone | 0d | 2004-03-30 | 2004-03-30 | 275 |  |  | 52d | 3d |  |
| 261 | 1.5.4.1.2 | Deliver STE-D FM 2 (stays at UCB for SWEA/STE-D FM 2 I&T) | milestone | 0d | 2004-04-09 | 2004-04-09 | 283 |  |  | 70d | 21d |  |
| 262 | 1.5.4.1.3 | Deliver STE-U FM 1 (stays at UCB for BOOM Suite FM 1 I&T) | milestone | 0d | 2004-04-05 | 2004-04-05 | 276 |  |  | 51d | 3d |  |
| 263 | 1.5.4.1.4 | Deliver STE-U FM 2 (stays at UCB for BOOM Suite FM 2 I&T) | milestone | 0d | 2004-04-09 | 2004-04-09 | 284 |  |  | 88d | 0d |  |
| 264 | 1.5.4.2 | **STE-U/D Housing** |  | 38d | 2003-11-21 A | 2004-01-16 |  | 71% | 11d | 100d |  |  |
| 265 | 1.5.4.2.1 | Fabricate STE FM 1 Box |  | 38d | 2003-11-21 A | 2004-01-16 |  | 71% | 11d | 61d | 10d | start no earlier than 2003-11-21 |
| 266 | 1.5.4.2.2 | Fabricate STE FM 2 Box |  | 38d | 2003-11-21 A | 2004-01-16 |  | 71% | 11d | 100d | 30d | start no earlier than 2003-11-21 |
| 267 | 1.5.4.3 | **STE-U/D Detector Boards** |  | 153d | 2003-08-29 A | 2004-04-09 |  | 51% | 75.73d | 88d |  |  |
| 268 | 1.5.4.3.1 | Coupon Test STE FM 1 & FM 2 Detector Printed Wiring Board |  | 17d | 2003-10-10 A | 2003-11-04 A | 270, 278 | 100% |  |  |  | start no earlier than 2003-10-10 |
| 269 | 1.5.4.3.2 | **FM 1** |  | 149d | 2003-08-29 A | 2004-04-05 |  | 47% | 78.7d | 51d |  |  |
| 270 | 1.5.4.3.2.1 | Fabrication STE FM 1 Detector Printed Wiring Board |  | 29d | 2003-08-29 A | 2003-10-09 A |  | 100% |  |  |  | start no earlier than 2003-08-29 |
| 271 | 1.5.4.3.2.2 | Load STE FM 1 Detector Printed Wiring Board |  | 49d | 2003-11-05 A | 2004-01-16 | 268 | 78% | 11d | 51d | 0d |  |
| 272 | 1.5.4.3.2.3 | Test STE FM 1 Detector Printed Wiring Board |  | 10d | 2004-01-20 | 2004-02-02 | 271 |  |  | 51d | 0d |  |
| 273 | 1.5.4.3.2.4 | **Integration & Test** |  | 44d | 2004-02-03 | 2004-04-05 |  |  |  | 51d |  |  |
| 274 | 1.5.4.3.2.4.1 | Integrate & Test STE-U/D FM 1 Detectors W/ FM 1 Housings |  | 20d | 2004-02-03 | 2004-03-02 | 265, 272 |  |  | 51d | 0d |  |
| 275 | 1.5.4.3.2.4.2 | Calibrate STE-U/D FM 1 |  | 20d | 2004-03-03 | 2004-03-30 | 274 |  |  | 51d | 0d |  |
| 276 | 1.5.4.3.2.4.3 | STE-U FM 1 Thermal Vacuum/Balance |  | 14d | 2004-03-17 | 2004-04-05 | 275FS-10d |  |  | 51d | 0d |  |
| 277 | 1.5.4.3.3 | **FM 2** |  | 153d | 2003-08-29 A | 2004-04-09 |  | 48% | 79.78d | 88d |  |  |
| 278 | 1.5.4.3.3.1 | Fabricate STE FM 2 Detector Printed Wiring Board |  | 29d | 2003-08-29 A | 2003-10-09 A |  | 100% |  |  |  | start no earlier than 2003-08-29 |
| 279 | 1.5.4.3.3.2 | Load STE FM 2 Detector Printed Wiring Board |  | 63d | 2003-11-05 A | 2004-02-06 | 268 | 60% | 25d | 76d | 0d |  |
| 280 | 1.5.4.3.3.3 | Test STE FM 2 Detector Printed Wiring Board |  | 10d | 2004-02-09 | 2004-02-23 | 279 |  |  | 76d | 6d |  |

| ID | WBS | Task | Type | Duration | Start | Finish | Predecessors | Complete | Remaining | Total slack | Free slack | Constraint |
| --- | --- | --- | --- | --- | --- | --- | --- | --- | --- | --- | --- | --- |
| 281 | 1.5.4.3.3.4 | **Integration & Test** |  | 28d | 2004-03-03 | 2004-04-09 |  |  |  | 70d |  |  |
| 282 | 1.5.4.3.3.4.1 | Integrate & Test STE-U/D FM 2 Detectors W/ FM 2 Housings |  | 10d | 2004-03-03 | 2004-03-16 | 266, 280, 274 |  |  | 70d | 0d |  |
| 283 | 1.5.4.3.3.4.2 | Calibrate STE-U/D FM 2 |  | 18d | 2004-03-17 | 2004-04-09 | 282 |  |  | 70d | 0d |  |
| 284 | 1.5.4.3.3.4.3 | STE-U FM 2 Thermal Vacuum |  | 10d | 2004-03-29 | 2004-04-09 | 283FS-10d |  |  | 88d | 0d |  |
| 285 | 1.5.5 | **STE and SWEA - UCB** |  | 289d | 2003-07-01 A | 2004-08-20 |  | 67% | 96.21d | 21d |  |  |
| 286 | 1.5.5.1 | **Deliveries** |  | 119d | 2004-01-26 | 2004-07-13 |  |  |  | 49d |  |  |
| 287 | 1.5.5.1.1 | Deliver STE-U FM 1 Interface (stays at UCB for IDPU FM 1 I&T) | milestone | 0d | 2004-01-26 | 2004-01-26 | 336 |  |  | 102d | 28d |  |
| 288 | 1.5.5.1.2 | Deliver STE-U FM 2 Interface (stays at UCB for IDPU FM 2 I&T) | milestone | 0d | 2004-01-26 | 2004-01-26 | 345 |  |  | 108d | 68d |  |
| 289 | 1.5.5.1.3 | Deliver SWEA/STE-D FM 1 (stays at UCB for Boom Suite FM 1 I&T) | milestone | 0d | 2004-05-14 | 2004-05-14 | 342 |  |  | 49d | 1d |  |
| 290 | 1.5.5.1.4 | Deliver SWEA/STE-D FM 2 (stays at UCB for Boom Suite FM 2 I&T) | milestone | 0d | 2004-07-13 | 2004-07-13 | 351 |  |  | 49d | 0d |  |
| 291 | 1.5.5.2 | **SWEA Pedestal** |  | 137d | 2003-07-01 A | 2004-01-16 |  | 92% | 11d | 98d |  |  |
| 292 | 1.5.5.2.1 | Fabricate SWEA FM 1 Baseplate |  | 137d | 2003-07-01 A | 2004-01-16 |  | 92% | 11d | 72d | 0d | start no earlier than 2003-07-01 |
| 293 | 1.5.5.2.2 | Fabricate SWEA FM 2 Baseplate |  | 137d | 2003-07-01 A | 2004-01-16 |  | 92% | 11d | 98d | 0d | start no earlier than 2003-07-01 |
| 294 | 1.5.5.3 | **STE-D Pre-Amp Board** |  | 54d | 2003-09-22 A | 2003-12-09 |  | 89% | 5.81d | 124d |  |  |
| 295 | 1.5.5.3.1 | **FM 1** |  | 54d | 2003-09-22 A | 2003-12-09 |  | 87% | 6.92d | 98d |  |  |
| 296 | 1.5.5.3.1.1 | Fabricate STE-D FM 1 Preamp Printed Wiring Board |  | 34d | 2003-09-22 A | 2003-11-07 A |  | 100% |  |  |  | start no earlier than 2003-09-22 |
| 297 | 1.5.5.3.1.2 | Load STE-D FM 1 Preamp Printed Wiring Board |  | 5d | 2003-12-03 | 2003-12-09 | 301 |  |  | 98d | 26d |  |
| 298 | 1.5.5.3.2 | **FM 2** |  | 54d | 2003-09-22 A | 2003-12-09 |  | 87% | 6.92d | 124d |  |  |
| 299 | 1.5.5.3.2.1 | Fabricate STE-D FM 2 Preamp Printed Wiring Board |  | 34d | 2003-09-22 A | 2003-11-07 A |  | 100% |  |  |  | start no earlier than 2003-09-22 |
| 300 | 1.5.5.3.2.2 | Load STE-D FM 2 Preamp Printed Wiring Board |  | 5d | 2003-12-03 | 2003-12-09 | 301 |  |  | 124d | 26d |  |
| 301 | 1.5.5.3.3 | Coupon Test STE-D FM 1 & FM 2 Pre-Amp Printed Wiring Boards |  | 15d | 2003-11-10 A | 2003-12-02 A | 296, 299 | 100% |  |  |  |  |
| 302 | 1.5.5.4 | **STE-D Shaper Board** |  | 30d | 2003-12-04 A | 2004-01-16 |  | 64% | 10.67d | 98d |  |  |
| 303 | 1.5.5.4.1 | **FM 1** |  | 30d | 2003-12-04 A | 2004-01-16 |  | 67% | 10d | 72d |  |  |
| 304 | 1.5.5.4.1.1 | Fabricate STE-D FM 1 Shaper Printed Wiring Board |  | 10d | 2003-12-04 A | 2003-12-17 A |  | 100% |  |  |  | start no earlier than 2003-12-04 |
| 305 | 1.5.5.4.1.2 | Load STE-D FM 1 Shaper Printed Wiring Board |  | 5d | 2004-01-12 | 2004-01-16 | 309 |  |  | 72d | 0d |  |

| ID | WBS | Task | Duration | Start | Finish | Predecessors | Complete | Remaining | Total slack | Free slack | Constraint |
| --- | --- | --- | --- | --- | --- | --- | --- | --- | --- | --- | --- |
| 306 | 1.5.5.4.2 | **FM 2** | 30d | 2003-12-04 A | 2004-01-16 |  | 67% | 10d | 98d |  |  |
| 307 | 1.5.5.4.2.1 | Fabricate STE-D FM 2 Shaper Printed Wiring Board | 10d | 2003-12-04 A | 2003-12-17 A |  | 100% |  |  |  | start no earlier than 2003-12-04 |
| 308 | 1.5.5.4.2.2 | Load STE-D FM 2 Shaper Printed Wiring Board | 5d | 2004-01-12 | 2004-01-16 | 309 |  |  | 98d | 0d |  |
| 309 | 1.5.5.4.3 | Coupon Test STE-D FM 1 & FM 2 Shaper Printed Wiring Boards | 15d | 2003-12-18 A | 2004-01-09 | 304, 307 | 60% | 6d | 72d | 0d |  |
| 310 | 1.5.5.5 | **STE-D Interface Board** | 30d | 2003-12-04 A | 2004-01-16 |  | 64% | 10.67d | 98d |  |  |
| 311 | 1.5.5.5.1 | **FM 1** | 30d | 2003-12-04 A | 2004-01-16 |  | 67% | 10d | 72d |  |  |
| 312 | 1.5.5.5.1.1 | Fabricate SWEA / STE-D FM 1 Digital to Analog Converter Printed Wiring Board | 10d | 2003-12-04 A | 2003-12-17 A |  | 100% |  |  |  | start no earlier than 2003-12-04 |
| 313 | 1.5.5.5.1.2 | Load SWEA / STE-D FM 1 Digital to Analog Converter Printed Wiring Board | 5d | 2004-01-12 | 2004-01-16 | 317 |  |  | 72d | 0d |  |
| 314 | 1.5.5.5.2 | **FM 2** | 30d | 2003-12-04 A | 2004-01-16 |  | 67% | 10d | 98d |  |  |
| 315 | 1.5.5.5.2.1 | Fabricate SWEA / STE-D FM 2 Digital to Analog Converter Printed Wiring Board | 10d | 2003-12-04 A | 2003-12-17 A |  | 100% |  |  |  | start no earlier than 2003-12-04 |
| 316 | 1.5.5.5.2.2 | Load SWEA / STE-D FM 2 Digital to Analog Converter Printed Wiring Board | 5d | 2004-01-12 | 2004-01-16 | 317 |  |  | 98d | 0d |  |
| 317 | 1.5.5.5.3 | Coupon Test STE-D FM 1 & FM 2 D/A Converter Printed Wiring Boards | 15d | 2003-12-18 A | 2004-01-09 | 312, 315 | 60% | 6d | 72d | 0d |  |
| 318 | 1.5.5.6 | **STE-U Pre-Amp Board** | 79d | 2003-09-22 A | 2004-01-15 |  | 95% | 4.29d | 109d |  |  |
| 319 | 1.5.5.6.1 | **FM 1** | 79d | 2003-09-22 A | 2004-01-15 A |  | 100% |  |  |  |  |
| 320 | 1.5.5.6.1.1 | Fabricate STE-U FM 1 Preamp Printed Wiring Board | 34d | 2003-09-22 A | 2003-11-07 A |  | 100% |  |  |  | start no earlier than 2003-09-22 |
| 321 | 1.5.5.6.1.2 | Load STE-U FM 1 Preamp Printed Wiring Board | 4d | 2004-01-12 A | 2004-01-15 A | 325 | 100% |  |  |  | start no earlier than 2004-01-12 |
| 322 | 1.5.5.6.2 | **FM 2** | 54d | 2003-09-22 A | 2003-12-09 |  | 87% | 6.92d | 134d |  |  |
| 323 | 1.5.5.6.2.1 | Fabricate STE-U FM 2 Preamp Printed Wiring Board | 34d | 2003-09-22 A | 2003-11-07 A |  | 100% |  |  |  | start no earlier than 2003-09-22 |
| 324 | 1.5.5.6.2.2 | Load STE-U FM 2 Preamp Printed Wiring Board | 5d | 2003-12-03 | 2003-12-09 | 325 |  |  | 134d | 26d |  |
| 325 | 1.5.5.6.3 | Coupon Test STE-U FM 1 & FM 2 Pre-Amp Printed Wiring Boards | 15d | 2003-11-10 A | 2003-12-02 A | 320, 323 | 100% |  |  |  |  |
| 326 | 1.5.5.7 | **STE-U Shaper & Interface Board** | 30d | 2003-12-04 A | 2004-01-16 |  | 64% | 10.67d | 108d |  |  |
| 327 | 1.5.5.7.1 | **FM 1** | 30d | 2003-12-04 A | 2004-01-16 |  | 67% | 10d | 102d |  |  |
| 328 | 1.5.5.7.1.1 | Fabricate STE-U FM 1Shaper & Interface Printed Wiring Board | 10d | 2003-12-04 A | 2003-12-17 A |  | 100% |  |  |  | start no earlier than 2003-12-04 |
| 329 | 1.5.5.7.1.2 | Load STE-U FM 1 Shaper & Interface Printed Wiring Board | 5d | 2004-01-12 | 2004-01-16 | 333 |  |  | 102d | 0d |  |

| ID | WBS | Task | Duration | Start | Finish | Predecessors | Complete | Remaining | Total slack | Free slack | Constraint |
| --- | --- | --- | --- | --- | --- | --- | --- | --- | --- | --- | --- |
| 330 | 1.5.5.7.2 | **FM 2** | 30d | 2003-12-04 A | 2004-01-16 |  | 67% | 10d | 108d |  |  |
| 331 | 1.5.5.7.2.1 | Fabricate STE-U FM 2 Shaper & Interface Printed Wiring Board | 10d | 2003-12-04 A | 2003-12-17 A |  | 100% |  |  |  | start no earlier than 2003-12-04 |
| 332 | 1.5.5.7.2.2 | Load STE-U FM 2 Shaper & Interface Printed Wiring Board | 5d | 2004-01-12 | 2004-01-16 | 333 |  |  | 108d | 0d |  |
| 333 | 1.5.5.7.3 | Coupon Test STE-U FM 1 & FM 2 Shaper & Interface Printed Wiring Boards | 15d | 2003-12-18 A | 2004-01-09 | 328, 331 | 60% | 6d | 102d | 0d |  |
| 334 | 1.5.5.8 | **Integration & Test** | 152d | 2004-01-20 | 2004-08-20 |  |  |  | 21d |  |  |
| 335 | 1.5.5.8.1 | **FM 1** | 152d | 2004-01-20 | 2004-08-20 |  |  |  | 18d |  |  |
| 336 | 1.5.5.8.1.1 | Integrate & Test STE-U FM 1 Interface Boards | 5d | 2004-01-20 | 2004-01-26 | 321, 329 |  |  | 102d | 0d |  |
| 337 | 1.5.5.8.1.2 | Integrate & Test SWEA/STE-D FM 1 Interface Boards | 20d | 2004-01-20 | 2004-02-17 | 292, 297, 305, 313 |  |  | 72d | 0d |  |
| 338 | 1.5.5.8.1.3 | Integrate & Test SWEA/STE-D FM 1 Interface with SWEA/STE-D FM 1 LVPS | 10d | 2004-03-22 | 2004-04-02 | 337, 70 |  |  | 49d | 0d |  |
| 339 | 1.5.5.8.1.4 | Clean/Coat/Stake SWEA/STE-D Interface | 10d | 2004-02-18 | 2004-03-02 | 337 |  |  | 72d | 23d |  |
| 340 | 1.5.5.8.1.5 | Integrate & Test SWEA/STE-D FM 1 Combined | 5d | 2004-04-05 | 2004-04-09 | 338, 339, 253, 260 |  |  | 49d | 0d |  |
| 341 | 1.5.5.8.1.6 | Calibrate SWEA/STE FM 1 | 20d | 2004-04-12 | 2004-05-07 | 340 |  |  | 49d | 0d |  |
| 342 | 1.5.5.8.1.7 | SWEA/STE FM 1 Vibration | 5d | 2004-05-10 | 2004-05-14 | 341 |  |  | 49d | 0d |  |
| 343 | 1.5.5.8.1.8 | SWEA/STE-D FM 1 Thermal Vac/Thermal Balance | 14d | 2004-08-03 | 2004-08-20 | 16 |  |  | 18d | 0d |  |
| 344 | 1.5.5.8.2 | **FM 2** | 124d | 2004-01-20 | 2004-07-13 |  |  |  | 49d |  |  |
| 345 | 1.5.5.8.2.1 | Integrate & Test STE-U FM 2 Interface Boards | 5d | 2004-01-20 | 2004-01-26 | 324, 332 |  |  | 108d | 0d |  |
| 346 | 1.5.5.8.2.2 | Integrate & Test SWEA/STE-D FM 2 Interface Boards | 20d | 2004-01-20 | 2004-02-17 | 293, 300, 308, 316 |  |  | 98d | 49d |  |
| 347 | 1.5.5.8.2.3 | Integrate & Test SWEA/STE-D FM 2 Interface with SWEA/STE-D FM 2 LVPS | 10d | 2004-04-27 | 2004-05-10 | 346, 76 |  |  | 49d | 0d |  |
| 348 | 1.5.5.8.2.4 | Integrate & Test SWEA/STE-D FM 2 Combined | 10d | 2004-05-11 | 2004-05-24 | 347, 254, 261 |  |  | 49d | 0d |  |
| 349 | 1.5.5.8.2.5 | Calibrate SWEA/STE FM 2 | 20d | 2004-05-25 | 2004-06-22 | 348 |  |  | 49d | 0d |  |
| 350 | 1.5.5.8.2.6 | SWEA/STE FM 2 Vibration | 5d | 2004-06-23 | 2004-06-29 | 349 |  |  | 49d | 0d |  |
| 351 | 1.5.5.8.2.7 | SWEA/STE-D FM 2 Thermal Vac | 10d | 2004-06-30 | 2004-07-13 | 350 |  |  | 49d | 0d |  |
| 352 | 1.5.6 | **Boom Suite I&T - UCB** | 110d | 2004-04-09 | 2004-09-13 |  |  |  | 32d |  |  |
| 353 | 1.5.6.1 | **FM 1** | 110d | 2004-04-09 | 2004-09-13 |  |  |  | 18d |  |  |
| 354 | 1.5.6.1.1 | FM 1 Boom/MAG/STE-U I&T | 4d | 2004-04-09 | 2004-04-14 | 215, 243, 262 |  |  | 48d | 0d |  |
| 355 | 1.5.6.1.2 | FM 1 Boom/SWEA/STE/MAG I&T | 2d | 2004-05-18 | 2004-05-19 | 289, 189 |  |  | 48d | 29d |  |
| 356 | 1.5.6.1.3 | FM 1 Integrated Boom/IDPU I&T | 4d | 2004-07-01 | 2004-07-06 | 355, 189, 836 |  |  | 19d | 9d |  |
| 357 | 1.5.6.1.4 | BOOM Suite FM 1 Bakeout | 5d | 2004-08-23 | 2004-08-27 | 356, 343 |  |  | 18d | 0d |  |
| 358 | 1.5.6.1.5 | Final BOOM Suite FM 1 I & T | 10d | 2004-08-30 | 2004-09-13 | 357, 179 |  |  | 18d | 0d |  |

| ID | WBS | Task | Duration | Start | Finish | Predecessors | Complete | Remaining | Total slack | Free slack | Constraint |
| --- | --- | --- | --- | --- | --- | --- | --- | --- | --- | --- | --- |
| 359 | 1.5.6.2 | **FM 2** | 101d | 2004-04-12 | 2004-08-31 |  |  |  | 40d |  |  |
| 360 | 1.5.6.2.1 | FM 2 Boom/MAG/STE-U I&T | 4d | 2004-04-12 | 2004-04-15 | 237, 244, 263 |  |  | 88d | 0d |  |
| 361 | 1.5.6.2.2 | FM 2 Boom/SWEA/STE/MAG I&T | 2d | 2004-07-14 | 2004-07-15 | 290, 190 |  |  | 49d | 9d |  |
| 362 | 1.5.6.2.3 | FM 2 Integrated Boom/IDPU I&T | 4d | 2004-07-29 | 2004-08-03 | 361, 849, 190 |  |  | 40d | 0d |  |
| 363 | 1.5.6.2.4 | Boom Suite FM 2 EMC | 5d | 2004-08-04 | 2004-08-10 | 362 |  |  | 40d | 0d |  |
| 364 | 1.5.6.2.5 | BOOM Suite FM 2 Bakeout | 5d | 2004-08-11 | 2004-08-17 | 363 |  |  | 40d | 0d |  |
| 365 | 1.5.6.2.6 | Final BOOM Suite FM 2 I & T | 10d | 2004-08-18 | 2004-08-31 | 364, 184 |  |  | 40d | 0d |  |
| 366 | 1.6 | **SEP Suite - CIT** | 376d | 2003-06-02 A | 2004-11-26 |  | 31% | 258.78d | 0d |  |  |
| 367 | 1.6.1 | **SEP Mechanical - Sandy Shuman (GSFC)** | 82d | 2004-01-22 | 2004-05-17 |  |  |  | 5d |  |  |
| 368 | 1.6.1.1 | **SIT Electronics Enclosure (Priority 1)** | 21d | 2004-01-22 | 2004-02-20 |  |  |  | 5d |  |  |
| 369 | 1.6.1.1.1 | Complete Design/Drawings for SIT Enclosure | 5d | 2004-01-22 | 2004-01-28 |  |  |  | 5d | 0d | start no earlier than 2004-01-22 |
| 370 | 1.6.1.1.2 | Fabrication of SIT Enclosure | 10d | 2004-01-29 | 2004-02-11 | 369 |  |  | 53d | 0d |  |
| 371 | 1.6.1.1.3 | Inspection and Final Assembly of SIT Enclosure | 5d | 2004-02-12 | 2004-02-19 | 370 |  |  | 53d | 0d |  |
| 372 | 1.6.1.1.4 | Deliver SIT Enclosure to UMD | 1d | 2004-02-20 | 2004-02-20 | 371 |  |  | 53d | 0d |  |
| 373 | 1.6.1.2 | **SEP FM 1 & FM 2 LVPS Boxes (Priority 2)** | 23d | 2004-01-29 | 2004-03-02 |  |  |  | 5d |  |  |
| 374 | 1.6.1.2.1 | Complete Design/Drawings for SEP LVPS Boxes | 5d | 2004-01-29 | 2004-02-04 | 369 |  |  | 5d | 0d |  |
| 375 | 1.6.1.2.2 | Fabrication of SEP LVPS Boxes | 10d | 2004-02-05 | 2004-02-19 | 374 |  |  | 62d | 0d |  |
| 376 | 1.6.1.2.3 | Inspection and Final Assembly of SEP LVPS Boxes | 5d | 2004-02-20 | 2004-02-26 | 375 |  |  | 62d | 0d |  |
| 377 | 1.6.1.2.4 | Deliver SEP LVPS Boxes to UCB | 3d | 2004-02-27 | 2004-03-02 | 376 |  |  | 62d | 0d |  |
| 378 | 1.6.1.3 | **LET Telescope (Priority 3)** | 26d | 2004-02-05 | 2004-03-12 |  |  |  | 5d |  |  |
| 379 | 1.6.1.3.1 | Complete Design/Drawings for LET Telescope | 8d | 2004-02-05 | 2004-02-17 | 374 |  |  | 5d | 0d |  |
| 380 | 1.6.1.3.2 | Fabrication of LET Telescope | 10d | 2004-02-18 | 2004-03-02 | 379 |  |  | 47d | 0d |  |
| 381 | 1.6.1.3.3 | Inspection and Final Assembly of LET Telescope | 5d | 2004-03-03 | 2004-03-09 | 380 |  |  | 47d | 0d |  |
| 382 | 1.6.1.3.4 | Deliver LET Telescope to CIT | 3d | 2004-03-10 | 2004-03-12 | 381 |  |  | 47d | 0d |  |

| ID | WBS | Task | Type | Duration | Start | Finish | Predecessors | Total slack | Free slack |
| --- | --- | --- | --- | --- | --- | --- | --- | --- | --- |
| 383 | 1.6.1.4 | **SEP Central Bias Supply Shields (Priority 4)** |  | 20d | 2004-02-18 | 2004-03-16 |  | 5d |  |
| 384 | 1.6.1.4.1 | Complete Design/Drawings for Bias Supply Shields |  | 5d | 2004-02-18 | 2004-02-24 | 379 | 5d | 0d |
| 385 | 1.6.1.4.2 | Fabrication of Bias Supply Shields |  | 10d | 2004-02-25 | 2004-03-09 | 384 | 51d | 0d |
| 386 | 1.6.1.4.3 | Inspection and Delivery (to CIT) of Bias Supply Shields |  | 5d | 2004-03-10 | 2004-03-16 | 385 | 51d | 0d |
| 387 | 1.6.1.5 | **SEP Electronics Enclosure (Priority 5)** |  | 31d | 2004-02-25 | 2004-04-07 |  | 5d |  |
| 388 | 1.6.1.5.1 | Complete Design/Drawings for SEP Enclosure |  | 13d | 2004-02-25 | 2004-03-12 | 384 | 5d | 0d |
| 389 | 1.6.1.5.2 | Fabrication of SEP Enclosure |  | 10d | 2004-03-15 | 2004-03-26 | 388 | 47d | 0d |
| 390 | 1.6.1.5.3 | Inspection and Final Assembly of SEP Enclosure |  | 5d | 2004-03-29 | 2004-04-02 | 389 | 47d | 0d |
| 391 | 1.6.1.5.4 | Deliver SEP Enclosure to CIT |  | 3d | 2004-04-05 | 2004-04-07 | 390 | 47d | 5d |
| 392 | 1.6.1.6 | **HET Electronics Enclosure (Priority 6)** |  | 23d | 2004-03-15 | 2004-04-14 |  | 5d |  |
| 393 | 1.6.1.6.1 | Complete Design/Drawings for HET Enclosure |  | 8d | 2004-03-15 | 2004-03-24 | 388 | 5d | 0d |
| 394 | 1.6.1.6.2 | Fabrication of HET Enclosure |  | 10d | 2004-03-25 | 2004-04-07 | 393 | 23d | 0d |
| 395 | 1.6.1.6.3 | Inspection and Final Assembly of HET Enclosure |  | 5d | 2004-04-08 | 2004-04-14 | 394 | 23d | 0d |
| 396 | 1.6.1.6.4 | Deliver HET Enclosure (stays at GSFC) | milestone | 0d | 2004-04-14 | 2004-04-14 | 395 | 23d | 18d |
| 397 | 1.6.1.7 | **SIT Telescope (Priority 7)** |  | 34d | 2004-03-25 | 2004-05-11 |  | 5d |  |
| 398 | 1.6.1.7.1 | Complete Design/Drawings for SIT Telescope |  | 18d | 2004-03-25 | 2004-04-19 | 393 | 5d | 0d |
| 399 | 1.6.1.7.2 | Fabrication of SIT Telescope |  | 10d | 2004-04-20 | 2004-05-03 | 398 | 9d | 0d |
| 400 | 1.6.1.7.3 | Inspection and Final Assembly of SIT Telescope |  | 5d | 2004-05-04 | 2004-05-10 | 399 | 9d | 0d |
| 401 | 1.6.1.7.4 | Deliver SIT Telescope to UMD |  | 1d | 2004-05-11 | 2004-05-11 | 400 | 9d | 0d |
| 402 | 1.6.1.8 | **HET Telescope (Priority 8)** |  | 20d | 2004-04-20 | 2004-05-17 |  | 5d |  |
| 403 | 1.6.1.8.1 | Complete Design/Drawings for HET Telescope |  | 5d | 2004-04-20 | 2004-04-26 | 398 | 5d | 0d |
| 404 | 1.6.1.8.2 | Fabrication of HET Telescope |  | 10d | 2004-04-27 | 2004-05-10 | 403 | 5d | 0d |
| 405 | 1.6.1.8.3 | Inspection and Final Assembly of HET Telescope |  | 5d | 2004-05-11 | 2004-05-17 | 404, 396 | 5d | 0d |
| 406 | 1.6.1.8.4 | Deliver HET Telescope (stays at GSFC) | milestone | 0d | 2004-05-17 | 2004-05-17 | 405 | 5d | 0d |

| ID | WBS | Task | Type | Duration | Start | Finish | Predecessors | Complete | Remaining | Total slack | Free slack | Constraint |
| --- | --- | --- | --- | --- | --- | --- | --- | --- | --- | --- | --- | --- |
| 407 | 1.6.2 | **SEP Central - CIT** |  | 176d | 2003-08-01 A | 2004-04-14 |  | 38% | 108.77d | 68d |  |  |
| 408 | 1.6.2.1 | **Deliveries** |  | 31d | 2004-03-02 | 2004-04-14 |  |  |  | 68d |  |  |
| 409 | 1.6.2.1.1 | Deliver SEP Cen FM 1 Logic Board (stays at CIT for SEP Suite I&T) | milestone | 0d | 2004-04-14 | 2004-04-14 | 435 |  |  | 42d | 0d |  |
| 410 | 1.6.2.1.2 | Deliver SEP Cen FM 2 Logic Board (stays at CIT for SEP Suite I&T) | milestone | 0d | 2004-04-14 | 2004-04-14 | 442 |  |  | 68d | 0d |  |
| 411 | 1.6.2.1.3 | Deliver SEP Cen FM 1 Analog/Post-Reg Board (stays at CIT for SEP Suite I&T) | milestone | 0d | 2004-04-09 | 2004-04-09 | 460 |  |  | 45d | 3d |  |
| 412 | 1.6.2.1.4 | Deliver SEP Cen FM 2 Analog/Post-Reg Board (stays at CIT for SEP Suite I&T) | milestone | 0d | 2004-04-09 | 2004-04-09 | 467 |  |  | 71d | 3d |  |
| 413 | 1.6.2.1.5 | Deliver SEP Cen FM 1 SSD Bias Supply Board (stays at CIT for SEP Suite I&T) | milestone | 0d | 2004-04-09 | 2004-04-09 | 485 |  |  | 45d | 3d |  |
| 414 | 1.6.2.1.6 | Deliver SEP Cen FM 2 SSD Bias Supply Board (stays at CIT for SEP Suite I&T) | milestone | 0d | 2004-04-09 | 2004-04-09 | 492 |  |  | 71d | 3d |  |
| 415 | 1.6.2.1.7 | Deliver Final SEP Central Flight Software to SEP I&T | milestone | 0d | 2004-03-02 | 2004-03-02 | 495 |  |  | 73d | 31d |  |
| 416 | 1.6.2.2 | **Logic Board** |  | 67d | 2004-01-09 | 2004-04-14 |  |  |  | 68d |  |  |
| 417 | 1.6.2.2.1 | **Assembly** |  | 26d | 2004-01-09 | 2004-02-17 |  |  |  | 86d |  |  |
| 418 | 1.6.2.2.1.1 | **FM 1** |  | 13d | 2004-01-09 | 2004-01-28 |  |  |  | 86d |  |  |
| 419 | 1.6.2.2.1.1.1 | Assemble FM 1 SEP Central Logic board |  | 5d | 2004-01-09 | 2004-01-15 |  |  |  | 86d | 0d | start no earlier than 2004-01-09 |
| 420 | 1.6.2.2.1.1.2 | Post-assembly QA inspection of FM 1 SEP Central Logic Board |  | 1d | 2004-01-16 | 2004-01-16 | 419 |  |  | 86d | 0d |  |
| 421 | 1.6.2.2.1.1.3 | Rework/haywire/trim FM 1 SEP Central Logic board |  | 1d | 2004-01-27 | 2004-01-27 | 430 |  |  | 86d | 0d |  |
| 422 | 1.6.2.2.1.1.4 | Post-rework QA inspection of FM 1 SEP Central Logic Board |  | 1d | 2004-01-28 | 2004-01-28 | 421 |  |  | 86d | 44d |  |
| 423 | 1.6.2.2.1.2 | **FM 2** |  | 21d | 2004-01-16 | 2004-02-17 |  |  |  | 99d |  |  |
| 424 | 1.6.2.2.1.2.1 | Assemble FM 2 SEP Central Logic board |  | 5d | 2004-01-16 | 2004-01-23 | 419 |  |  | 107d | 0d |  |
| 425 | 1.6.2.2.1.2.2 | Post-assembly QA inspection of FM 2 SEP Central Logic Board |  | 1d | 2004-01-26 | 2004-01-26 | 424 |  |  | 107d | 0d |  |
| 426 | 1.6.2.2.1.2.3 | Rework/haywire/trim FM 2 SEP Central Logic board |  | 1d | 2004-02-09 | 2004-02-09 | 437 |  |  | 103d | 4d | start no earlier than 2004-02-09 |
| 427 | 1.6.2.2.1.2.4 | Post-rework QA inspection of FM 2 SEP Central Logic Boards |  | 1d | 2004-02-17 | 2004-02-17 | 426 |  |  | 99d | 31d | start no earlier than 2004-02-17 |
| 428 | 1.6.2.2.2 | **Test** |  | 61d | 2004-01-20 | 2004-04-14 |  |  |  | 68d |  |  |
| 429 | 1.6.2.2.2.1 | **FM 1** |  | 61d | 2004-01-20 | 2004-04-14 |  |  |  | 42d |  |  |
| 430 | 1.6.2.2.2.1.1 | Test FM 1 SEP Central Logic board (initial) |  | 5d | 2004-01-20 | 2004-01-26 | 420 |  |  | 86d | 0d |  |
| 431 | 1.6.2.2.2.1.2 | Stake/conformal coat FM 1 SEP Central Logic board |  | 2d | 2004-04-01 | 2004-04-02 | 422 |  |  | 42d | 0d | start no earlier than 2004-04-01 |
| 432 | 1.6.2.2.2.1.3 | Bakeout FM 1 SEP Central Logic board |  | 1d | 2004-04-05 | 2004-04-05 | 431 |  |  | 42d | 0d |  |
| 433 | 1.6.2.2.2.1.4 | Post-conf. coat QA inspection of FM 1 SEP Central Logic Board |  | 1d | 2004-04-06 | 2004-04-06 | 432 |  |  | 42d | 0d |  |
| 434 | 1.6.2.2.2.1.5 | Test FM 1 SEP Central Logic board (final) |  | 5d | 2004-04-07 | 2004-04-13 | 433 |  |  | 42d | 0d |  |
| 435 | 1.6.2.2.2.1.6 | FM 1 SEP Central Logic Board Mass properties/photo |  | 1d | 2004-04-14 | 2004-04-14 | 434 |  |  | 42d | 0d |  |

| ID | WBS | Task | Duration | Start | Finish | Predecessors | Complete | Remaining | Total slack | Free slack | Constraint |
| --- | --- | --- | --- | --- | --- | --- | --- | --- | --- | --- | --- |
| 436 | 1.6.2.2.2.2 | **FM 2** | 56d | 2004-01-27 | 2004-04-14 |  |  |  | 68d |  |  |
| 437 | 1.6.2.2.2.2.1 | Test FM 2 SEP Central Logic board (initial) | 5d | 2004-01-27 | 2004-02-02 | 425 |  |  | 107d | 4d |  |
| 438 | 1.6.2.2.2.2.2 | Stake/conformal coat FM 2 SEP Central Logic board | 2d | 2004-04-01 | 2004-04-02 | 427 |  |  | 68d | 0d | start no earlier than 2004-04-01 |
| 439 | 1.6.2.2.2.2.3 | Bakeout FM 2 SEP Central Logic board | 1d | 2004-04-05 | 2004-04-05 | 438 |  |  | 68d | 0d |  |
| 440 | 1.6.2.2.2.2.4 | Post-conf. coat QA inspection of FM 2 SEP Central Logic Board | 1d | 2004-04-06 | 2004-04-06 | 439 |  |  | 68d | 0d |  |
| 441 | 1.6.2.2.2.2.5 | Test FM 2 SEP Central Logic board (final) | 5d | 2004-04-07 | 2004-04-13 | 440 |  |  | 68d | 0d |  |
| 442 | 1.6.2.2.2.2.6 | FM 2 SEP Central Logic Board Mass properties/photo | 1d | 2004-04-14 | 2004-04-14 | 441 |  |  | 68d | 0d |  |
| 443 | 1.6.2.3 | **Analog/Post-Reg Board** | 88d | 2003-12-04 A | 2004-04-09 |  | 24% | 66.65d | 71d |  |  |
| 444 | 1.6.2.3.1 | **Assembly** | 45d | 2003-12-04 A | 2004-02-09 |  | 59% | 18.48d | 107d |  |  |
| 445 | 1.6.2.3.1.1 | **FM 1** | 45d | 2003-12-04 A | 2004-02-09 |  | 61% | 17.68d | 81d |  |  |
| 446 | 1.6.2.3.1.1.1 | Assemble Analog/Post-reg Flight Printed Circuit Board 1 | 5d | 2003-12-04 A | 2003-12-10 |  | 85% | 0.75d | 116d | 0d | start no earlier than 2003-12-04 |
| 447 | 1.6.2.3.1.1.2 | Rework/haywire/trim Analog/Post-reg Flight Board 1 | 1d | 2004-02-06 | 2004-02-06 | 455 |  |  | 81d | 0d |  |
| 448 | 1.6.2.3.1.1.3 | Post rework QA inspection Flight Board 1 | 1d | 2004-02-09 | 2004-02-09 | 447 |  |  | 81d | 36d |  |
| 449 | 1.6.2.3.1.2 | **FM 2** | 40d | 2003-12-11 A | 2004-02-09 |  | 57% | 17.14d | 107d |  |  |
| 450 | 1.6.2.3.1.2.1 | Assemble Analog/Post-reg Flight Printed Circuit Board 2 | 5d | 2003-12-11 A | 2003-12-17 | 446 | 80% | 1d | 137d | 30d |  |
| 451 | 1.6.2.3.1.2.2 | Rework/haywire/trim Analog/Post-reg Flight Board 2 | 1d | 2004-02-06 | 2004-02-06 | 462 |  |  | 107d | 0d |  |
| 452 | 1.6.2.3.1.2.3 | Post rework QA inspection Flight Board 2 | 1d | 2004-02-09 | 2004-02-09 | 451 |  |  | 107d | 36d |  |
| 453 | 1.6.2.3.2 | **Test** | 48d | 2004-02-03 | 2004-04-09 |  |  |  | 71d |  |  |
| 454 | 1.6.2.3.2.1 | **FM 1** | 48d | 2004-02-03 | 2004-04-09 |  |  |  | 45d |  |  |
| 455 | 1.6.2.3.2.1.1 | Test Analog/Post-reg Flight Board 1 (initial) | 3d | 2004-02-03 | 2004-02-05 | 446 |  |  | 81d | 0d | start no earlier than 2004-02-03 |
| 456 | 1.6.2.3.2.1.2 | Stake/conformal coat Analog/Post-reg Flight Board 1 | 2d | 2004-04-01 | 2004-04-02 | 448 |  |  | 45d | 0d | start no earlier than 2004-04-01 |
| 457 | 1.6.2.3.2.1.3 | Bakeout Analog/Post-reg Flight Board 1 | 1d | 2004-04-05 | 2004-04-05 | 456 |  |  | 45d | 0d |  |
| 458 | 1.6.2.3.2.1.4 | Post-conf coat QA inspection Flight Board 1 | 1d | 2004-04-06 | 2004-04-06 | 457 |  |  | 45d | 0d |  |
| 459 | 1.6.2.3.2.1.5 | Test Analog/Post-reg Flight Board 1 (final) | 2d | 2004-04-07 | 2004-04-08 | 458 |  |  | 45d | 0d |  |
| 460 | 1.6.2.3.2.1.6 | Analog/Post-reg Flight Board 1 Mass properties/photo | 1d | 2004-04-09 | 2004-04-09 | 459 |  |  | 45d | 0d |  |

| ID | WBS | Task | Duration | Start | Finish | Predecessors | Total slack | Free slack | Constraint |
| --- | --- | --- | --- | --- | --- | --- | --- | --- | --- |
| 461 | 1.6.2.3.2.2 | **FM 2** | 48d | 2004-02-03 | 2004-04-09 |  | 71d |  |  |
| 462 | 1.6.2.3.2.2.1 | Test Analog/Post-reg Flight Board 2 (initial) | 3d | 2004-02-03 | 2004-02-05 | 450 | 107d | 0d | start no earlier than 2004-02-03 |
| 463 | 1.6.2.3.2.2.2 | Stake/conformal coat Analog/Post-reg Flight Board 2 | 2d | 2004-04-01 | 2004-04-02 | 452 | 71d | 0d | start no earlier than 2004-04-01 |
| 464 | 1.6.2.3.2.2.3 | Bakeout Analog/Post-reg Flight Board 2 | 1d | 2004-04-05 | 2004-04-05 | 463 | 71d | 0d |  |
| 465 | 1.6.2.3.2.2.4 | Post-conf coat QA inspection Flight Board 2 | 1d | 2004-04-06 | 2004-04-06 | 464 | 71d | 0d |  |
| 466 | 1.6.2.3.2.2.5 | Test Analog/Post-reg Flight Board 2 (final) | 2d | 2004-04-07 | 2004-04-08 | 465 | 71d | 0d |  |
| 467 | 1.6.2.3.2.2.6 | Analog/Post-reg Flight Board 2 Mass properties/photo | 1d | 2004-04-09 | 2004-04-09 | 466 | 71d | 0d |  |
| 468 | 1.6.2.4 | **SEP Solid State Detector Bias Supply Board** | 63d | 2004-01-12 | 2004-04-09 |  | 71d |  |  |
| 469 | 1.6.2.4.1 | **Assembly** | 53d | 2004-01-12 | 2004-03-26 |  | 74d |  |  |
| 470 | 1.6.2.4.1.1 | **FM 1** | 50d | 2004-01-12 | 2004-03-23 |  | 51d |  |  |
| 471 | 1.6.2.4.1.1.1 | Assemble flight Solid State Detector Bias Supply Printed Circuit Board 1 | 10d | 2004-01-12 | 2004-01-26 |  | 86d | 0d | start no earlier than 2004-01-12 |
| 472 | 1.6.2.4.1.1.2 | Rework/haywire/trim Solid State Detector Bias Supply flight board 1 | 1d | 2004-03-22 | 2004-03-22 | 480 | 51d | 0d |  |
| 473 | 1.6.2.4.1.1.3 | Post rework QA inspection of Solid State Detector Bias Supply board 1 | 1d | 2004-03-23 | 2004-03-23 | 472 | 51d | 6d |  |
| 474 | 1.6.2.4.1.2 | **FM 2** | 43d | 2004-01-27 | 2004-03-26 |  | 74d |  |  |
| 475 | 1.6.2.4.1.2.1 | Assemble flight Solid State Detector Bias Supply Printed Circuit Board 2 | 10d | 2004-01-27 | 2004-02-09 | 471 | 102d | 28d |  |
| 476 | 1.6.2.4.1.2.2 | Rework/haywire/trim Solid State Detector Bias Supply flight board 2 | 1d | 2004-03-25 | 2004-03-25 | 487 | 74d | 0d |  |
| 477 | 1.6.2.4.1.2.3 | Post rework QA inspection of Solid State Detector Bias Supply board 2 | 1d | 2004-03-26 | 2004-03-26 | 476 | 74d | 3d |  |
| 478 | 1.6.2.4.2 | **Test** | 18d | 2004-03-17 | 2004-04-09 |  | 51d |  |  |
| 479 | 1.6.2.4.2.1 | **FM 1** | 18d | 2004-03-17 | 2004-04-09 |  | 45d |  |  |
| 480 | 1.6.2.4.2.1.1 | Test Solid State Detector Bias Supply flight board 1 (initial) | 3d | 2004-03-17 | 2004-03-19 | 471, 386 | 51d | 0d |  |
| 481 | 1.6.2.4.2.1.2 | Stake/conformal coat Solid State Detector Bias Supply flight board 1 | 2d | 2004-04-01 | 2004-04-02 | 473 | 45d | 0d | start no earlier than 2004-04-01 |
| 482 | 1.6.2.4.2.1.3 | Bakeout Solid State Detector Bias Supply flight board 1 | 1d | 2004-04-05 | 2004-04-05 | 481 | 45d | 0d |  |
| 483 | 1.6.2.4.2.1.4 | Post-conf coat QA inspection of Solid State Detector Bias Supply board 1 | 1d | 2004-04-06 | 2004-04-06 | 482 | 45d | 0d |  |
| 484 | 1.6.2.4.2.1.5 | Test Solid State Detector Bias Supply flight board 1 (final) | 2d | 2004-04-07 | 2004-04-08 | 483 | 45d | 0d |  |
| 485 | 1.6.2.4.2.1.6 | Solid State Detector Bias Supply FM 1 Mass properties/photo | 1d | 2004-04-09 | 2004-04-09 | 484 | 45d | 0d |  |

| ID | WBS | Task | Duration | Start | Finish | Predecessors | Complete | Remaining | Total slack | Free slack | Constraint |
| --- | --- | --- | --- | --- | --- | --- | --- | --- | --- | --- | --- |
| 486 | 1.6.2.4.2.2 | **FM 2** | 15d | 2004-03-22 | 2004-04-09 |  |  |  | 71d |  |  |
| 487 | 1.6.2.4.2.2.1 | Test Solid State Detector Bias Supply flight board 2 (initial) | 3d | 2004-03-22 | 2004-03-24 | 475, 386, 480 |  |  | 74d | 0d |  |
| 488 | 1.6.2.4.2.2.2 | Stake/conformal coat Solid State Detector Bias Supply flight board 2 | 2d | 2004-04-01 | 2004-04-02 | 477 |  |  | 71d | 0d | start no earlier than 2004-04-01 |
| 489 | 1.6.2.4.2.2.3 | Bakeout Solid State Detector Bias Supply flight board 2 | 1d | 2004-04-05 | 2004-04-05 | 488 |  |  | 71d | 0d |  |
| 490 | 1.6.2.4.2.2.4 | Post-conf coat QA inspection of Solid State Detector Bias Supply board 2 | 1d | 2004-04-06 | 2004-04-06 | 489 |  |  | 71d | 0d |  |
| 491 | 1.6.2.4.2.2.5 | Test Solid State Detector Bias Supply flight board 2 (final) | 2d | 2004-04-07 | 2004-04-08 | 490 |  |  | 71d | 0d |  |
| 492 | 1.6.2.4.2.2.6 | Solid State Detector Bias Supply FM 2 Mass properties/photo | 1d | 2004-04-09 | 2004-04-09 | 491 |  |  | 71d | 0d |  |
| 493 | 1.6.2.5 | **Flight Software** | 145d | 2003-08-01 A | 2004-03-02 |  | 65% | 50.5d | 73d |  |  |
| 494 | 1.6.2.5.1 | SEP Central Build 3 | 105d | 2003-08-01 A | 2004-01-02 |  | 90% | 10.5d | 73d | 0d | start no earlier than 2003-08-01 |
| 495 | 1.6.2.5.2 | Final Flight S/W Build | 40d | 2004-01-05 | 2004-03-02 | 494 |  |  | 73d | 0d |  |
| 496 | 1.6.3 | **HET - GSFC** | 199d | 2003-10-01 | 2004-07-15 |  |  |  | 82d |  |  |
| 497 | 1.6.3.1 | **Deliveries** | 199d | 2003-10-01 | 2004-07-15 |  |  |  | 92d |  |  |
| 498 | 1.6.3.1.1 | Deliver HET FM 1 (to CIT for SEP Suite I&T) | 2d | 2004-06-16 | 2004-06-17 | 539 |  |  | 19d | 0d |  |
| 499 | 1.6.3.1.2 | Deliver HET FM 2 (to CIT for SEP Suite I&T) | 2d | 2004-07-14 | 2004-07-15 | 542 |  |  | 5d | 0d |  |
| 500 | 1.6.3.1.3 | Deliver Final HET Flight Software to SEP I&T | 2d | 2003-10-01 | 2003-10-02 |  |  |  | 289d |  |  |
| 501 | 1.6.3.2 | **Detectors** | 60d | 2004-01-06 | 2004-03-31 |  |  |  | 38d |  |  |
| 502 | 1.6.3.2.1 | Receive & Inspect HET Flight Detectors | 40d | 2004-01-06 | 2004-03-03 |  |  |  | 38d | 0d | start no earlier than 2004-01-06 |
| 503 | 1.6.3.2.2 | **Detector Testing** | 60d | 2004-01-06 | 2004-03-31 |  |  |  | 38d |  |  |
| 504 | 1.6.3.2.2.1 | Capacitance, Current, Depletion, Alpha Resin Testing | 60d | 2004-01-06 | 2004-03-31 | 502SS |  |  | 38d | 0d |  |
| 505 | 1.6.3.2.2.2 | Life Test HET Detectors | 60d | 2004-01-06 | 2004-03-31 | 504SS |  |  | 38d | 33d |  |
| 506 | 1.6.3.3 | **Electronics Board** | 82d | 2004-01-22 | 2004-05-17 |  |  |  | 7d |  |  |
| 507 | 1.6.3.3.1 | **Assembly** | 44d | 2004-01-22 | 2004-03-24 |  |  |  | 7d |  |  |
| 508 | 1.6.3.3.1.1 | Install Socket on HET Electronics FM 1 Board for ETU ACTEL | 1d | 2004-01-22 | 2004-01-22 |  |  |  | 7d | 0d | start no earlier than 2004-01-22 |
| 509 | 1.6.3.3.1.2 | Complete Population of HET Electronics FM 1 Board | 1d | 2004-01-23 | 2004-01-23 | 508 |  |  | 7d | 0d |  |
| 510 | 1.6.3.3.1.3 | Populate HET Electronics FM 2 Board | 10d | 2004-03-11 | 2004-03-24 | 509, 516, 561 |  |  | 7d | 0d |  |

| ID | WBS | Task | Duration | Start | Finish | Predecessors | Total slack | Free slack | Constraint |
| --- | --- | --- | --- | --- | --- | --- | --- | --- | --- |
| 511 | 1.6.3.3.2 | **Test** | 80d | 2004-01-26 | 2004-05-17 |  | 7d |  |  |
| 512 | 1.6.3.3.2.1 | **FM 1** | 78d | 2004-01-26 | 2004-05-13 |  | 7d |  |  |
| 513 | 1.6.3.3.2.1.1 | Test HET FM 1 Electronics Board w/ETU ACTEL | 20d | 2004-01-26 | 2004-02-23 | 509 | 7d | 0d |  |
| 514 | 1.6.3.3.2.1.2 | Remove ETU ACTEL and socket from HET FM 1 Electronics Board | 1d | 2004-02-24 | 2004-02-24 | 513 | 7d | 0d |  |
| 515 | 1.6.3.3.2.1.3 | Install Flight ACTEL on HET FM 1 Electronics Board | 1d | 2004-02-25 | 2004-02-25 | 514 | 7d | 0d |  |
| 516 | 1.6.3.3.2.1.4 | Retest HET FM 1 Electronics Board w/Flight ACTEL | 10d | 2004-02-26 | 2004-03-10 | 515, 561 | 7d | 0d |  |
| 517 | 1.6.3.3.2.1.5 | Conformal Coat HET FM 1 Electronics Board | 2d | 2004-03-11 | 2004-03-12 | 516 | 45d | 38d |  |
| 518 | 1.6.3.3.2.1.6 | Retest Conformal Coated HET FM 1 Electronics Board | 2d | 2004-05-06 | 2004-05-07 | 517, 522 | 7d | 0d |  |
| 519 | 1.6.3.3.2.1.7 | Bakeout HET FM 1 Electronics Board | 2d | 2004-05-10 | 2004-05-11 | 518 | 7d | 0d |  |
| 520 | 1.6.3.3.2.1.8 | Retest Bakedout HET FM 1 Electronics Board | 2d | 2004-05-12 | 2004-05-13 | 519, 524 | 7d | 0d |  |
| 521 | 1.6.3.3.2.2 | **FM 2** | 38d | 2004-03-25 | 2004-05-17 |  | 7d |  |  |
| 522 | 1.6.3.3.2.2.1 | Test HET FM 2 Electronics Board | 30d | 2004-03-25 | 2004-05-05 | 510, 513 | 7d | 0d |  |
| 523 | 1.6.3.3.2.2.2 | Conformal Coat HET FM 2 Electronics Board | 2d | 2004-05-06 | 2004-05-07 | 522 | 7d | 0d |  |
| 524 | 1.6.3.3.2.2.3 | Retest Conformal Coated HET FM 2 Electronics Board | 2d | 2004-05-10 | 2004-05-11 | 523, 518 | 7d | 0d |  |
| 525 | 1.6.3.3.2.2.4 | Bakeout HET FM 2 Electronics Board | 2d | 2004-05-12 | 2004-05-13 | 524 | 20d | 0d |  |
| 526 | 1.6.3.3.2.2.5 | Retest Bakedout HET FM 2 Electronics Board | 2d | 2004-05-14 | 2004-05-17 | 525, 520 | 20d | 5d |  |
| 527 | 1.6.3.4 | **Flight Software** | 70d | 2004-01-22 | 2004-04-29 |  | 17d |  |  |
| 528 | 1.6.3.4.1 | **Design** | 10d | 2004-01-22 | 2004-02-04 |  | 17d |  |  |
| 529 | 1.6.3.4.1.1 | Complete Definition of HET PH Event Processing | 10d | 2004-01-22 | 2004-02-04 |  | 17d | 0d | start no earlier than 2004-01-22 |
| 530 | 1.6.3.4.2 | **Coding** | 20d | 2004-02-05 | 2004-03-04 |  | 17d |  |  |
| 531 | 1.6.3.4.2.1 | Code HET PH Event Processing Update for Flight | 10d | 2004-02-05 | 2004-02-19 | 529 | 17d | 0d |  |
| 532 | 1.6.3.4.2.2 | Code HET Telemetry Formatting Update for Flight | 10d | 2004-02-20 | 2004-03-04 | 531 | 17d | 0d |  |
| 533 | 1.6.3.4.3 | **Test** | 40d | 2004-03-05 | 2004-04-29 |  | 17d |  |  |
| 534 | 1.6.3.4.3.1 | Test Integrated HET S/W with Simulated Data | 15d | 2004-03-05 | 2004-03-25 | 532 | 17d | 0d |  |
| 535 | 1.6.3.4.3.2 | Verify HET On-Board Software | 25d | 2004-03-26 | 2004-04-29 | 534 | 17d | 12d |  |

| ID | WBS | Task | Type | Duration | Start | Finish | Predecessors | Complete | Remaining | Total slack | Free slack | Constraint |
| --- | --- | --- | --- | --- | --- | --- | --- | --- | --- | --- | --- | --- |
| 536 | 1.6.3.5 | **Integration & Test** |  | 40d | 2004-05-18 | 2004-07-13 |  |  |  | 5d |  |  |
| 537 | 1.6.3.5.1 | **FM 1** |  | 20d | 2004-05-18 | 2004-06-15 |  |  |  | 5d |  |  |
| 538 | 1.6.3.5.1.1 | Integrate HET FM 1 Electronics Telescope (Ahead) |  | 5d | 2004-05-18 | 2004-05-24 | 520, 406, 505, 535 |  |  | 5d | 0d |  |
| 539 | 1.6.3.5.1.2 | Test HET FM 1 Telescope (Ahead) |  | 15d | 2004-05-25 | 2004-06-15 | 538 |  |  | 5d | 0d |  |
| 540 | 1.6.3.5.2 | **FM 2** |  | 35d | 2004-05-25 | 2004-07-13 |  |  |  | 5d |  |  |
| 541 | 1.6.3.5.2.1 | Integrate HET FM 2 Electronics Telescope (Behind) |  | 5d | 2004-05-25 | 2004-06-01 | 526, 538, 406, 505, 535 |  |  | 15d | 10d |  |
| 542 | 1.6.3.5.2.2 | Test HET FM 2 Telescope (Behind) |  | 20d | 2004-06-16 | 2004-07-13 | 539, 541 |  |  | 5d | 0d |  |
| 543 | 1.6.4 | **LET - CIT** |  | 207d | 2003-07-14 A | 2004-05-07 |  | 51% | 101.03d | 53d |  |  |
| 544 | 1.6.4.1 | **Deliveries** |  | 79d | 2004-01-15 | 2004-05-07 |  |  |  | 53d |  |  |
| 545 | 1.6.4.1.1 | Deliver LET FM 1 (stays at CIT for SEP I&T) | milestone | 0d | 2004-05-07 | 2004-05-07 | 588, 600 |  |  | 47d | 0d |  |
| 546 | 1.6.4.1.2 | Deliver LET FM 2 (stays at CIT for SEP I&T) | milestone | 0d | 2004-05-07 | 2004-05-07 | 595, 602 |  |  | 53d | 0d |  |
| 547 | 1.6.4.1.3 | Deliver LET Flight Software Build 3 | milestone | 0d | 2004-01-15 | 2004-01-15 | 597 |  |  | 126d | 79d |  |
| 548 | 1.6.4.2 | **Detectors** |  | 142d | 2003-07-14 A | 2004-02-05 |  | 48% | 73.8d | 72d |  |  |
| 549 | 1.6.4.2.1 | **Detector Testing** |  | 136d | 2003-07-14 A | 2004-01-28 |  | 42% | 78.99d | 78d |  |  |
| 550 | 1.6.4.2.1.1 | Perform Detector Noise & breakdown Testing |  | 76d | 2003-09-02 A | 2003-12-19 |  | 35% | 49.4d | 103d | 0d | start no earlier than 2003-09-02 |
| 551 | 1.6.4.2.1.2 | Perform Detector Thermal Vac Testing |  | 75d | 2003-09-15 A | 2004-01-02 | 550SS+9d | 40% | 45d | 95d | 0d |  |
| 552 | 1.6.4.2.1.3 | Perform Detector Alphas Testing |  | 76d | 2003-09-02 A | 2003-12-19 | 550SS | 35% | 49.4d | 103d | 9d |  |
| 553 | 1.6.4.2.1.4 | Analyze Detector Testing Data |  | 75d | 2003-09-15 A | 2004-01-02 | 551SS, 552SS | 35% | 48.75d | 95d | 48d |  |
| 554 | 1.6.4.2.1.5 | Capacitance, Current, Depletion, Alpha Resolution |  | 136d | 2003-07-14 A | 2004-01-28 |  | 50% | 68d | 78d | 0d | start no earlier than 2003-07-14 |
| 555 | 1.6.4.2.1.6 | Life Test LET Flight Detectors |  | 76d | 2003-07-28 A | 2003-11-13 | 554SS+10d | 50% | 38d | 128d | 81d |  |
| 556 | 1.6.4.2.2 | **Hybrids** |  | 128d | 2003-08-01 A | 2004-02-05 |  | 72% | 36.07d | 20d |  |  |
| 557 | 1.6.4.2.2.1 | Package and Test Flight Hybrids Lot 1 (7-10 Parts) |  | 21d | 2003-08-01 A | 2003-08-29 A |  | 100% |  |  |  | start no earlier than 2003-08-01 |
| 558 | 1.6.4.2.2.2 | Package and Test Flight Hybrids Lot 2 (10 Parts) |  | 24d | 2003-09-02 A | 2003-10-03 A | 557 | 100% |  |  |  |  |
| 559 | 1.6.4.2.2.3 | Package and Test Flight Hybrids Lot 3 (20 Parts) |  | 83d | 2003-09-16 A | 2004-01-15 | 558SS+10d | 60% | 33.2d | 30d | 10d |  |
| 560 | 1.6.4.2.2.4 | Select parts for flight |  | 2d | 2004-02-02 | 2004-02-03 | 559, 557, 558 |  |  | 20d | 0d | start no earlier than 2004-02-02 |
| 561 | 1.6.4.2.2.5 | Deliver HET Hybrids to GSFC |  | 2d | 2004-02-04 | 2004-02-05 | 560 |  |  | 20d | 13d |  |

| ID | WBS | Task | Duration | Start | Finish | Predecessors | Complete | Remaining | Total slack | Free slack | Constraint |
| --- | --- | --- | --- | --- | --- | --- | --- | --- | --- | --- | --- |
| 562 | 1.6.4.3 | **Detector/Misc Board** | 146d | 2003-09-15 A | 2004-04-14 |  | 62% | 55.4d | 70d |  |  |
| 563 | 1.6.4.3.1 | **Remaining Procurements** | 95d | 2003-09-15 A | 2004-02-02 |  | 99% | 0.93d | 80d |  |  |
| 564 | 1.6.4.3.1.1 | Procure LET Detector Board Flight Parts | 95d | 2003-09-15 A | 2004-02-02 |  | 99% | 0.95d | 80d | 0d | start no earlier than 2003-09-15 |
| 565 | 1.6.4.3.1.2 | Procure flight LET Detector Printed Circuit Board | 2d | 2003-10-14 A | 2003-10-15 A |  | 100% |  |  |  | start no earlier than 2003-10-14 |
| 566 | 1.6.4.3.2 | **Fabrication** | 58d | 2003-11-12 A | 2004-02-05 |  | 40% | 34.8d | 80d |  |  |
| 567 | 1.6.4.3.2.1 | Receive/inspect/database flight parts for LET Detector Board | 2d | 2004-02-03 | 2004-02-04 | 564 |  |  | 80d | 0d |  |
| 568 | 1.6.4.3.2.2 | Inspect flight LET Detector Printed Circuit Boards (coupons & elec continuity) | 2d | 2003-11-12 A | 2003-11-13 A | 565FS+18d | 100% |  |  |  |  |
| 569 | 1.6.4.3.2.3 | Burn-in flight FPGA/EEPROM for LET Detector Board | 1d | 2004-02-05 | 2004-02-05 | 567 |  |  | 80d | 0d |  |
| 570 | 1.6.4.3.3 | **Assembly** | 48d | 2004-02-06 | 2004-04-14 |  |  |  | 70d |  |  |
| 571 | 1.6.4.3.3.1 | **FM 1** | 18d | 2004-02-06 | 2004-03-03 |  |  |  | 80d |  |  |
| 572 | 1.6.4.3.3.1.1 | Assemble LET FM 1 Detector Board | 10d | 2004-02-06 | 2004-02-20 | 567, 568, 569 |  |  | 80d | 0d |  |
| 573 | 1.6.4.3.3.1.2 | Post-assembly QA inspection for flight LET Detector Boards | 1d | 2004-02-23 | 2004-02-23 | 572 |  |  | 84d | 0d |  |
| 574 | 1.6.4.3.3.1.3 | Rework/haywire/trim flight LET Detector Boards | 1d | 2004-03-02 | 2004-03-02 | 583 |  |  | 84d | 0d |  |
| 575 | 1.6.4.3.3.1.4 | Post-rework QA inspection for LET Detector Boards | 1d | 2004-03-03 | 2004-03-03 | 574 |  |  | 84d | 20d |  |
| 576 | 1.6.4.3.3.2 | **FM 2** | 18d | 2004-02-23 | 2004-03-17 |  |  |  | 80d |  |  |
| 577 | 1.6.4.3.3.2.1 | Assemble LET FM 2 Detector Board | 10d | 2004-02-23 | 2004-03-05 | 572 |  |  | 80d | 0d |  |
| 578 | 1.6.4.3.3.2.2 | Post-assembly QA inspection for flight LET Detector Boards | 1d | 2004-03-08 | 2004-03-08 | 577 |  |  | 80d | 0d |  |
| 579 | 1.6.4.3.3.2.3 | Rework/haywire/trim flight LET Detector Boards | 1d | 2004-03-16 | 2004-03-16 | 590 |  |  | 80d | 0d |  |
| 580 | 1.6.4.3.3.2.4 | Post-rework QA inspection for LET Detector Boards | 1d | 2004-03-17 | 2004-03-17 | 579 |  |  | 80d | 10d |  |
| 581 | 1.6.4.3.3.3 | **Test** | 37d | 2004-02-24 | 2004-04-14 |  |  |  | 70d |  |  |
| 582 | 1.6.4.3.3.3.1 | **FM 1** | 37d | 2004-02-24 | 2004-04-14 |  |  |  | 64d |  |  |
| 583 | 1.6.4.3.3.3.1.1 | Test LET FM 1 Detector Boards (initial) | 5d | 2004-02-24 | 2004-03-01 | 573 |  |  | 84d | 0d |  |
| 584 | 1.6.4.3.3.3.1.2 | Stake/conformal coat LET FM 1 Detector Boards | 2d | 2004-04-01 | 2004-04-02 | 575 |  |  | 64d | 0d | start no earlier than 2004-04-01 |
| 585 | 1.6.4.3.3.3.1.3 | Bakeout LET FM 1 Detector Boards | 1d | 2004-04-05 | 2004-04-05 | 584 |  |  | 64d | 0d |  |
| 586 | 1.6.4.3.3.3.1.4 | Post-conf. Coat QA inspection of LET FM 1 Detector Boards | 1d | 2004-04-06 | 2004-04-06 | 585 |  |  | 64d | 0d |  |
| 587 | 1.6.4.3.3.3.1.5 | Test LET FM 1 Detector Boards (final) | 5d | 2004-04-07 | 2004-04-13 | 586 |  |  | 64d | 0d |  |
| 588 | 1.6.4.3.3.3.1.6 | LET FM 1 Detector Board Mass properties/photo | 1d | 2004-04-14 | 2004-04-14 | 587 |  |  | 64d | 17d |  |

| ID | WBS | Task | Duration | Start | Finish | Predecessors | Complete | Remaining | Total slack | Free slack | Constraint |
| --- | --- | --- | --- | --- | --- | --- | --- | --- | --- | --- | --- |
| 589 | 1.6.4.3.3.3.2 | **FM 2** | 27d | 2004-03-09 | 2004-04-14 |  |  |  | 70d |  |  |
| 590 | 1.6.4.3.3.3.2.1 | Test LET FM 2 Detector Boards (initial) | 5d | 2004-03-09 | 2004-03-15 | 578 |  |  | 80d | 0d |  |
| 591 | 1.6.4.3.3.3.2.2 | Stake/conformal coat LET FM 2 Detector Boards | 2d | 2004-04-01 | 2004-04-02 | 580 |  |  | 70d | 0d | start no earlier than 2004-04-01 |
| 592 | 1.6.4.3.3.3.2.3 | Bakeout LET FM 2 Detector Boards | 1d | 2004-04-05 | 2004-04-05 | 591 |  |  | 70d | 0d |  |
| 593 | 1.6.4.3.3.3.2.4 | Post-conf. Coat QA inspection of LET FM 2 Detector Boards | 1d | 2004-04-06 | 2004-04-06 | 592 |  |  | 70d | 0d |  |
| 594 | 1.6.4.3.3.3.2.5 | Test LET FM 2 Detector Boards (final) | 5d | 2004-04-07 | 2004-04-13 | 593 |  |  | 70d | 0d |  |
| 595 | 1.6.4.3.3.3.2.6 | LET FM 2 Detector Board Mass properties/photo | 1d | 2004-04-14 | 2004-04-14 | 594 |  |  | 70d | 17d |  |
| 596 | 1.6.4.4 | **Flight Software** | 114d | 2003-08-01 A | 2004-01-15 |  | 90% | 11.4d | 126d |  |  |
| 597 | 1.6.4.4.1 | Let Flight Software Build 3 | 114d | 2003-08-01 A | 2004-01-15 |  | 90% | 11.4d | 126d | 0d | start no earlier than 2003-08-01 |
| 598 | 1.6.4.5 | **Integration & Test** | 40d | 2004-03-15 | 2004-05-07 |  |  |  | 47d |  |  |
| 599 | 1.6.4.5.1 | **FM 1** | 40d | 2004-03-15 | 2004-05-07 |  |  |  | 47d |  |  |
| 600 | 1.6.4.5.1.1 | Integrate LET FM 1 Housing With Detectors | 40d | 2004-03-15 | 2004-05-07 | 550, 551, 552, 553, 554, 555, 382 |  |  | 47d | 0d |  |
| 601 | 1.6.4.5.2 | **FM 2** | 40d | 2004-03-15 | 2004-05-07 |  |  |  | 53d |  |  |
| 602 | 1.6.4.5.2.1 | Integrate LET FM 2 Housing With Detectors | 40d | 2004-03-15 | 2004-05-07 | 550, 551, 552, 553, 554, 555, 382 |  |  | 53d | 0d |  |
| 603 | 1.6.5 | **SEPT - Kiel/ESTEC** | 260d | 2003-08-08 A | 2004-08-18 |  | 35% | 167.91d | 68d |  |  |
| 604 | 1.6.5.1 | **Deliveries** | 122d | 2004-03-01 | 2004-08-18 |  |  |  | 49d |  |  |
| 605 | 1.6.5.1.1 | Deliver SEPT-NS FM 1 to CIT for SEP I&T and Suite EMC | 5d | 2004-03-12 | 2004-03-18 | 649, 650 |  |  | 81d | 0d |  |
| 606 | 1.6.5.1.2 | Deliver SEPT-E FM 1 to CIT for SEP I&T and Suite EMC | 5d | 2004-03-01 | 2004-03-05 | 656, 657 |  |  | 90d | 0d |  |
| 607 | 1.6.5.1.3 | Final Delivery of SEPT FM 1 to APL | 2d | 2004-08-17 | 2004-08-18 | 651, 658 |  |  | 35d | 30d |  |
| 608 | 1.6.5.1.4 | Deliver SEPT-NS FM 2 to CIT for SEP I&T and Suite EMC | 5d | 2004-03-08 | 2004-03-12 | 664, 665 |  |  | 91d | 0d |  |
| 609 | 1.6.5.1.5 | Deliver SEPT-E FM 2 to CIT for SEP I&T and Suite EMC | 5d | 2004-03-08 | 2004-03-12 | 671, 672 |  |  | 91d | 0d |  |
| 610 | 1.6.5.1.6 | Final Delivery of SEPT FM 2 to APL | 2d | 2004-08-17 | 2004-08-18 | 666, 673 |  |  | 49d | 34d |  |
| 611 | 1.6.5.2 | **Mechanical Assembly** | 46d | 2003-12-22 A | 2004-02-27 |  | 66% | 15.71d | 190d |  |  |
| 612 | 1.6.5.2.1 | **FM 1** | 13d | 2003-12-22 A | 2004-01-09 A |  | 100% |  |  |  |  |
| 613 | 1.6.5.2.1.1 | Assemble SEPT-NS FM 1 Sensor and E-Box Housing | 13d | 2003-12-22 A | 2004-01-09 A |  | 100% |  |  |  | start no earlier than 2003-12-22 |
| 614 | 1.6.5.2.1.2 | Assemble SEPT-E FM 1 Sensor and E-Box Housing | 13d | 2003-12-22 A | 2004-01-09 A |  | 100% |  |  |  | start no earlier than 2003-12-22 |

| ID | WBS | Task | Duration | Start | Finish | Predecessors | Complete | Remaining | Total slack | Free slack | Constraint |
| --- | --- | --- | --- | --- | --- | --- | --- | --- | --- | --- | --- |
| 615 | 1.6.5.2.2 | **FM 2** | 14d | 2003-12-29 A | 2004-01-16 A |  | 100% |  |  |  |  |
| 616 | 1.6.5.2.2.1 | Assemble SEPT-NS FM 2 Sensor and E-Box Housing | 14d | 2003-12-29 A | 2004-01-16 A | 613SS+4d | 100% |  |  |  |  |
| 617 | 1.6.5.2.2.2 | Assemble SEPT-E FM 2 Sensor and E-Box Housing | 14d | 2003-12-29 A | 2004-01-16 A | 614SS+4d | 100% |  |  |  |  |
| 618 | 1.6.5.2.3 | **Spare** | 28d | 2004-01-20 | 2004-02-27 |  |  |  | 190d |  |  |
| 619 | 1.6.5.2.3.1 | Assemble SEPT Spare Sensor and E-Box Housing | 28d | 2004-01-20 | 2004-02-27 | 616, 617 |  |  | 190d |  |  |
| 620 | 1.6.5.3 | **Electronics** | 144d | 2003-08-08 A | 2004-03-08 |  | 43% | 82.09d | 184d |  |  |
| 621 | 1.6.5.3.1 | **Assembly** | 124d | 2003-08-08 A | 2004-02-06 |  | 44% | 68.95d | 184d |  |  |
| 622 | 1.6.5.3.1.1 | **FM 2** | 106d | 2003-08-08 A | 2004-01-12 A |  | 100% |  |  |  |  |
| 623 | 1.6.5.3.1.1.1 | Assemble SEPT-NS FM 2 Electronics | 106d | 2003-08-08 A | 2004-01-12 A |  | 100% |  |  |  | start no earlier than 2003-08-08 |
| 624 | 1.6.5.3.1.1.2 | Assemble SEPT-E FM 2 Electronics | 92d | 2003-08-08 A | 2003-12-19 A |  | 100% |  |  |  | start no earlier than 2003-08-08 |
| 625 | 1.6.5.3.1.2 | **Spare** | 124d | 2003-08-08 | 2004-02-06 |  |  |  | 184d |  |  |
| 626 | 1.6.5.3.1.2.1 | Assemble SEPT-NS FS Electronics | 124d | 2003-08-08 | 2004-02-06 | 623SS |  |  | 184d | 0d |  |
| 627 | 1.6.5.3.1.2.2 | Assemble SEPT-E FS Electronics | 124d | 2003-08-08 | 2004-02-06 | 624SS |  |  | 184d | 0d |  |
| 628 | 1.6.5.3.2 | **Test** | 59d | 2003-12-11 A | 2004-03-08 |  | 35% | 38.55d | 184d |  |  |
| 629 | 1.6.5.3.2.1 | **FM 2** | 34d | 2003-12-11 A | 2004-01-30 |  | 74% | 8.74d | 209d |  |  |
| 630 | 1.6.5.3.2.1.1 | SEPT-NS FM 2 Electronics Test | 4d | 2004-01-13 A | 2004-01-16 A | 623 | 100% |  |  |  |  |
| 631 | 1.6.5.3.2.1.2 | SEPT-E FM 2 Electronics Test | 4d | 2003-12-11 A | 2003-12-16 A | 624FS-7d | 100% |  |  |  |  |
| 632 | 1.6.5.3.2.1.3 | Coat SEPT-NS FM 2 Electronics Board | 4d | 2004-01-20 | 2004-01-23 | 630 |  |  | 209d | 0d |  |
| 633 | 1.6.5.3.2.1.4 | Coat SEPT-E FM 2 Electronics Board | 5d | 2003-12-17 A | 2003-12-23 A | 631 | 100% |  |  |  |  |
| 634 | 1.6.5.3.2.1.5 | SEPT-NS FM 2 Mechanical Integration | 5d | 2004-01-26 | 2004-01-30 | 632 |  |  | 209d |  |  |
| 635 | 1.6.5.3.2.1.6 | SEPT-E FM 2 Mechanical Integration | 13d | 2003-12-24 A | 2004-01-13 A | 633 | 100% |  |  |  |  |
| 636 | 1.6.5.3.2.2 | **Spare** | 20d | 2004-02-09 | 2004-03-08 |  |  |  | 184d |  |  |
| 637 | 1.6.5.3.2.2.1 | SEPT-NS Flight Spare Electronics Test | 5d | 2004-02-09 | 2004-02-13 | 626 |  |  | 184d | 0d |  |
| 638 | 1.6.5.3.2.2.2 | SEPT-E Flight Spare Electronics Test | 5d | 2004-02-09 | 2004-02-13 | 627 |  |  | 184d | 0d |  |
| 639 | 1.6.5.3.2.2.3 | Coat SEPT-NS FS Electronics Board | 5d | 2004-02-17 | 2004-02-23 | 637 |  |  | 184d | 0d |  |
| 640 | 1.6.5.3.2.2.4 | Coat SEPT-E FS Electronics Board | 5d | 2004-02-17 | 2004-02-23 | 638 |  |  | 184d | 0d |  |
| 641 | 1.6.5.3.2.2.5 | SEPT-NS FS Mechanical Integration | 10d | 2004-02-24 | 2004-03-08 | 639 |  |  | 184d |  |  |
| 642 | 1.6.5.3.2.2.6 | SEPT-E FS Mechanical Integration | 10d | 2004-02-24 | 2004-03-08 | 640 |  |  | 184d |  |  |

| ID | WBS | Task | Duration | Start | Finish | Predecessors | Complete | Remaining | Total slack | Free slack | Constraint |
| --- | --- | --- | --- | --- | --- | --- | --- | --- | --- | --- | --- |
| 643 | 1.6.5.4 | **Integration & Test** | 153d | 2004-01-12 A | 2004-08-16 |  | 3% | 148.55d | 49d |  |  |
| 644 | 1.6.5.4.1 | **FM 1** | 153d | 2004-01-12 A | 2004-08-16 |  | 6% | 144.1d | 35d |  |  |
| 645 | 1.6.5.4.1.1 | **SEPT-NS** | 144d | 2004-01-26 | 2004-08-16 |  |  |  | 35d |  |  |
| 646 | 1.6.5.4.1.1.1 | SEPT-NS FM 1 Integration & Test | 5d | 2004-01-26 | 2004-01-30 | 613 |  |  | 81d | 0d | start no earlier than 2004-01-26 |
| 647 | 1.6.5.4.1.1.2 | Muon and Radioactive Source Test | 5d | 2004-02-02 | 2004-02-06 | 646 |  |  | 81d | 0d |  |
| 648 | 1.6.5.4.1.1.3 | SEPT-NS FM 1 Vibration and Acoustics | 10d | 2004-02-09 | 2004-02-23 | 647 |  |  | 81d | 0d |  |
| 649 | 1.6.5.4.1.1.4 | SEPT-NS FM 1 Thermal Vac | 10d | 2004-02-24 | 2004-03-08 | 648 |  |  | 81d | 0d |  |
| 650 | 1.6.5.4.1.1.5 | SEPT-NS FM 1 Bake Out | 3d | 2004-03-09 | 2004-03-11 | 649 |  |  | 81d | 0d |  |
| 651 | 1.6.5.4.1.1.6 | SEPT-NS FM 1 Thermal Balance | 10d | 2004-08-03 | 2004-08-16 | 16 |  |  | 35d | 0d |  |
| 652 | 1.6.5.4.1.2 | **SEPT-E** | 153d | 2004-01-12 A | 2004-08-16 |  | 12% | 135.21d | 35d |  |  |
| 653 | 1.6.5.4.1.2.1 | SEPT-E FM 1 Integration & Test | 5d | 2004-01-12 A | 2004-01-16 A | 614 | 100% |  |  |  |  |
| 654 | 1.6.5.4.1.2.2 | Muon and Radioactive Source Test | 5d | 2004-01-20 | 2004-01-26 | 653 |  |  | 90d | 0d |  |
| 655 | 1.6.5.4.1.2.3 | SEPT-E FM 1 Vibration and Acoustics | 10d | 2004-01-27 | 2004-02-09 | 654 |  |  | 90d | 0d |  |
| 656 | 1.6.5.4.1.2.4 | SEPT-E FM 1 Thermal Vac | 10d | 2004-02-10 | 2004-02-24 | 655 |  |  | 90d | 0d |  |
| 657 | 1.6.5.4.1.2.5 | SEPT-E FM 1 Bake Out | 3d | 2004-02-25 | 2004-02-27 | 656 |  |  | 90d | 0d |  |
| 658 | 1.6.5.4.1.2.6 | SEPT-E FM 1 Thermal Balance | 10d | 2004-08-03 | 2004-08-16 | 16 |  |  | 35d | 0d |  |
| 659 | 1.6.5.4.2 | **FM 2** | 148d | 2004-01-20 | 2004-08-16 |  |  |  | 49d |  |  |
| 660 | 1.6.5.4.2.1 | **SEPT-NS** | 148d | 2004-01-20 | 2004-08-16 |  |  |  | 49d |  |  |
| 661 | 1.6.5.4.2.1.1 | SEPT-NS FM 2 Integration & Test | 5d | 2004-01-20 | 2004-01-26 | 616 |  |  | 91d | 0d |  |
| 662 | 1.6.5.4.2.1.2 | Muon and Radioactive Source Test | 5d | 2004-01-27 | 2004-02-02 | 661 |  |  | 91d | 0d |  |
| 663 | 1.6.5.4.2.1.3 | SEPT-NS FM 2 Vibration and Acoustics | 10d | 2004-02-03 | 2004-02-17 | 662 |  |  | 91d | 0d |  |
| 664 | 1.6.5.4.2.1.4 | SEPT-NS FM 2 Thermal Vac | 10d | 2004-02-18 | 2004-03-02 | 663 |  |  | 91d | 0d |  |
| 665 | 1.6.5.4.2.1.5 | SEPT-NS FM 2 Bake Out | 3d | 2004-03-03 | 2004-03-05 | 664 |  |  | 91d | 0d |  |
| 666 | 1.6.5.4.2.1.6 | SEPT-NS FM 2 Thermal Balance | 10d | 2004-08-03 | 2004-08-16 | 16 |  |  | 49d | 0d |  |

| ID | WBS | Task | Duration | Start | Finish | Predecessors | Complete | Remaining | Total slack | Free slack | Constraint |
| --- | --- | --- | --- | --- | --- | --- | --- | --- | --- | --- | --- |
| 667 | 1.6.5.4.2.2 | **SEPT-E** | 148d | 2004-01-20 | 2004-08-16 |  |  |  | 49d |  |  |
| 668 | 1.6.5.4.2.2.1 | SEPT-E FM 2 Integration & Test | 5d | 2004-01-20 | 2004-01-26 | 617 |  |  | 91d | 0d |  |
| 669 | 1.6.5.4.2.2.2 | Muon and Radioactive Source Test | 5d | 2004-01-27 | 2004-02-02 | 668 |  |  | 91d | 0d |  |
| 670 | 1.6.5.4.2.2.3 | SEPT-E FM 2 Vibration and Acoustics | 10d | 2004-02-03 | 2004-02-17 | 669 |  |  | 91d | 0d |  |
| 671 | 1.6.5.4.2.2.4 | SEPT-E FM 2 Thermal Vac | 10d | 2004-02-18 | 2004-03-02 | 670 |  |  | 91d | 0d |  |
| 672 | 1.6.5.4.2.2.5 | SEPT-E FM 2 Bake Out | 3d | 2004-03-03 | 2004-03-05 | 671 |  |  | 91d | 0d |  |
| 673 | 1.6.5.4.2.2.6 | SEPT-E FM 2 Thermal Balance | 10d | 2004-08-03 | 2004-08-16 | 16 |  |  | 49d | 0d |  |
| 674 | 1.6.6 | **SIT - UMD** | 348d | 2003-06-02 A | 2004-10-15 |  | 27% | 255.68d | 28d |  |  |
| 675 | 1.6.6.1 | **Deliveries** | 57d | 2004-07-13 | 2004-09-30 |  |  |  | 10d |  |  |
| 676 | 1.6.6.1.1 | Deliver SIT FM 1 to CIT for SEP I&T and Suite EMC | 2d | 2004-07-13 | 2004-07-14 | 774 |  |  | 10d | 0d |  |
| 677 | 1.6.6.1.2 | Deliver SIT FM 1 back to GSFC for Environmental Testing | 2d | 2004-08-03 | 2004-08-04 | 16 |  |  | 10d | 5d |  |
| 678 | 1.6.6.1.3 | Final Delivery of SIT FM 1 to APL | 1d | 2004-09-30 | 2004-09-30 | 806 |  |  | 5d | 0d |  |
| 679 | 1.6.6.1.4 | Deliver SIT FM 2 to CIT for SEP I&T | 2d | 2004-07-20 | 2004-07-21 | 779 |  |  | 9d | 0d |  |
| 680 | 1.6.6.1.5 | Deliver SIT FM 2 back to GSFC for Environmental Testing | 2d | 2004-08-10 | 2004-08-11 | 865 |  |  | 5d | 0d |  |
| 681 | 1.6.6.1.6 | Final Delivery of SIT FM 2 to APL | 1d | 2004-09-30 | 2004-09-30 | 806 |  |  | 19d | 4d |  |
| 682 | 1.6.6.2 | **Detectors** | 43d | 2004-01-05 | 2004-03-05 |  |  |  | 58d |  |  |
| 683 | 1.6.6.2.1 | **Detector Testing** | 43d | 2004-01-05 | 2004-03-05 |  |  |  | 58d |  |  |
| 684 | 1.6.6.2.1.1 | **FM 1** | 43d | 2004-01-05 | 2004-03-05 |  |  |  | 53d |  |  |
| 685 | 1.6.6.2.1.1.1 | Test FM 1 Solid States Detectors | 24d | 2004-01-05 | 2004-02-06 |  |  |  | 62d | 0d | start no earlier than 2004-01-05 |
| 686 | 1.6.6.2.1.1.2 | Test FM 1 Foils | 24d | 2004-01-05 | 2004-02-06 | 685SS |  |  | 62d | 0d |  |
| 687 | 1.6.6.2.1.1.3 | Alpha Tests FM 1 w/Proto Elect | 10d | 2004-02-23 | 2004-03-05 | 685, 686, 372 |  |  | 53d | 0d |  |
| 688 | 1.6.6.2.1.2 | **FM 2** | 43d | 2004-01-05 | 2004-03-05 |  |  |  | 58d |  |  |
| 689 | 1.6.6.2.1.2.1 | Test FM 2 Solid States Detectors | 24d | 2004-01-05 | 2004-02-06 | 685SS |  |  | 67d | 9d |  |
| 690 | 1.6.6.2.1.2.2 | Test FM 2 Foils | 24d | 2004-01-05 | 2004-02-06 | 686SS |  |  | 67d | 9d |  |
| 691 | 1.6.6.2.1.2.3 | Alpha Tests FM 2 w/Proto Elect | 10d | 2004-02-23 | 2004-03-05 | 689, 690, 372 |  |  | 58d | 24d |  |

| ID | WBS | Task | Type | Duration | Start | Finish | Predecessors | Complete | Remaining | Total slack | Free slack | Constraint |
| --- | --- | --- | --- | --- | --- | --- | --- | --- | --- | --- | --- | --- |
| 692 | 1.6.6.3 | **ACTEL - for SIT Logic Board** |  | 11d | 2004-02-27 | 2004-03-12 |  |  |  | 81d |  |  |
| 693 | 1.6.6.3.1 | Burn Final SIT ACTEL Chip (at GSFC) |  | 1d | 2004-02-27 | 2004-02-27 |  |  |  | 81d | 0d | start no earlier than 2004-02-27 |
| 694 | 1.6.6.3.2 | Evaluate (Test) SIT Final ACTEL Chip |  | 10d | 2004-03-01 | 2004-03-12 | 693 |  |  | 81d | 71d |  |
| 695 | 1.6.6.4 | **TOF Boards** |  | 20d | 2004-01-30 | 2004-02-27 |  |  |  | 66d |  |  |
| 696 | 1.6.6.4.1 | Receive Analog and Digital TOF Boards (FM 1 & FM 2) | milestone | 0d | 2004-01-30 | 2004-01-30 |  |  |  | 66d | 0d | start no earlier than 2004-01-30 |
| 697 | 1.6.6.4.2 | **Test** |  | 20d | 2004-01-30 | 2004-02-27 |  |  |  | 66d |  |  |
| 698 | 1.6.6.4.2.1 | **FM 1** |  | 10d | 2004-01-30 | 2004-02-12 |  |  |  | 66d |  |  |
| 699 | 1.6.6.4.2.1.1 | FM 1 TOF Boards Functional Test |  | 10d | 2004-01-30 | 2004-02-12 | 696 |  |  | 66d | 0d |  |
| 700 | 1.6.6.4.2.2 | **FM 2** |  | 10d | 2004-02-13 | 2004-02-27 |  |  |  | 66d |  |  |
| 701 | 1.6.6.4.2.2.1 | FM 2 TOF Boards Functional Test |  | 10d | 2004-02-13 | 2004-02-27 | 696, 699 |  |  | 66d | 52d |  |
| 702 | 1.6.6.5 | **Energy Board** |  | 76d | 2003-11-10 A | 2004-03-02 |  | 57% | 32.42d | 64d |  |  |
| 703 | 1.6.6.5.1 | **Assembly** |  | 46d | 2003-11-10 A | 2004-01-16 |  | 76% | 11.02d | 79d |  |  |
| 704 | 1.6.6.5.1.1 | **FM 1** |  | 46d | 2003-11-10 A | 2004-01-16 |  | 76% | 11d | 64d |  |  |
| 705 | 1.6.6.5.1.1.1 | Assemble FM 1 Energy Board |  | 46d | 2003-11-10 A | 2004-01-16 |  | 76% | 11d | 64d | 0d | start no earlier than 2003-11-10 |
| 706 | 1.6.6.5.1.2 | **FM 2** |  | 46d | 2003-11-10 A | 2004-01-16 |  | 76% | 11.04d | 79d |  |  |
| 707 | 1.6.6.5.1.2.1 | Assemble FM 2 Energy Board |  | 46d | 2003-11-10 A | 2004-01-16 | 705SS | 76% | 11.04d | 79d | 15d |  |
| 708 | 1.6.6.5.2 | **Test** |  | 30d | 2004-01-20 | 2004-03-02 |  |  |  | 64d |  |  |
| 709 | 1.6.6.5.2.1 | **FM 1** |  | 15d | 2004-01-20 | 2004-02-09 |  |  |  | 64d |  |  |
| 710 | 1.6.6.5.2.1.1 | Bench Test/Calibration |  | 10d | 2004-01-20 | 2004-02-02 | 705 |  |  | 64d | 0d |  |
| 711 | 1.6.6.5.2.1.2 | Thermal |  | 3d | 2004-02-03 | 2004-02-05 | 710 |  |  | 64d | 0d |  |
| 712 | 1.6.6.5.2.1.3 | Voltage Margin |  | 2d | 2004-02-06 | 2004-02-09 | 711 |  |  | 64d | 0d |  |
| 713 | 1.6.6.5.2.2 | **FM 2** |  | 15d | 2004-02-10 | 2004-03-02 |  |  |  | 64d |  |  |
| 714 | 1.6.6.5.2.2.1 | FM 2 Energy Board Functional Test |  | 15d | 2004-02-10 | 2004-03-02 | 707, 712 |  |  | 64d | 50d |  |
| 715 | 1.6.6.6 | **Logic Board** |  | 165d | 2003-11-10 A | 2004-07-06 |  | 31% | 113.58d | 9d |  |  |
| 716 | 1.6.6.6.1 | **Design** |  | 3d | 2003-11-17 A | 2003-11-19 A |  | 100% |  |  |  |  |
| 717 | 1.6.6.6.1.1 | Layout new Logic Board Design |  | 3d | 2003-11-17 A | 2003-11-19 A |  | 100% |  |  |  | start no earlier than 2003-11-17 |

| ID | WBS | Task | Duration | Start | Finish | Predecessors | Complete | Remaining | Total slack | Free slack | Constraint |
| --- | --- | --- | --- | --- | --- | --- | --- | --- | --- | --- | --- |
| 718 | 1.6.6.6.2 | **Fabrication** | 10d | 2004-02-02 | 2004-02-13 |  |  |  | 24d |  |  |
| 719 | 1.6.6.6.2.1 | FM 1 & FM 2 Logic Board Fabrication | 10d | 2004-02-02 | 2004-02-13 | 717, 733 |  |  | 24d | 0d | start no earlier than 2004-02-02 |
| 720 | 1.6.6.6.3 | **Assembly** | 88d | 2004-03-02 | 2004-07-02 |  |  |  | 9d |  |  |
| 721 | 1.6.6.6.3.1 | **FM 1** | 83d | 2004-03-02 | 2004-06-25 |  |  |  | 10d |  |  |
| 722 | 1.6.6.6.3.1.1 | Assemble FM 1 Logic Board with ETU ACTELs | 11d | 2004-03-02 | 2004-03-16 | 735 |  |  | 24d | 0d |  |
| 723 | 1.6.6.6.3.1.2 | Disassembel FM 1 Logic Board with ETU ACTELs | 1d | 2004-06-22 | 2004-06-22 | 788 |  |  | 10d | 0d |  |
| 724 | 1.6.6.6.3.1.3 | Retrofit/Inspect FM 1 Flight ACTELs | 2d | 2004-06-23 | 2004-06-24 | 723, 694 |  |  | 10d | 0d |  |
| 725 | 1.6.6.6.3.1.4 | Reassemble FM 1 Logic Board with Flight ACTELs | 1d | 2004-06-25 | 2004-06-25 | 724 |  |  | 10d | 0d |  |
| 726 | 1.6.6.6.3.2 | **FM 2** | 88d | 2004-03-02 | 2004-07-02 |  |  |  | 9d |  |  |
| 727 | 1.6.6.6.3.2.1 | Assemble FM 2 Logic Board with ETU ACTELS | 11d | 2004-03-02 | 2004-03-16 | 735 |  |  | 39d | 15d |  |
| 728 | 1.6.6.6.3.2.2 | Disassemble FM 2 Logic Boards | 1d | 2004-06-29 | 2004-06-29 | 797, 723SS |  |  | 9d | 0d |  |
| 729 | 1.6.6.6.3.2.3 | Retrofit/Inspect Flight ACTELS | 2d | 2004-06-30 | 2004-07-01 | 728, 694 |  |  | 9d | 0d |  |
| 730 | 1.6.6.6.3.2.4 | Reassemble FM 2 Logic Boards | 1d | 2004-07-02 | 2004-07-02 | 729 |  |  | 9d | 0d |  |
| 731 | 1.6.6.6.4 | **Test** | 165d | 2003-11-10 A | 2004-07-06 |  | 42% | 96.25d | 9d |  |  |
| 732 | 1.6.6.6.4.1 | **ETU** | 55d | 2003-11-10 A | 2004-01-30 |  | 75% | 13.75d | 24d |  |  |
| 733 | 1.6.6.6.4.1.1 | Test New ETU Logic Board | 55d | 2003-11-10 A | 2004-01-30 |  | 75% | 13.75d | 24d | 0d | start no earlier than 2003-11-10 |
| 734 | 1.6.6.6.4.2 | **FM1 & FM 2** | 10d | 2004-02-17 | 2004-03-01 |  |  |  | 24d |  |  |
| 735 | 1.6.6.6.4.2.1 | Coupon Testing | 10d | 2004-02-17 | 2004-03-01 | 719 |  |  | 24d | 0d |  |
| 736 | 1.6.6.6.4.3 | **FM 1** | 74d | 2004-03-17 | 2004-06-29 |  |  |  | 10d |  |  |
| 737 | 1.6.6.6.4.3.1 | Functional Test of FM 1 Logic Board w/ETU ACTELS | 15d | 2004-03-17 | 2004-04-06 | 722 |  |  | 24d | 0d |  |
| 738 | 1.6.6.6.4.3.2 | Funtional Test of FM 1 Logic Board w/Flight ACTELS | 2d | 2004-06-28 | 2004-06-29 | 725 |  |  | 10d | 0d |  |
| 739 | 1.6.6.6.4.4 | **FM 2** | 64d | 2004-04-07 | 2004-07-06 |  |  |  | 9d |  |  |
| 740 | 1.6.6.6.4.4.1 | Functional Test of FM 2 Logic Board w/ETU ACTELS | 15d | 2004-04-07 | 2004-04-27 | 727, 737 |  |  | 24d | 10d |  |
| 741 | 1.6.6.6.4.4.2 | Functional Test of FM 2 Logic Board w/Flight ACTELS | 2d | 2004-07-05 | 2004-07-06 | 730 |  |  | 9d | 0d |  |

| ID | WBS | Task | Duration | Start | Finish | Predecessors | Complete | Remaining | Total slack | Free slack | Constraint |
| --- | --- | --- | --- | --- | --- | --- | --- | --- | --- | --- | --- |
| 742 | 1.6.6.7 | **Mother Board** | 50d | 2003-12-22 | 2004-03-04 |  |  |  | 49d |  |  |
| 743 | 1.6.6.7.1 | **Design** | 15d | 2003-12-22 | 2004-01-13 |  |  |  | 49d |  |  |
| 744 | 1.6.6.7.1.1 | **FM 1 & FM 2** | 15d | 2003-12-22 | 2004-01-13 |  |  |  | 49d |  |  |
| 745 | 1.6.6.7.1.1.1 | Finalize Mother Board Layout | 15d | 2003-12-22 | 2004-01-13 |  |  |  | 49d | 0d | start no earlier than 2003-12-22 |
| 746 | 1.6.6.7.2 | **Fabrication** | 15d | 2004-01-14 | 2004-02-04 |  |  |  | 49d |  |  |
| 747 | 1.6.6.7.2.1 | **FM 1 & FM 2** | 15d | 2004-01-14 | 2004-02-04 |  |  |  | 49d |  |  |
| 748 | 1.6.6.7.2.1.1 | Fabricate FM 1 & FM 2 Mother Boards | 15d | 2004-01-14 | 2004-02-04 | 745 |  |  | 49d | 0d |  |
| 749 | 1.6.6.7.3 | **Assembly** | 10d | 2004-02-05 | 2004-02-19 |  |  |  | 49d |  |  |
| 750 | 1.6.6.7.3.1 | Assemble FM 1 Mother Board | 10d | 2004-02-05 | 2004-02-19 | 748 |  |  | 49d | 0d |  |
| 751 | 1.6.6.7.3.2 | Assemble FM 2 Mother Board | 10d | 2004-02-05 | 2004-02-19 | 750SS |  |  | 54d | 5d |  |
| 752 | 1.6.6.7.4 | **Test** | 20d | 2004-02-05 | 2004-03-04 |  |  |  | 59d |  |  |
| 753 | 1.6.6.7.4.1 | **FM 1 & FM 2** | 15d | 2004-02-05 | 2004-02-26 |  |  |  | 191d |  |  |
| 754 | 1.6.6.7.4.1.1 | Coupon Testing of Mother Boards | 15d | 2004-02-05 | 2004-02-26 | 748 |  |  | 191d |  |  |
| 755 | 1.6.6.7.4.2 | **FM 1** | 5d | 2004-02-20 | 2004-02-26 |  |  |  | 49d |  |  |
| 756 | 1.6.6.7.4.2.1 | Functional Test FM 1 Mother Board | 5d | 2004-02-20 | 2004-02-26 | 750 |  |  | 49d | 0d |  |
| 757 | 1.6.6.7.4.3 | **FM 2** | 5d | 2004-02-27 | 2004-03-04 |  |  |  | 49d |  |  |
| 758 | 1.6.6.7.4.3.1 | Functional Test FM 2 Mother Board | 5d | 2004-02-27 | 2004-03-04 | 751, 756 |  |  | 49d | 15d |  |
| 759 | 1.6.6.8 | **HVPS** | 62d | 2004-01-12 | 2004-04-08 |  |  |  | 34d |  |  |
| 760 | 1.6.6.8.1 | **Test** | 62d | 2004-01-12 | 2004-04-08 |  |  |  | 34d |  |  |
| 761 | 1.6.6.8.1.1 | **FM 1** | 10d | 2004-01-12 | 2004-01-26 |  |  |  | 81d |  |  |
| 762 | 1.6.6.8.1.1.1 | Functional Test SIT FM 1 HVPS | 10d | 2004-01-12 | 2004-01-26 | 72 |  |  | 81d | 28d | start no earlier than 2004-01-12 |
| 763 | 1.6.6.8.1.2 | **FM 2** | 10d | 2004-03-26 | 2004-04-08 |  |  |  | 34d |  |  |
| 764 | 1.6.6.8.1.2.1 | Functional Test SIT FM 2 HVPS | 10d | 2004-03-26 | 2004-04-08 | 78, 758 |  |  | 34d | 0d |  |
| 765 | 1.6.6.9 | **Flight Software** | 210d | 2003-06-02 A | 2004-04-01 |  | 70% | 63d | 65d |  |  |
| 766 | 1.6.6.9.1 | **Test** | 210d | 2003-06-02 A | 2004-04-01 |  | 70% | 63d | 65d |  |  |
| 767 | 1.6.6.9.1.1 | **FM 1 & FM 2** | 210d | 2003-06-02 A | 2004-04-01 |  | 70% | 63d | 65d |  |  |
| 768 | 1.6.6.9.1.1.1 | Validate SIT On-Board Code | 210d | 2003-06-02 A | 2004-04-01 |  | 70% | 63d | 65d | 55d | start no earlier than 2003-06-02 |

| ID | WBS | Task | Duration | Start | Finish | Predecessors | Total slack | Free slack |
| --- | --- | --- | --- | --- | --- | --- | --- | --- |
| 769 | 1.6.6.10 | **Integration & Test** | 95d | 2004-03-08 | 2004-07-19 |  | 9d |  |
| 770 | 1.6.6.10.1 | **FM 1** | 9d | 2004-06-30 | 2004-07-12 |  | 10d |  |
| 771 | 1.6.6.10.1.1 | Disassemble SIT FM 1 | 1d | 2004-06-30 | 2004-06-30 | 738 | 10d | 0d |
| 772 | 1.6.6.10.1.2 | Conformal Coat SIT FM 1 Boards | 2d | 2004-07-01 | 2004-07-02 | 771 | 10d | 0d |
| 773 | 1.6.6.10.1.3 | Reassemble SIT FM 1 | 1d | 2004-07-05 | 2004-07-05 | 772 | 10d | 0d |
| 774 | 1.6.6.10.1.4 | Post-Coat Retest SIT FM 1 | 5d | 2004-07-06 | 2004-07-12 | 773 | 10d | 0d |
| 775 | 1.6.6.10.2 | **FM 2** | 9d | 2004-07-07 | 2004-07-19 |  | 9d |  |
| 776 | 1.6.6.10.2.1 | Disassemble SIT FM 2 | 1d | 2004-07-07 | 2004-07-07 | 741 | 9d | 0d |
| 777 | 1.6.6.10.2.2 | Conformal Coat SIT FM 2 Boards | 2d | 2004-07-08 | 2004-07-09 | 776 | 9d | 0d |
| 778 | 1.6.6.10.2.3 | Reassemble SIT FM 2 | 1d | 2004-07-12 | 2004-07-12 | 777 | 9d | 0d |
| 779 | 1.6.6.10.2.4 | Post-Coat Retest SIT FM 2 | 5d | 2004-07-13 | 2004-07-19 | 778 | 9d | 0d |
| 780 | 1.6.6.10.3 | **FM 1** | 75d | 2004-03-08 | 2004-06-21 |  | 10d |  |
| 781 | 1.6.6.10.3.1 | Integrate SIT FM 1 HVPS and SIT FM 1 Telescope Without Electronics | 3d | 2004-03-08 | 2004-03-10 | 762, 687 | 53d | 44d |
| 782 | 1.6.6.10.3.2 | Integrate SIT FM 1Telescope | 2d | 2004-05-12 | 2004-05-13 | 737, 699, 756, 712, 781, 401 | 9d | 0d |
| 783 | 1.6.6.10.3.3 | SIT FM 1 Debug | 5d | 2004-05-14 | 2004-05-20 | 782 | 9d | 0d |
| 784 | 1.6.6.10.3.4 | SIT FM 1 Bench Test | 5d | 2004-05-21 | 2004-05-27 | 783 | 9d | 0d |
| 785 | 1.6.6.10.3.5 | SIT FM 1 Alpha TEST | 5d | 2004-05-28 | 2004-06-04 | 784 | 9d | 0d |
| 786 | 1.6.6.10.3.6 | SIT FM 1 Noise Removal | 5d | 2004-06-07 | 2004-06-11 | 785 | 9d | 0d |
| 787 | 1.6.6.10.3.7 | SIT FM 1 Thermal Test | 5d | 2004-06-14 | 2004-06-18 | 786 | 10d | 0d |
| 788 | 1.6.6.10.3.8 | SIT FM 1 Functional Test | 1d | 2004-06-21 | 2004-06-21 | 787, 768 | 10d | 0d |
| 789 | 1.6.6.10.4 | **FM 2** | 56d | 2004-04-09 | 2004-06-28 |  | 9d |  |
| 790 | 1.6.6.10.4.1 | Integrate SIT FM 2 HVPS and SIT FM 2 Telescope Without Electronics | 3d | 2004-04-09 | 2004-04-13 | 764, 691 | 34d | 20d |
| 791 | 1.6.6.10.4.2 | Integrate SIT FM 2 Telescope | 2d | 2004-05-12 | 2004-05-13 | 740, 701, 758, 714, 790, 401 | 14d | 0d |
| 792 | 1.6.6.10.4.3 | SIT FM 2 Debug | 5d | 2004-05-14 | 2004-05-20 | 791 | 14d | 0d |
| 793 | 1.6.6.10.4.4 | SIT FM 2 Bench Test | 5d | 2004-05-21 | 2004-05-27 | 792 | 14d | 0d |
| 794 | 1.6.6.10.4.5 | SIT FM 2 Alpha Test | 5d | 2004-05-28 | 2004-06-04 | 793 | 14d | 0d |
| 795 | 1.6.6.10.4.6 | SIT FM 2 Noise Removal | 5d | 2004-06-14 | 2004-06-18 | 794, 786 | 9d | 0d |
| 796 | 1.6.6.10.4.7 | SIT FM 2 Thermal Test | 5d | 2004-06-21 | 2004-06-25 | 795 | 9d | 0d |
| 797 | 1.6.6.10.4.8 | SIT FM 2 Functional Test | 1d | 2004-06-28 | 2004-06-28 | 796 | 9d | 0d |

| ID | WBS | Task | Duration | Start | Finish | Predecessors | Complete | Remaining | Total slack | Free slack | Constraint |
| --- | --- | --- | --- | --- | --- | --- | --- | --- | --- | --- | --- |
| 798 | 1.6.6.11 | **Environmental Testing at GSFC (FM 1 & FM 2)** | 34d | 2004-08-12 | 2004-09-29 |  |  |  | 5d |  |  |
| 799 | 1.6.6.11.1 | SIT FM 1 & FM 2 Vibration and Acoustics | 10d | 2004-08-12 | 2004-08-25 | 677, 680 |  |  | 5d | 0d |  |
| 800 | 1.6.6.11.2 | Functional Test | 1d | 2004-08-26 | 2004-08-26 | 799 |  |  | 5d | 0d |  |
| 801 | 1.6.6.11.3 | SIT FM 1 & FM 2 Thermal Balance | 5d | 2004-08-27 | 2004-09-02 | 800 |  |  | 5d | 0d |  |
| 802 | 1.6.6.11.4 | SIT FM 1 & FM 2 Thermal Vac | 10d | 2004-09-03 | 2004-09-17 | 801 |  |  | 5d | 0d |  |
| 803 | 1.6.6.11.5 | Disassemble SIT Instruments | 2d | 2004-09-20 | 2004-09-21 | 802 |  |  | 5d | 0d |  |
| 804 | 1.6.6.11.6 | Bake Out | 3d | 2004-09-22 | 2004-09-24 | 803 |  |  | 5d | 0d |  |
| 805 | 1.6.6.11.7 | Reassemble Instruments | 2d | 2004-09-27 | 2004-09-28 | 804 |  |  | 5d | 0d |  |
| 806 | 1.6.6.11.8 | Functional Test | 1d | 2004-09-29 | 2004-09-29 | 805 |  |  | 5d | 0d |  |
| 807 | 1.6.6.12 | **Emulators/Simulators/GSE** | 211d | 2003-12-17 A | 2004-10-15 |  | 9% | 191.82d | 28d |  |  |
| 808 | 1.6.6.12.1 | **Simulators** | 80d | 2003-12-17 A | 2004-04-12 |  | 13% | 70d | 159d |  |  |
| 809 | 1.6.6.12.1.1 | Labview CPU Ready | 80d | 2003-12-17 A | 2004-04-12 |  | 13% | 70d | 159d | 0d | start no earlier than 2003-12-17 |
| 810 | 1.6.6.12.1.2 | Test Simulator | 80d | 2003-12-17 A | 2004-04-12 | 809SS | 13% | 70d | 159d |  |  |
| 811 | 1.6.6.12.2 | **GSE** | 60d | 2004-07-22 | 2004-10-15 |  |  |  | 28d |  |  |
| 812 | 1.6.6.12.2.1 | Pulse Generator | 60d | 2004-07-22 | 2004-10-15 | 676, 679 |  |  | 28d |  |  |
| 813 | 1.6.7 | **SEP Suite I&T - CIT** | 333d | 2003-08-01 A | 2004-11-26 |  | 28% | 238.5d | 0d |  |  |
| 814 | 1.6.7.1 | **ETU** | 5d | 2004-02-23 | 2004-02-27 |  |  |  | 190d |  |  |
| 815 | 1.6.7.1.1 | Complete Integration/Test of SEP Central EM with Sensors | 5d | 2004-02-23 | 2004-02-27 |  |  |  | 190d |  | start no earlier than 2004-02-23 |
| 816 | 1.6.7.2 | **FM 1 & FM 2** | 143d | 2004-03-08 | 2004-09-24 |  |  |  | 42d |  |  |
| 817 | 1.6.7.2.1 | Software Support For SEP Integration | 115d | 2004-04-15 | 2004-09-24 | 828SS |  |  | 42d |  |  |
| 818 | 1.6.7.2.2 | Generate SEPT integration & test procedure | 5d | 2004-03-08 | 2004-03-12 | 829FS-10d |  |  | 86d | 24d |  |
| 819 | 1.6.7.2.3 | Generate LET integration & test procedure | 5d | 2004-04-05 | 2004-04-09 | 830FS-10d |  |  | 67d | 20d |  |
| 820 | 1.6.7.2.4 | Generate HET integration & test procedure | 5d | 2004-06-07 | 2004-06-11 | 832FS-10d |  |  | 24d | 5d |  |
| 821 | 1.6.7.2.5 | Generate SIT integration & test procedure | 5d | 2004-07-02 | 2004-07-08 | 837FS-10d |  |  | 15d | 5d |  |
| 822 | 1.6.7.2.6 | Generate SEP system test procedure | 5d | 2004-07-05 | 2004-07-09 | 838FS-10d |  |  | 15d | 5d |  |
| 823 | 1.6.7.2.7 | Software Support For Acceptance Testing of SEP Instruments | 27d | 2004-07-19 | 2004-08-24 | 839SS |  |  | 64d |  |  |
| 824 | 1.6.7.2.8 | Generate SEP-IDPU integration procedure | 5d | 2004-06-08 | 2004-06-14 | 833FS-10d |  |  | 20d | 0d |  |
| 825 | 1.6.7.2.9 | Generate SEP-IDPU test procedure | 5d | 2004-06-15 | 2004-06-21 | 824 |  |  | 20d | 1d |  |
| 826 | 1.6.7.2.10 | Software Support of SEP Accelerator Tests | 20d | 2004-07-01 | 2004-07-28 | 873SS-10d |  |  | 83d |  |  |

| ID | WBS | Task | Duration | Start | Finish | Predecessors | Total slack | Free slack |
| --- | --- | --- | --- | --- | --- | --- | --- | --- |
| 827 | 1.6.7.3 | **FM 1** | 86d | 2004-03-19 | 2004-07-19 |  | 10d |  |
| 828 | 1.6.7.3.1 | Integrate/test SEP Central FM 1 | 1d | 2004-04-15 | 2004-04-15 | 409, 411, 413, 69, 391, 415 | 42d | 0d |
| 829 | 1.6.7.3.2 | Receive & inspect SEPT FM 1 | 1d | 2004-03-19 | 2004-03-19 | 605, 606 | 81d | 0d |
| 830 | 1.6.7.3.3 | Integrate & test SEPT FM 1 | 1d | 2004-04-16 | 2004-04-16 | 818, 828, 829 | 62d | 0d |
| 831 | 1.6.7.3.4 | Integrate & test LET FM 1 | 1d | 2004-05-10 | 2004-05-10 | 819, 830, 545, 547 | 47d | 28d |
| 832 | 1.6.7.3.5 | Receive & inspect HET FM 1 | 1d | 2004-06-18 | 2004-06-18 | 498 | 19d | 0d |
| 833 | 1.6.7.3.6 | Integrate & test HET FM 1 | 1d | 2004-06-21 | 2004-06-21 | 820, 831, 832 | 19d | 0d |
| 834 | 1.6.7.3.7 | Integrate SEP FM 1 - IDPU FM 1 | 1d | 2004-06-22 | 2004-06-22 | 824, 833, 162 | 19d | 0d |
| 835 | 1.6.7.3.8 | Test SEP FM 1 - IDPU FM 1 | 1d | 2004-06-23 | 2004-06-23 | 825, 834 | 19d | 0d |
| 836 | 1.6.7.3.9 | Rework SEP FM 1 - IDPU FM 1 issues and retest | 5d | 2004-06-24 | 2004-06-30 | 835 | 19d | 0d |
| 837 | 1.6.7.3.10 | Receive & inspect SIT FM 1 | 1d | 2004-07-15 | 2004-07-15 | 676 | 10d | 0d |
| 838 | 1.6.7.3.11 | Integrate & test SIT FM 1 | 1d | 2004-07-16 | 2004-07-16 | 821, 833, 837, 836 | 10d | 0d |
| 839 | 1.6.7.3.12 | SEP system test FM 1 | 1d | 2004-07-19 | 2004-07-19 | 822, 838 | 10d | 0d |
| 840 | 1.6.7.4 | **FM 2** | 100d | 2004-03-15 | 2004-08-02 |  | 5d |  |
| 841 | 1.6.7.4.1 | Integrate/testSEP Central FM 2 | 1d | 2004-04-15 | 2004-04-15 | 410, 412, 414, 391, 415 | 68d | 0d |
| 842 | 1.6.7.4.2 | Receive & inspect SEPT FM 2 | 1d | 2004-03-15 | 2004-03-15 | 608, 609 | 91d | 23d |
| 843 | 1.6.7.4.3 | Integrate & test SEPT FM 2 | 1d | 2004-04-16 | 2004-04-16 | 818, 841, 842 | 68d | 15d |
| 844 | 1.6.7.4.4 | Integrate & test LET FM 2 | 1d | 2004-05-10 | 2004-05-10 | 819, 843, 546, 547 | 53d | 48d |
| 845 | 1.6.7.4.5 | Receive & inspect HET FM 2 | 1d | 2004-07-16 | 2004-07-16 | 499 | 5d | 0d |
| 846 | 1.6.7.4.6 | Integrate & test HET FM 2 | 1d | 2004-07-19 | 2004-07-19 | 820, 844, 845 | 5d | 0d |
| 847 | 1.6.7.4.7 | Integrate SEP FM 2 - IDPU FM 2 | 1d | 2004-07-20 | 2004-07-20 | 824, 846, 163 | 5d | 0d |
| 848 | 1.6.7.4.8 | Test SEP FM 2 - IDPU FM 2 | 1d | 2004-07-21 | 2004-07-21 | 825, 847 | 5d | 0d |
| 849 | 1.6.7.4.9 | Rework SEP FM 2 - IDPU FM 2 issues and retest | 5d | 2004-07-22 | 2004-07-28 | 848 | 5d | 0d |
| 850 | 1.6.7.4.10 | Receive & inspect SIT FM 2 | 1d | 2004-07-22 | 2004-07-22 | 679 | 9d | 4d |
| 851 | 1.6.7.4.11 | Integrate & test SIT FM 2 | 1d | 2004-07-29 | 2004-07-29 | 821, 849, 850 | 5d | 0d |
| 852 | 1.6.7.4.12 | Integrate FM 2 LVPS into SEP Central (if necessary) | 1d | 2004-07-30 | 2004-07-30 | 841, 75, 851 | 5d | 0d |
| 853 | 1.6.7.4.13 | SEP FM 2 system test | 1d | 2004-08-02 | 2004-08-02 | 822, 851, 852 | 5d | 0d |

| ID | WBS | Task | Duration | Start | Finish | Predecessors | Complete | Remaining | Total slack | Free slack | Constraint |
| --- | --- | --- | --- | --- | --- | --- | --- | --- | --- | --- | --- |
| 854 | 1.6.7.5 | **Environmental Test (at JPL)** | 119d | 2004-05-03 | 2004-10-19 |  |  |  | 26d |  |  |
| 855 | 1.6.7.5.1 | Generate Environmental Test Procedures | 15d | 2004-05-03 | 2004-05-21 |  |  |  | 54d | 0d | start no earlier than 2004-05-03 |
| 856 | 1.6.7.5.2 | Manufacture test cables (JPL) | 10d | 2004-05-24 | 2004-06-07 | 855 |  |  | 54d | 43d |  |
| 857 | 1.6.7.5.3 | **FM 1** | 41d | 2004-08-06 | 2004-10-04 |  |  |  | 11d |  |  |
| 858 | 1.6.7.5.3.1 | FM 1 LET/HET/SEP Central Vibration/Acoustics Test | 10d | 2004-08-06 | 2004-08-19 | 16FS+3d, 855, 856 |  |  | 11d | 0d |  |
| 859 | 1.6.7.5.3.2 | FM 1 LET/HET/SEP Central Thermal Balance Test | 5d | 2004-08-20 | 2004-08-26 | 858 |  |  | 11d | 0d |  |
| 860 | 1.6.7.5.3.3 | FM 1 LET/HET/SEP Central T/V Test | 15d | 2004-08-27 | 2004-09-17 | 859 |  |  | 11d | 0d |  |
| 861 | 1.6.7.5.3.4 | Evaluate SEP performance | 10d | 2004-09-20 | 2004-10-01 | 860 |  |  | 36d | 0d |  |
| 862 | 1.6.7.5.3.5 | Generate test reports | 11d | 2004-09-20 | 2004-10-04 | 861SS |  |  | 36d |  |  |
| 863 | 1.6.7.5.3.6 | Bakeout Clean SEP exterior & prepare for delivery | 3d | 2004-09-20 | 2004-09-22 | 860 |  |  | 11d | 0d |  |
| 864 | 1.6.7.5.4 | **FM 2** | 54d | 2004-08-03 | 2004-10-19 |  |  |  | 5d |  |  |
| 865 | 1.6.7.5.4.1 | FM 2 EMI/EMC Test at CalTech | 5d | 2004-08-03 | 2004-08-09 | 853 |  |  | 5d | 0d |  |
| 866 | 1.6.7.5.4.2 | FM 2 LET/HET/SEP Central Vibration/Acoustics Test | 10d | 2004-08-20 | 2004-09-02 | 865, 858 |  |  | 15d | 0d |  |
| 867 | 1.6.7.5.4.3 | FM 2 LET/HET/SEP Central Thermal Balance Test | 5d | 2004-09-03 | 2004-09-10 | 866 |  |  | 15d | 0d |  |
| 868 | 1.6.7.5.4.4 | FM 2 LET/HET/SEP Central T/V Test | 15d | 2004-09-13 | 2004-10-01 | 867 |  |  | 15d | 0d |  |
| 869 | 1.6.7.5.4.5 | Evaluate SEP performance | 10d | 2004-10-04 | 2004-10-18 | 868 |  |  | 26d | 0d |  |
| 870 | 1.6.7.5.4.6 | Generate test reports | 11d | 2004-10-04 | 2004-10-19 | 869SS |  |  | 26d |  |  |
| 871 | 1.6.7.5.4.7 | Bakeout Clean SEP exterior & prepare for delivery | 3d | 2004-10-04 | 2004-10-06 | 868 |  |  | 15d | 0d |  |
| 872 | 1.6.7.6 | **Accelerator Test (at MSU)** | 10d | 2004-07-15 | 2004-07-28 |  |  |  | 83d |  |  |
| 873 | 1.6.7.6.1 | LET/SEP Cen end-to-end test at Accelerator | 10d | 2004-07-15 | 2004-07-28 | 880 |  |  | 83d | 0d |  |
| 874 | 1.6.7.7 | **GSE** | 333d | 2003-08-01 A | 2004-11-26 |  | 48% | 171.72d | 0d |  |  |
| 875 | 1.6.7.7.1 | **Design hardware** | 71d | 2004-01-05 | 2004-04-14 |  |  |  | 157d |  |  |
| 876 | 1.6.7.7.1.1 | GSE H/W Calibration equipment | 71d | 2004-01-05 | 2004-04-14 |  |  |  | 157d |  | start no earlier than 2004-01-05 |
| 877 | 1.6.7.7.2 | **End-to-End Test Equipment** | 234d | 2003-08-11 A | 2004-07-14 |  | 86% | 33.29d | 83d |  |  |
| 878 | 1.6.7.7.2.1 | Design | 203d | 2003-08-11 A | 2004-06-01 |  | 90% | 20.3d | 83d | 0d | start no earlier than 2003-08-11 |
| 879 | 1.6.7.7.2.2 | Assemble | 5d | 2004-07-01 | 2004-07-07 | 878FS+21d |  |  | 83d | 0d |  |
| 880 | 1.6.7.7.2.3 | Test | 5d | 2004-07-08 | 2004-07-14 | 879 |  |  | 83d | 0d |  |

Notes:
- 872: The Accelerator Test Date is still TBD. The actually testing date will depend on availability of the facility at MSU and the readiness of our flight hardware. The date currently reflected in the schedule is therefore subject to change as required.

| ID | WBS | Task | Duration | Start | Finish | Predecessors | Complete | Remaining | Total slack | Constraint |
| --- | --- | --- | --- | --- | --- | --- | --- | --- | --- | --- |
| 881 | 1.6.7.7.3 | **GSE software** | 333d | 2003-08-01 A | 2004-11-26 |  | 31% | 230d | 0d |  |
| 882 | 1.6.7.7.3.1 | Write user's guide | 4d | 2004-02-02 | 2004-02-05 |  |  |  | 0d | start no earlier than 2004-02-02 |
| 883 | 1.6.7.7.3.2 | Build GSE software release 2 | 114d | 2003-08-01 A | 2004-01-15 |  | 70% | 34.2d | 14d | start no earlier than 2003-08-01 |
| 884 | 1.6.7.7.3.3 | Write user's guide supplement | 10d | 2004-02-06 | 2004-02-20 | 882, 883 |  |  | 0d |  |
| 885 | 1.6.7.7.3.4 | Build GSE software release 3 | 130d | 2004-05-24 | 2004-11-26 | 884FS+65d |  |  | 0d |  |
