# IMPACT Master Schedule

Schedule from MS Project, 2003-02-26 to 2005-11-21, status date 2004-02-29, A marks actual dates.
IMPACT Instrument Suites
NASA GSFC - STEREO
This is the IMPACT Consolidated Schedule. Creation began in October 2003 and was then put on hold and subsequently completed in January 2004. Completed tasks, redundant milestones, contingency blocks and obsolete tasks were deleted from this schedule. / Schedule was baselined on 2/18/04 with status through January 31, 2004.

## Calendars

- Standard: Mon-Fri 08:00-12:00, 13:00-17:00; Sat-Sun off. Exceptions (off unless hours are given): 2003-05-26, 2003-07-04, 2003-09-01, 2003-10-13, 2003-11-11, 2003-11-27, 2003-12-25, 2004-01-01, 2004-01-19, 2004-02-16, 2004-05-31, 2004-09-06, 2004-10-11, 2004-11-11, 2004-11-25.
- Boom Test Calendar: Mon-Fri 08:00-12:00, 13:00-17:00; Sat-Sun off. Exceptions (off unless hours are given): 2003-05-26, 2003-07-04, 2003-09-01, 2003-10-13, 2003-11-11, 2003-11-27, 2003-12-25, 2004-01-01, 2004-01-19, 2004-02-16, 2004-02-28 to 2004-02-29 08:00-12:00, 13:00-17:00, 2004-03-06 to 2004-03-07 08:00-12:00, 13:00-17:00, 2004-05-31, 2004-09-06, 2004-10-11, 2004-11-11, 2004-11-25.

## Schedule

| ID | WBS | Task | Type | Duration | Start | Finish | Predecessors | Complete | Remaining | Baseline start | Baseline finish | Baseline duration | Total slack | Free slack | Constraint |
| --- | --- | --- | --- | --- | --- | --- | --- | --- | --- | --- | --- | --- | --- | --- | --- |
| 1 | 1 | **IMPACT - Dave Curtis (UCB) & Lil Reichenthal (GSFC)** |  | 699d | 2003-02-26 A | 2005-11-21 |  | 60% | 281.81d | 2003-02-26 | 2005-11-18 | 698d | 0d |  |  |
| 2 | 1.1 | **Suite Deliveries to APL** |  | 37d | 2004-09-02 | 2004-10-28 |  |  |  | 2004-08-13 | 2004-10-28 | 51d | 0d |  |  |
| 3 | 1.1.1 | FM 1 Target Delivery Date | milestone | 0d | 2004-10-07 | 2004-10-07 | 5, 7 |  |  | 2004-10-07 | 2004-10-07 | 0d | 0d |  | must start on 2004-10-07 |
| 4 | 1.1.2 | FM 1 Target Delivery Date | milestone | 0d | 2004-10-28 | 2004-10-28 | 8, 6 |  |  | 2004-10-28 | 2004-10-28 | 0d | 0d |  | must start on 2004-10-28 |
| 5 | 1.1.3 | Boom Suite FM 1 Ready for Delivery to APL | milestone | 0d | 2004-09-02 | 2004-09-02 | 351 |  |  | 2004-08-13 | 2004-08-13 | 0d | 23d |  |  |
| 6 | 1.1.4 | Boom Suite FM 2 Ready for Delivery to APL | milestone | 0d | 2004-10-06 | 2004-10-06 | 357 |  |  | 2004-09-28 | 2004-09-28 | 0d | 14d |  |  |
| 7 | 1.1.5 | SEP Suite FM 1 Ready for Delivery to APL | milestone | 0d | 2004-09-28 | 2004-09-28 | 764, 584, 520 |  |  | 2004-09-14 | 2004-09-14 | 0d | 6d |  |  |
| 8 | 1.1.6 | SEP Suite FM 2 Ready for Delivery to APL | milestone | 0d | 2004-10-14 | 2004-10-14 | 771, 587 |  |  | 2004-10-12 | 2004-10-12 | 0d | 9d |  |  |
| 9 | 1.2 | **Environmental Testing - PER, Impact Suite EMC, Snapshots of Boom & SEP Suite Test Flows** |  | 188d | 2004-01-14 A | 2004-10-07 |  | 3% | 182.39d | 2004-01-14 | 2004-10-05 | 186d | 289d |  |  |
| 10 | 1.2.1 | **Reviews (PER and TRR's) - TRR Dates are Tentative** |  | 138d | 2004-01-14 A | 2004-07-28 |  | 25% | 103.5d | 2004-01-14 | 2004-07-08 | 124d | 339d |  |  |
| 11 | 1.2.1.1 | Instrument PER at UCB |  | 1d | 2004-01-14 A | 2004-01-14 A |  | 100% |  | 2004-01-14 | 2004-01-14 | 1d |  |  | start no earlier than 2004-01-14 |
| 12 | 1.2.1.2 | TRR 1 - Prior to FM 1 SEPT Thermal Vac |  | 1d | 2004-02-13 A | 2004-02-13 A | 39SS-6d | 100% |  | 2004-02-13 | 2004-02-13 | 1d |  |  |  |
| 13 | 1.2.1.3 | TRR 2 - Prior to FM 1 STE-U Thermal Vac/Thermal Balance |  | 1d | 2004-04-19 | 2004-04-19 | 21SS |  |  | 2004-03-25 | 2004-03-25 | 1d | 410d |  | start no earlier than 2004-04-19 |
| 14 | 1.2.1.4 | TRR 3 - Prior to FM 1 Boom Structure Vibration |  | 1d | 2004-04-19 | 2004-04-19 | 22SS-9d |  |  | 2004-04-20 | 2004-04-20 | 1d | 410d |  |  |
| 15 | 1.2.1.5 | TRR 4 - Prior to FM 1 IDPU Vibration |  | 1d | 2004-05-18 | 2004-05-18 | 23SS-5d |  |  | 2004-04-26 | 2004-04-26 | 1d | 389d |  |  |
| 16 | 1.2.1.6 | TRR 5 - Prior to FM 1 SWEA Vibration |  | 1d | 2004-06-08 | 2004-06-08 | 26SS-5d |  |  | 2004-05-28 | 2004-05-28 | 1d | 375d |  |  |
| 17 | 1.2.1.7 | TRR 6 - Prior to FM 1 Impact Suite EMC (for Boom and SEP) |  | 1d | 2004-07-12 | 2004-07-12 | 19SS-5d |  |  | 2004-06-22 | 2004-06-22 | 1d | 351d |  |  |
| 18 | 1.2.1.8 | TRR 7 - Prior to FM 1 SIT Vibration |  | 1d | 2004-07-28 | 2004-07-28 | 43SS-5d |  |  | 2004-07-08 | 2004-07-08 | 1d | 339d |  |  |
| 19 | 1.2.2 | IMPACT Suite FM 1 EMC Testing at UCB |  | 10d | 2004-07-19 | 2004-07-30 | 350, 742, 416 |  |  | 2004-06-29 | 2004-07-12 | 10d | -1d | 0d |  |
| 20 | 1.2.3 | **Boom Suite FM 1 Environmental Test Flow Snapshot - UCB** |  | 98d | 2004-04-05 | 2004-08-19 |  |  |  | 2004-04-01 | 2004-07-30 | 86d | 323d |  |  |
| 21 | 1.2.3.1 | STE-U Thermal Vac/Thermal Balance/Bake Out |  | 14d | 2004-04-05 | 2004-04-22 | 270SS |  |  | 2004-04-01 | 2004-04-20 | 14d | 407d | 10d |  |
| 22 | 1.2.3.2 | Boom Structure Vibration |  | 4d | 2004-04-30 | 2004-05-05 | 210SS |  |  | 2004-04-27 | 2004-04-30 | 4d | 398d | 0d |  |
| 23 | 1.2.3.3 | IDPU Vibration |  | 5d | 2004-05-25 | 2004-06-01 | 173SS |  |  | 2004-05-03 | 2004-05-07 | 5d | 380d | 0d |  |
| 24 | 1.2.3.4 | Boom Structure Thermal Vac & Bake Out |  | 15d | 2004-05-06 | 2004-05-26 | 211SS |  |  | 2004-05-03 | 2004-05-21 | 15d | 383d |  |  |
| 25 | 1.2.3.5 | IDPU Thermal Vac & Bake Out |  | 10d | 2004-06-02 | 2004-06-15 | 174SS |  |  | 2004-05-10 | 2004-05-21 | 10d | 370d |  |  |
| 26 | 1.2.3.6 | SWEA/STE Vibration |  | 5d | 2004-06-15 | 2004-06-21 | 336SS |  |  | 2004-06-07 | 2004-06-11 | 5d | 366d | 0d |  |
| 27 | 1.2.3.7 | SWEA/STE Thermal Vac/Thermal Balance/Bake Out |  | 14d | 2004-08-02 | 2004-08-19 | 337SS |  |  | 2004-07-13 | 2004-07-30 | 14d | 323d |  |  |

Notes:
- 1: This is the new IMPACT Consolidated Schedule. Creation began in October 2003 and was then put on hold and subsequently completed in January 2004. Completed tasks, redundant milestones, contingency blocks and obsolete tasks were deleted from this schedule. / Schedule was baselined on 2/18/04 with status through January 31, 2004.
- 7: The SEPT (FM 1) and SIT (FM 1 & 2) instruments are being delivered directly to APL after their environmental testing at GSFC and seperate from the other SEP Suite instruments (SEP Central, LET and HET).
- 8: The SEPT (FM 1) and SIT (FM 1 & 2) instruments are being delivered directly to APL after their environmental testing at GSFC and seperate from the other SEP Suite instruments (SEP Central, LET and HET).
- 11: This is the initial IMPACT PER. Additional TRR's (Test Readiness Reviews) will be scheduled and held as the suite instruments become ready for their environmental testing.
- 20: This section is a "snapshot" of the environmental test flow for the FM 1 Boom Suite. It reflects the details of the testing activities found within the body of the schedule. It was placed in the schedule to allow someone to get a quick look at the test flow and the associated dates. The tasks contained within this section are not tied to any other activities (and do not drive any other activities) and so therefore you will see large float values associated with them. It is simply a quick look at the test flow so that one does not have to filter through the schedule to locate the environmental test activities.

| ID | WBS | Task | Duration | Start | Finish | Predecessors | Complete | Remaining | Baseline start | Baseline finish | Baseline duration | Total slack | Free slack |
| --- | --- | --- | --- | --- | --- | --- | --- | --- | --- | --- | --- | --- | --- |
| 28 | 1.2.4 | **Boom Suite FM 2 Environmental Test Flow Snapshot - UCB** | 83d | 2004-05-27 | 2004-09-22 |  |  |  | 2004-04-27 | 2004-09-14 | 99d | 300d |  |
| 29 | 1.2.4.1 | STE-U Thermal Vac/Bake Out | 10d | 2004-05-27 | 2004-06-10 | 278SS |  |  | 2004-04-27 | 2004-05-10 | 10d | 373d |  |
| 30 | 1.2.4.2 | IDPU Vibration | 5d | 2004-07-07 | 2004-07-13 | 177SS |  |  | 2004-05-10 | 2004-05-14 | 5d | 350d |  |
| 31 | 1.2.4.3 | Boom Structure Vibration | 4d | 2004-06-17 | 2004-06-22 | 232SS |  |  | 2004-05-17 | 2004-05-20 | 4d | 365d |  |
| 32 | 1.2.4.4 | IDPU Thermal Vac & Bake Out | 10d | 2004-07-14 | 2004-07-27 | 178SS |  |  | 2004-05-17 | 2004-05-28 | 10d | 340d |  |
| 33 | 1.2.4.5 | Boom Structure Thermal Vac & Bake Out | 15d | 2004-06-23 | 2004-07-13 | 233SS |  |  | 2004-05-24 | 2004-06-14 | 15d | 350d |  |
| 34 | 1.2.4.6 | SWEA/STE Vibration | 5d | 2004-08-17 | 2004-08-23 | 344SS |  |  | 2004-08-09 | 2004-08-13 | 5d | 321d |  |
| 35 | 1.2.4.7 | SWEA/STE Thermal Vac & Bake Out | 10d | 2004-08-24 | 2004-09-07 | 345SS |  |  | 2004-08-16 | 2004-08-27 | 10d | 311d |  |
| 36 | 1.2.4.8 | Boom Suite FM 2 EMC | 5d | 2004-09-16 | 2004-09-22 | 356SS |  |  | 2004-09-08 | 2004-09-14 | 5d | 300d |  |
| 37 | 1.2.5 | **SEP Suite FM 1 Environmental Test Flow Snapshot** | 157d | 2004-02-19 A | 2004-09-28 |  | 4% | 150.59d | 2004-02-17 | 2004-09-14 | 149d | 296d |  |
| 38 | 1.2.5.1 | SEPT (NS & E) Vibration (in Europe) | 4d | 2004-02-19 A | 2004-02-24 A | 556SS | 100% |  | 2004-02-17 | 2004-02-24 | 8d |  |  |
| 39 | 1.2.5.2 | SEPT (NS & E) Thermal Vac (in Europe) | 10d | 2004-02-27 | 2004-03-11 | 557SS, 564SS |  |  | 2004-02-25 | 2004-03-08 | 9d | 437d | 0d |
| 40 | 1.2.5.3 | SEPT (NS & E) Bake Out (in Europe) | 2d | 2004-03-12 | 2004-03-15 | 558SS, 565SS |  |  | 2004-03-09 | 2004-03-10 | 2d | 435d |  |
| 41 | 1.2.5.4 | SEPT (NS & E) Thermal Balance (at GSFC) | 10d | 2004-08-02 | 2004-08-13 | 559SS, 566SS |  |  | 2004-07-13 | 2004-07-26 | 10d | 327d |  |
| 42 | 1.2.5.5 | LET/HET/SEP Cen Accelerator Test (at MSU) | 11d | 2004-08-02 | 2004-08-16 | 773SS |  |  | 2004-07-13 | 2004-07-27 | 11d | 326d |  |
| 43 | 1.2.5.6 | SIT Vibe and Acoustics (at GSFC) | 10d | 2004-08-04 | 2004-08-17 | 697SS |  |  | 2004-07-15 | 2004-07-28 | 10d | 325d | 0d |
| 44 | 1.2.5.7 | LET/HET/SEP Cen Vibe and Acoustics (at JPL) | 10d | 2004-08-12 | 2004-08-25 | 759SS |  |  | 2004-07-23 | 2004-08-05 | 10d | 319d |  |
| 45 | 1.2.5.8 | SIT Thermal Balance (at GSFC) | 5d | 2004-08-19 | 2004-08-25 | 699SS |  |  | 2004-07-30 | 2004-08-05 | 5d | 319d |  |
| 46 | 1.2.5.9 | LET/HET/SEP Cen Thermal Balance (at JPL) | 5d | 2004-08-26 | 2004-09-01 | 760SS |  |  | 2004-08-06 | 2004-08-12 | 5d | 314d |  |
| 47 | 1.2.5.10 | SIT Thermal Vac (at GSFC) | 10d | 2004-08-26 | 2004-09-09 | 700SS |  |  | 2004-08-06 | 2004-08-19 | 10d | 309d |  |
| 48 | 1.2.5.11 | LET/HET/SEP Cen Thermal Vac (at JPL) | 15d | 2004-09-02 | 2004-09-23 | 761SS |  |  | 2004-08-19 | 2004-09-09 | 15d | 299d |  |
| 49 | 1.2.5.12 | SIT Bake Out (at GSFC) | 3d | 2004-09-14 | 2004-09-16 | 702SS |  |  | 2004-08-24 | 2004-08-26 | 3d | 304d |  |
| 50 | 1.2.5.13 | LET/HET/SEP Cen Bake Out (at JPL) | 3d | 2004-09-24 | 2004-09-28 | 764SS |  |  | 2004-09-10 | 2004-09-14 | 3d | 296d |  |
| 51 | 1.2.6 | **SEP Suite FM 2 Environmental Test Flow Snapshot** | 164d | 2004-02-19 A | 2004-10-07 |  | 5% | 156.55d | 2004-02-17 | 2004-10-05 | 164d | 289d |  |
| 52 | 1.2.6.1 | SEPT (NS & E) Vibe and Acoustics (in Europe) | 4d | 2004-02-19 A | 2004-02-24 A | 571SS | 100% |  | 2004-02-17 | 2004-02-24 | 8d |  |  |
| 53 | 1.2.6.2 | SEPT (NS & E) Thermal Vac (in Europe) | 10d | 2004-03-05 | 2004-03-18 | 572SS, 578SS |  |  | 2004-03-09 | 2004-03-17 | 9d | 432d |  |
| 54 | 1.2.6.3 | SEPT (NS & E) Bake Out (in Europe) | 2d | 2004-03-19 | 2004-03-22 | 573SS, 579SS |  |  | 2004-03-18 | 2004-03-19 | 2d | 430d |  |
| 55 | 1.2.6.4 | LET/HET/SEP Cen Accelerator Test (at MSU) | 11d | 2004-08-02 | 2004-08-16 | 774SS |  |  | 2004-07-13 | 2004-07-27 | 11d | 326d |  |
| 56 | 1.2.6.5 | LET/HET/SEP Cen Vibe and Acoustics (at JPL) | 10d | 2004-08-23 | 2004-09-03 | 767SS |  |  | 2004-07-23 | 2004-08-05 | 10d | 312d |  |
| 57 | 1.2.6.6 | SEP Suite FM 2 EMC (at Caltech) | 5d | 2004-08-16 | 2004-08-20 | 766SS |  |  | 2004-08-12 | 2004-08-18 | 5d | 322d |  |
| 58 | 1.2.6.7 | LET/HET/SEP Cen Thermal Vac (at JPL) | 15d | 2004-09-07 | 2004-09-27 | 768SS |  |  | 2004-08-19 | 2004-09-09 | 15d | 297d |  |
| 59 | 1.2.6.8 | SIT Vibe and Acoustics (at GSFC) | 10d | 2004-08-25 | 2004-09-08 | 706SS |  |  | 2004-08-23 | 2004-09-03 | 10d | 310d |  |
| 60 | 1.2.6.9 | SIT Thermal Balance (at GSFC) | 5d | 2004-09-10 | 2004-09-16 | 708SS |  |  | 2004-09-08 | 2004-09-14 | 5d | 304d |  |
| 61 | 1.2.6.10 | LET/HET/SEP Cen Bake Out (at JPL) | 3d | 2004-09-28 | 2004-09-30 | 771SS |  |  | 2004-09-10 | 2004-09-14 | 3d | 294d |  |
| 62 | 1.2.6.11 | SIT Thermal Vac (at GSFC) | 10d | 2004-09-17 | 2004-09-30 | 709SS |  |  | 2004-09-15 | 2004-09-28 | 10d | 294d |  |
| 63 | 1.2.6.12 | SIT Bake Out (at GSFC) | 3d | 2004-10-05 | 2004-10-07 | 711SS |  |  | 2004-10-01 | 2004-10-05 | 3d | 289d |  |

Notes:
- 28: This section is a "snapshot" of the environmental test flow for the FM 2 Boom Suite. It reflects the details of the testing activities found within the body of the schedule. It was placed in the schedule to allow someone to get a quick look at the test flow and the associated dates. The tasks contained within this section are not tied to any other activities (and do not drive any other activities) and so therefore you will see large float values associated with them. It is simply a quick look at the test flow so that one does not have to filter through the schedule to locate the environmental test activities.
- 37: This section is a "snapshot" of the environmental test flow for the FM 1 SEP Suite. It reflects the details of the testing activities found within the body of the schedule. It was placed in the schedule to allow someone to get a quick look at the test flow and the associated dates. The tasks contained within this section are not tied to any other activities (and do not drive any other activities) and so therefore you will see large float values associated with them. It is simply a quick look at the test flow so that one does not have to filter through the schedule to locate the environmental test activities.
- 38: There was a failure on the SEPT door during Vibration Test. Vibration Test will be repeated once the fix to the door is implemented. Time and place is TBD.
- 51: This section is a "snapshot" of the environmental test flow for the FM 2 SEP Suite. It reflects the details of the testing activities found within the body of the schedule. It was placed in the schedule to allow someone to get a quick look at the test flow and the associated dates. The tasks contained within this section are not tied to any other activities (and do not drive any other activities) and so therefore you will see large float values associated with them. It is simply a quick look at the test flow so that one does not have to filter through the schedule to locate the environmental test activities.
- 52: There was a failure on the SEPT door during Vibration Test. Vibration Test will be repeated once the fix to the door is implemented. Time and place is TBD.

| ID | WBS | Task | Type | Duration | Start | Finish | Predecessors | Complete | Remaining | Baseline start | Baseline finish | Baseline duration | Total slack | Free slack | Constraint |
| --- | --- | --- | --- | --- | --- | --- | --- | --- | --- | --- | --- | --- | --- | --- | --- |
| 64 | 1.3 | **Power Converters - UCB** |  | 339d | 2003-02-26 A | 2004-06-29 |  | 62% | 130.2d | 2003-02-26 | 2004-06-23 | 335d | 8d |  |  |
| 65 | 1.3.1 | **Deliveries** |  | 141d | 2003-12-09 A | 2004-06-29 |  | 20% | 112.8d | 2003-12-09 | 2004-04-30 | 100d | 8d |  |  |
| 66 | 1.3.1.1 | **FM 1** |  | 111d | 2003-12-09 A | 2004-05-17 |  | 40% | 66.6d | 2003-12-09 | 2004-04-23 | 95d | 9d |  |  |
| 67 | 1.3.1.1.1 | Deliver IDPU FM 1 LVPS (stays at UCB) | milestone | 0d | 2004-05-17 | 2004-05-17 | 121 |  |  | 2004-04-23 | 2004-04-23 | 0d | 9d | 0d |  |
| 68 | 1.3.1.1.2 | Deliver SEP FM 1 LVPS (to Caltech) |  | 1d | 2004-04-09 | 2004-04-09 | 125 |  |  | 2004-04-06 | 2004-04-06 | 1d | 37d | 27d |  |
| 69 | 1.3.1.1.3 | Deliver SWEA/STE FM 1 LVPS (stays at UCB) | milestone | 0d | 2004-04-23 | 2004-04-23 | 129 |  |  | 2004-04-15 | 2004-04-15 | 0d | 7d | 0d |  |
| 70 | 1.3.1.1.4 | Deliver PLASTIC FM 1 LVPS (to UNH) |  | 2d | 2004-04-12 | 2004-04-13 | 133 |  |  | 2004-03-24 | 2004-03-25 | 2d | 15d |  | finish no later than 2004-05-04 |
| 71 | 1.3.1.1.5 | Deliver SIT FM 1 HVPS (to UMD) |  | 2d | 2003-12-09 A | 2003-12-10 A | 135 | 100% |  | 2003-12-09 | 2003-12-10 | 2d |  |  |  |
| 72 | 1.3.1.2 | **FM 2** |  | 32d | 2004-05-14 | 2004-06-29 |  |  |  | 2004-04-12 | 2004-04-30 | 15d | 7d |  |  |
| 73 | 1.3.1.2.1 | Deliver IDPU FM 2 LVPS (stays at UCB) | milestone | 0d | 2004-06-29 | 2004-06-29 | 140 |  |  | 2004-04-30 | 2004-04-30 | 0d | 19d | 0d |  |
| 74 | 1.3.1.2.2 | Deliver SEP FM 2 LVPS (to Caltech) |  | 1d | 2004-05-18 | 2004-05-18 | 144 |  |  | 2004-04-19 | 2004-04-19 | 1d | 10d | 0d |  |
| 75 | 1.3.1.2.3 | Deliver SWEA/STE FM 2 LVPS (stays at UCB) | milestone | 0d | 2004-06-07 | 2004-06-07 | 148 |  |  | 2004-04-26 | 2004-04-26 | 0d | 24d | 10d |  |
| 76 | 1.3.1.2.4 | Deliver PLASTIC FM 2 LVPS (to UNH) |  | 2d | 2004-05-21 | 2004-05-24 | 152 |  |  | 2004-04-12 | 2004-04-13 | 2d | 12d |  | finish no later than 2004-06-10 |
| 77 | 1.3.1.2.5 | Deliver SIT FM 2 HVPS (to UMD) |  | 2d | 2004-05-14 | 2004-05-17 | 156 |  |  | 2004-04-12 | 2004-04-13 | 2d | 7d | 0d |  |
| 78 | 1.3.2 | **Remaining Flight Procurements** |  | 95d | 2003-10-24 A | 2004-03-12 |  | 75% | 23.75d | 2003-10-24 | 2004-02-19 | 79d | 13d |  |  |
| 79 | 1.3.2.1 | Procure IDPU Flight Printed Wiring Board |  | 10d | 2004-03-01 | 2004-03-12 | 85 |  |  | 2004-02-05 | 2004-02-19 | 10d | 13d | 0d | start no earlier than 2004-03-01 |
| 80 | 1.3.2.2 | Procure SEP Flight Printed Wiring Board |  | 10d | 2003-11-24 A | 2003-12-08 A | 86 | 100% |  | 2003-11-24 | 2003-12-08 | 10d |  |  | start no earlier than 2003-11-24 |
| 81 | 1.3.2.3 | Procure SWEA Flight Printed Wiring Board |  | 10d | 2003-12-04 A | 2003-12-17 A | 87 | 100% |  | 2003-12-04 | 2003-12-17 | 10d |  |  |  |
| 82 | 1.3.2.4 | Procure PLASTIC Flight Printed Wiring Board |  | 10d | 2003-10-24 A | 2003-11-06 A |  | 100% |  | 2003-10-24 | 2003-11-06 | 10d |  |  | start no earlier than 2003-10-24 |
| 83 | 1.3.3 | **Fabrication** |  | 239d | 2003-02-26 A | 2004-02-06 A |  | 100% |  | 2003-02-26 | 2004-02-06 | 239d |  |  |  |
| 84 | 1.3.3.1 | **FM 1 & FM 2** |  | 195d | 2003-02-26 A | 2003-12-03 A |  | 100% |  | 2003-02-26 | 2003-12-03 | 195d |  |  |  |
| 85 | 1.3.3.1.1 | Re-layout IDPU LVPS Flight Printed Wiring Board |  | 186d | 2003-02-26 A | 2003-11-19 A |  | 100% |  | 2003-02-26 | 2003-11-19 | 186d |  |  | start no earlier than 2003-02-26 |
| 86 | 1.3.3.1.2 | Re-layout SEP LVPS Flight Printed Wiring Board |  | 32d | 2003-09-24 A | 2003-11-07 A |  | 100% |  | 2003-09-24 | 2003-11-07 | 32d |  |  | start no earlier than 2003-09-24 |
| 87 | 1.3.3.1.3 | Re-layout SWEA LVPS Flight Printed Wiring Board |  | 5d | 2003-11-26 A | 2003-12-03 A |  | 100% |  | 2003-11-26 | 2003-12-03 | 5d |  |  | start no earlier than 2003-11-26 |

| ID | WBS | Task | Duration | Start | Finish | Predecessors | Complete | Remaining | Baseline start | Baseline finish | Baseline duration | Total slack | Free slack | Constraint |
| --- | --- | --- | --- | --- | --- | --- | --- | --- | --- | --- | --- | --- | --- | --- |
| 88 | 1.3.3.2 | **FM 1** | 45d | 2003-09-29 A | 2003-12-03 A |  | 100% |  | 2003-09-29 | 2003-12-03 | 45d |  |  |  |
| 89 | 1.3.3.2.1 | Wind IDPU LVPS FM 1 Magnets | 10d | 2003-10-17 A | 2003-10-30 A |  | 100% |  | 2003-10-17 | 2003-10-30 | 10d |  |  | start no earlier than 2003-10-17 |
| 90 | 1.3.3.2.2 | Wind SEP LVPS FM 1 Magnets | 15d | 2003-09-29 A | 2003-10-20 A |  | 100% |  | 2003-09-29 | 2003-10-20 | 15d |  |  | start no earlier than 2003-09-29 |
| 91 | 1.3.3.2.3 | Wind SWEA LVPS FM 1 Magnets | 5d | 2003-11-26 A | 2003-12-03 A |  | 100% |  | 2003-11-26 | 2003-12-03 | 5d |  |  | start no earlier than 2003-11-26 |
| 92 | 1.3.3.2.4 | Wind PLASTIC LVPS FM 1 Magnets | 45d | 2003-09-29 A | 2003-12-03 A |  | 100% |  | 2003-09-29 | 2003-12-03 | 45d |  |  | start no earlier than 2003-09-29 |
| 93 | 1.3.3.3 | **FM 2** | 28d | 2003-12-29 A | 2004-02-06 A |  | 100% |  | 2003-12-29 | 2004-02-06 | 28d |  |  |  |
| 94 | 1.3.3.3.1 | Wind HVPS FM 2 Magnets | 28d | 2003-12-29 A | 2004-02-06 A |  | 100% |  | 2003-12-29 | 2004-02-06 | 28d |  |  | start no earlier than 2003-12-29 |
| 95 | 1.3.3.3.2 | Wind IDPU LVPS FM 2 Magnets | 28d | 2003-12-29 A | 2004-02-06 A | 94SS | 100% |  | 2003-12-29 | 2004-02-06 | 28d |  |  |  |
| 96 | 1.3.3.3.3 | Wind SEP LVPS FM 2 Magnets | 28d | 2003-12-29 A | 2004-02-06 A | 94SS | 100% |  | 2003-12-29 | 2004-02-06 | 28d |  |  |  |
| 97 | 1.3.3.3.4 | Wind SWEA LVPS FM 2 Magnets | 28d | 2003-12-29 A | 2004-02-06 A | 94SS | 100% |  | 2003-12-29 | 2004-02-06 | 28d |  |  |  |
| 98 | 1.3.3.3.5 | Wind PLASTIC LVPS FM 2 Magnets | 28d | 2003-12-29 A | 2004-02-06 A | 94SS | 100% |  | 2003-12-29 | 2004-02-06 | 28d |  |  |  |
| 99 | 1.3.4 | **Assembly** | 98d | 2003-12-29 A | 2004-05-17 |  | 45% | 53.51d | 2003-12-29 | 2004-03-19 | 57d | 8d |  |  |
| 100 | 1.3.4.1 | **FM 1** | 68d | 2003-12-29 A | 2004-04-05 |  | 78% | 14.81d | 2003-12-29 | 2004-03-12 | 52d | 13d |  |  |
| 101 | 1.3.4.1.1 | Assemble IDPU FM 1 LVPS | 12d | 2004-03-19 | 2004-04-05 | 89, 113 |  |  | 2004-02-26 | 2004-03-12 | 12d | 13d | 0d |  |
| 102 | 1.3.4.1.2 | Assemble SEP FM 1 LVPS | 40d | 2004-01-12 A | 2004-03-09 A | 114, 90 | 100% |  | 2004-01-12 | 2004-02-23 | 29d |  |  | start no earlier than 2004-01-12 |
| 103 | 1.3.4.1.3 | Assemble SWEA FM 1 LVPS | 20d | 2004-02-13 A | 2004-03-12 | 91, 115 | 50% | 10d | 2004-02-13 | 2004-03-04 | 14d | 7d | 0d | start no earlier than 2004-02-13 |
| 104 | 1.3.4.1.4 | Assemble PLASTIC FM 1 LVPS | 29d | 2003-12-29 A | 2004-02-09 A | 116, 92 | 100% |  | 2003-12-29 | 2004-02-09 | 29d |  |  | start no earlier than 2003-12-29 |
| 105 | 1.3.4.2 | **FM 2** | 46d | 2004-03-15 | 2004-05-17 |  |  |  | 2004-02-09 | 2004-03-19 | 29d | 7d |  |  |
| 106 | 1.3.4.2.1 | Assemble IDPU FM 2 LVPS | 15d | 2004-04-27 | 2004-05-17 | 95, 119 |  |  | 2004-03-01 | 2004-03-19 | 15d | 19d | 0d | start no earlier than 2004-03-01 |
| 107 | 1.3.4.2.2 | Assemble SEP FM 2 LVPS | 15d | 2004-03-16 | 2004-04-05 | 96, 123 |  |  | 2004-02-13 | 2004-03-05 | 15d | 10d | 0d | start no earlier than 2004-02-13 |
| 108 | 1.3.4.2.3 | Assemble SWEA FM 2 LVPS | 15d | 2004-04-05 | 2004-04-23 | 97, 127 |  |  | 2004-02-24 | 2004-03-15 | 15d | 24d | 0d | start no earlier than 2004-02-24 |
| 109 | 1.3.4.2.4 | Assemble PLASTIC FM 2 LVPS | 14d | 2004-03-22 | 2004-04-08 | 98, 131 |  |  | 2004-02-09 | 2004-02-27 | 14d | 12d | 0d | start no earlier than 2004-02-09 |
| 110 | 1.3.4.2.5 | Assemble SIT FM 2 HVPS | 14d | 2004-03-15 | 2004-04-01 | 94, 103 |  |  | 2004-02-09 | 2004-02-27 | 14d | 7d | 0d |  |
| 111 | 1.3.5 | **Testing** | 166d | 2003-10-31 A | 2004-06-29 |  | 17% | 137.72d | 2003-10-31 | 2004-06-23 | 162d | 8d |  |  |
| 112 | 1.3.5.1 | **FM 1 & FM 2** | 79d | 2003-11-24 A | 2004-03-18 |  | 80% | 15.8d | 2003-11-24 | 2004-02-25 | 63d | 13d |  |  |
| 113 | 1.3.5.1.1 | Coupon Test IDPU Flight Printed Wiring Board | 4d | 2004-03-15 | 2004-03-18 | 79 |  |  | 2004-02-20 | 2004-02-25 | 4d | 13d | 0d |  |
| 114 | 1.3.5.1.2 | Coupon Test SEP Flight Printed Wiring Board | 5d | 2003-12-09 A | 2003-12-15 A | 80 | 100% |  | 2003-12-09 | 2003-12-15 | 5d |  |  |  |
| 115 | 1.3.5.1.3 | Coupon Test SWEA Flight Printed Wiring Board | 6d | 2004-01-09 A | 2004-01-16 A | 81 | 100% |  | 2004-01-09 | 2004-01-16 | 6d |  |  | start no earlier than 2004-01-09 |
| 116 | 1.3.5.1.4 | Coupon Test PLASTIC Flight Printed Wiring Board | 5d | 2003-11-24 A | 2003-12-01 A | 82 | 100% |  | 2003-11-24 | 2003-12-01 | 5d |  |  | start no earlier than 2003-11-24 |

| ID | WBS | Task | Duration | Start | Finish | Predecessors | Complete | Remaining | Baseline start | Baseline finish | Baseline duration | Total slack | Free slack | Constraint |
| --- | --- | --- | --- | --- | --- | --- | --- | --- | --- | --- | --- | --- | --- | --- |
| 117 | 1.3.5.2 | **FM 1** | 136d | 2003-10-31 A | 2004-05-17 |  | 26% | 100.84d | 2003-10-31 | 2004-06-23 | 162d | 9d |  |  |
| 118 | 1.3.5.2.1 | **IDPU** | 30d | 2004-04-06 | 2004-05-17 |  |  |  | 2004-03-15 | 2004-04-23 | 30d | 13d |  |  |
| 119 | 1.3.5.2.1.1 | Test IDPU FM 1 LVPS | 15d | 2004-04-06 | 2004-04-26 | 101 |  |  | 2004-03-15 | 2004-04-02 | 15d | 13d | 0d |  |
| 120 | 1.3.5.2.1.2 | Coat & Stake IDPU LVPS FM 1 Boards | 5d | 2004-04-27 | 2004-05-03 | 119 |  |  | 2004-04-05 | 2004-04-09 | 5d | 13d | 0d |  |
| 121 | 1.3.5.2.1.3 | Retest IDPU LVPS FM 1 Boards | 10d | 2004-05-04 | 2004-05-17 | 120 |  |  | 2004-04-12 | 2004-04-23 | 10d | 13d | 0d |  |
| 122 | 1.3.5.2.2 | **SEP** | 22d | 2004-03-10 | 2004-04-08 |  |  |  | 2004-02-24 | 2004-04-05 | 30d | 6d |  |  |
| 123 | 1.3.5.2.2.1 | Test SEP FM 1 LVPS | 4d | 2004-03-10 | 2004-03-15 | 102 |  |  | 2004-02-24 | 2004-03-15 | 15d | 10d | 0d |  |
| 124 | 1.3.5.2.2.2 | Coat & Stake SEP LVPS FM 1 Boards | 5d | 2004-03-16 | 2004-03-22 | 123 |  |  | 2004-03-16 | 2004-03-22 | 5d | 40d | 3d |  |
| 125 | 1.3.5.2.2.3 | Retest SEP LVPS FM 1 Boards | 10d | 2004-03-26 | 2004-04-08 | 124, 369 |  |  | 2004-03-23 | 2004-04-05 | 10d | 37d | 0d |  |
| 126 | 1.3.5.2.3 | **SWEA** | 30d | 2004-03-15 | 2004-04-23 |  |  |  | 2004-03-05 | 2004-04-15 | 30d | 7d |  |  |
| 127 | 1.3.5.2.3.1 | Test SWEA FM 1 LVPS | 15d | 2004-03-15 | 2004-04-02 | 103 |  |  | 2004-03-05 | 2004-03-25 | 15d | 7d | 0d |  |
| 128 | 1.3.5.2.3.2 | Coat & Stake SWEA LVPS FM 1 Boards | 5d | 2004-04-05 | 2004-04-09 | 127 |  |  | 2004-03-26 | 2004-04-01 | 5d | 7d | 0d |  |
| 129 | 1.3.5.2.3.3 | Retest SWEA LVPS FM 1 Boards | 10d | 2004-04-12 | 2004-04-23 | 128 |  |  | 2004-04-02 | 2004-04-15 | 10d | 7d | 0d |  |
| 130 | 1.3.5.2.4 | **PLASTIC** | 43d | 2004-02-10 A | 2004-04-09 |  | 30% | 30d | 2004-02-10 | 2004-03-23 | 30d | 15d |  |  |
| 131 | 1.3.5.2.4.1 | Test PLASTIC FM 1 LVPS | 28d | 2004-02-10 A | 2004-03-19 | 104 | 46% | 15d | 2004-02-10 | 2004-03-02 | 15d | 12d | 0d |  |
| 132 | 1.3.5.2.4.2 | Coat & Stake PLASTIC LVPS FM 1 Boards | 5d | 2004-03-22 | 2004-03-26 | 131 |  |  | 2004-03-03 | 2004-03-09 | 5d | 15d | 0d |  |
| 133 | 1.3.5.2.4.3 | Retest PLASTIC LVPS FM 1 Boards | 10d | 2004-03-29 | 2004-04-09 | 132 |  |  | 2004-03-10 | 2004-03-23 | 10d | 15d | 0d |  |
| 134 | 1.3.5.2.5 | **SIT** | 25d | 2003-10-31 A | 2003-12-08 A |  | 100% |  | 2003-10-31 | 2004-06-23 | 162d |  |  |  |
| 135 | 1.3.5.2.5.1 | Test SIT FM 1 HVPS | 25d | 2003-10-31 A | 2003-12-08 A |  | 100% |  | 2003-10-31 | 2003-12-08 | 25d |  |  | start no earlier than 2003-10-31 |
| 136 | 1.3.5.3 | **FM 2** | 62d | 2004-04-02 | 2004-06-29 |  |  |  | 2004-03-01 | 2004-04-30 | 45d | 7d |  |  |
| 137 | 1.3.5.3.1 | **IDPU** | 30d | 2004-05-18 | 2004-06-29 |  |  |  | 2004-03-22 | 2004-04-30 | 30d | 19d |  |  |
| 138 | 1.3.5.3.1.1 | Test IDPU FM 2 LVPS | 15d | 2004-05-18 | 2004-06-08 | 106 |  |  | 2004-03-22 | 2004-04-09 | 15d | 19d | 0d |  |
| 139 | 1.3.5.3.1.2 | Coat & Stake IDPU LVPS FM 2 Boards | 5d | 2004-06-09 | 2004-06-15 | 138 |  |  | 2004-04-12 | 2004-04-16 | 5d | 19d | 0d |  |
| 140 | 1.3.5.3.1.3 | Retest IDPU LVPS FM 2 Boards | 10d | 2004-06-16 | 2004-06-29 | 139 |  |  | 2004-04-19 | 2004-04-30 | 10d | 19d | 0d |  |

| ID | WBS | Task | Type | Duration | Start | Finish | Predecessors | Complete | Remaining | Baseline start | Baseline finish | Baseline duration | Total slack | Free slack | Constraint |
| --- | --- | --- | --- | --- | --- | --- | --- | --- | --- | --- | --- | --- | --- | --- | --- |
| 141 | 1.3.5.3.2 | **SEP** |  | 30d | 2004-04-06 | 2004-05-17 |  |  |  | 2004-03-08 | 2004-04-16 | 30d | 6d |  |  |
| 142 | 1.3.5.3.2.1 | Test SEP FM 2 LVPS |  | 15d | 2004-04-06 | 2004-04-26 | 107 |  |  | 2004-03-08 | 2004-03-26 | 15d | 10d | 0d |  |
| 143 | 1.3.5.3.2.2 | Coat & Stake SEP LVPS FM 2 Boards |  | 5d | 2004-04-27 | 2004-05-03 | 142 |  |  | 2004-03-29 | 2004-04-02 | 5d | 10d | 0d |  |
| 144 | 1.3.5.3.2.3 | Retest SEP LVPS FM 2 Boards |  | 10d | 2004-05-04 | 2004-05-17 | 143, 369 |  |  | 2004-04-05 | 2004-04-16 | 10d | 10d | 0d |  |
| 145 | 1.3.5.3.3 | **SWEA** |  | 30d | 2004-04-26 | 2004-06-07 |  |  |  | 2004-03-16 | 2004-04-26 | 30d | 24d |  |  |
| 146 | 1.3.5.3.3.1 | Test SWEA FM 2 LVPS |  | 15d | 2004-04-26 | 2004-05-14 | 108 |  |  | 2004-03-16 | 2004-04-05 | 15d | 24d | 0d |  |
| 147 | 1.3.5.3.3.2 | Coat & Stake SWEA LVPS FM 2 Boards |  | 5d | 2004-05-17 | 2004-05-21 | 146 |  |  | 2004-04-06 | 2004-04-12 | 5d | 24d | 0d |  |
| 148 | 1.3.5.3.3.3 | Retest SWEA LVPS FM 2 Boards |  | 10d | 2004-05-24 | 2004-06-07 | 147 |  |  | 2004-04-13 | 2004-04-26 | 10d | 24d | 0d |  |
| 149 | 1.3.5.3.4 | **PLASTIC** |  | 30d | 2004-04-09 | 2004-05-20 |  |  |  | 2004-03-01 | 2004-04-09 | 30d | 12d |  |  |
| 150 | 1.3.5.3.4.1 | Test PLASTIC FM 2 LVPS |  | 15d | 2004-04-09 | 2004-04-29 | 109 |  |  | 2004-03-01 | 2004-03-19 | 15d | 12d | 0d |  |
| 151 | 1.3.5.3.4.2 | Coat & Stake PLASTIC LVPS FM 2 Boards |  | 5d | 2004-04-30 | 2004-05-06 | 150 |  |  | 2004-03-22 | 2004-03-26 | 5d | 12d | 0d |  |
| 152 | 1.3.5.3.4.3 | Retest PLASTIC LVPS FM 2 Boards |  | 10d | 2004-05-07 | 2004-05-20 | 151 |  |  | 2004-03-29 | 2004-04-09 | 10d | 12d | 0d |  |
| 153 | 1.3.5.3.5 | **SIT** |  | 30d | 2004-04-02 | 2004-05-13 |  |  |  | 2004-03-01 | 2004-04-09 | 30d | 7d |  |  |
| 154 | 1.3.5.3.5.1 | Test SIT FM 2 HVPS |  | 15d | 2004-04-02 | 2004-04-22 | 110 |  |  | 2004-03-01 | 2004-03-19 | 15d | 7d | 0d |  |
| 155 | 1.3.5.3.5.2 | Coat & Stake SIT FM 2 HVPS Boards |  | 5d | 2004-04-23 | 2004-04-29 | 154 |  |  | 2004-03-22 | 2004-03-26 | 5d | 7d | 0d |  |
| 156 | 1.3.5.3.5.3 | Retest SIT FM 2 HVPS Boards |  | 10d | 2004-04-30 | 2004-05-13 | 155 |  |  | 2004-03-29 | 2004-04-09 | 10d | 7d | 0d |  |
| 157 | 1.4 | **IDPU - UCB** |  | 340d | 2003-05-05 A | 2004-09-07 |  | 76% | 83.19d | 2003-05-05 | 2004-09-07 | 340d | 0d |  |  |
| 158 | 1.4.1 | **Deliveries** |  | 30d | 2004-06-15 | 2004-07-27 |  |  |  | 2004-04-13 | 2004-05-28 | 33d | 13d |  |  |
| 159 | 1.4.1.1 | IDPU FM 1 Complete (to UCB for Boom I&T, then to CIT for SEP I&T, Suite EMC, BO & Final Boom I&T) | milestone | 0d | 2004-06-15 | 2004-06-15 | 174 |  |  | 2004-05-21 | 2004-05-21 | 0d | 9d | 6d |  |
| 160 | 1.4.1.2 | IDPU FM 2 Complete (to CIT for SEP I&T, then to UCB for Boom I&T, Boom EMC, BO & Final Boom I&T) | milestone | 0d | 2004-07-27 | 2004-07-27 | 178 |  |  | 2004-05-28 | 2004-05-28 | 0d | 19d | 0d |  |
| 161 | 1.4.2 | **Flight Software** |  | 237d | 2003-05-05 A | 2004-04-13 |  | 89% | 25.62d | 2003-05-05 | 2004-04-13 | 237d | 60d |  |  |
| 162 | 1.4.2.1 | IDPU S/W Build #2.5 |  | 131d | 2003-05-05 A | 2003-11-07 A |  | 100% |  | 2003-05-05 | 2003-11-07 | 131d |  |  | start no earlier than 2003-05-05 |
| 163 | 1.4.2.2 | IDPU S/W Build #3 (also goes to UNH) |  | 165d | 2003-08-15 A | 2004-04-13 |  | 81% | 32d | 2003-08-15 | 2004-04-13 | 165d | 60d |  | start no earlier than 2003-08-15 |
| 164 | 1.4.3 | **GSE** |  | 301d | 2003-06-30 A | 2004-09-07 |  | 72% | 83.78d | 2003-06-30 | 2004-09-07 | 301d | 0d |  |  |
| 165 | 1.4.3.1 | STE Science Display |  | 27d | 2003-10-23 A | 2003-12-02 A |  | 100% |  | 2003-10-23 | 2003-12-02 | 27d |  |  | start no earlier than 2003-10-23 |
| 166 | 1.4.3.2 | SWEA Science Display |  | 167d | 2003-06-30 A | 2004-03-01 A |  | 100% |  | 2003-06-30 | 2004-02-23 | 162d |  |  | start no earlier than 2003-06-30 |
| 167 | 1.4.3.3 | GSE Continued Development (LOE) |  | 291d | 2003-07-15 A | 2004-09-07 |  | 54% | 135d | 2003-07-15 | 2004-09-07 | 291d | 0d |  | must start on 2003-07-15 |

| ID | WBS | Task | Type | Duration | Start | Finish | Predecessors | Complete | Remaining | Baseline start | Baseline finish | Baseline duration | Total slack | Free slack | Constraint | Calendar |
| --- | --- | --- | --- | --- | --- | --- | --- | --- | --- | --- | --- | --- | --- | --- | --- | --- |
| 168 | 1.4.4 | **Integration & Test** |  | 203d | 2003-10-07 A | 2004-07-27 |  | 38% | 124.92d | 2003-10-07 | 2004-05-28 | 162d | 19d |  |  |  |
| 169 | 1.4.4.1 | IDPU DCB FM 2 Board Level Testing |  | 15d | 2003-10-07 A | 2003-10-28 A |  | 100% |  | 2003-10-07 | 2003-10-28 | 15d |  |  | start no earlier than 2003-10-07 |  |
| 170 | 1.4.4.2 | IDPU DCB Clean/Stake/Coat (FM 1 & FM 2) |  | 10d | 2003-12-26 A | 2004-01-09 A | 169 | 100% |  | 2003-12-26 | 2004-01-09 | 10d |  |  | start no earlier than 2003-12-26 |  |
| 171 | 1.4.4.3 | **FM 1** |  | 20d | 2004-05-18 | 2004-06-15 |  |  |  | 2004-04-26 | 2004-05-21 | 20d | 9d |  |  |  |
| 172 | 1.4.4.3.1 | IDPU FM 1 I & T |  | 5d | 2004-05-18 | 2004-05-24 | 162, 67, 237, 281, 170 |  |  | 2004-04-26 | 2004-04-30 | 5d | 13d | 0d |  |  |
| 173 | 1.4.4.3.2 | IDPU FM 1 Vibration |  | 5d | 2004-05-25 | 2004-06-01 | 172 |  |  | 2004-05-03 | 2004-05-07 | 5d | 13d | 0d |  |  |
| 174 | 1.4.4.3.3 | IDPU FM 1 Thermal Vacuum & Bake Out |  | 10d | 2004-06-02 | 2004-06-15 | 173 |  |  | 2004-05-10 | 2004-05-21 | 10d | 13d | 0d |  |  |
| 175 | 1.4.4.4 | **FM 2** |  | 20d | 2004-06-30 | 2004-07-27 |  |  |  | 2004-05-03 | 2004-05-28 | 20d | 19d |  |  |  |
| 176 | 1.4.4.4.1 | IDPU FM 2 I & T |  | 5d | 2004-06-30 | 2004-07-06 | 73, 238, 282, 169, 170 |  |  | 2004-05-03 | 2004-05-07 | 5d | 19d | 0d |  |  |
| 177 | 1.4.4.4.2 | IDPU FM 2 Vibration |  | 5d | 2004-07-07 | 2004-07-13 | 176 |  |  | 2004-05-10 | 2004-05-14 | 5d | 19d | 0d |  |  |
| 178 | 1.4.4.4.3 | IDPU FM 2 Thermal Vacuum & Bake Out |  | 10d | 2004-07-14 | 2004-07-27 | 163, 177 |  |  | 2004-05-17 | 2004-05-28 | 10d | 19d | 0d |  |  |
| 179 | 1.5 | **BOOM Suite - UCB** |  | 321d | 2003-07-01 A | 2004-10-06 |  | 72% | 90.29d | 2003-07-01 | 2004-09-28 | 315d | 14d |  |  |  |
| 180 | 1.5.1 | **BOOM Structure - UCB** |  | 216d | 2003-09-10 A | 2004-07-19 |  | 85% | 31.33d | 2003-09-10 | 2004-06-18 | 195d | 49d |  |  |  |
| 181 | 1.5.1.1 | **Deliveries** |  | 133d | 2004-01-09 A | 2004-07-19 |  |  | 133d | 2004-01-09 | 2004-06-18 | 112d | 49d |  |  |  |
| 182 | 1.5.1.1.1 | Protoflight Boom available for I&T (if needed) | milestone | 0d | 2004-01-09 A | 2004-01-09 A | 187 | 100% |  | 2004-01-09 | 2004-01-09 | 0d |  |  |  |  |
| 183 | 1.5.1.1.2 | Deliver Boom Structure FM 1 (stays at UCB for Boom Suite FM 1 I&T) | milestone | 0d | 2004-06-02 | 2004-06-02 | 212 |  |  | 2004-05-27 | 2004-05-27 | 0d | 16d | 13d |  |  |
| 184 | 1.5.1.1.3 | Deliver Boom Structure FM 2 (stays at UCB for Boom Suite FM 2 I&T) | milestone | 0d | 2004-07-19 | 2004-07-19 | 234 |  |  | 2004-06-18 | 2004-06-18 | 0d | 49d | 35d |  |  |
| 185 | 1.5.1.2 | **Protoflight** |  | 79d | 2003-09-16 A | 2004-01-09 A |  | 100% |  | 2003-09-16 | 2004-01-09 | 79d |  |  |  |  |
| 186 | 1.5.1.2.1 | Protoflight Boom Post Environmental Deployment Test |  | 35d | 2003-09-16 A | 2003-11-04 A |  | 100% |  | 2003-09-16 | 2003-11-04 | 35d |  |  | start no earlier than 2003-09-16 |  |
| 187 | 1.5.1.2.2 | Document Protoflight Boom Test Results |  | 44d | 2003-11-05 A | 2004-01-09 A | 186 | 100% |  | 2003-11-05 | 2004-01-09 | 44d |  |  |  |  |
| 188 | 1.5.1.3 | **Flight Procurements** |  | 40d | 2003-09-10 A | 2003-11-05 A |  | 100% |  | 2003-09-10 | 2003-11-05 | 40d |  |  |  |  |
| 189 | 1.5.1.3.1 | Receive and Inspect Flight Boom Structure Tubes (FM 1) |  | 32d | 2003-09-10 A | 2003-10-24 A |  | 100% |  | 2003-09-10 | 2003-10-24 | 32d |  |  | start no earlier than 2003-09-10 |  |
| 190 | 1.5.1.3.2 | Receive and Inspect Flight Boom Structure Tubes (FM 2) |  | 40d | 2003-09-10 A | 2003-11-05 A |  | 100% |  | 2003-09-10 | 2003-11-05 | 40d |  |  | start no earlier than 2003-09-10 |  |
| 191 | 1.5.1.4 | **FM 1** |  | 170d | 2003-09-29 A | 2004-06-02 |  | 79% | 35.75d | 2003-09-29 | 2004-05-27 | 167d | 20d |  |  |  |
| 192 | 1.5.1.4.1 | **Telescoping** |  | 84d | 2003-10-27 A | 2004-02-29 A |  | 100% |  | 2003-10-27 | 2004-02-29 | 84d |  |  |  |  |
| 193 | 1.5.1.4.1.1 | **Fabrication, Assembly & Test** |  | 84d | 2003-10-27 A | 2004-02-29 A |  | 100% |  | 2003-10-27 | 2004-02-29 | 84d |  |  |  |  |
| 194 | 1.5.1.4.1.1.1 | Machine FM 1 Boom Structure Tubes as necessary |  | 5d | 2003-10-27 A | 2003-10-31 A | 189 | 100% |  | 2003-10-27 | 2003-10-31 | 5d |  |  |  |  |
| 195 | 1.5.1.4.1.1.2 | Machine FM 1 Boom Structure Parts (Rings) |  | 38d | 2003-11-07 A | 2004-01-05 A | 189FF+47d | 100% |  | 2003-11-07 | 2004-01-05 | 38d |  |  |  |  |
| 196 | 1.5.1.4.1.1.3 | Assemble FM 1 Boom Structure Telescoping Assembly |  | 5d | 2004-02-23 A | 2004-02-27 A | 194, 195 | 100% |  | 2004-02-23 | 2004-02-27 | 5d |  |  | start no earlier than 2004-02-23 |  |
| 197 | 1.5.1.4.1.1.4 | Test FM 1 Boom Structure Telescoping Assembly |  | 2d | 2004-02-28 A | 2004-02-29 A | 196 | 100% |  | 2004-02-28 | 2004-02-29 | 2d |  |  |  | Boom Test Calendar |

| ID | WBS | Task | Duration | Start | Finish | Predecessors | Complete | Remaining | Baseline start | Baseline finish | Baseline duration | Total slack | Free slack | Constraint | Calendar |
| --- | --- | --- | --- | --- | --- | --- | --- | --- | --- | --- | --- | --- | --- | --- | --- |
| 198 | 1.5.1.4.2 | **Harness** | 109d | 2003-09-29 A | 2004-03-08 A |  | 100% |  | 2003-09-29 | 2004-03-08 | 109d |  |  |  |  |
| 199 | 1.5.1.4.2.1 | **Fabrication** | 103d | 2003-09-29 A | 2004-02-27 A |  | 100% |  | 2003-09-29 | 2004-02-27 | 103d |  |  |  |  |
| 200 | 1.5.1.4.2.1.1 | Machine FM 1 Harness Parts | 103d | 2003-09-29 A | 2004-02-27 A |  | 100% |  | 2003-09-29 | 2004-02-27 | 103d |  |  | start no earlier than 2003-09-29 |  |
| 201 | 1.5.1.4.2.2 | **Assembly & Test** | 6d | 2004-03-01 A | 2004-03-08 A |  | 100% |  | 2004-03-01 | 2004-03-08 | 6d |  |  |  |  |
| 202 | 1.5.1.4.2.2.1 | Assemble FM 1 Harness subassembly | 7d | 2004-03-01 A | 2004-03-07 A | 200 | 100% |  | 2004-03-01 | 2004-03-07 | 7d |  |  | start no earlier than 2004-03-01 | Boom Test Calendar |
| 203 | 1.5.1.4.2.2.2 | FM1 Harness Test | 1d | 2004-03-08 A | 2004-03-08 A | 202 | 100% |  | 2004-03-08 | 2004-03-08 | 1d |  |  |  |  |
| 204 | 1.5.1.4.3 | **Mounting** | 38d | 2003-09-29 A | 2003-11-21 A |  | 100% |  | 2003-09-29 | 2003-11-21 | 38d |  |  |  |  |
| 205 | 1.5.1.4.3.1 | FM 1Boom Structure Mounting Fabrication | 28d | 2003-09-29 A | 2003-11-06 A |  | 100% |  | 2003-09-29 | 2003-11-06 | 28d |  |  | start no earlier than 2003-09-29 |  |
| 206 | 1.5.1.4.3.2 | FM 1Boom Structure Mounting Assembly | 10d | 2003-11-07 A | 2003-11-21 A | 205 | 100% |  | 2003-11-07 | 2003-11-21 | 10d |  |  |  |  |
| 207 | 1.5.1.4.4 | **Integration & Test** | 57d | 2004-03-15 | 2004-06-02 |  |  |  | 2004-03-09 | 2004-05-27 | 58d | 16d |  |  |  |
| 208 | 1.5.1.4.4.1 | Integrate FM 1 Boom Structure subassemblies & Harness Completion | 20d | 2004-03-15 | 2004-04-09 | 197, 203, 230FS-5d |  |  | 2004-03-09 | 2004-04-05 | 20d | 20d | 0d |  |  |
| 209 | 1.5.1.4.4.2 | FM 1 Boom Structure Deployment Test | 10d | 2004-04-12 | 2004-04-23 | 208 |  |  | 2004-04-06 | 2004-04-19 | 10d | 20d | 0d |  |  |
| 210 | 1.5.1.4.4.3 | FM 1 Boom Structure Vibration Test | 4d | 2004-04-30 | 2004-05-05 | 209, 348 |  |  | 2004-04-27 | 2004-04-30 | 4d | 20d | 0d |  |  |
| 211 | 1.5.1.4.4.4 | FM 1 Boom Structure Themal Vac & Bake Out | 15d | 2004-05-06 | 2004-05-26 | 210 |  |  | 2004-05-03 | 2004-05-21 | 15d | 20d | 0d |  |  |
| 212 | 1.5.1.4.4.5 | FM 1 Boom Structure Post Environmental Deployment Test | 4d | 2004-05-27 | 2004-06-02 | 211 |  |  | 2004-05-24 | 2004-05-27 | 4d | 20d | 0d |  |  |
| 213 | 1.5.1.5 | **FM 2** | 203d | 2003-09-29 A | 2004-07-19 |  | 83% | 33.97d | 2003-09-29 | 2004-06-18 | 182d | 49d |  |  |  |
| 214 | 1.5.1.5.1 | **Telescoping** | 78d | 2003-11-06 A | 2004-03-02 A |  | 100% |  | 2003-11-06 | 2004-03-16 | 88d |  |  |  |  |
| 215 | 1.5.1.5.1.1 | **Fabrication, Assembly & Test** | 78d | 2003-11-06 A | 2004-03-02 A |  | 100% |  | 2003-11-06 | 2004-03-16 | 88d |  |  |  |  |
| 216 | 1.5.1.5.1.1.1 | Machine FM 2 Boom Structure Tubes as necessary | 11d | 2003-11-06 A | 2003-11-21 A | 190 | 100% |  | 2003-11-06 | 2003-11-21 | 11d |  |  |  |  |
| 217 | 1.5.1.5.1.1.2 | Machine FM 2 Boom Structure Parts (Rings) | 38d | 2003-11-07 A | 2004-01-05 A | 195SS | 100% |  | 2003-11-07 | 2004-01-05 | 38d |  |  |  |  |
| 218 | 1.5.1.5.1.1.3 | Assemble FM 2 Boom Structure Telescoping Assembly | 5d | 2004-02-23 A | 2004-02-27 A | 216, 217, 196SS | 100% |  | 2004-02-23 | 2004-02-27 | 5d |  |  |  |  |
| 219 | 1.5.1.5.1.1.4 | Test FM 2 Boom Structure Telescoping Assembly | 2d | 2004-03-01 A | 2004-03-02 A | 218 | 100% |  | 2004-03-15 | 2004-03-16 | 2d |  |  |  |  |
| 220 | 1.5.1.5.2 | **Harness** | 110d | 2003-09-29 A | 2004-03-09 A |  | 100% |  | 2003-09-29 | 2004-03-16 | 115d |  |  |  |  |
| 221 | 1.5.1.5.2.1 | **Fabrication** | 103d | 2003-09-29 A | 2004-02-27 A |  | 100% |  | 2003-09-29 | 2004-02-27 | 103d |  |  |  |  |
| 222 | 1.5.1.5.2.1.1 | Machine FM 2 Harness Parts | 103d | 2003-09-29 A | 2004-02-27 A | 200SS | 100% |  | 2003-09-29 | 2004-02-27 | 103d |  |  |  |  |

| ID | WBS | Task | Duration | Start | Finish | Predecessors | Complete | Remaining | Baseline start | Baseline finish | Baseline duration | Total slack | Free slack | Constraint |
| --- | --- | --- | --- | --- | --- | --- | --- | --- | --- | --- | --- | --- | --- | --- |
| 223 | 1.5.1.5.2.2 | **Assembly & Test** | 7d | 2004-03-01 A | 2004-03-09 A |  | 100% |  | 2004-03-01 | 2004-03-16 | 12d |  |  |  |
| 224 | 1.5.1.5.2.2.1 | Assemble FM 2 Harness subassembly | 6d | 2004-03-01 A | 2004-03-08 A | 222 | 100% |  | 2004-03-01 | 2004-03-15 | 11d |  |  |  |
| 225 | 1.5.1.5.2.2.2 | FM 2 Harness Test | 1d | 2004-03-09 A | 2004-03-09 A | 224 | 100% |  | 2004-03-16 | 2004-03-16 | 1d |  |  |  |
| 226 | 1.5.1.5.3 | **Mounting** | 38d | 2003-09-29 A | 2003-11-21 A |  | 100% |  | 2003-09-29 | 2003-11-21 | 38d |  |  |  |
| 227 | 1.5.1.5.3.1 | FM 2 Boom Structure Mountings Fabrication | 28d | 2003-09-29 A | 2003-11-06 A | 205SS | 100% |  | 2003-09-29 | 2003-11-06 | 28d |  |  |  |
| 228 | 1.5.1.5.3.2 | FM 2 Boom Structure Mountings Assembly | 10d | 2003-11-07 A | 2003-11-21 A | 227 | 100% |  | 2003-11-07 | 2003-11-21 | 10d |  |  |  |
| 229 | 1.5.1.5.4 | **Integration & Test** | 93d | 2004-03-10 | 2004-07-19 |  |  |  | 2004-03-17 | 2004-06-18 | 67d | 16d |  |  |
| 230 | 1.5.1.5.4.1 | Integrate FM 2 Boom Structure subassemblies & Harness Completion | 8d | 2004-03-10 | 2004-03-19 | 219, 225 |  |  | 2004-03-17 | 2004-04-13 | 20d | 20d | 0d |  |
| 231 | 1.5.1.5.4.2 | FM 2 Boom Structure Deployment Test | 10d | 2004-03-22 | 2004-04-02 | 230 |  |  | 2004-04-14 | 2004-04-27 | 10d | 97d | 48d |  |
| 232 | 1.5.1.5.4.3 | FM 2 Boom Structure Vibration Test | 4d | 2004-06-17 | 2004-06-22 | 231, 353 |  |  | 2004-05-17 | 2004-05-20 | 4d | 49d | 0d |  |
| 233 | 1.5.1.5.4.4 | FM 2 Boom Structure Themal Vac & Bake Out | 15d | 2004-06-23 | 2004-07-13 | 232, 211 |  |  | 2004-05-24 | 2004-06-14 | 15d | 49d | 0d |  |
| 234 | 1.5.1.5.4.5 | FM 2 Boom Structure Post Environmental Deployment Test | 4d | 2004-07-14 | 2004-07-19 | 233 |  |  | 2004-06-15 | 2004-06-18 | 4d | 49d | 0d |  |
| 235 | 1.5.2 | **MAG - GSFC** | 27d | 2004-02-20 A | 2004-03-29 |  | 22% | 21d | 2004-02-20 | 2004-03-29 | 27d | 84d |  |  |
| 236 | 1.5.2.1 | **Deliveries** | 2d | 2004-03-26 | 2004-03-29 |  |  |  | 2004-03-26 | 2004-03-29 | 2d | 39d |  |  |
| 237 | 1.5.2.1.1 | Deliver MAG FM 1 (to UCB for IDPU/BOOM Suite FM 1 I&T) | 2d | 2004-03-26 | 2004-03-29 | 241 |  |  | 2004-03-26 | 2004-03-29 | 2d | 39d | 19d |  |
| 238 | 1.5.2.1.2 | Deliver MAG FM 2 (to UCB for IDPU/BOOM Suite FM 2 I&T) | 2d | 2004-03-26 | 2004-03-29 | 244 |  |  | 2004-03-26 | 2004-03-29 | 2d | 84d | 52d |  |
| 239 | 1.5.2.2 | **FM 1** | 25d | 2004-02-20 A | 2004-03-25 |  | 24% | 19d | 2004-02-20 | 2004-03-25 | 25d | 39d |  |  |
| 240 | 1.5.2.2.1 | FM 1 MAG Testing | 10d | 2004-02-20 A | 2004-03-04 |  | 60% | 4d | 2004-02-20 | 2004-03-04 | 10d | 35d | 0d | start no earlier than 2004-02-20 |
| 241 | 1.5.2.2.2 | MAG FM 1 Calibration | 15d | 2004-03-05 | 2004-03-25 | 240 |  |  | 2004-03-05 | 2004-03-25 | 15d | 39d | 0d |  |
| 242 | 1.5.2.3 | **FM 2** | 25d | 2004-02-20 A | 2004-03-25 |  | 24% | 19d | 2004-02-20 | 2004-03-25 | 25d | 84d |  |  |
| 243 | 1.5.2.3.1 | FM 2 MAG Testing | 10d | 2004-02-20 A | 2004-03-04 |  | 60% | 4d | 2004-02-20 | 2004-03-04 | 10d | 61d | 0d | start no earlier than 2004-02-20 |
| 244 | 1.5.2.3.2 | MAG FM 2 Calibration | 15d | 2004-03-05 | 2004-03-25 | 243 |  |  | 2004-03-05 | 2004-03-25 | 15d | 84d | 0d |  |
| 245 | 1.5.3 | **SWEA - CESR** | 102d | 2003-12-08 A | 2004-05-03 |  | 8% | 94.15d | 2003-12-08 | 2004-04-20 | 93d | 58d |  |  |
| 246 | 1.5.3.1 | **Deliveries** | 102d | 2003-12-08 A | 2004-05-03 |  | 50% | 51d | 2003-12-08 | 2004-04-20 | 93d | 58d |  |  |
| 247 | 1.5.3.1.1 | SWEA FM 1 Delivery to UCB | 3d | 2003-12-08 A | 2003-12-10 A |  | 100% |  | 2003-12-08 | 2003-12-10 | 3d |  |  | start no earlier than 2003-12-08 |
| 248 | 1.5.3.1.2 | SWEA FM 2 Delivery to UCB | 3d | 2004-04-29 | 2004-05-03 | 251 |  |  | 2004-04-16 | 2004-04-20 | 3d | 58d | 44d |  |

| ID | WBS | Task | Type | Duration | Start | Finish | Predecessors | Complete | Remaining | Baseline start | Baseline finish | Baseline duration | Total slack | Free slack | Constraint |
| --- | --- | --- | --- | --- | --- | --- | --- | --- | --- | --- | --- | --- | --- | --- | --- |
| 249 | 1.5.3.2 | **FM 2** |  | 33d | 2004-03-15 | 2004-04-28 |  |  |  | 2004-02-10 | 2004-04-15 | 47d | 58d |  |  |
| 250 | 1.5.3.2.1 | SWEA FM 2 Final Assembly (Block 2) |  | 3d | 2004-03-15 | 2004-03-17 |  |  |  | 2004-02-10 | 2004-02-12 | 3d | 58d | 0d | start no earlier than 2004-03-15 |
| 251 | 1.5.3.2.2 | SWEA FM 2 Calibration |  | 30d | 2004-03-18 | 2004-04-28 | 250 |  |  | 2004-02-13 | 2004-04-15 | 44d | 58d | 0d |  |
| 252 | 1.5.4 | **STE - UCB** |  | 196d | 2003-08-29 A | 2004-06-10 |  | 70% | 58.4d | 2003-08-29 | 2004-05-10 | 174d | 49d |  |  |
| 253 | 1.5.4.1 | **Deliveries** |  | 38d | 2004-04-16 | 2004-06-10 |  |  |  | 2004-04-14 | 2004-05-10 | 18d | 22d |  |  |
| 254 | 1.5.4.1.1 | Deliver STE-D FM 1 (stays at UCB for SWEA/STE-D FM 1 I&T) | milestone | 0d | 2004-04-16 | 2004-04-16 | 269 |  |  | 2004-04-14 | 2004-04-14 | 0d | 18d | 15d |  |
| 255 | 1.5.4.1.2 | Deliver STE-D FM 2 (stays at UCB for SWEA/STE-D FM 2 I&T) | milestone | 0d | 2004-06-10 | 2004-06-10 | 277 |  |  | 2004-05-10 | 2004-05-10 | 0d | 31d | 17d |  |
| 256 | 1.5.4.1.3 | Deliver STE-U FM 1 (stays at UCB for BOOM Suite FM 1 I&T) | milestone | 0d | 2004-04-22 | 2004-04-22 | 270 |  |  | 2004-04-20 | 2004-04-20 | 0d | 17d | 1d |  |
| 257 | 1.5.4.1.4 | Deliver STE-U FM 2 (stays at UCB for BOOM Suite FM 2 I&T) | milestone | 0d | 2004-06-10 | 2004-06-10 | 278 |  |  | 2004-05-10 | 2004-05-10 | 0d | 49d | 0d |  |
| 258 | 1.5.4.2 | **STE-U/D Housing** |  | 53d | 2003-11-21 A | 2004-02-09 A |  | 100% |  | 2003-11-21 | 2004-02-09 | 53d |  |  |  |
| 259 | 1.5.4.2.1 | Fabricate STE FM 1 Box |  | 53d | 2003-11-21 A | 2004-02-09 A |  | 100% |  | 2003-11-21 | 2004-02-09 | 53d |  |  | start no earlier than 2003-11-21 |
| 260 | 1.5.4.2.2 | Fabricate STE FM 2 Box |  | 53d | 2003-11-21 A | 2004-02-09 A |  | 100% |  | 2003-11-21 | 2004-02-09 | 53d |  |  | start no earlier than 2003-11-21 |
| 261 | 1.5.4.3 | **STE-U/D Detector Boards** |  | 196d | 2003-08-29 A | 2004-06-10 |  | 61% | 76.77d | 2003-08-29 | 2004-05-10 | 174d | 49d |  |  |
| 262 | 1.5.4.3.1 | Coupon Test STE FM 1 & FM 2 Detector Printed Wiring Board |  | 17d | 2003-10-10 A | 2003-11-04 A | 264, 272 | 100% |  | 2003-10-10 | 2003-11-04 | 17d |  |  | start no earlier than 2003-10-10 |
| 263 | 1.5.4.3.2 | **FM 1** |  | 162d | 2003-08-29 A | 2004-04-22 |  | 64% | 57.93d | 2003-08-29 | 2004-04-20 | 160d | 21d |  |  |
| 264 | 1.5.4.3.2.1 | Fabrication STE FM 1 Detector Printed Wiring Board |  | 29d | 2003-08-29 A | 2003-10-09 A |  | 100% |  | 2003-08-29 | 2003-10-09 | 29d |  |  | start no earlier than 2003-08-29 |
| 265 | 1.5.4.3.2.2 | Load STE FM 1 Detector Printed Wiring Board |  | 60d | 2003-11-05 A | 2004-02-03 A | 262 | 100% |  | 2003-11-05 | 2004-02-03 | 60d |  |  |  |
| 266 | 1.5.4.3.2.3 | Test STE FM 1 Detector Printed Wiring Board |  | 10d | 2004-02-04 A | 2004-02-18 A | 265 | 100% |  | 2004-02-04 | 2004-02-18 | 10d |  |  |  |
| 267 | 1.5.4.3.2.4 | **Integration & Test** |  | 46d | 2004-02-19 A | 2004-04-22 |  | 11% | 41.12d | 2004-02-19 | 2004-04-20 | 44d | 21d |  |  |
| 268 | 1.5.4.3.2.4.1 | Integrate & Test STE-U/D FM 1 Detectors W/ FM 1 Housings |  | 34d | 2004-02-19 A | 2004-04-06 | 259, 266 | 21% | 27d | 2004-02-19 | 2004-03-17 | 20d | 21d | 0d |  |
| 269 | 1.5.4.3.2.4.2 | Calibrate STE-U/D FM 1 |  | 18d | 2004-03-24 | 2004-04-16 | 268FS-10d |  |  | 2004-03-18 | 2004-04-14 | 20d | 21d | 0d |  |
| 270 | 1.5.4.3.2.4.3 | STE-U FM 1 Thermal Vacuum/Balance/Bake Out |  | 14d | 2004-04-05 | 2004-04-22 | 269FS-10d |  |  | 2004-04-01 | 2004-04-20 | 14d | 21d | 0d |  |
| 271 | 1.5.4.3.3 | **FM 2** |  | 196d | 2003-08-29 A | 2004-06-10 |  | 53% | 92.31d | 2003-08-29 | 2004-05-10 | 174d | 49d |  |  |
| 272 | 1.5.4.3.3.1 | Fabricate STE FM 2 Detector Printed Wiring Board |  | 29d | 2003-08-29 A | 2003-10-09 A |  | 100% |  | 2003-08-29 | 2003-10-09 | 29d |  |  | start no earlier than 2003-08-29 |
| 273 | 1.5.4.3.3.2 | Load STE FM 2 Detector Printed Wiring Board |  | 63d | 2003-11-05 A | 2004-03-12 | 262, 266FF+17d | 84% | 10d | 2003-11-05 | 2004-03-17 | 63d | 51d | 0d |  |
| 274 | 1.5.4.3.3.3 | Test STE FM 2 Detector Printed Wiring Board |  | 5d | 2004-03-15 | 2004-03-19 | 273 |  |  | 2004-03-18 | 2004-03-31 | 10d | 51d | 20d |  |

| ID | WBS | Task | Type | Duration | Start | Finish | Predecessors | Complete | Remaining | Baseline start | Baseline finish | Baseline duration | Total slack | Free slack | Constraint |
| --- | --- | --- | --- | --- | --- | --- | --- | --- | --- | --- | --- | --- | --- | --- | --- |
| 275 | 1.5.4.3.3.4 | **Integration & Test** |  | 38d | 2004-04-19 | 2004-06-10 |  |  |  | 2004-04-01 | 2004-05-10 | 28d | 31d |  |  |
| 276 | 1.5.4.3.3.4.1 | Integrate & Test STE-U/D FM 2 Detectors W/ FM 2 Housings |  | 20d | 2004-04-19 | 2004-05-14 | 260, 274, 268FS-10d, 269 |  |  | 2004-04-01 | 2004-04-14 | 10d | 31d | 0d |  |
| 277 | 1.5.4.3.3.4.2 | Calibrate STE-U/D FM 2 |  | 28d | 2004-05-03 | 2004-06-10 | 276FS-10d |  |  | 2004-04-15 | 2004-05-10 | 18d | 31d | 0d |  |
| 278 | 1.5.4.3.3.4.3 | STE-U FM 2 Thermal Vacuum/Bake Out |  | 10d | 2004-05-27 | 2004-06-10 | 277FS-10d |  |  | 2004-04-27 | 2004-05-10 | 10d | 49d | 0d |  |
| 279 | 1.5.5 | **STE and SWEA - UCB** |  | 300d | 2003-07-01 A | 2004-09-07 |  | 72% | 83.15d | 2003-07-01 | 2004-08-27 | 294d | 14d |  |  |
| 280 | 1.5.5.1 | **Deliveries** |  | 115d | 2004-03-26 | 2004-09-07 |  |  |  | 2004-02-27 | 2004-08-27 | 129d | 14d |  |  |
| 281 | 1.5.5.1.1 | Deliver STE-U FM 1 Interface (stays at UCB for IDPU FM 1 I&T) | milestone | 0d | 2004-03-26 | 2004-03-26 | 330 |  |  | 2004-02-27 | 2004-02-27 | 0d | 45d | 36d |  |
| 282 | 1.5.5.1.2 | Deliver STE-U FM 2 Interface (stays at UCB for IDPU FM 2 I&T) | milestone | 0d | 2004-04-02 | 2004-04-02 | 339 |  |  | 2004-03-01 | 2004-03-01 | 0d | 57d |  |  |
| 283 | 1.5.5.1.3 | Deliver SWEA/STE-D FM 1 (stays at UCB for Boom Suite FM 1 I&T) | milestone | 0d | 2004-06-21 | 2004-06-21 | 336 |  |  | 2004-06-11 | 2004-06-11 | 0d | 7d | 0d |  |
| 284 | 1.5.5.1.4 | Deliver SWEA/STE-D FM 2 (stays at UCB for Boom Suite FM 2 I&T) | milestone | 0d | 2004-09-07 | 2004-09-07 | 345 |  |  | 2004-08-27 | 2004-08-27 | 0d | 14d | 0d |  |
| 285 | 1.5.5.2 | **SWEA Pedestal** |  | 152d | 2003-07-01 A | 2004-02-09 A |  | 100% |  | 2003-07-01 | 2004-02-09 | 152d |  |  |  |
| 286 | 1.5.5.2.1 | Fabricate SWEA FM 1 Baseplate |  | 152d | 2003-07-01 A | 2004-02-09 A |  | 100% |  | 2003-07-01 | 2004-02-09 | 152d |  |  | start no earlier than 2003-07-01 |
| 287 | 1.5.5.2.2 | Fabricate SWEA FM 2 Baseplate |  | 152d | 2003-07-01 A | 2004-02-09 A |  | 100% |  | 2003-07-01 | 2004-02-09 | 152d |  |  | start no earlier than 2003-07-01 |
| 288 | 1.5.5.3 | **STE-D Pre-Amp Board** |  | 119d | 2003-09-22 A | 2004-03-15 |  | 89% | 12.8d | 2003-09-22 | 2004-02-23 | 104d | 63d |  |  |
| 289 | 1.5.5.3.1 | **FM 1** |  | 119d | 2003-09-22 A | 2004-03-15 |  | 87% | 15.26d | 2003-09-22 | 2004-02-23 | 104d | 12d |  |  |
| 290 | 1.5.5.3.1.1 | Fabricate STE-D FM 1 Preamp Printed Wiring Board |  | 34d | 2003-09-22 A | 2003-11-07 A |  | 100% |  | 2003-09-22 | 2003-11-07 | 34d |  |  | start no earlier than 2003-09-22 |
| 291 | 1.5.5.3.1.2 | Load STE-D FM 1 Preamp Printed Wiring Board |  | 5d | 2004-03-09 | 2004-03-15 | 295 |  |  | 2004-02-17 | 2004-02-23 | 5d | 16d | 0d | start no earlier than 2004-03-09 |
| 292 | 1.5.5.3.2 | **FM 2** |  | 119d | 2003-09-22 A | 2004-03-15 |  | 87% | 15.26d | 2003-09-22 | 2004-02-23 | 104d | 63d |  |  |
| 293 | 1.5.5.3.2.1 | Fabricate STE-D FM 2 Preamp Printed Wiring Board |  | 34d | 2003-09-22 A | 2003-11-07 A |  | 100% |  | 2003-09-22 | 2003-11-07 | 34d |  |  | start no earlier than 2003-09-22 |
| 294 | 1.5.5.3.2.2 | Load STE-D FM 2 Preamp Printed Wiring Board |  | 5d | 2004-03-09 | 2004-03-15 | 291SS |  |  | 2004-02-17 | 2004-02-23 | 5d | 63d | 49d |  |
| 295 | 1.5.5.3.3 | Coupon Test STE-D FM 1 & FM 2 Pre-Amp Printed Wiring Boards |  | 15d | 2003-11-10 A | 2003-12-02 A | 290, 293 | 100% |  | 2003-11-10 | 2003-12-02 | 15d |  |  |  |
| 296 | 1.5.5.4 | **STE-D Shaper Board** |  | 118d | 2003-12-04 A | 2004-05-21 |  | 78% | 26.22d | 2003-12-04 | 2004-05-13 | 112d | 14d |  |  |
| 297 | 1.5.5.4.1 | **FM 1** |  | 67d | 2003-12-04 A | 2004-03-11 |  | 67% | 22.33d | 2003-12-04 | 2004-02-20 | 53d | 14d |  |  |
| 298 | 1.5.5.4.1.1 | Fabricate STE-D FM 1 Shaper Printed Wiring Board |  | 10d | 2003-12-04 A | 2003-12-17 A |  | 100% |  | 2003-12-04 | 2003-12-17 | 10d |  |  | start no earlier than 2003-12-04 |
| 299 | 1.5.5.4.1.2 | Load STE-D FM 1 Shaper Printed Wiring Board |  | 5d | 2004-03-05 | 2004-03-11 | 303 |  |  | 2004-02-13 | 2004-02-20 | 5d | 18d | 0d | start no earlier than 2004-03-05 |

| ID | WBS | Task | Duration | Start | Finish | Predecessors | Complete | Remaining | Baseline start | Baseline finish | Baseline duration | Total slack | Free slack | Constraint |
| --- | --- | --- | --- | --- | --- | --- | --- | --- | --- | --- | --- | --- | --- | --- |
| 300 | 1.5.5.4.2 | **FM 2** | 118d | 2003-12-04 A | 2004-05-21 |  | 67% | 39.33d | 2003-12-04 | 2004-05-13 | 112d | 14d |  |  |
| 301 | 1.5.5.4.2.1 | Fabricate STE-D FM 2 Shaper Printed Wiring Board | 10d | 2003-12-04 A | 2003-12-17 A |  | 100% |  | 2003-12-04 | 2003-12-17 | 10d |  |  | start no earlier than 2003-12-04 |
| 302 | 1.5.5.4.2.2 | Load STE-D FM 2 Shaper Printed Wiring Board | 5d | 2004-05-17 | 2004-05-21 | 303, 334 |  |  | 2004-05-07 | 2004-05-13 | 5d | 14d | 0d |  |
| 303 | 1.5.5.4.3 | Coupon Test STE-D FM 1 & FM 2 Shaper Printed Wiring Boards | 15d | 2003-12-18 A | 2004-01-09 A | 298, 301 | 100% |  | 2003-12-18 | 2004-01-09 | 15d |  |  |  |
| 304 | 1.5.5.5 | **STE-D Interface Board** | 118d | 2003-12-04 A | 2004-05-21 |  | 78% | 26.22d | 2003-12-04 | 2004-05-13 | 112d | 14d |  |  |
| 305 | 1.5.5.5.1 | **FM 1** | 67d | 2003-12-04 A | 2004-03-11 |  | 67% | 22.33d | 2003-12-04 | 2004-02-20 | 53d | 14d |  |  |
| 306 | 1.5.5.5.1.1 | Fabricate SWEA / STE-D FM 1 Digital to Analog Converter Printed Wiring Board | 10d | 2003-12-04 A | 2003-12-17 A |  | 100% |  | 2003-12-04 | 2003-12-17 | 10d |  |  | start no earlier than 2003-12-04 |
| 307 | 1.5.5.5.1.2 | Load SWEA / STE-D FM 1 Digital to Analog Converter Printed Wiring Board | 5d | 2004-03-05 | 2004-03-11 | 299SS |  |  | 2004-02-13 | 2004-02-20 | 5d | 18d | 2d |  |
| 308 | 1.5.5.5.2 | **FM 2** | 118d | 2003-12-04 A | 2004-05-21 |  | 67% | 39.33d | 2003-12-04 | 2004-05-13 | 112d | 14d |  |  |
| 309 | 1.5.5.5.2.1 | Fabricate SWEA / STE-D FM 2 Digital to Analog Converter Printed Wiring Board | 10d | 2003-12-04 A | 2003-12-17 A |  | 100% |  | 2003-12-04 | 2003-12-17 | 10d |  |  | start no earlier than 2003-12-04 |
| 310 | 1.5.5.5.2.2 | Load SWEA / STE-D FM 2 Digital to Analog Converter Printed Wiring Board | 5d | 2004-05-17 | 2004-05-21 | 302SS |  |  | 2004-05-07 | 2004-05-13 | 5d | 14d | 0d |  |
| 311 | 1.5.5.5.3 | Coupon Test STE-D FM 1 & FM 2 D/A Converter Printed Wiring Boards | 15d | 2003-12-18 A | 2004-01-09 A | 306, 309 | 100% |  | 2003-12-18 | 2004-01-09 | 15d |  |  |  |
| 312 | 1.5.5.6 | **STE-U Pre-Amp Board** | 119d | 2003-09-22 A | 2004-03-15 |  | 95% | 6.47d | 2003-09-22 | 2004-02-23 | 104d | 89d |  |  |
| 313 | 1.5.5.6.1 | **FM 1** | 79d | 2003-09-22 A | 2004-01-15 A |  | 100% |  | 2003-09-22 | 2004-01-15 | 79d |  |  |  |
| 314 | 1.5.5.6.1.1 | Fabricate STE-U FM 1 Preamp Printed Wiring Board | 34d | 2003-09-22 A | 2003-11-07 A |  | 100% |  | 2003-09-22 | 2003-11-07 | 34d |  |  | start no earlier than 2003-09-22 |
| 315 | 1.5.5.6.1.2 | Load STE-U FM 1 Preamp Printed Wiring Board | 4d | 2004-01-12 A | 2004-01-15 A | 319 | 100% |  | 2004-01-12 | 2004-01-15 | 4d |  |  | start no earlier than 2004-01-12 |
| 316 | 1.5.5.6.2 | **FM 2** | 119d | 2003-09-22 A | 2004-03-15 |  | 87% | 15.26d | 2003-09-22 | 2004-02-23 | 104d | 66d |  |  |
| 317 | 1.5.5.6.2.1 | Fabricate STE-U FM 2 Preamp Printed Wiring Board | 34d | 2003-09-22 A | 2003-11-07 A |  | 100% |  | 2003-09-22 | 2003-11-07 | 34d |  |  | start no earlier than 2003-09-22 |
| 318 | 1.5.5.6.2.2 | Load STE-U FM 2 Preamp Printed Wiring Board | 5d | 2004-03-09 | 2004-03-15 | 319 |  |  | 2004-02-17 | 2004-02-23 | 5d | 89d | 9d | start no earlier than 2004-03-09 |
| 319 | 1.5.5.6.3 | Coupon Test STE-U FM 1 & FM 2 Pre-Amp Printed Wiring Boards | 15d | 2003-11-10 A | 2003-12-02 A | 314, 317 | 100% |  | 2003-11-10 | 2003-12-02 | 15d |  |  |  |
| 320 | 1.5.5.7 | **STE-U Shaper & Interface Board** | 78d | 2003-12-04 A | 2004-03-26 |  | 66% | 26.49d | 2003-12-04 | 2004-02-20 | 53d | 80d |  |  |
| 321 | 1.5.5.7.1 | **FM 1** | 73d | 2003-12-04 A | 2004-03-19 |  | 43% | 41.26d | 2003-12-04 | 2004-02-20 | 53d | 45d |  |  |
| 322 | 1.5.5.7.1.1 | Fabricate STE-U FM 1Shaper & Interface Printed Wiring Board | 10d | 2003-12-04 A | 2003-12-17 A |  | 100% |  | 2003-12-04 | 2003-12-17 | 10d |  |  | start no earlier than 2003-12-04 |
| 323 | 1.5.5.7.1.2 | Load STE-U FM 1 Shaper & Interface Printed Wiring Board | 13d | 2004-03-03 | 2004-03-19 | 327 |  |  | 2004-02-13 | 2004-02-20 | 5d | 49d | 0d | start no earlier than 2004-03-03 |

| ID | WBS | Task | Duration | Start | Finish | Predecessors | Complete | Remaining | Baseline start | Baseline finish | Baseline duration | Total slack | Free slack | Constraint |
| --- | --- | --- | --- | --- | --- | --- | --- | --- | --- | --- | --- | --- | --- | --- |
| 324 | 1.5.5.7.2 | **FM 2** | 78d | 2003-12-04 A | 2004-03-26 |  | 67% | 26d | 2003-12-04 | 2004-02-20 | 53d | 57d |  |  |
| 325 | 1.5.5.7.2.1 | Fabricate STE-U FM 2 Shaper & Interface Printed Wiring Board | 10d | 2003-12-04 A | 2003-12-17 A |  | 100% |  | 2003-12-04 | 2003-12-17 | 10d |  |  | start no earlier than 2003-12-04 |
| 326 | 1.5.5.7.2.2 | Load STE-U FM 2 Shaper & Interface Printed Wiring Board | 5d | 2004-03-22 | 2004-03-26 | 323 |  |  | 2004-02-13 | 2004-02-20 | 5d | 80d | 0d |  |
| 327 | 1.5.5.7.3 | Coupon Test STE-U FM 1 & FM 2 Shaper & Interface Printed Wiring Boards | 15d | 2003-12-18 A | 2004-01-09 A | 322, 325 | 100% |  | 2003-12-18 | 2004-01-09 | 15d |  |  |  |
| 328 | 1.5.5.8 | **Integration & Test** | 124d | 2004-03-16 | 2004-09-07 |  |  |  | 2004-02-23 | 2004-08-27 | 134d | 14d |  |  |
| 329 | 1.5.5.8.1 | **FM 1** | 112d | 2004-03-16 | 2004-08-19 |  |  |  | 2004-02-23 | 2004-07-30 | 114d | 16d |  |  |
| 330 | 1.5.5.8.1.1 | Integrate & Test STE-U FM 1 Interface Boards | 5d | 2004-03-22 | 2004-03-26 | 315, 323 |  |  | 2004-02-23 | 2004-02-27 | 5d | 49d | 0d |  |
| 331 | 1.5.5.8.1.2 | Integrate & Test SWEA/STE-D FM 1 Interface Boards | 20d | 2004-03-16 | 2004-04-12 | 286, 291, 299, 307 |  |  | 2004-02-24 | 2004-03-22 | 20d | 16d | 0d |  |
| 332 | 1.5.5.8.1.3 | Integrate & Test SWEA/STE-D FM 1 Interface with SWEA/STE-D FM 1 LVPS | 10d | 2004-04-26 | 2004-05-07 | 331, 69 |  |  | 2004-04-16 | 2004-04-29 | 10d | 7d | 0d |  |
| 333 | 1.5.5.8.1.4 | Clean/Coat/Stake SWEA/STE-D Interface | 10d | 2004-04-13 | 2004-04-26 | 331 |  |  | 2004-03-23 | 2004-04-05 | 10d | 16d | 9d |  |
| 334 | 1.5.5.8.1.5 | Integrate & Test SWEA/STE-D FM 1 Combined | 5d | 2004-05-10 | 2004-05-14 | 332, 333, 247, 254 |  |  | 2004-04-30 | 2004-05-06 | 5d | 7d | 0d |  |
| 335 | 1.5.5.8.1.6 | Calibrate SWEA/STE FM 1 | 20d | 2004-05-17 | 2004-06-14 | 334 |  |  | 2004-05-07 | 2004-06-04 | 20d | 7d | 0d |  |
| 336 | 1.5.5.8.1.7 | SWEA/STE FM 1 Vibration | 5d | 2004-06-15 | 2004-06-21 | 335 |  |  | 2004-06-07 | 2004-06-11 | 5d | 7d | 0d |  |
| 337 | 1.5.5.8.1.8 | SWEA/STE-D FM 1 Thermal Vac/Thermal Balance/Bake Out | 14d | 2004-08-02 | 2004-08-19 | 19 |  |  | 2004-07-13 | 2004-07-30 | 14d | 23d | 0d |  |
| 338 | 1.5.5.8.2 | **FM 2** | 115d | 2004-03-29 | 2004-09-07 |  |  |  | 2004-02-24 | 2004-08-27 | 133d | 14d |  |  |
| 339 | 1.5.5.8.2.1 | Integrate & Test STE-U FM 2 Interface Boards | 5d | 2004-03-29 | 2004-04-02 | 318, 326 |  |  | 2004-02-24 | 2004-03-01 | 5d | 80d | 0d |  |
| 340 | 1.5.5.8.2.2 | Integrate & Test SWEA/STE-D FM 2 Interface Boards | 20d | 2004-05-24 | 2004-06-21 | 287, 294, 302, 310 |  |  | 2004-05-14 | 2004-06-11 | 20d | 14d | 0d |  |
| 341 | 1.5.5.8.2.3 | Integrate & Test SWEA/STE-D FM 2 Interface with SWEA/STE-D FM 2 LVPS | 10d | 2004-06-22 | 2004-07-05 | 340, 75 |  |  | 2004-06-14 | 2004-06-25 | 10d | 14d | 0d |  |
| 342 | 1.5.5.8.2.4 | Integrate & Test SWEA/STE-D FM 2 Combined | 10d | 2004-07-06 | 2004-07-19 | 341, 248, 255 |  |  | 2004-06-28 | 2004-07-09 | 10d | 14d | 0d |  |
| 343 | 1.5.5.8.2.5 | Calibrate SWEA/STE FM 2 | 20d | 2004-07-20 | 2004-08-16 | 342 |  |  | 2004-07-12 | 2004-08-06 | 20d | 14d | 0d |  |
| 344 | 1.5.5.8.2.6 | SWEA/STE FM 2 Vibration | 5d | 2004-08-17 | 2004-08-23 | 343 |  |  | 2004-08-09 | 2004-08-13 | 5d | 14d | 0d |  |
| 345 | 1.5.5.8.2.7 | SWEA/STE-D FM 2 Thermal Vac & bake Out | 10d | 2004-08-24 | 2004-09-07 | 344 |  |  | 2004-08-16 | 2004-08-27 | 10d | 14d | 0d |  |
| 346 | 1.5.6 | **Boom Suite I&T - UCB** | 116d | 2004-04-26 | 2004-10-06 |  |  |  | 2004-04-21 | 2004-09-28 | 113d | 14d |  |  |
| 347 | 1.5.6.1 | **FM 1** | 93d | 2004-04-26 | 2004-09-02 |  |  |  | 2004-04-21 | 2004-08-13 | 82d | 20d |  |  |
| 348 | 1.5.6.1.1 | FM 1 Boom/MAG/STE-U I&T | 4d | 2004-04-26 | 2004-04-29 | 209, 237, 256 |  |  | 2004-04-21 | 2004-04-26 | 4d | 20d | 0d |  |
| 349 | 1.5.6.1.2 | FM 1 Boom/SWEA/STE/MAG I&T | 2d | 2004-06-22 | 2004-06-23 | 283, 183 |  |  | 2004-06-14 | 2004-06-15 | 2d | 7d | 0d |  |
| 350 | 1.5.6.1.3 | FM 1 Integrated Boom/IDPU I&T | 4d | 2004-06-24 | 2004-06-29 | 349, 183, 159 |  |  | 2004-06-16 | 2004-06-21 | 4d | 7d | 0d |  |
| 351 | 1.5.6.1.4 | Final BOOM Suite FM 1 I & T | 10d | 2004-08-20 | 2004-09-02 | 350, 337 |  |  | 2004-08-02 | 2004-08-13 | 10d | 23d | 0d |  |

| ID | WBS | Task | Duration | Start | Finish | Predecessors | Complete | Remaining | Baseline start | Baseline finish | Baseline duration | Total slack | Free slack | Constraint |
| --- | --- | --- | --- | --- | --- | --- | --- | --- | --- | --- | --- | --- | --- | --- |
| 352 | 1.5.6.2 | **FM 2** | 83d | 2004-06-11 | 2004-10-06 |  |  |  | 2004-05-11 | 2004-09-28 | 99d | 14d |  |  |
| 353 | 1.5.6.2.1 | FM 2 Boom/MAG/STE-U I&T | 4d | 2004-06-11 | 2004-06-16 | 231, 238, 257 |  |  | 2004-05-11 | 2004-05-14 | 4d | 49d | 0d |  |
| 354 | 1.5.6.2.2 | FM 2 Boom/SWEA/STE/MAG I&T | 2d | 2004-09-08 | 2004-09-09 | 284, 184 |  |  | 2004-08-30 | 2004-08-31 | 2d | 14d | 0d |  |
| 355 | 1.5.6.2.3 | FM 2 Integrated Boom/IDPU I&T | 4d | 2004-09-10 | 2004-09-15 | 354, 184, 751 |  |  | 2004-09-01 | 2004-09-07 | 4d | 14d | 0d |  |
| 356 | 1.5.6.2.4 | Boom Suite FM 2 EMC | 5d | 2004-09-16 | 2004-09-22 | 355 |  |  | 2004-09-08 | 2004-09-14 | 5d | 14d | 0d |  |
| 357 | 1.5.6.2.5 | Final BOOM Suite FM 2 I & T | 10d | 2004-09-23 | 2004-10-06 | 356 |  |  | 2004-09-15 | 2004-09-28 | 10d | 14d | 0d |  |
| 358 | 1.6 | **SEP Suite - CIT** | 348d | 2003-06-02 A | 2004-10-15 |  | 55% | 155.99d | 2003-06-02 | 2004-10-21 | 352d | 9d |  |  |
| 359 | 1.6.1 | **SEP Mechanical - Sandy Shuman (GSFC)** | 90d | 2004-01-27 A | 2004-06-02 |  | 18% | 73.74d | 2004-01-27 | 2004-06-02 | 90d | 41d |  |  |
| 360 | 1.6.1.1 | **SIT Electronics Enclosure (Priority 1)** | 44d | 2004-02-09 A | 2004-04-09 |  | 38% | 27.08d | 2004-02-09 | 2004-03-16 | 26d | 43d |  |  |
| 361 | 1.6.1.1.1 | Complete Design/Drawings for SIT Enclosure | 10d | 2004-02-09 A | 2004-02-23 A |  | 100% |  | 2004-02-09 | 2004-02-23 | 10d |  |  | start no earlier than 2004-02-09 |
| 362 | 1.6.1.1.2 | Fabrication of SIT Enclosure | 10d | 2004-03-19 | 2004-04-01 | 361FS+18d |  |  | 2004-02-24 | 2004-03-08 | 10d | 43d | 0d |  |
| 363 | 1.6.1.1.3 | Inspection and Final Assembly of SIT Enclosure | 5d | 2004-04-02 | 2004-04-08 | 362 |  |  | 2004-03-09 | 2004-03-15 | 5d | 43d | 0d |  |
| 364 | 1.6.1.1.4 | Deliver SIT Enclosure to UMD | 1d | 2004-04-09 | 2004-04-09 | 363 |  |  | 2004-03-16 | 2004-03-16 | 1d | 43d | 36d |  |
| 365 | 1.6.1.2 | **SEP FM 1 & FM 2 LVPS Boxes (Priority 2)** | 33d | 2004-02-09 A | 2004-03-25 |  | 42% | 19d | 2004-02-09 | 2004-03-11 | 23d | 37d |  |  |
| 366 | 1.6.1.2.1 | Complete Design/Drawings for SEP LVPS Boxes | 5d | 2004-02-09 A | 2004-02-13 A | 361SS | 100% |  | 2004-02-09 | 2004-02-13 | 5d |  |  |  |
| 367 | 1.6.1.2.2 | Fabrication of SEP LVPS Boxes | 20d | 2004-02-17 A | 2004-03-15 | 366 | 45% | 11d | 2004-02-17 | 2004-03-01 | 10d | 33d | 0d |  |
| 368 | 1.6.1.2.3 | Inspection and Final Assembly of SEP LVPS Boxes | 5d | 2004-03-16 | 2004-03-22 | 367 |  |  | 2004-03-02 | 2004-03-08 | 5d | 37d | 0d |  |
| 369 | 1.6.1.2.4 | Deliver SEP LVPS Boxes to UCB | 3d | 2004-03-23 | 2004-03-25 | 368 |  |  | 2004-03-09 | 2004-03-11 | 3d | 37d | 0d |  |
| 370 | 1.6.1.3 | **SEP Electronics Enclosure (Priority 3)** | 42d | 2004-02-17 A | 2004-04-14 |  | 21% | 33d | 2004-02-17 | 2004-03-30 | 31d | 51d |  |  |
| 371 | 1.6.1.3.1 | Complete Design/Drawings for SEP Enclosure | 24d | 2004-02-17 A | 2004-03-19 | 366 | 38% | 15d | 2004-02-17 | 2004-03-04 | 13d | 9d | 0d |  |
| 372 | 1.6.1.3.2 | Fabrication of SEP Enclosure | 10d | 2004-03-22 | 2004-04-02 | 371 |  |  | 2004-03-05 | 2004-03-18 | 10d | 51d | 0d |  |
| 373 | 1.6.1.3.3 | Inspection and Final Assembly of SEP Enclosure | 5d | 2004-04-05 | 2004-04-09 | 372 |  |  | 2004-03-19 | 2004-03-25 | 5d | 51d | 0d |  |
| 374 | 1.6.1.3.4 | Deliver SEP Enclosure to CIT | 3d | 2004-04-12 | 2004-04-14 | 373 |  |  | 2004-03-26 | 2004-03-30 | 3d | 51d | 27d |  |
| 375 | 1.6.1.4 | **SEP Central Bias Supply Shields (Priority 4)** | 20d | 2004-03-15 | 2004-04-09 |  |  |  | 2004-03-05 | 2004-04-01 | 20d | 13d |  |  |
| 376 | 1.6.1.4.1 | Complete Design/Drawings for Bias Supply Shields | 5d | 2004-03-15 | 2004-03-19 | 371FS-5d |  |  | 2004-03-05 | 2004-03-11 | 5d | 13d | 0d |  |
| 377 | 1.6.1.4.2 | Fabrication of Bias Supply Shields | 10d | 2004-03-22 | 2004-04-02 | 376 |  |  | 2004-03-12 | 2004-03-25 | 10d | 13d | 0d |  |
| 378 | 1.6.1.4.3 | Inspection and Delivery (to CIT) of Bias Supply Shields | 5d | 2004-04-05 | 2004-04-09 | 377 |  |  | 2004-03-26 | 2004-04-01 | 5d | 13d | 0d |  |

| ID | WBS | Task | Type | Duration | Start | Finish | Predecessors | Complete | Remaining | Baseline start | Baseline finish | Baseline duration | Total slack | Free slack | Constraint |
| --- | --- | --- | --- | --- | --- | --- | --- | --- | --- | --- | --- | --- | --- | --- | --- |
| 379 | 1.6.1.5 | **LET Telescope (Priority 5)** |  | 26d | 2004-03-22 | 2004-04-26 |  |  |  | 2004-03-12 | 2004-04-16 | 26d | 15d |  |  |
| 380 | 1.6.1.5.1 | Complete Design/Drawings for LET Telescope |  | 8d | 2004-03-22 | 2004-03-31 | 376 |  |  | 2004-03-12 | 2004-03-23 | 8d | 15d | 0d |  |
| 381 | 1.6.1.5.2 | Fabrication of LET Telescope |  | 10d | 2004-04-01 | 2004-04-14 | 380 |  |  | 2004-03-24 | 2004-04-06 | 10d | 29d | 0d |  |
| 382 | 1.6.1.5.3 | Inspection and Final Assembly of LET Telescope |  | 5d | 2004-04-15 | 2004-04-21 | 381 |  |  | 2004-04-07 | 2004-04-13 | 5d | 29d | 0d |  |
| 383 | 1.6.1.5.4 | Deliver LET Telescope to CIT |  | 3d | 2004-04-22 | 2004-04-26 | 382 |  |  | 2004-04-14 | 2004-04-16 | 3d | 29d | 19d |  |
| 384 | 1.6.1.6 | **HET Electronics Enclosure (Priority 6)** |  | 23d | 2004-04-01 | 2004-05-03 |  |  |  | 2004-03-24 | 2004-04-23 | 23d | 15d |  |  |
| 385 | 1.6.1.6.1 | Complete Design/Drawings for HET Enclosure |  | 8d | 2004-04-01 | 2004-04-12 | 380 |  |  | 2004-03-24 | 2004-04-02 | 8d | 15d | 0d |  |
| 386 | 1.6.1.6.2 | Fabrication of HET Enclosure |  | 10d | 2004-04-13 | 2004-04-26 | 385 |  |  | 2004-04-05 | 2004-04-16 | 10d | 15d | 0d |  |
| 387 | 1.6.1.6.3 | Inspection and Final Assembly of HET Enclosure |  | 5d | 2004-04-27 | 2004-05-03 | 386 |  |  | 2004-04-19 | 2004-04-23 | 5d | 15d | 0d |  |
| 388 | 1.6.1.6.4 | Deliver HET Enclosure (stays at GSFC) | milestone | 0d | 2004-05-03 | 2004-05-03 | 387 |  |  | 2004-04-23 | 2004-04-23 | 0d | 15d | 0d |  |
| 389 | 1.6.1.7 | **HET Telescope (Priority 7)** |  | 74d | 2004-01-27 A | 2004-05-10 |  | 38% | 46.1d | 2004-01-27 | 2004-04-30 | 68d | 15d |  |  |
| 390 | 1.6.1.7.1 | On Going work for HET Telescope (Complete Design/Drawings & Prep for Fab) |  | 46d | 2004-01-27 A | 2004-03-31 |  | 50% | 23d | 2004-01-27 | 2004-03-31 | 46d | 16d | 0d | start no earlier than 2004-01-27 |
| 391 | 1.6.1.7.2 | Fabrication of HET Telescope |  | 10d | 2004-04-01 | 2004-04-14 | 390 |  |  | 2004-04-01 | 2004-04-14 | 10d | 28d | 13d |  |
| 392 | 1.6.1.7.3 | Inspection and Final Assembly of HET Telescope |  | 5d | 2004-05-04 | 2004-05-10 | 391, 388 |  |  | 2004-04-26 | 2004-04-30 | 5d | 15d | 0d |  |
| 393 | 1.6.1.7.4 | Deliver HET Telescope (stays at GSFC) | milestone | 0d | 2004-05-10 | 2004-05-10 | 392 |  |  | 2004-04-30 | 2004-04-30 | 0d | 10d | 5d |  |
| 394 | 1.6.1.8 | **SIT Telescope (Priority 8)** |  | 34d | 2004-04-01 | 2004-05-18 |  |  |  | 2004-04-01 | 2004-05-18 | 34d | 16d |  |  |
| 395 | 1.6.1.8.1 | Complete Design/Drawings for SIT Telescope |  | 18d | 2004-04-01 | 2004-04-26 | 390 |  |  | 2004-04-01 | 2004-04-26 | 18d | 16d | 0d |  |
| 396 | 1.6.1.8.2 | Fabrication of SIT Telescope |  | 10d | 2004-04-27 | 2004-05-10 | 395 |  |  | 2004-04-27 | 2004-05-10 | 10d | 16d | 0d |  |
| 397 | 1.6.1.8.3 | Inspection and Final Assembly of SIT Telescope |  | 5d | 2004-05-11 | 2004-05-17 | 396 |  |  | 2004-05-11 | 2004-05-17 | 5d | 16d | 0d |  |
| 398 | 1.6.1.8.4 | Deliver SIT Telescope to UMD (Includes the Foils and Detectors) |  | 1d | 2004-05-18 | 2004-05-18 | 397 |  |  | 2004-05-18 | 2004-05-18 | 1d | 16d | 9d |  |
| 399 | 1.6.1.9 | **Shipping Containers for HET, SIT & SEP Central (Priority 9)** |  | 23d | 2004-04-27 | 2004-05-27 |  |  |  | 2004-04-27 | 2004-05-27 | 23d | 27d |  |  |
| 400 | 1.6.1.9.1 | Design |  | 5d | 2004-04-27 | 2004-05-03 | 395 |  |  | 2004-04-27 | 2004-05-03 | 5d | 27d | 0d |  |
| 401 | 1.6.1.9.2 | Fabrication/Machining |  | 10d | 2004-05-04 | 2004-05-17 | 400 |  |  | 2004-05-04 | 2004-05-17 | 10d | 27d | 0d |  |
| 402 | 1.6.1.9.3 | Inspection and Assembly |  | 5d | 2004-05-18 | 2004-05-24 | 401 |  |  | 2004-05-18 | 2004-05-24 | 5d | 27d | 0d |  |
| 403 | 1.6.1.9.4 | HET Container stays at GSFC | milestone | 0d | 2004-05-24 | 2004-05-24 | 402 |  |  | 2004-05-24 | 2004-05-24 | 0d | 23d | 17d |  |
| 404 | 1.6.1.9.5 | SIT Container to UMD |  | 1d | 2004-05-25 | 2004-05-25 | 402 |  |  | 2004-05-25 | 2004-05-25 | 1d | 29d |  |  |
| 405 | 1.6.1.9.6 | SEP Central Container to CIT |  | 3d | 2004-05-25 | 2004-05-27 | 402 |  |  | 2004-05-25 | 2004-05-27 | 3d | 44d |  |  |

| ID | WBS | Task | Type | Duration | Start | Finish | Predecessors | Complete | Remaining | Baseline start | Baseline finish | Baseline duration | Total slack | Free slack | Constraint |
| --- | --- | --- | --- | --- | --- | --- | --- | --- | --- | --- | --- | --- | --- | --- | --- |
| 406 | 1.6.1.10 | **LET Radiation Test Fixture (Priority 10)** |  | 21d | 2004-05-04 | 2004-06-02 |  |  |  | 2004-05-04 | 2004-06-02 | 21d | 28d |  |  |
| 407 | 1.6.1.10.1 | Design |  | 5d | 2004-05-04 | 2004-05-10 | 400 |  |  | 2004-05-04 | 2004-05-10 | 5d | 28d | 0d |  |
| 408 | 1.6.1.10.2 | Fabrication |  | 10d | 2004-05-11 | 2004-05-24 | 407 |  |  | 2004-05-11 | 2004-05-24 | 10d | 28d | 0d |  |
| 409 | 1.6.1.10.3 | Inspection and Assembly |  | 5d | 2004-05-25 | 2004-06-01 | 408 |  |  | 2004-05-25 | 2004-06-01 | 5d | 28d | 0d |  |
| 410 | 1.6.1.10.4 | Deliver to CIT for SEP I&T |  | 1d | 2004-06-02 | 2004-06-02 | 409 |  |  | 2004-06-02 | 2004-06-02 | 1d | 28d |  |  |
| 411 | 1.6.2 | **SEP Central - CIT** |  | 211d | 2003-08-01 A | 2004-06-03 |  | 56% | 91.9d | 2003-08-01 | 2004-06-03 | 211d | 49d |  |  |
| 412 | 1.6.2.1 | **Deliveries** |  | 35d | 2004-04-14 | 2004-06-03 |  |  |  | 2004-04-14 | 2004-06-03 | 35d | 49d |  |  |
| 413 | 1.6.2.1.1 | Deliver all SEP Cen FM 1 Boards to SEP I&T (stays at CIT) | milestone | 0d | 2004-05-21 | 2004-05-21 | 437 |  |  | 2004-05-10 | 2004-05-10 | 0d | 24d | 0d |  |
| 414 | 1.6.2.1.2 | Deliver all SEP Cen FM 2 Boards & FM 2 LVPS to SEP I&T (stays at CIT) | milestone | 0d | 2004-05-21 | 2004-05-21 | 437 |  |  | 2004-05-10 | 2004-05-10 | 0d | 57d | 0d |  |
| 415 | 1.6.2.1.3 | SEP Central Build 3 Software Complete | milestone | 0d | 2004-04-14 | 2004-04-14 | 439 |  |  | 2004-04-14 | 2004-04-14 | 0d | 51d | 27d |  |
| 416 | 1.6.2.1.4 | Final SEP Central Flight Software Complete | milestone | 0d | 2004-06-03 | 2004-06-03 | 440 |  |  | 2004-06-03 | 2004-06-03 | 0d | 30d |  |  |
| 417 | 1.6.2.2 | **Logic Board** |  | 30d | 2004-02-13 A | 2004-03-26 |  | 33% | 20d | 2004-02-13 | 2004-03-26 | 30d | 33d |  |  |
| 418 | 1.6.2.2.1 | **Assembly** |  | 10d | 2004-02-13 A | 2004-02-27 A |  | 100% |  | 2004-02-13 | 2004-02-27 | 10d |  |  |  |
| 419 | 1.6.2.2.1.1 | Assemble FM 1 SEP Central Logic board |  | 10d | 2004-02-13 A | 2004-02-27 A |  | 100% |  | 2004-02-13 | 2004-02-27 | 10d |  |  | start no earlier than 2004-02-13 |
| 420 | 1.6.2.2.1.2 | Assemble FM 2 SEP Central Logic board |  | 10d | 2004-02-13 A | 2004-02-27 A | 419SS | 100% |  | 2004-02-13 | 2004-02-27 | 10d |  |  |  |
| 421 | 1.6.2.2.2 | **Test** |  | 20d | 2004-03-01 | 2004-03-26 |  |  |  | 2004-03-01 | 2004-03-26 | 20d | 29d |  |  |
| 422 | 1.6.2.2.2.1 | Test FM 1 SEP Central Logic board (initial) |  | 20d | 2004-03-01 | 2004-03-26 | 419 |  |  | 2004-03-01 | 2004-03-26 | 20d | 33d | 20d |  |
| 423 | 1.6.2.2.2.2 | Test FM 2 SEP Central Logic board (initial) |  | 20d | 2004-03-01 | 2004-03-26 | 420 |  |  | 2004-03-01 | 2004-03-26 | 20d | 33d | 20d |  |
| 424 | 1.6.2.3 | **Analog/Post-Reg Board** |  | 0d | 2004-01-27 A | 2004-01-27 A |  | 100% |  | 2004-01-27 | 2004-01-27 | 0d |  |  |  |
| 425 | 1.6.2.3.1 | FM 1 Analog/Post-Reg Board Complete Test and awaiting Conformal Coat with other SEP Central Boards | milestone | 0d | 2004-01-27 A | 2004-01-27 A |  | 100% |  | 2004-01-27 | 2004-01-27 | 0d |  |  | start no earlier than 2004-01-27 |
| 426 | 1.6.2.3.2 | FM 2 Analog/Post-Reg Board Complete Test and awaiting Conformal Coat with other SEP Central Boards | milestone | 0d | 2004-01-27 A | 2004-01-27 A |  | 100% |  | 2004-01-27 | 2004-01-27 | 0d |  |  | start no earlier than 2004-01-27 |
| 427 | 1.6.2.4 | **SEP Solid State Detector Bias Supply Board** |  | 68d | 2004-01-20 A | 2004-04-23 |  | 56% | 29.92d | 2004-01-20 | 2004-04-15 | 62d | 13d |  |  |
| 428 | 1.6.2.4.1 | **Assembly & Initial Test** |  | 40d | 2004-01-20 A | 2004-03-16 |  | 70% | 12d | 2004-01-20 | 2004-03-16 | 40d | 27d |  |  |
| 429 | 1.6.2.4.1.1 | Assemble and Initial Test FM 1 SSD Bias Supply Board |  | 40d | 2004-01-20 A | 2004-03-16 |  | 70% | 12d | 2004-01-20 | 2004-03-16 | 40d | 27d | 0d | start no earlier than 2004-01-20 |
| 430 | 1.6.2.4.1.2 | Assemble and Initial Test FM 2 SSD Bias Supply Board |  | 40d | 2004-01-20 A | 2004-03-16 | 429SS | 70% | 12d | 2004-01-20 | 2004-03-16 | 40d | 27d | 18d |  |

| ID | WBS | Task | Type | Duration | Start | Finish | Predecessors | Complete | Remaining | Baseline start | Baseline finish | Baseline duration | Total slack | Free slack | Constraint |
| --- | --- | --- | --- | --- | --- | --- | --- | --- | --- | --- | --- | --- | --- | --- | --- |
| 431 | 1.6.2.4.2 | **Final Test** |  | 10d | 2004-04-12 | 2004-04-23 |  |  |  | 2004-04-02 | 2004-04-15 | 10d | 9d |  |  |
| 432 | 1.6.2.4.2.1 | Final Test FM 1 SSD Bias Supply Board |  | 10d | 2004-04-12 | 2004-04-23 | 429, 378 |  |  | 2004-04-02 | 2004-04-15 | 10d | 13d | 0d |  |
| 433 | 1.6.2.4.2.2 | Final Test FM 2 SSD Bias Supply Board |  | 10d | 2004-04-12 | 2004-04-23 | 430, 378 |  |  | 2004-04-02 | 2004-04-15 | 10d | 13d | 0d |  |
| 434 | 1.6.2.5 | **Conformal Coat, Mass Properties and Bake Out (SEP Central, LET, SEP LVPS)** |  | 20d | 2004-04-26 | 2004-05-21 |  |  |  | 2004-04-16 | 2004-05-10 | 17d | 10d |  |  |
| 435 | 1.6.2.5.1 | Stake/Conformal Coat All SEP Central and LET Boards |  | 10d | 2004-04-26 | 2004-05-07 | 422, 423, 425, 426, 432, 433, 507, 508 |  |  | 2004-04-16 | 2004-04-29 | 10d | 13d | 0d |  |
| 436 | 1.6.2.5.2 | Mass Properties/Photo All SEP Central and LET Boards |  | 4d | 2004-05-10 | 2004-05-13 | 435 |  |  | 2004-04-30 | 2004-05-05 | 4d | 13d | 3d |  |
| 437 | 1.6.2.5.3 | Bake Out All SEP Central/LET Boards and SEP LVPS (FM 1 & 2) |  | 3d | 2004-05-19 | 2004-05-21 | 436, 74, 68 |  |  | 2004-05-06 | 2004-05-10 | 3d | 10d | 0d |  |
| 438 | 1.6.2.6 | **Flight Software** |  | 211d | 2003-08-01 A | 2004-06-03 |  | 68% | 68d | 2003-08-01 | 2004-06-03 | 211d | 30d |  |  |
| 439 | 1.6.2.6.1 | SEP Central Build 3 |  | 176d | 2003-08-01 A | 2004-04-14 |  | 81% | 33d | 2003-08-01 | 2004-04-14 | 176d | 26d | 0d | start no earlier than 2003-08-01 |
| 440 | 1.6.2.6.2 | Final Flight S/W Build |  | 35d | 2004-04-15 | 2004-06-03 | 439 |  |  | 2004-04-15 | 2004-06-03 | 35d | 30d | 0d |  |
| 441 | 1.6.3 | **HET - GSFC** |  | 132d | 2004-01-06 A | 2004-07-12 |  | 46% | 71.62d | 2004-01-06 | 2004-06-23 | 119d | 28d |  |  |
| 442 | 1.6.3.1 | **Deliveries** |  | 39d | 2004-05-18 | 2004-07-12 |  |  |  | 2004-04-30 | 2004-06-23 | 38d | 28d |  |  |
| 443 | 1.6.3.1.1 | Deliver HET FM 1 (to CIT for SEP Suite I&T) |  | 2d | 2004-06-18 | 2004-06-21 | 403, 488 |  |  | 2004-06-01 | 2004-06-02 | 2d | 10d | 0d |  |
| 444 | 1.6.3.1.2 | Deliver HET FM 2 (to CIT for SEP Suite I&T) |  | 2d | 2004-07-09 | 2004-07-12 | 492, 403 |  |  | 2004-06-22 | 2004-06-23 | 2d | 28d | 0d |  |
| 445 | 1.6.3.1.3 | Deliver Final HET Flight Software to SEP I&T |  | 2d | 2004-05-18 | 2004-05-19 | 482 |  |  | 2004-04-30 | 2004-05-03 | 2d | 32d | 22d |  |
| 446 | 1.6.3.2 | **Detectors (Batch 1)** |  | 40d | 2004-01-06 A | 2004-03-03 A |  | 100% |  | 2004-01-06 | 2004-03-31 | 60d |  |  |  |
| 447 | 1.6.3.2.1 | Receive & Inspect HET Flight Detectors |  | 40d | 2004-01-06 A | 2004-03-03 A |  | 100% |  | 2004-01-06 | 2004-03-03 | 40d |  |  | start no earlier than 2004-01-06 |
| 448 | 1.6.3.2.2 | **Detector Testing** |  | 40d | 2004-01-06 A | 2004-03-03 A |  | 100% |  | 2004-01-06 | 2004-03-31 | 60d |  |  |  |
| 449 | 1.6.3.2.2.1 | Capacitance, Current, Depletion, Alpha Resolution Testing |  | 40d | 2004-01-06 A | 2004-03-03 A | 447SS | 100% |  | 2004-01-06 | 2004-03-31 | 60d |  |  |  |
| 450 | 1.6.3.2.2.2 | Life Test HET Detectors |  | 40d | 2004-01-06 A | 2004-03-03 A | 449SS | 100% |  | 2004-01-06 | 2004-03-31 | 60d |  |  |  |
| 451 | 1.6.3.3 | **Replacement HET Detectors (Batch 2)** |  | 66d | 2004-03-12 A | 2004-06-14 |  |  | 66d | 2004-03-12 | 2004-06-14 | 66d | 11d |  |  |
| 452 | 1.6.3.3.1 | Receive H1 Detector Mounts | milestone | 0d | 2004-03-12 A | 2004-03-12 A |  | 100% |  | 2004-03-12 | 2004-03-12 | 0d |  |  | start no earlier than 2004-03-12 |
| 453 | 1.6.3.3.2 | Receive H3 Detector Mounts | milestone | 0d | 2004-03-26 | 2004-03-26 |  |  |  | 2004-03-26 | 2004-03-26 | 0d | 20d | 14d | start no earlier than 2004-03-26 |
| 454 | 1.6.3.3.3 | Detector Mounting at Micron |  | 20d | 2004-04-15 | 2004-05-12 | 452, 453 |  |  | 2004-04-15 | 2004-05-12 | 20d | 11d | 0d | start no earlier than 2004-04-15 |
| 455 | 1.6.3.3.4 | Detector Delivery to GSFC |  | 2d | 2004-05-13 | 2004-05-14 | 454 |  |  | 2004-05-13 | 2004-05-14 | 2d | 11d | 0d |  |
| 456 | 1.6.3.3.5 | Detector Testing at GSFC |  | 20d | 2004-05-17 | 2004-06-14 | 455 |  |  | 2004-05-17 | 2004-06-14 | 20d | 11d | 1d |  |

| ID | WBS | Task | Duration | Start | Finish | Predecessors | Complete | Remaining | Baseline start | Baseline finish | Baseline duration | Total slack | Free slack | Constraint |
| --- | --- | --- | --- | --- | --- | --- | --- | --- | --- | --- | --- | --- | --- | --- |
| 457 | 1.6.3.4 | **Electronics Board** | 73d | 2004-01-22 A | 2004-05-04 |  | 31% | 50.13d | 2004-01-22 | 2004-05-13 | 80d | 53d |  |  |
| 458 | 1.6.3.4.1 | **Assembly** | 38d | 2004-01-22 A | 2004-03-16 |  | 50% | 19d | 2004-01-22 | 2004-03-12 | 36d | 53d |  |  |
| 459 | 1.6.3.4.1.1 | Install Socket on HET Electronics FM 1 Board for ETU ACTEL | 1d | 2004-01-22 A | 2004-01-22 A |  | 100% |  | 2004-01-22 | 2004-01-22 | 1d |  |  | start no earlier than 2004-01-22 |
| 460 | 1.6.3.4.1.2 | Complete Population of HET Electronics FM 1 Board (ETU ACTEL) | 1d | 2004-01-23 A | 2004-01-23 A | 459 | 100% |  | 2004-01-23 | 2004-01-23 | 1d |  |  |  |
| 461 | 1.6.3.4.1.3 | Complete Population of HET Electronics FM 2 Board (Flight ACTEL) | 2d | 2004-03-15 | 2004-03-16 | 460, 467, 501 |  |  | 2004-03-11 | 2004-03-12 | 2d | 53d | 0d |  |
| 462 | 1.6.3.4.2 | **Test** | 71d | 2004-01-26 A | 2004-05-04 |  | 30% | 49.43d | 2004-01-26 | 2004-05-13 | 78d | 53d |  |  |
| 463 | 1.6.3.4.2.1 | **FM 1** | 44d | 2004-01-26 A | 2004-03-26 |  | 55% | 20d | 2004-01-26 | 2004-03-22 | 40d | 46d |  |  |
| 464 | 1.6.3.4.2.1.1 | Test HET FM 1 Electronics Board w/ETU ACTEL | 23d | 2004-01-26 A | 2004-02-26 A | 460 | 100% |  | 2004-01-26 | 2004-02-23 | 20d |  |  |  |
| 465 | 1.6.3.4.2.1.2 | Remove ETU ACTEL and socket from HET FM 1 Electronics Board | 0.5d | 2004-02-27 A | 2004-02-27 A | 464 | 100% |  | 2004-02-24 | 2004-02-24 | 1d |  |  |  |
| 466 | 1.6.3.4.2.1.3 | Install Flight ACTEL on HET FM 1 Electronics Board | 0.5d | 2004-02-27 A | 2004-02-27 A | 465 | 100% |  | 2004-02-25 | 2004-02-25 | 1d |  |  |  |
| 467 | 1.6.3.4.2.1.4 | Retest HET FM 1 Electronics Board w/Flight ACTEL | 10d | 2004-03-01 | 2004-03-12 | 466 |  |  | 2004-02-26 | 2004-03-10 | 10d | 46d | 0d |  |
| 468 | 1.6.3.4.2.1.5 | Clean, Bake, Conformal Coat HET FM 1 Electronics Board | 5d | 2004-03-15 | 2004-03-19 | 467 |  |  | 2004-03-11 | 2004-03-12 | 2d | 46d | 0d |  |
| 469 | 1.6.3.4.2.1.6 | Retest Conformal Coated HET FM 1 Electronics Board | 5d | 2004-03-22 | 2004-03-26 | 468 |  |  | 2004-03-15 | 2004-03-16 | 2d | 46d | 22d |  |
| 470 | 1.6.3.4.2.2 | **FM 2** | 35d | 2004-03-17 | 2004-05-04 |  |  |  | 2004-03-23 | 2004-05-13 | 38d | 53d |  |  |
| 471 | 1.6.3.4.2.2.1 | Test HET FM 2 Electronics Board | 25d | 2004-03-17 | 2004-04-20 | 461, 464 |  |  | 2004-03-23 | 2004-05-03 | 30d | 53d | 0d |  |
| 472 | 1.6.3.4.2.2.2 | Clean, Bake, Conformal Coat HET FM 2 Electronics Board | 5d | 2004-04-21 | 2004-04-27 | 471 |  |  | 2004-05-04 | 2004-05-05 | 2d | 53d | 0d |  |
| 473 | 1.6.3.4.2.2.3 | Retest Conformal Coated HET FM 2 Electronics Board | 5d | 2004-04-28 | 2004-05-04 | 472, 469 |  |  | 2004-05-06 | 2004-05-07 | 2d | 53d | 14d |  |
| 474 | 1.6.3.5 | **Flight Software** | 82d | 2004-01-22 A | 2004-05-17 |  | 32% | 56d | 2004-01-22 | 2004-04-29 | 70d | 10d |  |  |
| 475 | 1.6.3.5.1 | **Design** | 22d | 2004-01-22 A | 2004-02-23 A |  | 100% |  | 2004-01-22 | 2004-02-04 | 10d |  |  |  |
| 476 | 1.6.3.5.1.1 | Complete Definition of HET PH Event Processing | 22d | 2004-01-22 A | 2004-02-23 A |  | 100% |  | 2004-01-22 | 2004-02-04 | 10d |  |  | start no earlier than 2004-01-22 |
| 477 | 1.6.3.5.2 | **Coding** | 20d | 2004-02-24 A | 2004-03-22 |  | 20% | 16d | 2004-02-05 | 2004-03-04 | 20d | 10d |  |  |
| 478 | 1.6.3.5.2.1 | Code HET PH Event Processing Update for Flight | 10d | 2004-02-24 A | 2004-03-08 | 476 | 40% | 6d | 2004-02-05 | 2004-02-19 | 10d | 10d | 0d |  |
| 479 | 1.6.3.5.2.2 | Code HET Telemetry Formatting Update for Flight | 10d | 2004-03-09 | 2004-03-22 | 478 |  |  | 2004-02-20 | 2004-03-04 | 10d | 10d | 0d |  |
| 480 | 1.6.3.5.3 | **Test** | 40d | 2004-03-23 | 2004-05-17 |  |  |  | 2004-03-05 | 2004-04-29 | 40d | 10d |  |  |
| 481 | 1.6.3.5.3.1 | Test Integrated HET S/W with Simulated Data | 15d | 2004-03-23 | 2004-04-12 | 479 |  |  | 2004-03-05 | 2004-03-25 | 15d | 10d | 0d |  |
| 482 | 1.6.3.5.3.2 | Verify HET On-Board Software | 25d | 2004-04-13 | 2004-05-17 | 481 |  |  | 2004-03-26 | 2004-04-29 | 25d | 10d | 0d |  |

| ID | WBS | Task | Type | Duration | Start | Finish | Predecessors | Complete | Remaining | Baseline start | Baseline finish | Baseline duration | Total slack | Free slack | Constraint |
| --- | --- | --- | --- | --- | --- | --- | --- | --- | --- | --- | --- | --- | --- | --- | --- |
| 483 | 1.6.3.6 | **Integration & Test** |  | 37d | 2004-05-18 | 2004-07-08 |  |  |  | 2004-05-03 | 2004-06-21 | 35d | 10d |  |  |
| 484 | 1.6.3.6.1 | **FM 1** |  | 22d | 2004-05-18 | 2004-06-17 |  |  |  | 2004-05-03 | 2004-05-28 | 20d | 10d |  |  |
| 485 | 1.6.3.6.1.1 | Integrate HET FM 1 Electronics Telescope (Ahead) |  | 5d | 2004-05-18 | 2004-05-24 | 450, 482, 393, 469 |  |  | 2004-05-03 | 2004-05-07 | 5d | 10d | 0d |  |
| 486 | 1.6.3.6.1.2 | Test HET FM 1 Telescope (Ahead) |  | 15d | 2004-05-25 | 2004-06-15 | 485 |  |  | 2004-05-10 | 2004-05-28 | 15d | 10d | 0d |  |
| 487 | 1.6.3.6.1.3 | Install new HET Flight Detectors in FM 1 |  | 1d | 2004-06-16 | 2004-06-16 | 456, 486 |  |  | 2004-06-16 | 2004-06-16 | 1d | 10d | 0d |  |
| 488 | 1.6.3.6.1.4 | Performance Test FM 1 with New Flight Detectors |  | 1d | 2004-06-17 | 2004-06-17 | 487 |  |  | 2004-06-17 | 2004-06-17 | 1d | 10d | 0d |  |
| 489 | 1.6.3.6.2 | **FM 2** |  | 32d | 2004-05-25 | 2004-07-08 |  |  |  | 2004-05-14 | 2004-06-21 | 26d | 28d |  |  |
| 490 | 1.6.3.6.2.1 | Integrate HET FM 2 Electronics Telescope (Behind) |  | 5d | 2004-05-25 | 2004-06-01 | 485, 450, 482, 393, 473 |  |  | 2004-05-14 | 2004-05-20 | 5d | 39d | 11d |  |
| 491 | 1.6.3.6.2.2 | Install new HET Flight Detectors in FM 2 |  | 1d | 2004-06-17 | 2004-06-17 | 490, 456, 487 |  |  | 2004-06-17 | 2004-06-17 | 1d | 28d | 0d |  |
| 492 | 1.6.3.6.2.3 | Test HET FM 2 Telescope (Behind) |  | 15d | 2004-06-18 | 2004-07-08 | 491 |  |  | 2004-06-01 | 2004-06-21 | 15d | 28d | 0d |  |
| 493 | 1.6.4 | **LET - CIT** |  | 237d | 2003-07-14 A | 2004-06-21 |  | 76% | 56.51d | 2003-07-14 | 2004-06-08 | 228d | 43d |  |  |
| 494 | 1.6.4.1 | **Deliveries** |  | 33d | 2004-05-04 | 2004-06-21 |  |  |  | 2004-05-04 | 2004-06-08 | 24d | 43d |  |  |
| 495 | 1.6.4.1.1 | Deliver LET FM 1 (stays at CIT for SEP I&T) | milestone | 0d | 2004-06-21 | 2004-06-21 | 513 |  |  | 2004-06-08 | 2004-06-08 | 0d | 6d | 0d |  |
| 496 | 1.6.4.1.2 | Deliver LET FM 2 (stays at CIT for SEP I&T) | milestone | 0d | 2004-06-21 | 2004-06-21 | 515 |  |  | 2004-06-08 | 2004-06-08 | 0d | 20d | 0d |  |
| 497 | 1.6.4.1.3 | Deliver LET Flight Software Build 3 | milestone | 0d | 2004-05-04 | 2004-05-04 | 510 |  |  | 2004-05-04 | 2004-05-04 | 0d | 39d | 33d |  |
| 498 | 1.6.4.2 | **Detectors** |  | 167d | 2003-07-14 A | 2004-03-12 |  | 94% | 10d | 2003-07-14 | 2004-03-12 | 167d | 60d |  |  |
| 499 | 1.6.4.2.1 | Complete LET Flight Detector Testing |  | 167d | 2003-07-14 A | 2004-03-12 |  | 94% | 10d | 2003-07-14 | 2004-03-12 | 167d | 56d | 50d | start no earlier than 2003-07-14 |
| 500 | 1.6.4.3 | **Hybrids** |  | 144d | 2003-08-01 A | 2004-03-01 A |  | 100% |  | 2003-08-01 | 2004-03-01 | 144d |  |  |  |
| 501 | 1.6.4.3.1 | Complete Test of Flight Hybrids (LET and to GSFC for HET FM 2) |  | 144d | 2003-08-01 A | 2004-03-01 A |  | 100% |  | 2003-08-01 | 2004-03-01 | 144d |  |  | start no earlier than 2003-08-01 |
| 502 | 1.6.4.4 | **Detector/Misc Board** |  | 21d | 2004-03-02 | 2004-03-30 |  |  |  | 2004-03-02 | 2004-03-30 | 21d | 31d |  |  |
| 503 | 1.6.4.4.1 | **Assembly** |  | 10d | 2004-03-02 | 2004-03-15 |  |  |  | 2004-03-02 | 2004-03-15 | 10d | 31d |  |  |
| 504 | 1.6.4.4.1.1 | Assemble LET FM 1 Detector Board |  | 10d | 2004-03-02 | 2004-03-15 | 501 |  |  | 2004-03-02 | 2004-03-15 | 10d | 31d | 0d |  |
| 505 | 1.6.4.4.1.2 | Assemble LET FM 2 Detector Board |  | 10d | 2004-03-02 | 2004-03-15 | 501 |  |  | 2004-03-02 | 2004-03-15 | 10d | 31d | 0d |  |
| 506 | 1.6.4.4.2 | **Test** |  | 11d | 2004-03-16 | 2004-03-30 |  |  |  | 2004-03-16 | 2004-03-30 | 11d | 31d |  |  |
| 507 | 1.6.4.4.2.1 | Test LET FM 1 Detector Board |  | 11d | 2004-03-16 | 2004-03-30 | 504 |  |  | 2004-03-16 | 2004-03-30 | 11d | 31d | 18d |  |
| 508 | 1.6.4.4.2.2 | Test LET FM 2 Detector Board |  | 11d | 2004-03-16 | 2004-03-30 | 505 |  |  | 2004-03-16 | 2004-03-30 | 11d | 31d | 18d |  |

| ID | WBS | Task | Duration | Start | Finish | Predecessors | Complete | Remaining | Baseline start | Baseline finish | Baseline duration | Total slack | Free slack | Constraint |
| --- | --- | --- | --- | --- | --- | --- | --- | --- | --- | --- | --- | --- | --- | --- |
| 509 | 1.6.4.5 | **Flight Software** | 190d | 2003-08-01 A | 2004-05-04 |  | 75% | 47d | 2003-08-01 | 2004-05-04 | 190d | 43d |  |  |
| 510 | 1.6.4.5.1 | Let Flight Software Build 3 | 190d | 2003-08-01 A | 2004-05-04 |  | 75% | 47d | 2003-08-01 | 2004-05-04 | 190d | 39d | 0d | start no earlier than 2003-08-01 |
| 511 | 1.6.4.6 | **Integration & Test** | 20d | 2004-05-24 | 2004-06-21 |  |  |  | 2004-05-11 | 2004-06-08 | 20d | 10d |  |  |
| 512 | 1.6.4.6.1 | **FM 1** | 20d | 2004-05-24 | 2004-06-21 |  |  |  | 2004-05-11 | 2004-06-08 | 20d | 6d |  |  |
| 513 | 1.6.4.6.1.1 | Integrate LET FM 1 Housing With Detectors | 20d | 2004-05-24 | 2004-06-21 | 499, 437, 383 |  |  | 2004-05-11 | 2004-06-08 | 20d | 10d | 0d |  |
| 514 | 1.6.4.6.2 | **FM 2** | 20d | 2004-05-24 | 2004-06-21 |  |  |  | 2004-05-11 | 2004-06-08 | 20d | 20d |  |  |
| 515 | 1.6.4.6.2.1 | Integrate LET FM 2 Housing With Detectors | 20d | 2004-05-24 | 2004-06-21 | 499, 437, 383 |  |  | 2004-05-11 | 2004-06-08 | 20d | 43d | 0d |  |
| 516 | 1.6.5 | **SEPT - Kiel/ESTEC** | 259d | 2003-08-08 A | 2004-08-17 |  | 79% | 54.42d | 2003-08-08 | 2004-07-28 | 245d | 35d |  |  |
| 517 | 1.6.5.1 | **Deliveries** | 110d | 2004-03-16 | 2004-08-17 |  |  |  | 2004-03-11 | 2004-07-28 | 99d | 35d |  |  |
| 518 | 1.6.5.1.1 | Deliver SEPT-NS FM 1 to CIT for SEP I&T and Suite EMC | 5d | 2004-03-16 | 2004-03-22 | 557, 558 |  |  | 2004-03-11 | 2004-03-17 | 5d | 72d | 0d |  |
| 519 | 1.6.5.1.2 | Deliver SEPT-E FM 1 to CIT for SEP I&T and Suite EMC | 5d | 2004-03-16 | 2004-03-22 | 565, 564 |  |  | 2004-03-11 | 2004-03-17 | 5d | 72d | 0d |  |
| 520 | 1.6.5.1.3 | Final Delivery of SEPT FM 1 to APL (after Therm Bal @ GSFC) | 2d | 2004-08-16 | 2004-08-17 | 559, 566, 550 |  |  | 2004-07-27 | 2004-07-28 | 2d | 35d | 33d |  |
| 521 | 1.6.5.1.4 | Deliver SEPT-NS FM 2 to CIT for SEP I&T and Suite EMC | 5d | 2004-03-23 | 2004-03-29 | 572, 573 |  |  | 2004-03-22 | 2004-03-26 | 5d | 100d | 0d |  |
| 522 | 1.6.5.1.5 | Deliver SEPT-E FM 2 to CIT for SEP I&T and Suite EMC | 5d | 2004-03-23 | 2004-03-29 | 578, 579 |  |  | 2004-03-22 | 2004-03-26 | 5d | 100d | 0d |  |
| 523 | 1.6.5.2 | **Mechanical Assembly** | 46d | 2003-12-22 A | 2004-02-27 A |  | 100% |  | 2003-12-22 | 2004-02-27 | 46d |  |  |  |
| 524 | 1.6.5.2.1 | **FM 1** | 13d | 2003-12-22 A | 2004-01-09 A |  | 100% |  | 2003-12-22 | 2004-01-09 | 13d |  |  |  |
| 525 | 1.6.5.2.1.1 | Assemble SEPT-NS FM 1 Sensor and E-Box Housing | 13d | 2003-12-22 A | 2004-01-09 A |  | 100% |  | 2003-12-22 | 2004-01-09 | 13d |  |  | start no earlier than 2003-12-22 |
| 526 | 1.6.5.2.1.2 | Assemble SEPT-E FM 1 Sensor and E-Box Housing | 13d | 2003-12-22 A | 2004-01-09 A |  | 100% |  | 2003-12-22 | 2004-01-09 | 13d |  |  | start no earlier than 2003-12-22 |
| 527 | 1.6.5.2.2 | **FM 2** | 14d | 2003-12-29 A | 2004-01-16 A |  | 100% |  | 2003-12-29 | 2004-01-16 | 14d |  |  |  |
| 528 | 1.6.5.2.2.1 | Assemble SEPT-NS FM 2 Sensor and E-Box Housing | 14d | 2003-12-29 A | 2004-01-16 A | 525SS+4d | 100% |  | 2003-12-29 | 2004-01-16 | 14d |  |  |  |
| 529 | 1.6.5.2.2.2 | Assemble SEPT-E FM 2 Sensor and E-Box Housing | 14d | 2003-12-29 A | 2004-01-16 A | 526SS+4d | 100% |  | 2003-12-29 | 2004-01-16 | 14d |  |  |  |
| 530 | 1.6.5.2.3 | **Spare** | 28d | 2004-01-20 A | 2004-02-27 A |  | 100% |  | 2004-01-20 | 2004-02-27 | 28d |  |  |  |
| 531 | 1.6.5.2.3.1 | Assemble SEPT Spare Sensor and E-Box Housing | 28d | 2004-01-20 A | 2004-02-27 A | 528, 529 | 100% |  | 2004-01-20 | 2004-02-27 | 28d |  |  |  |
| 532 | 1.6.5.3 | **Electronics** | 198d | 2003-08-08 A | 2004-05-21 |  | 88% | 23.1d | 2003-08-08 | 2004-05-21 | 198d | 94d |  |  |
| 533 | 1.6.5.3.1 | **Assembly** | 172d | 2003-08-08 A | 2004-04-15 |  | 91% | 15.81d | 2003-08-08 | 2004-04-15 | 172d | 105d |  |  |
| 534 | 1.6.5.3.1.1 | **FM 2** | 106d | 2003-08-08 A | 2004-01-12 A |  | 100% |  | 2003-08-08 | 2004-01-12 | 106d |  |  |  |
| 535 | 1.6.5.3.1.1.1 | Assemble SEPT-NS FM 2 Electronics | 106d | 2003-08-08 A | 2004-01-12 A |  | 100% |  | 2003-08-08 | 2004-01-12 | 106d |  |  | start no earlier than 2003-08-08 |
| 536 | 1.6.5.3.1.1.2 | Assemble SEPT-E FM 2 Electronics | 92d | 2003-08-08 A | 2003-12-19 A |  | 100% |  | 2003-08-08 | 2003-12-19 | 92d |  |  | start no earlier than 2003-08-08 |

| ID | WBS | Task | Duration | Start | Finish | Predecessors | Complete | Remaining | Baseline start | Baseline finish | Baseline duration | Total slack | Free slack | Constraint |
| --- | --- | --- | --- | --- | --- | --- | --- | --- | --- | --- | --- | --- | --- | --- |
| 537 | 1.6.5.3.1.2 | **Spare** | 172d | 2003-08-08 A | 2004-04-15 |  | 80% | 34d | 2003-08-08 | 2004-04-15 | 172d | 105d |  |  |
| 538 | 1.6.5.3.1.2.1 | Assemble SEPT FS Electronics | 172d | 2003-08-08 A | 2004-04-15 | 535SS | 80% | 34d | 2003-08-08 | 2004-04-15 | 172d | 105d | 6d |  |
| 539 | 1.6.5.3.2 | **Test** | 113d | 2003-12-11 A | 2004-05-21 |  | 70% | 33.9d | 2003-12-11 | 2004-05-21 | 113d | 94d |  |  |
| 540 | 1.6.5.3.2.1 | **FM 2** | 34d | 2003-12-11 A | 2004-01-30 A |  | 100% |  | 2003-12-11 | 2004-01-30 | 34d |  |  |  |
| 541 | 1.6.5.3.2.1.1 | SEPT-NS FM 2 Electronics Test | 4d | 2004-01-13 A | 2004-01-16 A | 535 | 100% |  | 2004-01-13 | 2004-01-16 | 4d |  |  |  |
| 542 | 1.6.5.3.2.1.2 | SEPT-E FM 2 Electronics Test | 4d | 2003-12-11 A | 2003-12-16 A | 536FS-7d | 100% |  | 2003-12-11 | 2003-12-16 | 4d |  |  |  |
| 543 | 1.6.5.3.2.1.3 | Coat SEPT-NS FM 2 Electronics Board | 4d | 2004-01-20 A | 2004-01-23 A | 541 | 100% |  | 2004-01-20 | 2004-01-23 | 4d |  |  |  |
| 544 | 1.6.5.3.2.1.4 | Coat SEPT-E FM 2 Electronics Board | 5d | 2003-12-17 A | 2003-12-23 A | 542 | 100% |  | 2003-12-17 | 2003-12-23 | 5d |  |  |  |
| 545 | 1.6.5.3.2.1.5 | SEPT-NS FM 2 Mechanical Integration | 5d | 2004-01-26 A | 2004-01-30 A | 543 | 100% |  | 2004-01-26 | 2004-01-30 | 5d |  |  |  |
| 546 | 1.6.5.3.2.1.6 | SEPT-E FM 2 Mechanical Integration | 13d | 2003-12-24 A | 2004-01-13 A | 544 | 100% |  | 2003-12-24 | 2004-01-13 | 13d |  |  |  |
| 547 | 1.6.5.3.2.2 | **Spare** | 20d | 2004-04-26 | 2004-05-21 |  |  |  | 2004-04-26 | 2004-05-21 | 20d | 94d |  |  |
| 548 | 1.6.5.3.2.2.1 | SEPT Flight Spare Electronics Test | 5d | 2004-04-26 | 2004-04-30 | 538 |  |  | 2004-04-26 | 2004-04-30 | 5d | 99d | 5d | start no earlier than 2004-04-26 |
| 549 | 1.6.5.3.2.2.2 | Coat SEPT FS Electronics Board | 5d | 2004-05-10 | 2004-05-14 | 548 |  |  | 2004-05-10 | 2004-05-14 | 5d | 94d | 0d | start no earlier than 2004-05-10 |
| 550 | 1.6.5.3.2.2.3 | SEPT FS Mechanical Integration | 5d | 2004-05-17 | 2004-05-21 | 549 |  |  | 2004-05-17 | 2004-05-21 | 5d | 94d | 59d |  |
| 551 | 1.6.5.4 | **Integration & Test** | 152d | 2004-01-12 A | 2004-08-13 |  | 48% | 78.38d | 2004-01-12 | 2004-07-26 | 138d | 35d |  |  |
| 552 | 1.6.5.4.1 | **FM 1** | 152d | 2004-01-12 A | 2004-08-13 |  | 42% | 88.67d | 2004-01-12 | 2004-07-26 | 138d | 35d |  |  |
| 553 | 1.6.5.4.1.1 | **SEPT-NS** | 143d | 2004-01-26 A | 2004-08-13 |  | 42% | 83.42d | 2004-01-26 | 2004-07-26 | 129d | 35d |  |  |
| 554 | 1.6.5.4.1.1.1 | SEPT-NS FM 1 Integration & Test | 5d | 2004-01-26 A | 2004-01-30 A | 525 | 100% |  | 2004-01-26 | 2004-01-30 | 5d |  |  | start no earlier than 2004-01-26 |
| 555 | 1.6.5.4.1.1.2 | Muon and Radioactive Source Test | 5d | 2004-02-02 A | 2004-02-06 A | 554 | 100% |  | 2004-02-02 | 2004-02-06 | 5d |  |  |  |
| 556 | 1.6.5.4.1.1.3 | SEPT-NS FM 1 Vibration | 4d | 2004-02-19 A | 2004-02-24 A | 555 | 100% |  | 2004-02-17 | 2004-02-20 | 4d |  |  | start no earlier than 2004-02-19 |
| 557 | 1.6.5.4.1.1.4 | SEPT-NS FM 1 Thermal Vac | 10d | 2004-02-27 A | 2004-03-11 | 556FS+2d | 10% | 9d | 2004-02-25 | 2004-03-08 | 9d | 68d | 0d |  |
| 558 | 1.6.5.4.1.1.5 | SEPT-NS FM 1 Bake Out | 2d | 2004-03-12 | 2004-03-15 | 557 |  |  | 2004-03-09 | 2004-03-10 | 2d | 72d | 0d |  |
| 559 | 1.6.5.4.1.1.6 | SEPT-NS FM 1 Thermal Balance (at GSFC after Suite EMC) | 10d | 2004-08-02 | 2004-08-13 | 19 |  |  | 2004-07-13 | 2004-07-26 | 10d | 35d | 0d |  |
| 560 | 1.6.5.4.1.2 | **SEPT-E** | 152d | 2004-01-12 A | 2004-08-13 |  | 42% | 88.67d | 2004-01-12 | 2004-07-26 | 138d | 35d |  |  |
| 561 | 1.6.5.4.1.2.1 | SEPT-E FM 1 Integration & Test | 5d | 2004-01-12 A | 2004-01-16 A | 526 | 100% |  | 2004-01-12 | 2004-01-16 | 5d |  |  |  |
| 562 | 1.6.5.4.1.2.2 | Muon and Radioactive Source Test | 5d | 2004-01-29 A | 2004-02-04 A | 561 | 100% |  | 2004-01-29 | 2004-02-04 | 5d |  |  | start no earlier than 2004-01-29 |
| 563 | 1.6.5.4.1.2.3 | SEPT-E FM 1 Vibration | 4d | 2004-02-19 A | 2004-02-24 A | 562, 556SS | 100% |  | 2004-02-21 | 2004-02-24 | 4d |  |  |  |
| 564 | 1.6.5.4.1.2.4 | SEPT-E FM 1 Thermal Vac | 10d | 2004-02-27 A | 2004-03-11 | 563, 557SS | 10% | 9d | 2004-02-25 | 2004-03-08 | 9d | 68d | 0d |  |
| 565 | 1.6.5.4.1.2.5 | SEPT-E FM 1 Bake Out | 2d | 2004-03-12 | 2004-03-15 | 564 |  |  | 2004-03-09 | 2004-03-10 | 2d | 72d | 0d |  |
| 566 | 1.6.5.4.1.2.6 | SEPT-E FM 1 Thermal Balance (at GSFC after Suite EMC) | 10d | 2004-08-02 | 2004-08-13 | 19 |  |  | 2004-07-13 | 2004-07-26 | 10d | 35d | 0d |  |

Notes:
- 556: There was a failure on the SEPT door during Vibration Test. Vibration Test will be repeated once the fix to the door is implemented. Time and place is TBD.
- 563: There was a failure on the SEPT door during Vibration Test. Vibration Test will be repeated once the fix to the door is implemented. Time and place is TBD.

| ID | WBS | Task | Duration | Start | Finish | Predecessors | Complete | Remaining | Baseline start | Baseline finish | Baseline duration | Total slack | Free slack | Constraint |
| --- | --- | --- | --- | --- | --- | --- | --- | --- | --- | --- | --- | --- | --- | --- |
| 567 | 1.6.5.4.2 | **FM 2** | 49d | 2004-01-12 A | 2004-03-22 |  | 57% | 21d | 2004-01-12 | 2004-03-19 | 48d | 77d |  |  |
| 568 | 1.6.5.4.2.1 | **SEPT-NS** | 44d | 2004-01-20 A | 2004-03-22 |  | 60% | 17.6d | 2004-01-20 | 2004-03-19 | 43d | 77d |  |  |
| 569 | 1.6.5.4.2.1.1 | SEPT-NS FM 2 Integration & Test | 8d | 2004-01-20 A | 2004-01-29 A | 528 | 100% |  | 2004-01-20 | 2004-01-29 | 8d |  |  |  |
| 570 | 1.6.5.4.2.1.2 | Muon and Radioactive Source Test | 6d | 2004-01-30 A | 2004-02-06 A | 569 | 100% |  | 2004-01-30 | 2004-02-06 | 6d |  |  |  |
| 571 | 1.6.5.4.2.1.3 | SEPT-NS FM 2 Vibration | 4d | 2004-02-19 A | 2004-02-24 A | 570, 556SS | 100% |  | 2004-02-17 | 2004-02-20 | 4d |  |  |  |
| 572 | 1.6.5.4.2.1.4 | SEPT-NS FM 2 Thermal Vac | 10d | 2004-03-05 | 2004-03-18 | 571 |  |  | 2004-03-09 | 2004-03-17 | 9d | 100d | 0d | start no earlier than 2004-03-05 |
| 573 | 1.6.5.4.2.1.5 | SEPT-NS FM 2 Bake Out | 2d | 2004-03-19 | 2004-03-22 | 572 |  |  | 2004-03-18 | 2004-03-19 | 2d | 100d | 0d |  |
| 574 | 1.6.5.4.2.2 | **SEPT-E** | 49d | 2004-01-12 A | 2004-03-22 |  | 54% | 22.62d | 2004-01-12 | 2004-03-19 | 48d | 77d |  |  |
| 575 | 1.6.5.4.2.2.1 | SEPT-E FM 2 Integration & Test | 5d | 2004-01-12 A | 2004-01-16 A | 561SS | 100% |  | 2004-01-12 | 2004-01-16 | 5d |  |  |  |
| 576 | 1.6.5.4.2.2.2 | Muon and Radioactive Source Test | 5d | 2004-01-29 A | 2004-02-04 A | 575, 562SS | 100% |  | 2004-01-29 | 2004-02-04 | 5d |  |  |  |
| 577 | 1.6.5.4.2.2.3 | SEPT-E FM 2 Vibration | 4d | 2004-02-19 A | 2004-02-24 A | 576, 556SS | 100% |  | 2004-02-21 | 2004-02-24 | 4d |  |  |  |
| 578 | 1.6.5.4.2.2.4 | SEPT-E FM 2 Thermal Vac | 10d | 2004-03-05 | 2004-03-18 | 577, 572SS |  |  | 2004-03-09 | 2004-03-17 | 9d | 100d | 0d |  |
| 579 | 1.6.5.4.2.2.5 | SEPT-E FM 2 Bake Out | 2d | 2004-03-19 | 2004-03-22 | 578 |  |  | 2004-03-18 | 2004-03-19 | 2d | 100d | 0d |  |
| 580 | 1.6.6 | **SIT - UMD** | 347d | 2003-06-02 A | 2004-10-14 |  | 54% | 158.84d | 2003-06-02 | 2004-10-20 | 351d | 9d |  |  |
| 581 | 1.6.6.1 | **Deliveries** | 69d | 2004-07-08 | 2004-10-14 |  |  |  | 2004-06-18 | 2004-10-12 | 81d | -1d | 0d |  |
| 582 | 1.6.6.1.1 | Deliver SIT FM 1 to CIT for SEP I&T and Suite EMC | 2d | 2004-07-08 | 2004-07-09 | 404, 672 |  |  | 2004-06-18 | 2004-06-21 | 2d | -1d | 0d |  |
| 583 | 1.6.6.1.2 | Deliver SIT FM 1 back to GSFC for Environmental Testing (after EMC Test) | 2d | 2004-08-02 | 2004-08-03 | 19 |  |  | 2004-07-13 | 2004-07-14 | 2d | 10d | 0d |  |
| 584 | 1.6.6.1.3 | Final Delivery of SIT FM 1 to APL | 1d | 2004-09-22 | 2004-09-22 | 704 |  |  | 2004-09-01 | 2004-09-01 | 1d | 10d | 8d |  |
| 585 | 1.6.6.1.4 | Deliver SIT FM 2 to CIT for SEP I&T | 2d | 2004-08-05 | 2004-08-06 | 677, 404 |  |  | 2004-07-23 | 2004-07-26 | 2d | 7d | 0d |  |
| 586 | 1.6.6.1.5 | Deliver SIT FM 2 back to GSFC for Environmental Testing | 2d | 2004-08-23 | 2004-08-24 | 766 |  |  | 2004-08-19 | 2004-08-20 | 2d | 9d | 0d |  |
| 587 | 1.6.6.1.6 | Final Delivery of SIT FM 2 to APL | 1d | 2004-10-14 | 2004-10-14 | 713, 719 |  |  | 2004-10-12 | 2004-10-12 | 1d | 9d | 0d |  |
| 588 | 1.6.6.2 | **ACTEL - for SIT Logic Board** | 11d | 2004-05-17 | 2004-06-01 |  |  |  | 2004-02-27 | 2004-03-12 | 11d | 8d |  |  |
| 589 | 1.6.6.2.1 | Burn Final SIT ACTEL Chip (at GSFC) | 1d | 2004-05-17 | 2004-05-17 |  |  |  | 2004-02-27 | 2004-02-27 | 1d | 8d | 0d | start no earlier than 2004-05-17 |
| 590 | 1.6.6.2.2 | Evaluate (Test) SIT Final ACTEL Chip | 10d | 2004-05-18 | 2004-06-01 | 589 |  |  | 2004-03-01 | 2004-03-12 | 10d | 8d |  |  |

Notes:
- 571: There was a failure on the SEPT door during Vibration Test. Vibration Test will be repeated once the fix to the door is implemented. Time and place is TBD.
- 577: There was a failure on the SEPT door during Vibration Test. Vibration Test will be repeated once the fix to the door is implemented. Time and place is TBD.

| ID | WBS | Task | Type | Duration | Start | Finish | Predecessors | Complete | Remaining | Baseline start | Baseline finish | Baseline duration | Total slack | Free slack | Constraint |
| --- | --- | --- | --- | --- | --- | --- | --- | --- | --- | --- | --- | --- | --- | --- | --- |
| 591 | 1.6.6.3 | **TOF Boards** |  | 51d | 2004-02-12 A | 2004-04-23 |  |  | 51d | 2004-02-12 | 2004-03-11 | 20d | 36d |  |  |
| 592 | 1.6.6.3.1 | Receive Analog and Digital TOF Boards (FM 1) | milestone | 0d | 2004-02-12 A | 2004-02-12 A |  | 100% |  | 2004-02-12 | 2004-02-12 | 0d |  |  | start no earlier than 2004-02-12 |
| 593 | 1.6.6.3.2 | Receive Analog and Digital TOF Boards (FM 2) |  | 20d | 2004-03-15 | 2004-04-09 | 596 |  |  | 2004-03-15 | 2004-04-09 | 20d | 36d | 0d |  |
| 594 | 1.6.6.3.3 | **Test** |  | 40d | 2004-03-01 | 2004-04-23 |  |  |  | 2004-02-12 | 2004-03-11 | 20d | 31d |  |  |
| 595 | 1.6.6.3.3.1 | **FM 1** |  | 10d | 2004-03-01 | 2004-03-12 |  |  |  | 2004-02-12 | 2004-02-26 | 10d | 31d |  |  |
| 596 | 1.6.6.3.3.1.1 | FM 1 TOF Boards Functional Test |  | 10d | 2004-03-01 | 2004-03-12 | 592 |  |  | 2004-02-12 | 2004-02-26 | 10d | 35d | 0d | start no earlier than 2004-03-01 |
| 597 | 1.6.6.3.3.2 | **FM 2** |  | 10d | 2004-04-12 | 2004-04-23 |  |  |  | 2004-02-27 | 2004-03-11 | 10d | 36d |  |  |
| 598 | 1.6.6.3.3.2.1 | FM 2 TOF Boards Functional Test |  | 10d | 2004-04-12 | 2004-04-23 | 592, 593 |  |  | 2004-02-27 | 2004-03-11 | 10d | 36d | 29d |  |
| 599 | 1.6.6.4 | **Energy Board** |  | 114d | 2003-11-10 A | 2004-04-23 |  | 75% | 28.79d | 2003-11-10 | 2004-04-02 | 99d | 36d |  |  |
| 600 | 1.6.6.4.1 | **Assembly** |  | 84d | 2003-11-10 A | 2004-03-12 |  | 88% | 10d | 2003-11-10 | 2004-02-20 | 69d | 51d |  |  |
| 601 | 1.6.6.4.1.1 | **FM 1** |  | 84d | 2003-11-10 A | 2004-03-12 |  | 88% | 10d | 2003-11-10 | 2004-02-20 | 69d | 16d |  |  |
| 602 | 1.6.6.4.1.1.1 | Assemble FM 1 Energy Board |  | 84d | 2003-11-10 A | 2004-03-12 |  | 88% | 10d | 2003-11-10 | 2004-02-20 | 69d | 16d | 0d | start no earlier than 2003-11-10 |
| 603 | 1.6.6.4.1.2 | **FM 2** |  | 84d | 2003-11-10 A | 2004-03-12 |  | 88% | 10d | 2003-11-10 | 2004-02-20 | 69d | 51d |  |  |
| 604 | 1.6.6.4.1.2.1 | Assemble FM 2 Energy Board |  | 84d | 2003-11-10 A | 2004-03-12 | 602SS | 88% | 10d | 2003-11-10 | 2004-02-20 | 69d | 51d | 15d |  |
| 605 | 1.6.6.4.2 | **Test** |  | 30d | 2004-03-15 | 2004-04-23 |  |  |  | 2004-02-23 | 2004-04-02 | 30d | 16d |  |  |
| 606 | 1.6.6.4.2.1 | **FM 1** |  | 15d | 2004-03-15 | 2004-04-02 |  |  |  | 2004-02-23 | 2004-03-12 | 15d | 16d |  |  |
| 607 | 1.6.6.4.2.1.1 | Bench Test/Calibration |  | 10d | 2004-03-15 | 2004-03-26 | 602 |  |  | 2004-02-23 | 2004-03-05 | 10d | 20d | 0d |  |
| 608 | 1.6.6.4.2.1.2 | Thermal |  | 3d | 2004-03-29 | 2004-03-31 | 607 |  |  | 2004-03-08 | 2004-03-10 | 3d | 20d | 0d |  |
| 609 | 1.6.6.4.2.1.3 | Voltage Margin |  | 2d | 2004-04-01 | 2004-04-02 | 608 |  |  | 2004-03-11 | 2004-03-12 | 2d | 20d | 0d |  |
| 610 | 1.6.6.4.2.2 | **FM 2** |  | 15d | 2004-04-05 | 2004-04-23 |  |  |  | 2004-03-15 | 2004-04-02 | 15d | 36d |  |  |
| 611 | 1.6.6.4.2.2.1 | FM 2 Energy Board Functional Test |  | 15d | 2004-04-05 | 2004-04-23 | 604, 609 |  |  | 2004-03-15 | 2004-04-02 | 15d | 36d | 29d |  |
| 612 | 1.6.6.5 | **Logic Board** |  | 177d | 2003-11-10 A | 2004-07-22 |  | 51% | 86.85d | 2003-11-10 | 2004-07-09 | 168d | 7d |  |  |
| 613 | 1.6.6.5.1 | **Design** |  | 3d | 2003-11-17 A | 2003-11-19 A |  | 100% |  | 2003-11-17 | 2003-11-19 | 3d |  |  |  |
| 614 | 1.6.6.5.1.1 | Layout new Logic Board Design |  | 3d | 2003-11-17 A | 2003-11-19 A |  | 100% |  | 2003-11-17 | 2003-11-19 | 3d |  |  | start no earlier than 2003-11-17 |

| ID | WBS | Task | Duration | Start | Finish | Predecessors | Complete | Remaining | Baseline start | Baseline finish | Baseline duration | Total slack | Free slack | Constraint |
| --- | --- | --- | --- | --- | --- | --- | --- | --- | --- | --- | --- | --- | --- | --- |
| 615 | 1.6.6.5.2 | **Fabrication** | 10d | 2004-03-08 | 2004-03-19 |  |  |  | 2004-02-09 | 2004-02-23 | 10d | -5d | 0d |  |
| 616 | 1.6.6.5.2.1 | FM 1 & FM 2 Logic Board Fabrication | 10d | 2004-03-08 | 2004-03-19 | 614, 630 |  |  | 2004-02-09 | 2004-02-23 | 10d | -1d | 0d | start no earlier than 2004-02-02 |
| 617 | 1.6.6.5.3 | **Assembly** | 81d | 2004-03-29 | 2004-07-20 |  |  |  | 2004-03-09 | 2004-07-07 | 86d | -5d | 0d |  |
| 618 | 1.6.6.5.3.1 | **FM 1** | 58d | 2004-03-29 | 2004-06-17 |  |  |  | 2004-03-09 | 2004-05-27 | 58d | -5d | 0d |  |
| 619 | 1.6.6.5.3.1.1 | Assemble FM 1 Logic Board with ETU ACTELs | 11d | 2004-03-29 | 2004-04-12 | 632 |  |  | 2004-03-09 | 2004-03-23 | 11d | -1d | 0d |  |
| 620 | 1.6.6.5.3.1.2 | Disassembel FM 1 Logic Board with ETU ACTELs | 1d | 2004-06-14 | 2004-06-14 | 686 |  |  | 2004-05-24 | 2004-05-24 | 1d | -1d | 0d |  |
| 621 | 1.6.6.5.3.1.3 | Retrofit/Inspect FM 1 Flight ACTELs | 2d | 2004-06-15 | 2004-06-16 | 620, 590 |  |  | 2004-05-25 | 2004-05-26 | 2d | -1d | 0d |  |
| 622 | 1.6.6.5.3.1.4 | Reassemble FM 1 Logic Board with Flight ACTELs | 1d | 2004-06-17 | 2004-06-17 | 621 |  |  | 2004-05-27 | 2004-05-27 | 1d | -1d | 0d |  |
| 623 | 1.6.6.5.3.2 | **FM 2** | 81d | 2004-03-29 | 2004-07-20 |  |  |  | 2004-03-09 | 2004-07-07 | 86d | 7d |  |  |
| 624 | 1.6.6.5.3.2.1 | Assemble FM 2 Logic Board with ETU ACTELS | 11d | 2004-03-29 | 2004-04-12 | 632 |  |  | 2004-03-09 | 2004-03-23 | 11d | 30d | 15d |  |
| 625 | 1.6.6.5.3.2.2 | Disassemble FM 2 Logic Boards | 1d | 2004-07-15 | 2004-07-15 | 695, 620SS |  |  | 2004-07-02 | 2004-07-02 | 1d | 7d | 0d |  |
| 626 | 1.6.6.5.3.2.3 | Retrofit/Inspect Flight ACTELS | 2d | 2004-07-16 | 2004-07-19 | 625, 590 |  |  | 2004-07-05 | 2004-07-06 | 2d | 7d | 0d |  |
| 627 | 1.6.6.5.3.2.4 | Reassemble FM 2 Logic Boards | 1d | 2004-07-20 | 2004-07-20 | 626 |  |  | 2004-07-07 | 2004-07-07 | 1d | 7d | 0d |  |
| 628 | 1.6.6.5.4 | **Test** | 177d | 2003-11-10 A | 2004-07-22 |  | 67% | 58.5d | 2003-11-10 | 2004-07-09 | 168d | 7d |  |  |
| 629 | 1.6.6.5.4.1 | **ETU** | 79d | 2003-11-10 A | 2004-03-05 A |  | 100% |  | 2003-11-10 | 2004-02-06 | 60d |  |  |  |
| 630 | 1.6.6.5.4.1.1 | Test New ETU Logic Board | 79d | 2003-11-10 A | 2004-03-05 A |  | 100% |  | 2003-11-10 | 2004-02-06 | 60d |  |  | start no earlier than 2003-11-10 |
| 631 | 1.6.6.5.4.2 | **FM1 & FM 2** | 5d | 2004-03-22 | 2004-03-26 |  |  |  | 2004-02-24 | 2004-03-08 | 10d | -5d | 0d |  |
| 632 | 1.6.6.5.4.2.1 | Coupon Testing | 5d | 2004-03-22 | 2004-03-26 | 616 |  |  | 2004-02-24 | 2004-03-08 | 10d | -1d | 0d |  |
| 633 | 1.6.6.5.4.3 | **FM 1** | 49d | 2004-04-13 | 2004-06-21 |  |  |  | 2004-03-24 | 2004-06-01 | 49d | -5d | 0d |  |
| 634 | 1.6.6.5.4.3.1 | Functional Test of FM 1 Logic Board w/ETU ACTELS | 15d | 2004-04-13 | 2004-05-03 | 619 |  |  | 2004-03-24 | 2004-04-13 | 15d | -1d | 0d |  |
| 635 | 1.6.6.5.4.3.2 | Funtional Test of FM 1 Logic Board w/Flight ACTELS | 2d | 2004-06-18 | 2004-06-21 | 622 |  |  | 2004-05-28 | 2004-06-01 | 2d | -1d | 0d |  |
| 636 | 1.6.6.5.4.4 | **FM 2** | 57d | 2004-05-04 | 2004-07-22 |  |  |  | 2004-04-14 | 2004-07-09 | 62d | 7d |  |  |
| 637 | 1.6.6.5.4.4.1 | Functional Test of FM 2 Logic Board w/ETU ACTELS | 15d | 2004-05-04 | 2004-05-24 | 624, 634 |  |  | 2004-04-14 | 2004-05-04 | 15d | 15d | 8d |  |
| 638 | 1.6.6.5.4.4.2 | Functional Test of FM 2 Logic Board w/Flight ACTELS | 2d | 2004-07-21 | 2004-07-22 | 627 |  |  | 2004-07-08 | 2004-07-09 | 2d | 7d | 0d |  |

| ID | WBS | Task | Duration | Start | Finish | Predecessors | Complete | Remaining | Baseline start | Baseline finish | Baseline duration | Total slack | Free slack | Constraint |
| --- | --- | --- | --- | --- | --- | --- | --- | --- | --- | --- | --- | --- | --- | --- |
| 639 | 1.6.6.6 | **Mother Board** | 76d | 2003-12-22 A | 2004-04-09 |  | 63% | 28.5d | 2003-12-22 | 2004-03-25 | 65d | 33d |  |  |
| 640 | 1.6.6.6.1 | **Design** | 30d | 2003-12-22 A | 2004-02-04 A |  | 100% |  | 2003-12-22 | 2004-02-04 | 30d |  |  |  |
| 641 | 1.6.6.6.1.1 | **FM 1 & FM 2** | 30d | 2003-12-22 A | 2004-02-04 A |  | 100% |  | 2003-12-22 | 2004-02-04 | 30d |  |  |  |
| 642 | 1.6.6.6.1.1.1 | Finalize Mother Board Layout | 30d | 2003-12-22 A | 2004-02-04 A |  | 100% |  | 2003-12-22 | 2004-02-04 | 30d |  |  | start no earlier than 2003-12-22 |
| 643 | 1.6.6.6.2 | **Fabrication** | 15d | 2004-02-05 A | 2004-02-26 A |  | 100% |  | 2004-02-05 | 2004-02-26 | 15d |  |  |  |
| 644 | 1.6.6.6.2.1 | **FM 1 & FM 2** | 15d | 2004-02-05 A | 2004-02-26 A |  | 100% |  | 2004-02-05 | 2004-02-26 | 15d |  |  |  |
| 645 | 1.6.6.6.2.1.1 | Fabricate FM 1 & FM 2 Mother Boards | 15d | 2004-02-05 A | 2004-02-26 A | 642 | 100% |  | 2004-02-05 | 2004-02-26 | 15d |  |  |  |
| 646 | 1.6.6.6.3 | **Assembly** | 10d | 2004-03-15 | 2004-03-26 |  |  |  | 2004-02-27 | 2004-03-11 | 10d | 16d |  |  |
| 647 | 1.6.6.6.3.1 | Assemble FM 1 Mother Board | 10d | 2004-03-15 | 2004-03-26 | 645 |  |  | 2004-02-27 | 2004-03-11 | 10d | 20d | 0d | start no earlier than 2004-03-15 |
| 648 | 1.6.6.6.3.2 | Assemble FM 2 Mother Board | 10d | 2004-03-15 | 2004-03-26 | 647SS |  |  | 2004-02-27 | 2004-03-11 | 10d | 38d | 5d |  |
| 649 | 1.6.6.6.4 | **Test** | 31d | 2004-02-27 A | 2004-04-09 |  | 33% | 20.67d | 2004-02-27 | 2004-03-25 | 20d | 33d |  |  |
| 650 | 1.6.6.6.4.1 | **FM 1 & FM 2** | 5d | 2004-02-27 A | 2004-03-04 A |  | 100% |  | 2004-02-27 | 2004-03-18 | 15d |  |  |  |
| 651 | 1.6.6.6.4.1.1 | Coupon Testing of Mother Boards | 5d | 2004-02-27 A | 2004-03-04 A | 645 | 100% |  | 2004-02-27 | 2004-03-18 | 15d |  |  |  |
| 652 | 1.6.6.6.4.2 | **FM 1** | 5d | 2004-03-29 | 2004-04-02 |  |  |  | 2004-03-12 | 2004-03-18 | 5d | 16d |  |  |
| 653 | 1.6.6.6.4.2.1 | Functional Test FM 1 Mother Board | 5d | 2004-03-29 | 2004-04-02 | 647 |  |  | 2004-03-12 | 2004-03-18 | 5d | 20d | 0d |  |
| 654 | 1.6.6.6.4.3 | **FM 2** | 5d | 2004-04-05 | 2004-04-09 |  |  |  | 2004-03-19 | 2004-03-25 | 5d | 33d |  |  |
| 655 | 1.6.6.6.4.3.1 | Functional Test FM 2 Mother Board | 5d | 2004-04-05 | 2004-04-09 | 648, 653 |  |  | 2004-03-19 | 2004-03-25 | 5d | 33d | 26d |  |
| 656 | 1.6.6.7 | **HVPS** | 99d | 2004-01-12 A | 2004-06-01 |  | 75% | 24.75d | 2004-01-12 | 2004-04-27 | 75d | 7d |  |  |
| 657 | 1.6.6.7.1 | **Test** | 99d | 2004-01-12 A | 2004-06-01 |  | 75% | 24.75d | 2004-01-12 | 2004-04-27 | 75d | 7d |  |  |
| 658 | 1.6.6.7.1.1 | **FM 1** | 30d | 2004-01-12 A | 2004-02-24 A |  | 100% |  | 2004-01-12 | 2004-02-09 | 20d |  |  |  |
| 659 | 1.6.6.7.1.1.1 | Functional Test SIT FM 1 HVPS | 30d | 2004-01-12 A | 2004-02-24 A | 71 | 100% |  | 2004-01-12 | 2004-02-09 | 20d |  |  | start no earlier than 2004-01-12 |
| 660 | 1.6.6.7.1.2 | **FM 2** | 10d | 2004-05-18 | 2004-06-01 |  |  |  | 2004-04-14 | 2004-04-27 | 10d | 7d |  |  |
| 661 | 1.6.6.7.1.2.1 | Functional Test SIT FM 2 HVPS | 10d | 2004-05-18 | 2004-06-01 | 77, 655 |  |  | 2004-04-14 | 2004-04-27 | 10d | 7d | 0d |  |
| 662 | 1.6.6.8 | **Flight Software** | 210d | 2003-06-02 A | 2004-04-01 |  | 89% | 24d | 2003-06-02 | 2004-04-01 | 210d | 48d |  |  |
| 663 | 1.6.6.8.1 | **Test** | 210d | 2003-06-02 A | 2004-04-01 |  | 89% | 24d | 2003-06-02 | 2004-04-01 | 210d | 44d |  |  |
| 664 | 1.6.6.8.1.1 | **FM 1 & FM 2** | 210d | 2003-06-02 A | 2004-04-01 |  | 89% | 24d | 2003-06-02 | 2004-04-01 | 210d | 44d |  |  |
| 665 | 1.6.6.8.1.1.1 | Validate SIT On-Board Code | 210d | 2003-06-02 A | 2004-04-01 |  | 89% | 24d | 2003-06-02 | 2004-04-01 | 210d | 44d |  | start no earlier than 2003-06-02 |

| ID | WBS | Task | Duration | Start | Finish | Predecessors | Complete | Remaining | Baseline start | Baseline finish | Baseline duration | Total slack | Free slack |
| --- | --- | --- | --- | --- | --- | --- | --- | --- | --- | --- | --- | --- | --- |
| 666 | 1.6.6.9 | **Integration & Test (using ETU Telescope for FM 1)** | 115d | 2004-02-25 A | 2004-08-04 |  | 4% | 110.84d | 2004-03-31 | 2004-07-22 | 81d | 7d |  |
| 667 | 1.6.6.9.1 | **FM 1 (Flight Telescope)** | 12d | 2004-06-22 | 2004-07-07 |  |  |  | 2004-06-02 | 2004-06-17 | 12d | -5d | 0d |
| 668 | 1.6.6.9.1.1 | Disassemble SIT FM 1 | 1d | 2004-06-22 | 2004-06-22 | 635 |  |  | 2004-06-02 | 2004-06-02 | 1d | -1d | 0d |
| 669 | 1.6.6.9.1.2 | Conformal Coat SIT FM 1 Boards (includes FM 1 LVPS) | 2d | 2004-06-23 | 2004-06-24 | 668 |  |  | 2004-06-03 | 2004-06-04 | 2d | -1d | 0d |
| 670 | 1.6.6.9.1.3 | Reassemble SIT FM 1 with Flight Telescope | 1d | 2004-06-25 | 2004-06-25 | 669, 398, 364 |  |  | 2004-06-07 | 2004-06-07 | 1d | -1d | 0d |
| 671 | 1.6.6.9.1.4 | Bench Calibration SIT FM 1 w/Flight Telescope | 3d | 2004-06-28 | 2004-06-30 | 670 |  |  | 2004-06-08 | 2004-06-10 | 3d | -1d | 0d |
| 672 | 1.6.6.9.1.5 | Vacuum Test SIT FM 1 w/Flight Telescope | 5d | 2004-07-01 | 2004-07-07 | 671 |  |  | 2004-06-11 | 2004-06-17 | 5d | -1d | 0d |
| 673 | 1.6.6.9.2 | **FM 2** | 9d | 2004-07-23 | 2004-08-04 |  |  |  | 2004-07-12 | 2004-07-22 | 9d | 7d |  |
| 674 | 1.6.6.9.2.1 | Disassemble SIT FM 2 | 1d | 2004-07-23 | 2004-07-23 | 638 |  |  | 2004-07-12 | 2004-07-12 | 1d | 7d | 0d |
| 675 | 1.6.6.9.2.2 | Conformal Coat SIT FM 2 Boards | 2d | 2004-07-26 | 2004-07-27 | 674 |  |  | 2004-07-13 | 2004-07-14 | 2d | 7d | 0d |
| 676 | 1.6.6.9.2.3 | Reassemble SIT FM 2 | 1d | 2004-07-28 | 2004-07-28 | 675 |  |  | 2004-07-15 | 2004-07-15 | 1d | 7d | 0d |
| 677 | 1.6.6.9.2.4 | Post-Coat Retest SIT FM 2 | 5d | 2004-07-29 | 2004-08-04 | 676 |  |  | 2004-07-16 | 2004-07-22 | 5d | 7d | 0d |
| 678 | 1.6.6.9.3 | **FM 1 (ETU Telescope)** | 77d | 2004-02-25 A | 2004-06-11 |  | 10% | 69.55d | 2004-03-31 | 2004-05-21 | 38d | -5d | 0d |
| 679 | 1.6.6.9.3.1 | Integrate SIT FM 1 HVPS and SIT ETU Telescope Without Electronics | 3d | 2004-02-25 A | 2004-02-27 A | 659 | 100% |  | 2004-03-31 | 2004-04-02 | 3d |  |  |
| 680 | 1.6.6.9.3.2 | Integrate Electronics to SIT ETU Telescope | 2d | 2004-05-04 | 2004-05-05 | 634, 596, 653, 609, 679 |  |  | 2004-04-14 | 2004-04-15 | 2d | -1d | 0d |
| 681 | 1.6.6.9.3.3 | SIT FM 1 Debug | 5d | 2004-05-06 | 2004-05-12 | 680 |  |  | 2004-04-16 | 2004-04-22 | 5d | -1d | 0d |
| 682 | 1.6.6.9.3.4 | SIT FM 1 Bench Test | 5d | 2004-05-13 | 2004-05-19 | 681 |  |  | 2004-04-23 | 2004-04-29 | 5d | -1d | 0d |
| 683 | 1.6.6.9.3.5 | SIT FM 1 Alpha TEST | 5d | 2004-05-20 | 2004-05-26 | 682 |  |  | 2004-04-30 | 2004-05-06 | 5d | -1d | 0d |
| 684 | 1.6.6.9.3.6 | SIT FM 1 Noise Removal | 5d | 2004-05-27 | 2004-06-03 | 683 |  |  | 2004-05-07 | 2004-05-13 | 5d | -1d | 0d |
| 685 | 1.6.6.9.3.7 | SIT FM 1 Thermal Test | 5d | 2004-06-04 | 2004-06-10 | 684 |  |  | 2004-05-14 | 2004-05-20 | 5d | -1d | 0d |
| 686 | 1.6.6.9.3.8 | SIT FM 1 Functional Test | 1d | 2004-06-11 | 2004-06-11 | 685, 665 |  |  | 2004-05-21 | 2004-05-21 | 1d | -1d | 0d |
| 687 | 1.6.6.9.4 | **FM 2** | 31d | 2004-06-02 | 2004-07-14 |  |  |  | 2004-05-19 | 2004-07-01 | 31d | 7d |  |
| 688 | 1.6.6.9.4.1 | Integrate SIT FM 2 HVPS and SIT FM 2 Telescope Without Electronics | 3d | 2004-06-02 | 2004-06-04 | 661, 398, 364 |  |  | 2004-05-19 | 2004-05-21 | 3d | 7d | 0d |
| 689 | 1.6.6.9.4.2 | Integrate Electronics to SIT FM 2 Telescope | 2d | 2004-06-07 | 2004-06-08 | 637, 598, 655, 611, 688 |  |  | 2004-05-24 | 2004-05-25 | 2d | 7d | 0d |
| 690 | 1.6.6.9.4.3 | SIT FM 2 Debug | 5d | 2004-06-09 | 2004-06-15 | 689 |  |  | 2004-05-26 | 2004-06-02 | 5d | 7d | 0d |
| 691 | 1.6.6.9.4.4 | SIT FM 2 Bench Test | 5d | 2004-06-16 | 2004-06-22 | 690 |  |  | 2004-06-03 | 2004-06-09 | 5d | 7d | 0d |
| 692 | 1.6.6.9.4.5 | SIT FM 2 Alpha Test | 5d | 2004-06-23 | 2004-06-29 | 691 |  |  | 2004-06-10 | 2004-06-16 | 5d | 7d | 0d |
| 693 | 1.6.6.9.4.6 | SIT FM 2 Noise Removal | 5d | 2004-06-30 | 2004-07-06 | 692, 684 |  |  | 2004-06-17 | 2004-06-23 | 5d | 7d | 0d |
| 694 | 1.6.6.9.4.7 | SIT FM 2 Thermal Test | 5d | 2004-07-07 | 2004-07-13 | 693 |  |  | 2004-06-24 | 2004-06-30 | 5d | 7d | 0d |
| 695 | 1.6.6.9.4.8 | SIT FM 2 Functional Test | 1d | 2004-07-14 | 2004-07-14 | 694 |  |  | 2004-07-01 | 2004-07-01 | 1d | 7d | 0d |

| ID | WBS | Task | Duration | Start | Finish | Predecessors | Complete | Remaining | Baseline start | Baseline finish | Baseline duration | Total slack | Free slack | Constraint |
| --- | --- | --- | --- | --- | --- | --- | --- | --- | --- | --- | --- | --- | --- | --- |
| 696 | 1.6.6.10 | **Environmental Testing at GSFC (FM 1)** | 34d | 2004-08-04 | 2004-09-21 |  |  |  | 2004-07-15 | 2004-08-31 | 34d | 10d |  |  |
| 697 | 1.6.6.10.1 | SIT FM 1 Vibration and Acoustics | 10d | 2004-08-04 | 2004-08-17 | 583 |  |  | 2004-07-15 | 2004-07-28 | 10d | 10d | 0d |  |
| 698 | 1.6.6.10.2 | Functional Test | 1d | 2004-08-18 | 2004-08-18 | 697 |  |  | 2004-07-29 | 2004-07-29 | 1d | 10d | 0d |  |
| 699 | 1.6.6.10.3 | SIT FM 1 Thermal Balance | 5d | 2004-08-19 | 2004-08-25 | 698 |  |  | 2004-07-30 | 2004-08-05 | 5d | 10d | 0d |  |
| 700 | 1.6.6.10.4 | SIT FM 1 Thermal Vac | 10d | 2004-08-26 | 2004-09-09 | 699 |  |  | 2004-08-06 | 2004-08-19 | 10d | 10d | 0d |  |
| 701 | 1.6.6.10.5 | Disassemble SIT Instruments | 2d | 2004-09-10 | 2004-09-13 | 700 |  |  | 2004-08-20 | 2004-08-23 | 2d | 10d | 0d |  |
| 702 | 1.6.6.10.6 | Bake Out | 3d | 2004-09-14 | 2004-09-16 | 701 |  |  | 2004-08-24 | 2004-08-26 | 3d | 10d | 0d |  |
| 703 | 1.6.6.10.7 | Reassemble Instruments | 2d | 2004-09-17 | 2004-09-20 | 702 |  |  | 2004-08-27 | 2004-08-30 | 2d | 10d | 0d |  |
| 704 | 1.6.6.10.8 | Functional Test | 1d | 2004-09-21 | 2004-09-21 | 703 |  |  | 2004-08-31 | 2004-08-31 | 1d | 10d | 0d |  |
| 705 | 1.6.6.11 | **Environmental Testing at GSFC (FM 2)** | 34d | 2004-08-25 | 2004-10-13 |  |  |  | 2004-08-23 | 2004-10-08 | 34d | 9d |  |  |
| 706 | 1.6.6.11.1 | SIT FM 2 Vibration and Acoustics | 10d | 2004-08-25 | 2004-09-08 | 586 |  |  | 2004-08-23 | 2004-09-03 | 10d | 9d | 0d |  |
| 707 | 1.6.6.11.2 | Functional Test | 1d | 2004-09-09 | 2004-09-09 | 706 |  |  | 2004-09-07 | 2004-09-07 | 1d | 9d | 0d |  |
| 708 | 1.6.6.11.3 | SIT FM 2 Thermal Balance | 5d | 2004-09-10 | 2004-09-16 | 707 |  |  | 2004-09-08 | 2004-09-14 | 5d | 9d | 0d |  |
| 709 | 1.6.6.11.4 | SIT FM 2 Thermal Vac | 10d | 2004-09-17 | 2004-09-30 | 708 |  |  | 2004-09-15 | 2004-09-28 | 10d | 9d | 0d |  |
| 710 | 1.6.6.11.5 | Disassemble SIT Instruments | 2d | 2004-10-01 | 2004-10-04 | 709 |  |  | 2004-09-29 | 2004-09-30 | 2d | 9d | 0d |  |
| 711 | 1.6.6.11.6 | Bake Out | 3d | 2004-10-05 | 2004-10-07 | 710 |  |  | 2004-10-01 | 2004-10-05 | 3d | 9d | 0d |  |
| 712 | 1.6.6.11.7 | Reassemble Instruments | 2d | 2004-10-08 | 2004-10-12 | 711 |  |  | 2004-10-06 | 2004-10-07 | 2d | 9d | 0d |  |
| 713 | 1.6.6.11.8 | Functional Test | 1d | 2004-10-13 | 2004-10-13 | 712 |  |  | 2004-10-08 | 2004-10-08 | 1d | 9d | 0d |  |
| 714 | 1.6.6.12 | **Emulators/Simulators/GSE** | 203d | 2003-12-17 A | 2004-10-04 |  | 49% | 103.53d | 2003-12-17 | 2004-10-20 | 214d | 15d |  |  |
| 715 | 1.6.6.12.1 | **Simulators** | 80d | 2003-12-17 A | 2004-04-12 |  | 61% | 31d | 2003-12-17 | 2004-04-12 | 80d | 98d |  |  |
| 716 | 1.6.6.12.1.1 | Labview CPU Ready | 80d | 2003-12-17 A | 2004-04-12 |  | 61% | 31d | 2003-12-17 | 2004-04-12 | 80d | 0d |  | must start on 2003-12-17 |
| 717 | 1.6.6.12.1.2 | Test Simulator | 80d | 2003-12-17 A | 2004-04-12 | 716SS | 61% | 31d | 2003-12-17 | 2004-04-12 | 80d | 98d | 83d |  |
| 718 | 1.6.6.12.2 | **GSE** | 40d | 2004-08-09 | 2004-10-04 |  |  |  | 2004-07-27 | 2004-10-20 | 60d | 15d |  |  |
| 719 | 1.6.6.12.2.1 | Pulse Generator | 40d | 2004-08-09 | 2004-10-04 | 582, 585, 717 |  |  | 2004-07-27 | 2004-10-20 | 60d | 15d |  |  |

| ID | WBS | Task | Duration | Start | Finish | Predecessors | Complete | Remaining | Baseline start | Baseline finish | Baseline duration | Total slack | Free slack | Constraint |
| --- | --- | --- | --- | --- | --- | --- | --- | --- | --- | --- | --- | --- | --- | --- |
| 720 | 1.6.7 | **SEP Suite I&T - CIT** | 305d | 2003-08-01 A | 2004-10-15 |  | 39% | 186.22d | 2003-08-01 | 2004-10-21 | 309d | 9d |  |  |
| 721 | 1.6.7.1 | **ETU** | 5d | 2004-01-26 A | 2004-01-30 A |  | 100% |  | 2004-01-26 | 2004-01-30 | 5d |  |  |  |
| 722 | 1.6.7.1.1 | Complete Integration/Test of SEP Central EM with Sensors | 5d | 2004-01-26 A | 2004-01-30 A |  | 100% |  | 2004-01-26 | 2004-01-30 | 5d |  |  | start no earlier than 2004-01-26 |
| 723 | 1.6.7.2 | **FM 1 & FM 2** | 84d | 2004-03-10 | 2004-07-06 |  |  |  | 2004-03-05 | 2004-10-21 | 162d | 4d |  |  |
| 724 | 1.6.7.2.1 | Generate SEPT integration & test procedure | 5d | 2004-03-10 | 2004-03-16 | 733FS-10d |  |  | 2004-03-05 | 2004-03-11 | 5d | 77d | 53d |  |
| 725 | 1.6.7.2.2 | Generate LET integration & test procedure | 5d | 2004-05-18 | 2004-05-24 | 734FS-10d |  |  | 2004-05-05 | 2004-05-11 | 5d | 29d | 19d |  |
| 726 | 1.6.7.2.3 | Generate HET integration & test procedure | 5d | 2004-06-09 | 2004-06-15 | 736FS-10d |  |  | 2004-05-20 | 2004-05-26 | 5d | 15d | 5d |  |
| 727 | 1.6.7.2.4 | Generate SIT integration & test procedure | 5d | 2004-06-29 | 2004-07-05 | 740FS-10d |  |  | 2004-06-09 | 2004-06-15 | 5d | 4d |  |  |
| 728 | 1.6.7.2.5 | Generate SEP system test procedure | 5d | 2004-06-30 | 2004-07-06 | 741FS-10d |  |  | 2004-06-10 | 2004-06-16 | 5d | 4d |  |  |
| 729 | 1.6.7.2.6 | Generate SEP-IDPU integration procedure | 5d | 2004-06-10 | 2004-06-16 | 737FS-10d |  |  | 2004-05-27 | 2004-06-03 | 5d | 11d | 0d |  |
| 730 | 1.6.7.2.7 | Generate SEP-IDPU test procedure | 5d | 2004-06-17 | 2004-06-23 | 729 |  |  | 2004-06-04 | 2004-06-10 | 5d | 11d | 4d |  |
| 731 | 1.6.7.3 | **FM 1** | 83d | 2004-03-23 | 2004-07-16 |  |  |  | 2004-03-18 | 2004-06-28 | 72d | -1d | 0d |  |
| 732 | 1.6.7.3.1 | Integrate/test SEP Central FM 1 | 5d | 2004-05-24 | 2004-05-28 | 413, 415, 374 |  |  | 2004-05-11 | 2004-05-17 | 5d | 24d | 0d |  |
| 733 | 1.6.7.3.2 | Receive & inspect SEPT FM 1 | 1d | 2004-03-23 | 2004-03-23 | 518, 519 |  |  | 2004-03-18 | 2004-03-18 | 1d | 72d | 0d |  |
| 734 | 1.6.7.3.3 | Integrate & test SEPT FM 1 | 1d | 2004-06-01 | 2004-06-01 | 724, 732, 733 |  |  | 2004-05-18 | 2004-05-18 | 1d | 24d | 0d |  |
| 735 | 1.6.7.3.4 | Integrate & test LET FM 1 | 1d | 2004-06-22 | 2004-06-22 | 725, 734, 495, 497 |  |  | 2004-06-09 | 2004-06-09 | 1d | 10d | 0d |  |
| 736 | 1.6.7.3.5 | Receive & inspect HET FM 1 | 1d | 2004-06-22 | 2004-06-22 | 443, 445 |  |  | 2004-06-03 | 2004-06-03 | 1d | 10d | 0d |  |
| 737 | 1.6.7.3.6 | Integrate & test HET FM 1 | 1d | 2004-06-23 | 2004-06-23 | 726, 735, 736 |  |  | 2004-06-10 | 2004-06-10 | 1d | 10d | 0d |  |
| 738 | 1.6.7.3.7 | Integrate SEP FM 1 - IDPU FM 1 | 1d | 2004-06-24 | 2004-06-24 | 729, 737 |  |  | 2004-06-11 | 2004-06-11 | 1d | 10d | 3d |  |
| 739 | 1.6.7.3.8 | Test SEP FM 1 - IDPU FM 1 | 1d | 2004-06-30 | 2004-06-30 | 730, 738, 350 |  |  | 2004-06-22 | 2004-06-22 | 1d | 7d |  |  |
| 740 | 1.6.7.3.9 | Receive & inspect SIT FM 1 | 1d | 2004-07-12 | 2004-07-12 | 582 |  |  | 2004-06-22 | 2004-06-22 | 1d | -1d | 0d |  |
| 741 | 1.6.7.3.10 | Integrate & test SIT FM 1 | 1d | 2004-07-13 | 2004-07-13 | 727, 737, 740, 739 |  |  | 2004-06-23 | 2004-06-23 | 1d | -1d | 0d |  |
| 742 | 1.6.7.3.11 | SEP system test FM 1 | 3d | 2004-07-14 | 2004-07-16 | 728, 741, 410 |  |  | 2004-06-24 | 2004-06-28 | 3d | -1d | 0d |  |
| 743 | 1.6.7.4 | **FM 2** | 98d | 2004-03-30 | 2004-08-13 |  |  |  | 2004-03-29 | 2004-08-11 | 97d | 8d |  |  |
| 744 | 1.6.7.4.1 | Integrate/testSEP Central FM 2 | 5d | 2004-05-24 | 2004-05-28 | 414, 415, 374 |  |  | 2004-05-11 | 2004-05-17 | 5d | 57d | 0d |  |
| 745 | 1.6.7.4.2 | Receive & inspect SEPT FM 2 | 1d | 2004-03-30 | 2004-03-30 | 521, 522 |  |  | 2004-03-29 | 2004-03-29 | 1d | 100d | 43d |  |
| 746 | 1.6.7.4.3 | Integrate & test SEPT FM 2 | 1d | 2004-06-01 | 2004-06-01 | 724, 744, 745 |  |  | 2004-05-18 | 2004-05-18 | 1d | 57d | 14d |  |
| 747 | 1.6.7.4.4 | Integrate & test LET FM 2 | 1d | 2004-06-22 | 2004-06-22 | 725, 746, 496, 497 |  |  | 2004-06-09 | 2004-06-09 | 1d | 43d | 15d |  |
| 748 | 1.6.7.4.5 | Receive & inspect HET FM 2 | 1d | 2004-07-13 | 2004-07-13 | 444 |  |  | 2004-06-24 | 2004-06-24 | 1d | 28d | 0d |  |
| 749 | 1.6.7.4.6 | Integrate & test HET FM 2 | 1d | 2004-07-14 | 2004-07-14 | 726, 747, 748 |  |  | 2004-06-25 | 2004-06-25 | 1d | 28d | 9d |  |
| 750 | 1.6.7.4.7 | Integrate SEP FM 2 - IDPU FM 2 | 1d | 2004-07-28 | 2004-07-28 | 729, 749, 160 |  |  | 2004-06-28 | 2004-06-28 | 1d | 19d | 0d |  |
| 751 | 1.6.7.4.8 | Test SEP FM 2 - IDPU FM 2 | 1d | 2004-07-29 | 2004-07-29 | 730, 750 |  |  | 2004-06-29 | 2004-06-29 | 1d | 19d | 1d |  |
| 752 | 1.6.7.4.9 | Receive & inspect SIT FM 2 | 1d | 2004-08-09 | 2004-08-09 | 585 |  |  | 2004-07-27 | 2004-07-27 | 1d | 7d | 0d |  |
| 753 | 1.6.7.4.10 | Integrate & test SIT FM 2 | 1d | 2004-08-10 | 2004-08-10 | 727, 752 |  |  | 2004-08-06 | 2004-08-06 | 1d | 7d | 0d |  |
| 754 | 1.6.7.4.11 | SEP FM 2 system test | 3d | 2004-08-11 | 2004-08-13 | 728, 753 |  |  | 2004-08-09 | 2004-08-11 | 3d | 7d | 0d |  |

| ID | WBS | Task | Duration | Start | Finish | Predecessors | Complete | Remaining | Baseline start | Baseline finish | Baseline duration | Total slack | Free slack | Constraint |
| --- | --- | --- | --- | --- | --- | --- | --- | --- | --- | --- | --- | --- | --- | --- |
| 755 | 1.6.7.5 | **Environmental Test (at JPL)** | 105d | 2004-05-17 | 2004-10-13 |  |  |  | 2004-05-17 | 2004-09-24 | 93d | 11d |  |  |
| 756 | 1.6.7.5.1 | Generate Environmental Test Procedures | 15d | 2004-05-17 | 2004-06-07 |  |  |  | 2004-05-17 | 2004-06-07 | 15d | 46d |  | start no earlier than 2004-05-17 |
| 757 | 1.6.7.5.2 | Manufacture test cables (JPL) | 20d | 2004-06-01 | 2004-06-28 |  |  |  | 2004-06-01 | 2004-06-28 | 20d | 31d |  | start no earlier than 2004-06-01 |
| 758 | 1.6.7.5.3 | **FM 1** | 40d | 2004-08-12 | 2004-10-07 |  |  |  | 2004-07-23 | 2004-09-24 | 45d | -1d | 0d |  |
| 759 | 1.6.7.5.3.1 | FM 1 LET/HET/SEP Central Vibration/Acoustics Test | 10d | 2004-08-12 | 2004-08-25 | 19FS+3d, 756, 757, 773FS+3d |  |  | 2004-07-23 | 2004-08-05 | 10d | -1d | 0d |  |
| 760 | 1.6.7.5.3.2 | FM 1 LET/HET/SEP Central Thermal Balance Test | 5d | 2004-08-26 | 2004-09-01 | 759 |  |  | 2004-08-06 | 2004-08-12 | 5d | -1d | 0d |  |
| 761 | 1.6.7.5.3.3 | FM 1 LET/HET/SEP Central T/V Test | 15d | 2004-09-02 | 2004-09-23 | 760, 766 |  |  | 2004-08-19 | 2004-09-09 | 15d | -1d | 0d |  |
| 762 | 1.6.7.5.3.4 | Evaluate SEP performance | 10d | 2004-09-24 | 2004-10-07 | 761 |  |  | 2004-09-10 | 2004-09-23 | 10d | -1d | 0d |  |
| 763 | 1.6.7.5.3.5 | Generate test reports | 11d | 2004-09-23 | 2004-10-07 | 762SS |  |  | 2004-09-10 | 2004-09-24 | 11d | -1d | 0d | finish no later than 2004-10-07 |
| 764 | 1.6.7.5.3.6 | Bakeout Clean SEP exterior & prepare for delivery | 3d | 2004-09-24 | 2004-09-28 | 761 |  |  | 2004-09-10 | 2004-09-14 | 3d | 6d | 0d |  |
| 765 | 1.6.7.5.4 | **FM 2** | 41d | 2004-08-16 | 2004-10-13 |  |  |  | 2004-07-23 | 2004-09-24 | 45d | 7d |  |  |
| 766 | 1.6.7.5.4.1 | FM 2 EMI/EMC Test at CalTech | 5d | 2004-08-16 | 2004-08-20 | 754 |  |  | 2004-08-12 | 2004-08-18 | 5d | 7d | 0d |  |
| 767 | 1.6.7.5.4.2 | FM 2 LET/HET/SEP Central Vibration/Acoustics Test | 10d | 2004-08-23 | 2004-09-03 | 774FS+3d, 766 |  |  | 2004-07-23 | 2004-08-05 | 10d | 11d | 0d |  |
| 768 | 1.6.7.5.4.3 | FM 2 LET/HET/SEP Central T/V Test | 15d | 2004-09-07 | 2004-09-27 | 766, 767 |  |  | 2004-08-19 | 2004-09-09 | 15d | 11d | 0d |  |
| 769 | 1.6.7.5.4.4 | Evaluate SEP performance | 10d | 2004-09-28 | 2004-10-12 | 768 |  |  | 2004-09-10 | 2004-09-23 | 10d | 11d | 0d |  |
| 770 | 1.6.7.5.4.5 | Generate test reports | 11d | 2004-09-28 | 2004-10-13 | 769SS |  |  | 2004-09-10 | 2004-09-24 | 11d | 11d |  | finish no later than 2004-10-28 |
| 771 | 1.6.7.5.4.6 | Bakeout Clean SEP exterior & prepare for delivery | 3d | 2004-09-28 | 2004-09-30 | 768 |  |  | 2004-09-10 | 2004-09-14 | 3d | 18d | 0d |  |
| 772 | 1.6.7.6 | **Accelerator Test (at MSU)** | 5d | 2004-08-02 | 2004-08-06 |  |  |  | 2004-07-13 | 2004-07-19 | 5d | -1d | 0d |  |
| 773 | 1.6.7.6.1 | FM 1 LET/SEP Cen end-to-end test at Accelerator | 5d | 2004-08-02 | 2004-08-06 | 779, 19, 405 |  |  | 2004-07-13 | 2004-07-19 | 5d | -1d | 0d |  |
| 774 | 1.6.7.6.2 | FM 2 LET/SEP Cen end-to-end test at Accelerator | 5d | 2004-08-02 | 2004-08-06 | 773SS, 751 |  |  | 2004-07-13 | 2004-07-19 | 5d | 18d | 0d |  |
| 775 | 1.6.7.7 | **GSE** | 305d | 2003-08-01 A | 2004-10-15 |  | 55% | 137.48d | 2003-08-01 | 2004-10-15 | 305d | 9d |  |  |
| 776 | 1.6.7.7.1 | **End-to-End Test Equipment** | 218d | 2003-08-11 A | 2004-06-22 |  | 84% | 35.3d | 2003-08-11 | 2004-06-22 | 218d | 23d |  |  |
| 777 | 1.6.7.7.1.1 | Design | 192d | 2003-08-11 A | 2004-05-14 |  | 95% | 9.3d | 2003-08-11 | 2004-05-14 | 192d | 23d | 0d | start no earlier than 2003-08-11 |
| 778 | 1.6.7.7.1.2 | Assemble | 21d | 2004-05-17 | 2004-06-15 | 777 |  |  | 2004-05-17 | 2004-06-15 | 21d | 27d | 0d |  |
| 779 | 1.6.7.7.1.3 | Test | 5d | 2004-06-16 | 2004-06-22 | 778 |  |  | 2004-06-16 | 2004-06-22 | 5d | 27d |  |  |

Notes:
- 772: The Accelerator Test Date is still TBD. The actually testing date will depend on availability of the facility at MSU and the readiness of our flight hardware. The date currently reflected in the schedule is therefore subject to change as required.

| ID | WBS | Task | Duration | Start | Finish | Predecessors | Complete | Remaining | Baseline start | Baseline finish | Baseline duration | Total slack | Free slack | Constraint |
| --- | --- | --- | --- | --- | --- | --- | --- | --- | --- | --- | --- | --- | --- | --- |
| 780 | 1.6.7.7.2 | **GSE software** | 305d | 2003-08-01 A | 2004-10-15 |  | 34% | 200.66d | 2003-08-01 | 2004-10-15 | 305d | 9d |  |  |
| 781 | 1.6.7.7.2.1 | Build GSE software release 2 | 157d | 2003-08-01 A | 2004-03-18 |  | 66% | 53d | 2003-08-01 | 2004-03-18 | 157d | 0d |  | must start on 2003-08-01 |
| 782 | 1.6.7.7.2.2 | Write user's guide | 8d | 2004-03-22 | 2004-03-31 | 781 |  |  | 2004-03-22 | 2004-03-31 | 8d | 31d | 22d | start no earlier than 2004-03-22 |
| 783 | 1.6.7.7.2.3 | Build GSE software release 3 | 117d | 2004-05-03 | 2004-10-15 | 782 |  |  | 2004-05-03 | 2004-10-15 | 117d | 9d | 0d | start no earlier than 2004-05-03 |
| 784 | 1.6.7.7.2.4 | Write user's guide supplement | 22d | 2004-09-15 | 2004-10-15 | 783FS-22d |  |  | 2004-09-15 | 2004-10-15 | 22d | 9d |  | finish no later than 2004-10-28 |
| 785 | 1.7 | **SWEA and SIT Refurbishment (after S/C Environmental Testing)** | 40d | 2005-09-27 | 2005-11-21 |  |  |  | 2005-09-27 | 2005-11-18 | 39d | 0d |  |  |
| 786 | 1.7.1 | Ship SWEA FM 1 to UCB | 3d | 2005-09-27 | 2005-09-29 |  |  |  | 2005-09-27 | 2005-09-29 | 3d | 25d | 0d | start no earlier than 2005-09-27 |
| 787 | 1.7.2 | Ship (Hand Carry) SIT FM 1 to UMD | 1d | 2005-09-27 | 2005-09-27 |  |  |  | 2005-09-27 | 2005-09-27 | 1d | 27d | 0d | start no earlier than 2005-09-27 |
| 788 | 1.7.3 | Ship SWEA FM 2 to UCB | 3d | 2005-10-04 | 2005-10-06 |  |  |  | 2005-10-04 | 2005-10-06 | 3d | 20d | 0d | start no earlier than 2005-10-04 |
| 789 | 1.7.4 | Ship (Hand Carry) SIT FM 2 to UMD | 1d | 2005-10-04 | 2005-10-04 |  |  |  | 2005-10-04 | 2005-10-04 | 1d | 22d | 0d | start no earlier than 2005-10-04 |
| 790 | 1.7.5 | Vacuum Testing of SWEA FM 1 @ UCB | 5d | 2005-09-30 | 2005-10-06 | 786 |  |  | 2005-09-30 | 2005-10-06 | 5d | 25d | 5d |  |
| 791 | 1.7.6 | Vacuum Testing of SIT FM 1 @ UMD | 5d | 2005-09-28 | 2005-10-04 | 787 |  |  | 2005-09-28 | 2005-10-04 | 5d | 27d | 5d |  |
| 792 | 1.7.7 | Vacuum Testing of SWEA FM 2 @ UCB | 5d | 2005-10-07 | 2005-10-13 | 788 |  |  | 2005-10-07 | 2005-10-13 | 5d | 20d | 0d |  |
| 793 | 1.7.8 | Vacuum Testing of SIT FM 2 @ UMD | 5d | 2005-10-05 | 2005-10-11 | 789 |  |  | 2005-10-05 | 2005-10-11 | 5d | 22d | 0d |  |
| 794 | 1.7.9 | Ship SWEA FM 1 & 2 to Launch Site for Re-integration to S/C | 3d | 2005-10-14 | 2005-10-18 | 790, 792 |  |  | 2005-10-07 | 2005-10-11 | 3d | 20d | 0d |  |
| 795 | 1.7.10 | Ship SIT FM 1 & 2 to Launch Site for Re-integration to S/C | 3d | 2005-10-12 | 2005-10-14 | 791, 793 |  |  | 2005-10-05 | 2005-10-07 | 3d | 22d | 2d |  |
| 796 | 1.7.11 | Reintegration of SWEA and SIT to S/C (at Launch Site) | 3d | 2005-10-19 | 2005-10-21 | 794, 795 |  |  | 2005-10-12 | 2005-10-14 | 3d | 20d |  |  |
| 797 | 1.7.12 | Target Date for Reintegration to S/C | 1d | 2005-11-19 | 2005-11-21 | 796 |  |  | 2005-11-18 | 2005-11-18 | 1d | 0d |  | must start on 2005-11-19 |
